# Outline ELEXON Plan_kc

Schedule from MS Project, 2022-10-31 to 2027-05-28, status date 2024-04-17, A marks actual dates.

## Calendars

- Standard: Mon-Fri 08:00-12:00, 13:00-17:00; Sat-Sun off.

## Resources

| Resource |
| --- |
| PMO |
| SI |
| PPC |
| Lead Workstream |
| CPT |
| PP |
| SI Design |
| SI Design |
| SI Design |
| Design |
| SI DevOps |
| SI Test |
| PSG |
| DAG |
| TMAG |
| CCAG |
| Code drafters (SRO Design Team |
| Code Bodies) |
| CCAG PM |
| Programme Participants |
| Code drafters |
| CDWG |
| SRO Design Team |
| Code Bodies |
| Ofgem |
| Elexon resources TBC |
| LDP Programme Manager |
| SRO Client Programme Director |
| IPA |
| LDP |
| SRO |
| )) |
| ? |
| TBC |
| OOC |
| MHHSP |
| Adrian Page |
| Amy Clayton |
| Anand Kaveripatna |
| Berlinda Kugara |
| Cesar Lopes |
| Charlie Blanks |
| Chetan Ubale |
| Daniel Callender |
| Daniel Gee |
| David Hollinshead |
| Dean Bailey |
| Dominic Mooney |
| Elayaraja Jeyaraman |
| Georgi Rabotov |
| Giles Clayden |
| Helen Richardson |
| Ishti Bhatti |
| Jafer Shah |
| Jason Brogden |
| John Edmonds Bell |
| John Wiggins |
| Karthikeyan Ganesan |
| Kasimali Hajiyani |
| Kate Goodman |
| Keegan Moodley |
| Keith Clark |
| Keith Lawlor |
| kevin Davis |
| Kishore Konduru |
| Kyle Abraham |
| Mahjabeen Newaz |
| Martin Freeman |
| Matt Hall |
| Matthew Breen |
| Michael Inije |
| Michael Walton |
| Ming Li |
| Nathalia Revlien |
| Nick Sewell |
| Nigel Hunt |
| Oskar Cahill |
| Paul Pettitt |
| Rakhee Shah |
| Rebecca Farooq |
| Renu Rathor |
| Robert Short |
| Robert Topley |
| Saadia Sajjad |
| Sean Tuffy |
| Shaid Hussain |
| Sharmeen Shaikh |
| Simon Berry |
| Steve Bradford |
| Steve Weston |
| Taaran Suri |
| Waseem Mohammed |
| Zak Hussain |
| berli |
| SI Migration |
| v |
| Andrew Margan |
| Lee Cox |
| DIP SP |
| DIPS SP |
| DIPSP |
| Ian Smith |
| N/A |
| SIT Component Integration Testing 2 Preparation Complete (incl. approval of SI SIT Component Integration Test Readiness Report) |
| Nich |
| Nicola Farley |
| Warren Fulton |
| Richard Puddephatt |
| Matthew Bray |
| Programme |
| LDSOs |
| Ben Wickins |
| paul |
| LDSO |
| Simon chidwick |
| Stuart Scott |

## Schedule

| ID | WBS | Task | Type | Duration | Start | Finish | Complete | Remaining | Baseline start | Baseline finish | Baseline duration | Baseline 1 start | Baseline 1 finish | Total slack | Constraint | Resources | Work | Actual work | Baseline cost | Responsible | Involved | Update Version | Sched Status | RAG | Task Status | Text3 |
| --- | --- | --- | --- | --- | --- | --- | --- | --- | --- | --- | --- | --- | --- | --- | --- | --- | --- | --- | --- | --- | --- | --- | --- | --- | --- | --- |
| 1 | 1 | **Programme Plan** |  | 1195d | 2022-10-31 A | 2027-05-28 | 39% | 731.71d | 2022-10-31 | 2027-05-28 | 1195d |  |  | 0d |  | N/A | 1192170h | 418886h | -0 | N/A | N/A | 5.0 |  |  |  |  |
| 2 | 1.1 | MHHS Programme Start | milestone | 0d | 2022-10-31 A | 2022-10-31 A | 100% |  | 2022-10-31 | 2022-10-31 | 0d |  |  |  |  | N/A |  |  |  | N/A | N/A | 5.7 | Complete | COMPLETE |  |  |
| 3 | 1.2 | **PROGRAMME MANAGEMENT** |  | 1089d | 2022-10-31 A | 2026-12-31 | 35% | 708.19d | 2022-10-31 | 2026-12-31 | 1089d | 2022-10-31 | 2026-12-31 | 106d |  | N/A | 247224h | 84096.7h |  | N/A | N/A | 5.0 |  |  |  |  |
| 4 | 1.2.1 | **Programme Management** |  | 1089d | 2022-10-31 A | 2026-12-31 | 34% | 716d | 2022-10-31 | 2026-12-31 | 1089d | 2022-10-31 | 2026-12-31 | 106d |  | N/A | 60984h | 20888h |  | N/A | N/A | 5.0 |  |  | M10 |  |
| 5 | 1.2.1.1 | Sprint-based prioritisation planning and execution |  | 1089d | 2022-10-31 A | 2026-12-31 | 34% | 716d | 2022-10-31 | 2026-12-31 | 1089d | 2022-10-31 | 2026-12-31 | 106d | finish no earlier than 2026-12-31 | N/A | 8712h | 2984h |  | PMO | CPT | 5.0 | Green | GREEN |  |  |
| 6 | 1.2.1.2 | Programme governance secretariat |  | 1089d | 2022-10-31 A | 2026-12-31 | 34% | 716d | 2022-10-31 | 2026-12-31 | 1089d | 2022-10-31 | 2026-12-31 | 106d |  | N/A | 8712h | 2984h |  | PMO | CPT | 5.0 | Green | GREEN |  |  |
| 7 | 1.2.1.3 | RAID management and reporting |  | 1089d | 2022-10-31 A | 2026-12-31 | 34% | 716d | 2022-10-31 | 2026-12-31 | 1089d | 2022-10-31 | 2026-12-31 | 106d |  | N/A | 8712h | 2984h |  | PMO | CPT | 5.0 | Green | GREEN |  |  |
| 8 | 1.2.1.4 | Tracking against Programme outcomes and KPIs |  | 1089d | 2022-10-31 A | 2026-12-31 | 34% | 716d | 2022-10-31 | 2026-12-31 | 1089d | 2022-10-31 | 2026-12-31 | 106d |  | N/A | 8712h | 2984h |  | PMO | CPT | 5.0 | Green | GREEN |  |  |
| 9 | 1.2.1.5 | Change control and reporting |  | 1089d | 2022-10-31 A | 2026-12-31 | 34% | 716d | 2022-10-31 | 2026-12-31 | 1089d | 2022-10-31 | 2026-12-31 | 106d |  | N/A | 8712h | 2984h |  | PMO | CPT | 5.0 | Green | GREEN |  |  |
| 10 | 1.2.1.6 | Ongoing identification of lessons learned relating to the PMO and implementation of improvements |  | 1089d | 2022-10-31 A | 2026-12-31 | 34% | 716d | 2022-10-31 | 2026-12-31 | 1089d | 2022-10-31 | 2026-12-31 | 106d |  | N/A | 8712h | 2984h |  | PMO | CPT | 5.0 | Green | GREEN |  |  |
| 11 | 1.2.2 | **Programme Internal Assurance Reviews** |  | 1089d | 2022-10-31 A | 2026-12-31 | 34% | 716d | 2022-10-31 | 2026-12-31 | 1089d | 2022-10-31 | 2026-12-31 | 106d |  | N/A | 17424h | 5968h |  | N/A | N/A | 5.0 |  |  | M9 | D18A - Quarterly Assurance Report |
| 12 | 1.2.2.1 | Programme Internal Assurance Reviews |  | 1089d | 2022-10-31 A | 2026-12-31 | 34% | 716d | 2022-10-31 | 2026-12-31 | 1089d | 2022-10-31 | 2026-12-31 | 106d |  | N/A | 8712h | 2984h |  | CPT | PMO | 5.0 | Green | GREEN |  | D18A - Quarterly Assurance Report |
| 13 | 1.2.3 | **Engagement with PPs** |  | 1089d | 2022-10-31 A | 2026-12-31 | 34% | 715.91d | 2022-10-31 | 2026-12-31 | 1089d | 2022-10-31 | 2026-12-31 | 106d |  | N/A | 95808h | 32824.7h |  | N/A | N/A | 5.0 |  |  | M5,M6 |  |
| 14 | 1.2.3.1 | Ongoing PP liaison activities |  | 1089d | 2022-10-31 A | 2026-12-31 | 34% | 716d | 2022-10-31 | 2026-12-31 | 1089d | 2022-10-31 | 2026-12-31 | 106d |  | N/A | 8712h | 2984h |  | PPC | CPT | 5.0 | Green | GREEN |  |  |
| 15 | 1.2.3.2 | Milestone and Control Point objective setting |  | 1089d | 2022-10-31 A | 2026-12-31 | 34% | 716d | 2022-10-31 | 2026-12-31 | 1089d | 2022-10-31 | 2026-12-31 | 106d |  | N/A | 8712h | 2984h |  | PPC | CPT | 5.0 | Green | GREEN |  |  |
| 16 | 1.2.3.3 | Reporting |  | 1089d | 2022-10-31 A | 2026-12-31 | 34% | 716d | 2022-10-31 | 2026-12-31 | 1089d | 2022-10-31 | 2026-12-31 | 106d |  | N/A | 8712h | 2984h |  | PPC |  | 5.0 | Green | GREEN |  |  |
| 17 | 1.2.3.4 | **PP Engagement Events** |  | 1089d | 2022-10-31 A | 2026-12-31 | 34% | 716d | 2022-10-31 | 2026-12-31 | 1089d | 2022-10-31 | 2026-12-31 | 106d |  | N/A | 34848h | 11936h |  | N/A | N/A | 5.0 |  |  |  |  |
| 18 | 1.2.3.4.1 | Bilateral meetings |  | 1089d | 2022-10-31 A | 2026-12-31 | 34% | 716d | 2022-10-31 | 2026-12-31 | 1089d | 2022-10-31 | 2026-12-31 | 106d |  | N/A | 8712h | 2984h |  | PPC | CPT | 5.0 | Green | GREEN |  |  |
| 19 | 1.2.3.4.2 | Monthly webinars |  | 1089d | 2022-10-31 A | 2026-12-31 | 34% | 716d | 2022-10-31 | 2026-12-31 | 1089d | 2022-10-31 | 2026-12-31 | 106d |  | N/A | 8712h | 2984h |  | PPC | CPT | 5.0 | Green | GREEN |  |  |
| 20 | 1.2.3.4.3 | Open days |  | 1089d | 2022-10-31 A | 2026-12-31 | 34% | 716d | 2022-10-31 | 2026-12-31 | 1089d | 2022-10-31 | 2026-12-31 | 106d |  | N/A | 8712h | 2984h |  | PPC | CPT | 5.0 | Green | GREEN |  |  |
| 21 | 1.2.3.5 | **PP Communications** |  | 1088d | 2022-10-31 A | 2026-12-30 | 34% | 715d | 2022-10-31 | 2026-12-30 | 1088d | 2022-10-31 | 2026-12-30 | 107d |  | N/A | 26112h | 8952h |  | N/A | N/A | 5.0 |  |  |  |  |
| 22 | 1.2.3.5.1 | The Clock updates (weekly) |  | 1088d | 2022-10-31 A | 2026-12-30 | 34% | 715d | 2022-10-31 | 2026-12-30 | 1088d | 2022-10-31 | 2026-12-30 | 107d |  | N/A | 8704h | 2984h |  | PPC |  | 5.0 | Green | GREEN |  |  |
| 23 | 1.2.3.5.2 | Maintain and update content on public-facing Portal (and ongoing feedback reviews to identify and implement Portal improvements) |  | 1088d | 2022-10-31 A | 2026-12-30 | 34% | 715d | 2022-10-31 | 2026-12-30 | 1088d | 2022-10-31 | 2026-12-30 | 107d |  | N/A | 8704h | 2984h |  | PPC |  | 5.0 | Green | GREEN |  |  |
| 24 | 1.2.4 | **Code Change Support / Other Programme Alignment** |  | 1089d | 2022-10-31 A | 2026-12-31 | 34% | 716d | 2022-10-31 | 2026-12-31 | 1089d | 2022-10-31 | 2026-12-31 | 106d |  | N/A | 60984h | 20888h |  | N/A | N/A | 5.0 |  |  | M6 | D17 - Code Change Report & Recommendations |
| 25 | 1.2.4.1 | Support DCC/BEIS on SEC change |  | 1089d | 2022-10-31 A | 2026-12-31 | 34% | 716d | 2022-10-31 | 2026-12-31 | 1089d | 2022-10-31 | 2026-12-31 | 106d |  | N/A | 8712h | 2984h |  | CPT |  | 5.0 | Green | GREEN |  |  |
| 26 | 1.2.4.2 | Support on Smart Meters Act changes |  | 1089d | 2022-10-31 A | 2026-12-31 | 34% | 716d | 2022-10-31 | 2026-12-31 | 1089d | 2022-10-31 | 2026-12-31 | 106d |  | N/A | 8712h | 2984h |  | CPT |  | 5.0 | Green | GREEN |  |  |
| 27 | 1.2.4.3 | Support DCC/RECCo on CSS change |  | 1089d | 2022-10-31 A | 2026-12-31 | 34% | 716d | 2022-10-31 | 2026-12-31 | 1089d | 2022-10-31 | 2026-12-31 | 106d |  | N/A | 8712h | 2984h |  | CPT |  | 5.0 | Green | GREEN |  |  |
| 28 | 1.2.4.4 | Support Elexon on BSC change |  | 1089d | 2022-10-31 A | 2026-12-31 | 34% | 716d | 2022-10-31 | 2026-12-31 | 1089d | 2022-10-31 | 2026-12-31 | 106d |  | N/A | 8712h | 2984h |  | CPT |  | 5.0 | Green | GREEN |  |  |
| 29 | 1.2.4.5 | Support code change inside & outside CCIAG |  | 1089d | 2022-10-31 A | 2026-12-31 | 34% | 716d | 2022-10-31 | 2026-12-31 | 1089d | 2022-10-31 | 2026-12-31 | 106d |  | N/A | 8712h | 2984h |  | CPT |  | 5.0 | Green | GREEN |  |  |
| 30 | 1.2.4.6 | Support code change inside & outside CCAG |  | 1089d | 2022-10-31 A | 2026-12-31 | 34% | 716d | 2022-10-31 | 2026-12-31 | 1089d | 2022-10-31 | 2026-12-31 | 106d |  | N/A | 8712h | 2984h |  | CPT |  | 5.0 | Green | GREEN |  |  |

| ID | WBS | Task | Type | Duration | Start | Finish | Predecessors | Complete | Remaining | Baseline start | Baseline finish | Baseline duration | Baseline 1 start | Baseline 1 finish | Total slack | Constraint | Resources | Work | Actual work | Baseline cost | Responsible | Involved | Task Status | Update Version | Sched Status | RAG | Milestone ID | Text29 | Tier | Text3 | MHHS Programme Phase | Artefact ID |
| --- | --- | --- | --- | --- | --- | --- | --- | --- | --- | --- | --- | --- | --- | --- | --- | --- | --- | --- | --- | --- | --- | --- | --- | --- | --- | --- | --- | --- | --- | --- | --- | --- |
| 31 | 1.2.5 | **Programme Replan Baseline** |  | 163d | 2022-10-31 A | 2023-06-14 A |  | 100% |  | 2022-10-31 | 2023-06-14 | 163d | 2022-10-31 | 2023-06-14 |  |  | N/A | 3312h | 3312h |  | N/A | N/A | M5+ | 5.0 |  |  |  |  |  |  |  |  |
| 32 | 1.2.5.1 | Round 3 consultation preparation |  | 32d | 2022-10-31 A | 2022-12-13 A |  | 100% |  | 2022-10-31 | 2022-12-13 | 32d | 2022-10-31 | 2022-12-13 |  |  | N/A | 256h | 256h |  | PMO | CPT |  | 5.0 | Complete | COMPLETE |  |  |  |  |  |  |
| 33 | 1.2.5.2 | PSG decision to launch Round 3 consultation | milestone | 0d | 2022-12-07 A | 2022-12-07 A | 32FS-5d | 100% |  | 2022-12-07 | 2022-12-07 | 0d | 2022-12-07 | 2022-12-07 |  |  | N/A |  |  |  | PMO | PPC |  | 5.0 | Complete | COMPLETE |  |  |  |  |  |  |
| 34 | 1.2.5.3 | Round 3 consultation (incl. walkthroughs and Q&A) |  | 35d | 2022-12-14 A | 2023-01-31 A | 33FS+5d | 100% |  | 2022-12-14 | 2023-01-31 | 35d | 2022-12-14 | 2023-01-31 |  |  | N/A | 280h | 280h |  | PP | PMO, PPC,IPA |  | 5.0 | Complete | COMPLETE |  |  |  |  |  |  |
| 35 | 1.2.5.4 | Review and uplift of foundational testing documents to align with replan approach |  | 92d | 2022-12-14 A | 2023-04-20 A | 34SS | 100% |  | 2022-12-14 | 2023-04-20 | 92d | 2022-12-14 | 2023-04-20 |  |  | N/A | 736h | 736h |  | SI Test | CPT |  | 5.0 | Complete | COMPLETE |  |  |  |  |  |  |
| 36 | 1.2.5.5 | Round 3 consultation responses analysis (incl. identification of SIT volunteers) |  | 10d | 2023-02-01 A | 2023-02-14 A | 34 | 100% |  | 2023-02-01 | 2023-02-14 | 10d | 2023-02-01 | 2023-02-14 |  |  | N/A | 80h | 80h |  | PMO | CPT |  | 5.0 | Complete | COMPLETE |  |  |  |  |  |  |
| 37 | 1.2.5.6 | Replan re-drafting and supporting artefact updates (incl. engagement with Ofgem) |  | 26d | 2023-02-15 A | 2023-03-22 A | 36 | 100% |  | 2023-02-15 | 2023-03-22 | 26d | 2023-02-15 | 2023-03-22 |  |  | N/A | 208h | 208h |  | PMO | CPT,IPA,Ofgem |  | 5.0 | Complete | COMPLETE |  |  |  |  |  |  |
| 38 | 1.2.5.7 | Draft Replan Change Request |  | 31d | 2023-02-15 A | 2023-03-29 A | 36 | 100% |  | 2023-02-15 | 2023-03-29 | 31d | 2023-02-15 | 2023-03-29 |  |  | N/A | 248h | 248h |  | PMO | CPT |  | 5.0 | Complete | COMPLETE |  |  |  |  |  |  |
| 39 | 1.2.5.8 | PSG decision to issue CR for industry impact assessment | milestone | 0d | 2023-04-05 A | 2023-04-05 A | 38FS+5d | 100% |  | 2023-04-05 | 2023-04-05 | 0d | 2023-04-05 | 2023-04-05 |  |  | N/A |  |  |  | PMO | CPT |  | 5.0 | Complete | COMPLETE |  |  |  |  |  |  |
| 40 | 1.2.5.9 | Industry impact assessment |  | 10d | 2023-04-06 A | 2023-04-19 A | 39 | 100% |  | 2023-04-06 | 2023-04-19 | 10d | 2023-04-06 | 2023-04-19 |  |  | N/A | 80h | 80h |  | PP | PMO,PPC |  | 5.0 | Complete | COMPLETE |  |  |  |  |  |  |
| 41 | 1.2.5.10 | Replan playbacks (to assist PPs in impact assessment) |  | 5d | 2023-04-11 A | 2023-04-17 A | 40SS+3d | 100% |  | 2023-04-11 | 2023-04-17 | 5d | 2023-04-11 | 2023-04-17 |  |  | N/A | 40h | 40h |  | CPT | PPC,PP |  | 5.0 | Complete | COMPLETE |  |  |  |  |  |  |
| 42 | 1.2.5.11 | Industry impact assessment responses analysis |  | 5d | 2023-04-20 A | 2023-04-26 A | 40 | 100% |  | 2023-04-20 | 2023-04-26 | 5d | 2023-04-20 | 2023-04-26 |  |  | N/A | 40h | 40h |  | PMO | CPT |  | 5.0 | Complete | COMPLETE |  |  |  |  |  |  |
| 43 | 1.2.5.12 | Extraordinary PSG decision to agree baseline recommendation | milestone | 0d | 2023-05-03 A | 2023-05-03 A | 42FS+5d | 100% |  | 2023-05-03 | 2023-05-03 | 0d | 2023-05-03 | 2023-05-03 |  |  | N/A |  |  |  | CPT | PMO,PP |  | 5.0 | Complete | COMPLETE |  |  |  |  |  |  |
| 44 | 1.2.5.13 | Plan Rebaselined (subject to Ofgem decision) | milestone | 0d | 2023-06-08 A | 2023-06-08 A | 43FS+25d | 100% |  | 2023-06-08 | 2023-06-08 | 0d? | 2023-06-07 | 2023-06-07 |  | start no earlier than 2023-06-08 | N/A |  |  | -0 | CPT | PMO,PP |  | 5.0 | Complete | COMPLETE | T1-PM-1000 | PSG | T1 |  |  |  |
| 45 | 1.2.5.14 | Programme Replan playbacks and drop-in sessions |  | 5d | 2023-06-08 A | 2023-06-14 A | 44 | 100% |  | 2023-06-08 | 2023-06-14 | 5d | 2023-06-08 | 2023-06-14 |  |  | N/A | 40h | 40h |  | PMO | PPC, PP |  | 5.0 | Complete | COMPLETE |  |  |  |  |  |  |
| 46 | 1.3 | **DESIGN, BUILD & TEST (PIT)** |  | 1101d | 2022-10-31 A | 2027-01-18 |  | 75% | 278.74d | 2022-10-31 | 2027-01-18 | 1101d | 2022-10-31 | 2027-01-18 | 94d |  | N/A | 220136h | 122297h | -0 | N/A | N/A |  |  |  |  |  |  |  | 1 May 2022 - 31 Jul 2023 | Design, Build & Test (PIT) |  |
| 47 | 1.3.1 | **Design Baseline & Enduring PP Support** |  | 1101d | 2022-10-31 A | 2027-01-18 |  | 68% | 347.98d | 2022-10-31 | 2027-01-18 | 1101d | 2022-10-31 | 2027-01-18 | 94d |  | N/A | 45872h | 22632h |  | N/A | N/A |  | 5.0 |  |  |  |  |  |  | Design, Build & Test (PIT) |  |
| 48 | 1.3.1.1 | Physical design baselined (M5) | milestone | 0d | 2022-10-31 A | 2022-10-31 A |  | 100% |  | 2022-10-31 | 2022-10-31 | 0d | 2022-10-31 | 2022-10-31 |  |  | Paul Pettitt |  |  |  | SRO Design | SI Design,PP,IPA |  | 5.0 | Complete | COMPLETE | T1-DB-1000 | PSG | T1 |  | Design, Build & Test (PIT) | MHHS-ART001 |
| 49 | 1.3.1.2 | **M5 Design Work-Off Plan Implementation & Approval** |  | 79d | 2022-10-31 A | 2023-02-16 A |  | 100% |  | 2022-10-31 | 2023-02-16 | 79d | 2022-10-31 | 2023-02-16 |  |  | N/A | 1224h | 1224h |  | N/A | N/A |  | 5.0 |  |  |  |  |  |  | Design, Build & Test (PIT) |  |
| 50 | 1.3.1.2.1 | Implementation of M5 design Work-Off Plan |  | 74d | 2022-10-31 A | 2023-02-09 A | 48 | 100% |  | 2022-10-31 | 2023-02-09 | 74d | 2022-10-31 | 2023-02-09 |  |  | Paul Pettitt | 592h | 592h |  | SI Design | PP |  | 5.0 | Complete | COMPLETE |  |  |  |  | Design, Build & Test (PIT) |  |
| 51 | 1.3.1.2.2 | M5 design Work-Off Plan completion approved | milestone | 0d | 2023-02-16 A | 2023-02-16 A | 50FS+5d | 100% |  | 2023-02-16 | 2023-02-16 | 0d | 2023-02-16 | 2023-02-16 |  |  | Paul Pettitt |  |  |  | SI Design | PP |  | 5.0 | Complete | COMPLETE | T3-DB-0014 | DAG | T3 |  | Design, Build & Test (PIT) |  |
| 52 | 1.3.1.3 | **Enduring PP Design Support** |  | 1089d | 2022-10-31 A | 2026-12-31 A |  | 100% |  | 2022-10-31 | 2026-12-31 | 1089d | 2022-10-31 | 2026-12-31 |  |  | N/A | 18344h | 18344h |  | N/A | N/A |  | 5.0 |  |  |  |  |  |  | Design, Build & Test (PIT) |  |
| 53 | 1.3.1.3.1 | Design playbacks and drop-in sessions |  | 45d | 2022-10-31 A | 2022-12-30 A | 48 | 100% |  | 2022-10-31 | 2022-12-30 | 45d | 2022-10-31 | 2022-12-30 |  |  | Paul Pettitt | 360h | 360h |  | SI Design | PMO,PPC, SRO Design |  | 5.0 | Complete | COMPLETE |  |  |  |  | Design, Build & Test (PIT) |  |
| 54 | 1.3.1.3.2 | Support participants on E2E MHHS Design |  | 1089d | 2022-10-31 A | 2026-12-31 A | 48 | 100% |  | 2022-10-31 | 2026-12-31 | 1089d | 2022-10-31 | 2026-12-31 |  |  | Paul Pettitt | 8712h | 8712h |  | SI Design | PP |  | 5.0 | Complete | COMPLETE |  |  |  |  | Design, Build & Test (PIT) |  |
| 55 | 1.3.1.3.3 | DIP Onboarding Support |  | 70d | 2022-11-14 A | 2023-02-17 A |  | 100% |  | 2022-11-14 | 2023-02-17 | 70d | 2022-11-14 | 2023-02-17 |  | must start on 2022-11-14 | Paul Pettitt | 560h | 560h |  | SI Design | SRO Design |  | 5.0 | Complete | COMPLETE |  |  |  |  | Design, Build & Test (PIT) |  |
| 56 | 1.3.1.3.4 | iServer Launch | milestone | 0d | 2023-02-16 A | 2023-02-16 A | 51 | 100% |  | 2023-02-16 | 2023-02-16 | 0d | 2023-02-16 | 2023-02-16 |  |  | Paul Pettitt |  |  |  | SI Design | PP |  | 5.0 | Complete | COMPLETE |  |  |  |  | Design, Build & Test (PIT) |  |

| ID | WBS | Task | Type | Duration | Start | Finish | Predecessors | Complete | Remaining | Baseline start | Baseline finish | Baseline duration | Baseline 1 start | Baseline 1 finish | Total slack | Constraint | Resources | Work | Actual work | Baseline cost | Responsible | Involved | Update Version | MHHS Programme Phase | Sched Status | RAG | Milestone ID | Text29 | Tier |
| --- | --- | --- | --- | --- | --- | --- | --- | --- | --- | --- | --- | --- | --- | --- | --- | --- | --- | --- | --- | --- | --- | --- | --- | --- | --- | --- | --- | --- | --- |
| 57 | 1.3.1.4 | **Establish Design Change Management Processes** |  | 1101d | 2022-10-31 A | 2027-01-18 |  | 30% | 768.72d | 2022-10-31 | 2027-01-18 | 1101d | 2022-10-31 | 2027-01-18 | 94d |  | N/A | 17264h | 2832h |  | N/A | N/A | 5.0 | Design, Build & Test (PIT) |  |  |  |  |  |
| 58 | 1.3.1.4.1 | Internal review of internal change management processes |  | 35d | 2022-10-31 A | 2022-12-16 A |  | 100% |  | 2022-10-31 | 2022-12-16 | 35d | 2022-10-31 | 2022-12-16 |  |  | Paul Pettitt | 280h | 280h |  | SRO | SI Design | 5.0 | Design, Build & Test (PIT) | Complete | COMPLETE |  |  |  |
| 59 | 1.3.1.4.2 | SRO approval of internal change management processes | milestone | 0d | 2022-12-16 A | 2022-12-16 A | 58FF | 100% |  | 2022-12-16 | 2022-12-16 | 0d | 2022-12-16 | 2022-12-16 |  |  | Paul Pettitt |  |  |  | SRO | SI Design | 5.0 | Design, Build & Test (PIT) | Complete | COMPLETE |  |  |  |
| 60 | 1.3.1.4.3 | Change Process Webinar | milestone | 0d | 2023-01-16 A | 2023-01-16 A |  | 100% |  | 2023-01-16 | 2023-01-16 | 0d | 2023-01-16 | 2023-01-16 |  | must start on 2023-01-16 | Paul Pettitt |  |  |  | SI Design | PP | 5.0 | Design, Build & Test (PIT) | Complete | COMPLETE |  |  |  |
| 61 | 1.3.1.4.4 | Enduring change management process approved | milestone | 0d | 2023-02-16 A | 2023-02-16 A | 51FF | 100% |  | 2023-02-16 | 2023-02-16 | 0d | 2023-02-16 | 2023-02-16 |  |  | Paul Pettitt |  |  |  | SI Design | PP | 5.0 | Design, Build & Test (PIT) | Complete | COMPLETE | T3-DB-0016 | DAG | T3 |
| 62 | 1.3.1.4.5 | Maintain E2E MHHS Design (post-M5 design change management processes operational) |  | 1022d | 2023-02-17 A | 2027-01-18 | 61 | 28% | 738d | 2023-02-17 | 2027-01-18 | 1022d | 2023-02-17 | 2027-01-18 | 94d |  | Paul Pettitt | 8176h | 2272h |  | SI Design | PP | 5.0 | Design, Build & Test (PIT) | Green | GREEN |  |  |  |
| 63 | 1.3.1.5 | **Design Authority Mobilisation** |  | 29d | 2022-12-14 A | 2023-01-23 A |  | 100% |  | 2022-12-14 | 2023-01-23 | 29d | 2022-12-14 | 2023-01-23 |  |  | N/A | 232h | 232h |  | N/A | N/A | 5.0 | Design, Build & Test (PIT) |  |  |  |  |  |
| 64 | 1.3.1.5.1 | Design Authority ToR approved | milestone | 0d | 2022-12-14 A | 2022-12-14 A |  | 100% |  | 2022-12-14 | 2022-12-14 | 0d | 2022-12-14 | 2022-12-14 |  | must start on 2022-12-14 | Paul Pettitt |  |  |  | SI Design | PP | 5.0 | Design, Build & Test (PIT) | Complete | COMPLETE | T3-DB-0010 | DAG | T3 |
| 65 | 1.3.1.5.2 | Inaugural Design Authority | milestone | 0d | 2023-01-23 A | 2023-01-23 A | 64FS+29d | 100% |  | 2023-01-23 | 2023-01-23 | 0d | 2023-01-23 | 2023-01-23 |  |  | Paul Pettitt |  |  |  | SI Design | PP | 5.0 | Design, Build & Test (PIT) | Complete | COMPLETE |  |  |  |
| 66 | 1.3.1.6 | **Network Operation Services Adaptor Procurement** |  | 0d | 2023-05-23 A | 2023-05-23 A |  | 100% |  | 2023-02-02 | 2025-03-17 | 553d | 2023-02-01 | 2025-03-14 |  |  | N/A |  |  |  | N/A | N/A | 5.0 | Design, Build & Test (PIT) |  |  |  |  |  |
| 67 | 1.3.1.6.1 | All SIT LDSOs have procured their adapter providers | milestone | 0d | 2023-05-23 A | 2023-05-23 A | 527SS | 100% |  | 2023-05-23 | 2023-05-23 | 0d | 2023-05-23 | 2023-05-23 |  |  | Paul Pettitt |  |  |  | SI Design | PP | 5.0 | Design, Build & Test (PIT) | Complete | COMPLETE | T3-DB-0020 | DAG | T3 |
| 68 | 1.3.2 | **PP Mobilisation** |  | 67d | 2022-10-31 A | 2023-01-31 A |  | 100% |  | 2022-10-31 | 2023-01-31 | 67d | 2022-10-31 | 2023-01-31 |  |  | N/A | 3216h | 3216h |  | N/A | N/A | 5.0 | Design, Build & Test (PIT) |  |  |  |  |  |
| 69 | 1.3.2.1 | Set up governance |  | 67d | 2022-10-31 A | 2023-01-31 A |  | 100% |  | 2022-10-31 | 2023-01-31 | 67d | 2022-10-31 | 2023-01-31 |  |  | PP | 536h | 536h |  | PP |  | 5.0 | Design, Build & Test (PIT) | Complete | COMPLETE |  |  |  |
| 70 | 1.3.2.2 | Set up reporting |  | 67d | 2022-10-31 A | 2023-01-31 A |  | 100% |  | 2022-10-31 | 2023-01-31 | 67d | 2022-10-31 | 2023-01-31 |  |  | PP | 536h | 536h |  | PP |  | 5.0 | Design, Build & Test (PIT) | Complete | COMPLETE |  |  |  |
| 71 | 1.3.2.3 | Obtain funding |  | 67d | 2022-10-31 A | 2023-01-31 A |  | 100% |  | 2022-10-31 | 2023-01-31 | 67d | 2022-10-31 | 2023-01-31 |  |  | PP | 536h | 536h |  | PP |  | 5.0 | Design, Build & Test (PIT) | Complete | COMPLETE |  |  |  |
| 72 | 1.3.2.4 | Earmark resources |  | 67d | 2022-10-31 A | 2023-01-31 A |  | 100% |  | 2022-10-31 | 2023-01-31 | 67d | 2022-10-31 | 2023-01-31 |  |  | PP | 536h | 536h |  | PP |  | 5.0 | Design, Build & Test (PIT) | Complete | COMPLETE |  |  |  |
| 73 | 1.3.2.5 | Mobilise initial team |  | 67d | 2022-10-31 A | 2023-01-31 A |  | 100% |  | 2022-10-31 | 2023-01-31 | 67d | 2022-10-31 | 2023-01-31 |  |  | PP | 536h | 536h |  | PP |  | 5.0 | Design, Build & Test (PIT) | Complete | COMPLETE |  |  |  |
| 74 | 1.3.3 | **PIT Stub Specification and Delivery** |  | 430d | 2022-10-31 A | 2024-06-21 |  | 90% | 42.4d | 2022-10-31 | 2024-06-21 | 430d | 2022-10-31 | 2023-05-31 | 765d |  | N/A | 11984h | 6592h | -0 | N/A | N/A | 5.0 | Design, Build & Test (PIT) |  |  |  |  |  |
| 75 | 1.3.3.1 | **DIP Simulator** |  | 108d | 2022-10-31 A | 2023-03-29 A |  | 100% |  | 2022-10-31 | 2023-03-29 | 108d | 2022-10-31 | 2023-03-29 |  |  | N/A | 3208h | 3208h |  | N/A | N/A | 5.0 | Design, Build & Test (PIT) |  |  |  |  |  |
| 76 | 1.3.3.1.1 | Build & Test |  | 95d | 2022-10-31 A | 2023-03-10 A | 48 | 100% |  | 2022-10-31 | 2023-03-10 | 95d | 2022-10-31 | 2023-03-10 |  |  | Rebecca Farooq | 760h | 760h |  | SI DevOps |  | 5.0 | Design, Build & Test (PIT) | Complete | COMPLETE |  |  |  |
| 77 | 1.3.3.1.2 | UAT |  | 85d | 2022-11-14 A | 2023-03-10 A | 76SS+10d | 100% |  | 2022-11-14 | 2023-03-10 | 85d | 2022-11-14 | 2023-03-10 |  |  | Rebecca Farooq | 680h | 680h |  | SI Test |  | 5.0 | Design, Build & Test (PIT) | Complete | COMPLETE |  |  |  |
| 78 | 1.3.3.1.3 | Beta test |  | 95d | 2022-10-31 A | 2023-03-10 A | 76SS | 100% |  | 2022-10-31 | 2023-03-10 | 95d | 2022-10-31 | 2023-03-10 |  |  | Rebecca Farooq | 760h | 760h |  | PP | SI Test | 5.0 | Design, Build & Test (PIT) | Complete | COMPLETE |  |  |  |
| 79 | 1.3.3.1.4 | Prepare for release |  | 18d | 2023-03-06 A | 2023-03-29 A | 78FS-5d | 100% |  | 2023-03-06 | 2023-03-29 | 18d | 2023-03-06 | 2023-03-29 |  |  | Rebecca Farooq | 144h | 144h |  | SI DevOps |  | 5.0 | Design, Build & Test (PIT) | Complete | COMPLETE |  |  |  |
| 80 | 1.3.3.1.5 | DIP Simulator released | milestone | 0d | 2023-03-29 A | 2023-03-29 A | 79FF | 100% |  | 2023-03-29 | 2023-03-29 | 0d | 2023-03-29 | 2023-03-29 |  | start no earlier than 2023-01-30 | Rebecca Farooq |  |  |  | SI DevOps |  | 5.0 | Design, Build & Test (PIT) | Complete | COMPLETE | T3-DB-0018 | SITAG | T3 |

| ID | WBS | Task | Type | Duration | Start | Finish | Predecessors | Complete | Remaining | Baseline start | Baseline finish | Baseline duration | Baseline 1 start | Baseline 1 finish | Total slack | Free slack | Constraint | Resources | Work | Actual work | Baseline cost | Responsible | Involved | Update Version | MHHS Programme Phase | Sched Status | RAG | Milestone ID | Text29 | Tier | Task Status |
| --- | --- | --- | --- | --- | --- | --- | --- | --- | --- | --- | --- | --- | --- | --- | --- | --- | --- | --- | --- | --- | --- | --- | --- | --- | --- | --- | --- | --- | --- | --- | --- |
| 81 | 1.3.3.2 | **DIP Simulator Uplifts** |  | 252d | 2023-07-06 A | 2024-06-21 |  | 60% | 101.87d | 2023-07-06 | 2024-06-21 | 252d |  |  | 765d |  |  | N/A | 3144h | 888h | -0 | N/A | N/A | 5.1 | Design, Build & Test (PIT) |  |  |  |  |  |  |
| 82 | 1.3.3.2.1 | DIP Simulator uplifted to align with design releases - design/build/test |  | 27d | 2023-07-06 A | 2023-08-11 A | 118 | 100% |  | 2023-07-06 | 2023-08-11 | 27d |  |  |  |  |  | Rebecca Farooq | 216h | 216h |  | SI DevOps |  | 5.1 | Design, Build & Test (PIT) | Complete | COMPLETE |  |  |  |  |
| 83 | 1.3.3.2.2 | DIP Simulator uplifted to align with Interim Release 2 | milestone | 0d | 2023-08-11 A | 2023-08-11 A | 82 | 100% |  | 2023-08-11 | 2023-08-11 | 0d |  |  |  |  |  | Rebecca Farooq |  |  |  | SI DevOps |  | 5.1 | Design, Build & Test (PIT) | Complete | COMPLETE | T3-DB-0035 | SITAG | T3 |  |
| 84 | 1.3.3.2.3 | DIP Simulator uplifted to align with design releases - design/build/test |  | 20d | 2023-10-09 A | 2023-11-03 A | 127FS+2d | 100% |  | 2023-10-09 | 2023-11-03 | 20d |  |  |  |  |  | Rebecca Farooq | 160h | 160h |  | SI DevOps |  | 5.3 | Design, Build & Test (PIT) | Complete | COMPLETE |  |  |  |  |
| 85 | 1.3.3.2.4 | DIP Simulator uplifted to align with Interim Release 5 | milestone | 0d | 2023-11-03 A | 2023-11-03 A | 84 | 100% |  | 2023-11-03 | 2023-11-03 | 0d |  |  |  |  |  | Rebecca Farooq |  |  |  | SI DevOps |  | 5.11 | Design, Build & Test (PIT) | Complete | COMPLETE | T3-DB-0039 | SITAG | T3 |  |
| 86 | 1.3.3.2.5 | DIP Simulator uplifted to align with design releases - design/build/test |  | 37d | 2024-02-01 A | 2024-03-22 A | 135 | 100% |  | 2024-02-01 | 2024-03-22 | 37d |  |  |  |  |  | Matthew Bray | 296h | 296h |  | SI DevOps | PP,SRO,Testing | 5.14 | Design, Build & Test (PIT) | Complete | COMPLETE |  |  |  |  |
| 87 | 1.3.3.2.6 | DIP Simulator uplifted to align with Interim Release 7 | milestone | 0d | 2024-03-22 A | 2024-03-22 A | 86 | 100% |  | 2024-03-22 | 2024-03-22 | 0d |  |  |  |  |  | Matthew Bray |  |  |  | SI DevOps | PP,SRO,Testing | 5.14 | Design, Build & Test (PIT) | Complete | COMPLETE | T3-DB-0182 | SITAG | T3 |  |
| 88 | 1.3.3.2.7 | DIP Simulator uplifted to align with design releases - design/build/test |  | 57d | 2024-04-04 | 2024-06-21 | 139 |  |  | 2024-04-04 | 2024-06-21 | 57d |  |  | 765d | 0d |  | Matthew Bray | 456h |  |  | SI DevOps | PP,SRO,Testing | 5.14 | Design, Build & Test (PIT) | Overdue Start | GREEN |  |  |  | -13.67 |
| 89 | 1.3.3.2.8 | DIP Simulator uplifted to align with Interim Release 8 | milestone | 0d | 2024-06-21 | 2024-06-21 | 88 |  |  | 2024-06-21 | 2024-06-21 | 0d |  |  | 765d |  |  | Matthew Bray |  |  |  | SI DevOps | PP,SRO,Testing | 5.14 | Design, Build & Test (PIT) | Green | GREEN | T3-DB-0183 | SITAG | T3 | 64.71 |
| 90 | 1.3.3.3 | **Data Generator** |  | 130d | 2022-12-01 A | 2023-05-31 A |  | 100% |  | 2022-12-01 | 2023-05-31 | 130d | 2022-12-01 | 2023-05-31 |  |  |  | N/A | 2192h | 2192h |  | N/A | N/A | 5.0 | Design, Build & Test (PIT) |  |  |  |  |  |  |
| 91 | 1.3.3.3.1 | Design | manual | 15d | 2022-12-01 A | 2022-12-21 A |  | 100% |  | 2022-12-01 | 2022-12-21 | 15d | 2022-12-01 | 2022-12-21 |  |  |  | Rebecca Farooq | 120h | 120h |  | SI DevOps |  | 5.0 | Design, Build & Test (PIT) | Complete | COMPLETE |  |  |  |  |
| 92 | 1.3.3.3.2 | Build & Test |  | 50d | 2023-02-16 A | 2023-04-26 A | 91FS+40d | 100% |  | 2023-02-16 | 2023-04-26 | 50d | 2023-02-16 | 2023-04-26 |  |  |  | Rebecca Farooq | 400h | 400h |  | SI DevOps |  | 5.0 | Design, Build & Test (PIT) | Complete | COMPLETE |  |  |  |  |
| 93 | 1.3.3.3.3 | UAT |  | 10d | 2023-04-27 A | 2023-05-10 A | 92 | 100% |  | 2023-04-27 | 2023-05-10 | 10d | 2023-04-27 | 2023-05-10 |  |  |  | Rebecca Farooq | 80h | 80h |  | SI Test |  | 5.0 | Design, Build & Test (PIT) | Complete | COMPLETE |  |  |  |  |
| 94 | 1.3.3.3.4 | Beta test |  | 45d | 2023-03-30 A | 2023-05-31 A | 92FS-20d, 96FF | 100% |  | 2023-03-30 | 2023-05-31 | 45d | 2023-03-30 | 2023-05-31 |  |  |  | Rebecca Farooq | 360h | 360h |  | PP | SI Test | 5.0 | Design, Build & Test (PIT) | Complete | COMPLETE |  |  |  |  |
| 95 | 1.3.3.3.5 | Prepare for release |  | 24d | 2023-04-27 A | 2023-05-30 A | 93SS | 100% |  | 2023-04-27 | 2023-05-30 | 24d | 2023-04-27 | 2023-05-30 |  |  |  | Rebecca Farooq | 192h | 192h |  | SI DevOps |  | 5.0 | Design, Build & Test (PIT) | Complete | COMPLETE |  |  |  |  |
| 96 | 1.3.3.3.6 | Data Generator released | milestone | 0d | 2023-05-31 A | 2023-05-31 A | 95FS+1d | 100% |  | 2023-05-31 | 2023-05-31 | 0d | 2023-05-31 | 2023-05-31 |  |  |  | Rebecca Farooq |  |  |  | SI DevOps |  | 5.0 | Design, Build & Test (PIT) | Complete | COMPLETE | T3-DB-0022 | SITAG | T3 |  |
| 97 | 1.3.4 | **Design Artefact Releases** |  | 398d | 2023-02-22 A | 2024-08-30 |  | 92% | 32.1d | 2023-02-22 | 2024-08-30 | 398d | 2023-02-22 | 2023-09-29 | -5d | 0d |  | N/A | 13144h | 6449.41h | -0 | N/A | N/A | 5.0 | Design, Build & Test (PIT) |  |  |  |  |  |  |
| 98 | 1.3.4.1 | **Interim release 1** |  | 79d | 2023-02-22 A | 2023-06-12 A |  | 100% |  | 2023-02-22 | 2023-06-12 | 79d | 2023-02-22 | 2023-06-28 |  |  |  | N/A | 1416h | 1416h |  | N/A | N/A | 5.0 | Design, Build & Test (PIT) |  |  |  |  |  |  |
| 99 | 1.3.4.1.1 | Prioritise DINs and CR |  | 1d | 2023-02-22 A | 2023-02-22 A |  | 100% |  | 2023-02-22 | 2023-02-22 | 1d | 2023-02-22 | 2023-02-22 |  |  | must start on 2023-02-22 | Paul Pettitt | 8h | 8h |  | SI Design |  | 5.0 | Design, Build & Test (PIT) | Complete | COMPLETE |  |  |  |  |
| 100 | 1.3.4.1.2 | **Industry input session** |  | 7d | 2023-02-23 A | 2023-03-03 A |  | 100% |  | 2023-02-23 | 2023-03-03 | 7d | 2023-02-23 | 2023-03-03 |  |  |  | N/A | 96h | 96h |  | N/A | N/A | 5.0 | Design, Build & Test (PIT) |  |  |  |  |  |  |
| 101 | 1.3.4.1.2.1 | Raise a CR covering prioritized assessment cluster |  | 1d | 2023-02-23 A | 2023-02-23 A | 99 | 100% |  | 2023-02-23 | 2023-02-23 | 1d | 2023-02-23 | 2023-02-23 |  |  |  | Paul Pettitt | 8h | 8h |  | SI Design |  | 5.0 | Design, Build & Test (PIT) | Complete | COMPLETE |  |  |  |  |
| 102 | 1.3.4.1.2.2 | Organize Industry Input session to go through significant items to reach consensus |  | 1d | 2023-02-23 A | 2023-02-23 A | 101SS | 100% |  | 2023-02-23 | 2023-02-23 | 1d | 2023-02-23 | 2023-02-23 |  |  |  | Paul Pettitt; Berlinda Kugara | 16h | 16h |  | SI Design | PP | 5.0 | Design, Build & Test (PIT) | Complete | COMPLETE |  |  |  |  |
| 103 | 1.3.4.1.2.3 | Conduct Meeting |  | 1d | 2023-03-03 A | 2023-03-03 A | 102FS+5d | 100% |  | 2023-03-03 | 2023-03-03 | 1d | 2023-03-03 | 2023-03-03 |  |  |  | Paul Pettitt; Berlinda Kugara | 16h | 16h |  | SI Design | PP | 5.0 | Design, Build & Test (PIT) | Complete | COMPLETE |  |  |  |  |
| 104 | 1.3.4.1.3 | Update baselined artefacts |  | 10d | 2023-03-24 A | 2023-04-06 A |  | 100% |  | 2023-03-24 | 2023-04-06 | 10d | 2023-03-24 | 2023-04-06 |  |  |  | Paul Pettitt | 80h | 80h |  | SI Design |  | 5.0 | Design, Build & Test (PIT) | Complete | COMPLETE |  |  |  |  |

Notes:
- 85: Amber as S&E couldn't view design docs, & assess scope changes. Required workload likely more than 2 sprints (original estimate). Additional MS work & CIT testing support has stretched capacity further. Delivery could be delayed. / Action: 26/7/23 - forecast changed from 15/12/23 - 3/11/23 - Changed from Interim Release 6 to 5. Updated in milestone register
- 87: 11/12- Add new milestone to reflect confirmation of Interim Release Delivery dates. 20/12 - Approved at TMAG on 20/12
- 89: 11/12- Add new milestone to reflect confirmation of Interim Release Delivery dates 20/12 - Approved at TMAG on 20/12

| ID | WBS | Task | Type | Duration | Start | Finish | Predecessors | Complete | Remaining | Baseline start | Baseline finish | Baseline duration | Baseline 1 start | Baseline 1 finish | Total slack | Constraint | Resources | Work | Actual work | Baseline cost | Responsible | Involved | Update Version | MHHS Programme Phase | Sched Status | RAG | Milestone ID | Text29 | Tier | Action |
| --- | --- | --- | --- | --- | --- | --- | --- | --- | --- | --- | --- | --- | --- | --- | --- | --- | --- | --- | --- | --- | --- | --- | --- | --- | --- | --- | --- | --- | --- | --- |
| 105 | 1.3.4.1.4 | **Participant review and impact assess changes** |  | 18d | 2023-04-14 A | 2023-05-09 A |  | 100% |  | 2023-04-14 | 2023-05-09 | 18d | 2023-04-14 | 2023-05-09 |  |  | N/A | 288h | 288h |  | N/A | N/A | 5.0 | Design, Build & Test (PIT) |  |  |  |  |  |  |
| 106 | 1.3.4.1.4.1 | Issue Redline Version of documents |  | 1d | 2023-04-14 A | 2023-04-14 A | 104FS+5d | 100% |  | 2023-04-14 | 2023-04-14 | 1d | 2023-04-14 | 2023-04-14 |  |  | Paul Pettitt | 8h | 8h |  | SI Design |  | 5.0 | Design, Build & Test (PIT) | Complete | COMPLETE |  |  |  |  |
| 107 | 1.3.4.1.4.2 | Participants provide review comments to common log |  | 17d | 2023-04-17 A | 2023-05-09 A | 106 | 100% |  | 2023-04-17 | 2023-05-09 | 17d | 2023-04-17 | 2023-05-09 |  |  | Paul Pettitt | 136h | 136h |  | PP |  | 5.0 | Design, Build & Test (PIT) | Complete | COMPLETE |  |  |  |  |
| 108 | 1.3.4.1.5 | **Assurance review** |  | 19d | 2023-05-10 A | 2023-06-05 A |  | 100% |  | 2023-05-10 | 2023-06-05 | 19d | 2023-05-10 | 2023-06-05 |  |  | N/A | 304h | 304h |  | N/A | N/A | 5.0 | Design, Build & Test (PIT) |  |  |  |  |  |  |
| 109 | 1.3.4.1.5.1 | SI Design Review and Respond to Comments |  | 5d | 2023-05-10 A | 2023-05-16 A | 107 | 100% |  | 2023-05-10 | 2023-05-16 | 5d | 2023-05-10 | 2023-05-16 |  |  | Paul Pettitt | 40h | 40h |  | SI Design |  | 5.0 | Design, Build & Test (PIT) | Complete | COMPLETE |  |  |  |  |
| 110 | 1.3.4.1.5.2 | Prep for Assurance Review Meeting |  | 7d | 2023-05-17 A | 2023-05-25 A | 109 | 100% |  | 2023-05-17 | 2023-05-25 | 7d | 2023-05-17 | 2023-05-25 |  |  | Paul Pettitt | 56h | 56h |  | SI Design |  | 5.0 | Design, Build & Test (PIT) | Complete | COMPLETE |  |  |  |  |
| 111 | 1.3.4.1.5.3 | Conduct Assurance Review Meeting |  | 1d | 2023-05-26 A | 2023-05-26 A | 110 | 100% |  | 2023-05-26 | 2023-05-26 | 1d | 2023-05-26 | 2023-05-26 |  |  | Paul Pettitt | 8h | 8h |  | SI Design |  | 5.0 | Design, Build & Test (PIT) | Complete | COMPLETE |  |  |  |  |
| 112 | 1.3.4.1.5.4 | Update Artefacts following Assurance Review |  | 6d | 2023-05-29 A | 2023-06-05 A | 111 | 100% |  | 2023-05-29 | 2023-06-05 | 6d | 2023-05-29 | 2023-06-05 |  |  | Paul Pettitt | 48h | 48h |  | SI Design |  | 5.0 | Design, Build & Test (PIT) | Complete | COMPLETE |  |  |  |  |
| 113 | 1.3.4.1.6 | PSG Approval of interim release plan |  | 1d | 2023-06-08 A | 2023-06-08 A |  | 100% |  | 2023-06-08 | 2023-06-08 | 1d |  |  |  | must start on 2023-06-08 | Paul Pettitt | 8h | 8h |  | PP | SI Design | 5.1 | Design, Build & Test (PIT) | Complete | COMPLETE |  |  |  |  |
| 114 | 1.3.4.1.7 | Publish updated baselined artefacts | milestone | 0d | 2023-06-06 A | 2023-06-12 A | 112 | 100% |  | 2023-06-06 | 2023-06-12 | 5d | 2023-06-15 | 2023-06-21 |  |  | Paul Pettitt |  |  |  | SI Design |  | 5.0 | Design, Build & Test (PIT) | Complete | COMPLETE |  |  |  |  |
| 115 | 1.3.4.1.8 | Interim release 1 Go live | milestone | 0d | 2023-06-12 A | 2023-06-12 A | 114 | 100% |  | 2023-06-12 | 2023-06-12 | 0d | 2023-06-28 | 2023-06-28 |  |  | Paul Pettitt |  |  |  | SI Design |  | 5.0 | Design, Build & Test (PIT) | Complete | COMPLETE | T3-DB-0095 | DAG | T3 |  |
| 116 | 1.3.4.2 | **Interim release 2** |  | 27d | 2023-05-30 A | 2023-07-05 A |  | 100% |  | 2023-05-30 | 2023-07-05 | 27d | 2023-05-24 | 2023-07-28 |  |  | N/A | 432h | 432h |  | N/A | N/A | 5.0 | Design, Build & Test (PIT) |  |  |  |  |  |  |
| 117 | 1.3.4.2.1 | Update baselined artefacts |  | 27d | 2023-05-30 A | 2023-07-05 A |  | 100% |  | 2023-05-30 | 2023-07-05 | 27d |  |  |  | must start on 2023-05-30 | Paul Pettitt | 216h | 216h |  | SI Design | PP | 5.1 | Design, Build & Test (PIT) | Complete | COMPLETE |  |  |  |  |
| 118 | 1.3.4.2.2 | Interim release 2 Go live | milestone | 0d | 2023-07-05 A | 2023-07-05 A | 117 | 100% |  | 2023-07-05 | 2023-07-05 | 0d | 2023-07-28 | 2023-07-28 |  |  | Paul Pettitt |  |  |  | SI Design |  | 5.0 | Design, Build & Test (PIT) | Complete | COMPLETE | T3-DB-0096 | DAG | T3 |  |
| 119 | 1.3.4.3 | **Interim release 3** |  | 35d | 2023-06-15 A | 2023-08-02 A |  | 100% |  | 2023-06-15 | 2023-08-02 | 35d | 2023-06-29 | 2023-09-29 |  |  | N/A | 560h | 560h |  | N/A | N/A | 5.0 | Design, Build & Test (PIT) |  |  |  |  |  |  |
| 120 | 1.3.4.3.1 | Update baselined artefacts |  | 35d | 2023-06-15 A | 2023-08-02 A |  | 100% |  | 2023-06-15 | 2023-08-02 | 35d |  |  |  | must start on 2023-06-15 | Paul Pettitt | 280h | 280h |  | SI Design | PP | 5.1 | Design, Build & Test (PIT) | Complete | COMPLETE |  |  |  |  |
| 121 | 1.3.4.3.2 | Interim release 3 Go live | milestone | 0d | 2023-08-02 A | 2023-08-02 A | 120 | 100% |  | 2023-08-02 | 2023-08-02 | 0d | 2023-09-29 | 2023-09-29 |  |  | Paul Pettitt |  |  |  | SI Design |  | 5.0 | Design, Build & Test (PIT) | Complete | COMPLETE | T3-DB-0097 | DAG | T3 |  |
| 122 | 1.3.4.4 | **Interim release 4** |  | 36d | 2023-07-12 A | 2023-08-30 A |  | 100% |  | 2023-07-12 | 2023-08-30 | 36d |  |  |  |  | N/A | 576h | 576h |  | N/A | N/A | 5.1 | Design, Build & Test (PIT) |  |  |  |  |  |  |
| 123 | 1.3.4.4.1 | Update baselined artefacts |  | 36d | 2023-07-12 A | 2023-08-30 A |  | 100% |  | 2023-07-12 | 2023-08-30 | 36d |  |  |  | must start on 2023-07-12 | Paul Pettitt | 288h | 288h |  | SI Design | PP | 5.1 | Design, Build & Test (PIT) | Complete | COMPLETE |  |  |  |  |
| 124 | 1.3.4.4.2 | Interim release 4 Go live | milestone | 0d | 2023-08-30 A | 2023-08-30 A | 123 | 100% |  | 2023-08-30 | 2023-08-30 | 0d |  |  |  |  | Paul Pettitt |  |  |  | SI Design |  | 5.1 | Design, Build & Test (PIT) | Complete | COMPLETE | T3-DB-0081 | DAG | T3 |  |
| 125 | 1.3.4.5 | **Interim release 5** |  | 147d | 2023-08-17 A | 2024-03-08 |  | 99% | 0d | 2023-08-17 | 2024-03-08 | 147d |  |  | 0d |  | N/A | 1536h | 632.22h | -0 | N/A | N/A | 5.1 | Design, Build & Test (PIT) |  |  |  |  |  |  |
| 126 | 1.3.4.5.1 | Update baselined artefacts |  | 35d | 2023-08-17 A | 2023-10-04 A |  | 100% |  | 2023-08-17 | 2023-10-04 | 35d |  |  |  | must start on 2023-08-17 | Paul Pettitt | 280h | 280h |  | SI Design | PP | 5.1 | Design, Build & Test (PIT) | Complete | COMPLETE |  |  |  |  |
| 127 | 1.3.4.5.2 | Interim release 5 Go live | milestone | 0d | 2023-10-04 A | 2023-10-04 A | 126 | 100% |  | 2023-10-04 | 2023-10-04 | 0d |  |  |  |  | Paul Pettitt |  |  |  | SI Design |  | 5.1 | Design, Build & Test (PIT) | Complete | COMPLETE | T3-DB-0083 | DAG | T3 | 11/8 - successor is SIT functional (starts in march) |
| 128 | 1.3.4.5.3 | Interim Release 5 Deployed to SIT |  | 10d | 2024-02-26 A | 2024-03-08 A | 127FS+102d | 100% |  | 2024-02-26 | 2024-03-08 | 10d |  |  |  |  | Lee Cox | 80h | 80h |  | SI Testing | PP | 5.16 |  | Complete | COMPLETE |  |  |  |  |

| ID | WBS | Task | Type | Duration | Start | Finish | Predecessors | Complete | Remaining | Baseline start | Baseline finish | Baseline duration | Baseline 1 start | Baseline 1 finish | Total slack | Free slack | Constraint | Resources | Work | Actual work | Baseline cost | Responsible | Involved | Update Version | MHHS Programme Phase | Sched Status | RAG | Milestone ID | Text29 | Tier | Task Status | Action |
| --- | --- | --- | --- | --- | --- | --- | --- | --- | --- | --- | --- | --- | --- | --- | --- | --- | --- | --- | --- | --- | --- | --- | --- | --- | --- | --- | --- | --- | --- | --- | --- | --- |
| 129 | 1.3.4.6 | **Interim release 6** |  | 192d | 2023-09-14 A | 2024-06-07 |  | 78% | 42.67d | 2023-09-14 | 2024-06-07 | 192d |  |  | -5d | 0d |  | N/A | 1896h | 552.22h | -0 | N/A | N/A | 5.1 | Design, Build & Test (PIT) |  |  |  |  |  |  |  |
| 130 | 1.3.4.6.1 | Update baselined artefacts |  | 35d | 2023-09-14 A | 2023-11-01 A |  | 100% |  | 2023-09-14 | 2023-10-27 | 32d |  |  |  |  | must start on 2023-09-14 | Paul Pettitt | 280h | 280h |  | SI Design | PP | 5.1 | Design, Build & Test (PIT) | Complete | COMPLETE |  |  |  |  |  |
| 131 | 1.3.4.6.2 | Interim release 6 Go live | milestone | 0d | 2023-11-01 A | 2023-11-01 A | 130 | 100% |  | 2023-10-27 | 2023-10-27 | 0d |  |  |  |  |  | Paul Pettitt |  |  |  | SI Design |  | 5.11 | Design, Build & Test (PIT) | Complete | COMPLETE | T3-DB-0085 | DAG | T3 |  |  |
| 132 | 1.3.4.6.3 | Interim Release 6 Deployed to SIT |  | 10d | 2024-05-27 | 2024-06-07 | 131FS+147d |  |  | 2024-05-27 | 2024-06-07 | 10d |  |  | -5d | 0d |  | Lee Cox | 80h |  |  | SI Testing | PP | 5.16 |  | Green | GREEN |  |  |  | 39.33 |  |
| 133 | 1.3.4.7 | **Interim release 7** |  | 168d | 2023-10-18 A | 2024-06-07 |  | 88% | 19.53d | 2023-10-18 | 2024-06-07 | 168d |  |  | -5d | 0d |  | N/A | 2032h | 1089.66h | -0 | N/A | N/A | 5.5 | Design, Build & Test (PIT) |  |  |  |  |  |  |  |
| 134 | 1.3.4.7.1 | Update baselined artefacts |  | 76d | 2023-10-18 A | 2024-01-31 A |  | 100% |  | 2023-10-18 | 2024-01-31 | 76d |  |  |  |  | start no earlier than 2023-10-18 | Paul Pettitt | 608h | 608h |  | SI Design | PP | 5.5 | Design, Build & Test (PIT) | Complete | COMPLETE |  |  |  |  |  |
| 135 | 1.3.4.7.2 | Interim release 7 Go live | milestone | 0d | 2024-01-31 A | 2024-01-31 A | 134 | 100% |  | 2024-01-31 | 2024-01-31 | 0d |  |  |  |  |  | Paul Pettitt |  |  |  | SI Design | PP | 5.14 | Design, Build & Test (PIT) | Complete | COMPLETE | T3-DB-0098 | DAG | T3 |  | 4/8 - add as t3 milestones. Awaiting approval at TMAG |
| 136 | 1.3.4.7.3 | Interim Release 7 Deployed to SIT |  | 10d | 2024-05-27 | 2024-06-07 | 135FS+82d |  |  | 2024-05-27 | 2024-06-07 | 10d |  |  | -5d | 0d |  | Lee Cox | 80h |  |  | SI Testing | PP | 5.16 |  | Green | GREEN |  |  |  | 39.33 |  |
| 137 | 1.3.4.8 | **Interim release 8** |  | 143d | 2024-02-14 A | 2024-08-30 |  | 78% | 31.09d | 2024-02-14 | 2024-08-30 | 143d |  |  | -5d | 0d |  | N/A | 1512h | 1183.31h | -0 | N/A | N/A | 5.5 | Design, Build & Test (PIT) |  |  |  |  |  |  |  |
| 138 | 1.3.4.8.1 | Update baselined artefacts |  | 36d | 2024-02-14 A | 2024-04-03 A |  | 100% |  | 2024-02-14 | 2024-04-03 | 36d |  |  |  |  | start no earlier than 2024-02-14 | Paul Pettitt | 288h | 288h |  | SI Design | PP | 5.5 | Design, Build & Test (PIT) | Complete | COMPLETE |  |  |  |  |  |
| 139 | 1.3.4.8.2 | Interim release 8 Go live | milestone | 0d | 2024-04-03 A | 2024-04-03 A | 138 | 100% |  | 2024-04-03 | 2024-04-03 | 0d |  |  |  |  | start no earlier than 2024-01-10 | Paul Pettitt |  |  |  | SI Design | PP | 5.14 | Design, Build & Test (PIT) | Complete | COMPLETE | T3-DB-0099 | DAG | T3 |  | 4/8 - add as t3 milestones. Awaiting approval at TMAG |
| 140 | 1.3.4.8.3 | Interim Release 8 Deployed to SIT |  | 10d | 2024-08-19 | 2024-08-30 | 139FS+97d |  |  | 2024-08-19 | 2024-08-30 | 10d |  |  | -5d | 0d |  | Lee Cox | 80h |  |  | SI Testing | PP | 5.16 |  | Green | GREEN |  |  |  | 123.33 |  |
| 141 | 1.3.5 | **Queries Support / Knowledgebase & Tool Roll-Out (Systems)** |  | 325d | 2023-01-03 A | 2024-04-01 |  | 99% | 0d | 2023-01-03 | 2024-04-01 | 325d | 2023-01-03 | 2024-04-01 | 0d |  |  | N/A | 11920h | 10184h |  | N/A | N/A | 5.0 | Design, Build & Test (PIT) |  |  |  |  |  |  |  |
| 142 | 1.3.5.1 | **Query Management** |  | 325d | 2023-01-03 A | 2024-04-01 A |  | 100% |  | 2023-01-03 | 2024-04-01 | 325d | 2023-01-03 | 2024-04-01 |  |  |  | N/A | 7800h | 7800h |  | N/A | N/A | 5.0 | Design, Build & Test (PIT) |  |  |  |  |  |  |  |
| 143 | 1.3.5.1.1 | Respond to Participant Queries |  | 325d | 2023-01-03 A | 2024-04-01 A |  | 100% |  | 2023-01-03 | 2024-04-01 | 325d | 2023-01-03 | 2024-04-01 |  |  | must start on 2023-01-03 | Paul Pettitt | 2600h | 2600h |  | SI Design | PP | 5.0 | Design, Build & Test (PIT) | Complete | COMPLETE |  |  |  |  | 11/8 - runs out to end of the programme |
| 144 | 1.3.5.1.2 | Respond to Programme Queries |  | 325d | 2023-01-03 A | 2024-04-01 A | 143SS | 100% |  | 2023-01-03 | 2024-04-01 | 325d | 2023-01-03 | 2024-04-01 |  |  |  | Paul Pettitt | 2600h | 2600h |  | SI Design | PP | 5.0 | Design, Build & Test (PIT) | Complete | COMPLETE |  |  |  |  | 11/8 - runs out to end of the programme |
| 145 | 1.3.5.2 | **Query Support tooling (FreshDesk)** |  | 23d | 2023-06-01 A | 2023-07-03 A |  | 100% |  | 2023-06-01 | 2023-07-03 | 23d | 2023-06-01 | 2023-07-03 |  |  |  | N/A | 368h | 368h |  | N/A | N/A | 5.0 | Design, Build & Test (PIT) |  |  |  |  |  |  |  |
| 146 | 1.3.5.2.1 | Migrate to Standalone Freshdesk |  | 10d | 2023-06-01 A | 2023-06-14 A |  | 100% |  | 2023-06-01 | 2023-06-14 | 10d | 2023-06-01 | 2023-06-14 |  |  | must start on 2023-06-01 | Paul Pettitt | 80h | 80h |  | SI Design |  | 5.0 | Design, Build & Test (PIT) | Complete | COMPLETE |  |  |  |  |  |
| 147 | 1.3.5.2.2 | Develop reporting dashboard |  | 5d | 2023-06-15 A | 2023-06-21 A | 146 | 100% |  | 2023-06-15 | 2023-06-21 | 5d | 2023-06-15 | 2023-06-21 |  |  |  | Paul Pettitt | 40h | 40h |  | SI Design |  | 5.0 | Design, Build & Test (PIT) | Complete | COMPLETE |  |  |  |  |  |
| 148 | 1.3.5.2.3 | Issue to SRO for Review |  | 5d | 2023-06-22 A | 2023-06-28 A | 147 | 100% |  | 2023-06-22 | 2023-06-28 | 5d | 2023-06-22 | 2023-06-28 |  |  |  | Paul Pettitt | 40h | 40h |  | SI Design |  | 5.0 | Design, Build & Test (PIT) | Complete | COMPLETE |  |  |  |  |  |
| 149 | 1.3.5.2.4 | Update following review |  | 2d | 2023-06-29 A | 2023-06-30 A | 148 | 100% |  | 2023-06-29 | 2023-06-30 | 2d | 2023-06-29 | 2023-06-30 |  |  |  | Paul Pettitt | 16h | 16h |  | SI Design |  | 5.0 | Design, Build & Test (PIT) | Complete | COMPLETE |  |  |  |  |  |
| 150 | 1.3.5.2.5 | Sign off |  | 1d | 2023-07-03 A | 2023-07-03 A | 149 | 100% |  | 2023-07-03 | 2023-07-03 | 1d | 2023-07-03 | 2023-07-03 |  |  |  | Paul Pettitt | 8h | 8h |  | SI Design |  | 5.0 | Design, Build & Test (PIT) | Complete | COMPLETE |  |  |  |  |  |
| 151 | 1.3.5.3 | **KnowledgeBase Development** |  | 72d | 2023-06-01 A | 2023-09-08 A |  | 100% |  | 2023-06-01 | 2023-09-08 | 72d | 2023-06-01 | 2023-09-08 |  |  |  | N/A | 1152h | 1152h |  | N/A | N/A | 5.0 | Design, Build & Test (PIT) |  |  |  |  |  |  |  |
| 152 | 1.3.5.3.1 | Define Scope of KB |  | 1d | 2023-06-01 A | 2023-06-01 A | 146SS | 100% |  | 2023-06-01 | 2023-06-01 | 1d | 2023-06-01 | 2023-06-01 |  |  |  | Paul Pettitt | 8h | 8h |  | SI Design |  | 5.0 | Design, Build & Test (PIT) | Complete | COMPLETE |  |  |  |  |  |
| 153 | 1.3.5.3.2 | Capture Existing KB artefacts |  | 20d | 2023-06-02 A | 2023-06-29 A | 152 | 100% |  | 2023-06-02 | 2023-06-29 | 20d | 2023-06-02 | 2023-06-29 |  |  |  | Paul Pettitt | 160h | 160h |  | SI Design |  | 5.0 | Design, Build & Test (PIT) | Complete | COMPLETE |  |  |  |  |  |
| 154 | 1.3.5.3.3 | Tag artefacts |  | 5d | 2023-06-30 A | 2023-07-06 A | 153 | 100% |  | 2023-06-30 | 2023-07-06 | 5d | 2023-06-30 | 2023-07-06 |  |  |  | Paul Pettitt | 40h | 40h |  | SI Design |  | 5.0 | Design, Build & Test (PIT) | Complete | COMPLETE |  |  |  |  |  |
| 155 | 1.3.5.3.4 | Develop Participant Interfaces |  | 20d | 2023-07-07 A | 2023-08-03 A | 154 | 100% |  | 2023-07-07 | 2023-08-03 | 20d | 2023-07-07 | 2023-08-03 |  |  |  | Paul Pettitt | 160h | 160h |  | SI Design |  | 5.0 | Design, Build & Test (PIT) | Complete | COMPLETE |  |  |  |  |  |
| 156 | 1.3.5.3.5 | Promote to Collaboration Portal |  | 21d | 2023-08-04 A | 2023-09-01 A | 155 | 100% |  | 2023-08-04 | 2023-09-01 | 21d | 2023-08-04 | 2023-09-01 |  |  |  | Paul Pettitt | 168h | 168h |  | SI Design |  | 5.0 | Design, Build & Test (PIT) | Complete | COMPLETE |  |  |  |  |  |
| 157 | 1.3.5.3.6 | Link into FreshDesk |  | 5d | 2023-09-04 A | 2023-09-08 A | 156 | 100% |  | 2023-09-04 | 2023-09-08 | 5d | 2023-09-04 | 2023-09-08 |  |  |  | Paul Pettitt | 40h | 40h |  | SI Design |  | 5.0 | Design, Build & Test (PIT) | Complete | COMPLETE |  |  |  |  |  |

Notes:
- 134: 4/8 - Added in as per PPs advice
- 135: 27/11- Red because forecast date has changed to align with Testing Release Management. Discusssed with no objections at FTIG on 23/11. To be taken to Dec DAG for noting
- 138: 4/8 - Added in as per PPs advice
- 139: 27/11- Amber because forecast date has changed to align with Testing Release Management. Discusssed with no objections at FTIG on 23/11. To be taken to Dec DAG for noting

| ID | WBS | Task | Type | Duration | Start | Finish | Predecessors | Complete | Remaining | Baseline start | Baseline finish | Baseline duration | Baseline 1 start | Baseline 1 finish | Total slack | Free slack | Resources | Work | Actual work | Baseline cost | Responsible | Involved | Update Version | MHHS Programme Phase | Sched Status | RAG | Task Status | Milestone ID | Text29 | Tier |
| --- | --- | --- | --- | --- | --- | --- | --- | --- | --- | --- | --- | --- | --- | --- | --- | --- | --- | --- | --- | --- | --- | --- | --- | --- | --- | --- | --- | --- | --- | --- |
| 158 | 1.3.6 | **PP Design, Build & Test (DBT)** |  | 495d | 2022-10-31 A | 2024-09-20 |  | 91% | 46.8d | 2022-10-31 | 2026-02-16 | 861d | 2022-10-31 | 2026-02-16 | -2d | 0d | N/A | 63280h | 49301.4h | -0 | N/A | N/A | 5.0 | Design, Build & Test (PIT) |  |  |  |  |  |  |
| 159 | 1.3.6.1 | **PP Impact Assessment, Planning & Procurement** |  | 110d | 2022-10-31 A | 2023-03-31 A |  | 100% |  | 2022-10-31 | 2023-03-31 | 110d | 2022-10-31 | 2023-03-31 |  |  | N/A | 6040h | 6040h |  | N/A | N/A | 5.0 | Design, Build & Test (PIT) |  |  |  |  |  |  |
| 160 | 1.3.6.1.1 | **PP Impact Assessment** |  | 67d | 2022-10-31 A | 2023-01-31 A |  | 100% |  | 2022-10-31 | 2023-01-31 | 67d | 2022-10-31 | 2023-01-31 |  |  | N/A | 1608h | 1608h |  | N/A | N/A | 5.0 | Design, Build & Test (PIT) |  |  |  |  |  |  |
| 161 | 1.3.6.1.1.1 | Develop heatmap for impact of MHHS |  | 67d | 2022-10-31 A | 2023-01-31 A | 48 | 100% |  | 2022-10-31 | 2023-01-31 | 67d | 2022-10-31 | 2023-01-31 |  |  | PP | 536h | 536h |  | PP |  | 5.0 | Design, Build & Test (PIT) | Complete | COMPLETE |  |  |  |  |
| 162 | 1.3.6.1.1.2 | Develop detailed impact assessment |  | 67d | 2022-10-31 A | 2023-01-31 A | 48 | 100% |  | 2022-10-31 | 2023-01-31 | 67d | 2022-10-31 | 2023-01-31 |  |  | PP | 536h | 536h |  | PP |  | 5.0 | Design, Build & Test (PIT) | Complete | COMPLETE |  |  |  |  |
| 163 | 1.3.6.1.2 | **PP Planning** |  | 67d | 2022-10-31 A | 2023-01-31 A |  | 100% |  | 2022-10-31 | 2023-01-31 | 67d | 2022-10-31 | 2023-01-31 |  |  | N/A | 1792h | 1792h |  | N/A | N/A | 5.0 | Design, Build & Test (PIT) |  |  |  |  |  |  |
| 164 | 1.3.6.1.2.1 | Develop detailed short-term plan |  | 23d | 2022-10-31 A | 2022-11-30 A | 48 | 100% |  | 2022-10-31 | 2022-11-30 | 23d | 2022-10-31 | 2022-11-30 |  |  | PP | 184h | 184h |  | PP |  | 5.0 | Design, Build & Test (PIT) | Complete | COMPLETE |  |  |  |  |
| 165 | 1.3.6.1.2.2 | Develop overall project plan for implementation |  | 67d | 2022-10-31 A | 2023-01-31 A | 48 | 100% |  | 2022-10-31 | 2023-01-31 | 67d | 2022-10-31 | 2023-01-31 |  |  | PP | 536h | 536h |  | PP |  | 5.0 | Design, Build & Test (PIT) | Complete | COMPLETE |  |  |  |  |
| 166 | 1.3.6.1.2.3 | Develop procurement plan |  | 67d | 2022-10-31 A | 2023-01-31 A | 48 | 100% |  | 2022-10-31 | 2023-01-31 | 67d | 2022-10-31 | 2023-01-31 |  |  | PP | 536h | 536h |  | PP |  | 5.0 | Design, Build & Test (PIT) | Complete | COMPLETE |  |  |  |  |
| 167 | 1.3.6.1.3 | **PP Software/Service Procurement** |  | 110d | 2022-10-31 A | 2023-03-31 A |  | 100% |  | 2022-10-31 | 2023-03-31 | 110d | 2022-10-31 | 2023-03-31 |  |  | N/A | 1760h | 1760h |  | N/A | N/A | 5.0 | Design, Build & Test (PIT) |  |  |  |  |  |  |
| 168 | 1.3.6.1.3.1 | Run tender process |  | 67d | 2022-10-31 A | 2023-01-31 A | 48 | 100% |  | 2022-10-31 | 2023-01-31 | 67d | 2022-10-31 | 2023-01-31 |  |  | PP | 536h | 536h |  | PP |  | 5.0 | Design, Build & Test (PIT) | Complete | COMPLETE |  |  |  |  |
| 169 | 1.3.6.1.3.2 | Select provider & sign commercials |  | 43d | 2023-02-01 A | 2023-03-31 A | 168 | 100% |  | 2023-02-01 | 2023-03-31 | 43d | 2023-02-01 | 2023-03-31 |  |  | PP | 344h | 344h |  | PP |  | 5.0 | Design, Build & Test (PIT) | Complete | COMPLETE |  |  |  |  |
| 170 | 1.3.6.2 | **Central Systems DBT** |  | 325d | 2022-10-31 A | 2024-01-26 A |  | 100% |  | 2022-10-31 | 2024-02-23 | 345d | 2022-10-31 | 2024-05-13 |  |  | N/A | 27448h | 27448h | -0 | N/A | N/A | 5.0 | Design, Build & Test (PIT) |  |  | -316.67 |  |  |  |
| 171 | 1.3.6.2.1 | **Elexon Central Systems DBT CIT (Entering at Interval 1)** |  | 248d | 2022-10-31 A | 2023-10-11 A |  | 100% |  | 2022-10-31 | 2023-10-12 | 249d | 2022-10-31 | 2023-09-29 |  |  | N/A | 10552h | 10552h | -0 | N/A | N/A | 5.0 | Design, Build & Test (PIT) |  |  |  |  |  |  |
| 172 | 1.3.6.2.1.1 | **Design and Build** |  | 235d | 2022-10-31 A | 2023-09-22 A |  | 100% |  | 2022-10-31 | 2023-09-29 | 240d | 2022-10-31 | 2023-09-29 |  |  | N/A | 3760h | 3760h |  | N/A | N/A | 5.0 | Design, Build & Test (PIT) |  |  | -259.67 |  |  |  |
| 173 | 1.3.6.2.1.1.1 | Helix Design and Build |  | 235d | 2022-10-31 A | 2023-09-22 A | 2 | 100% |  | 2022-10-31 | 2023-09-29 | 240d | 2022-10-31 | 2023-09-29 |  |  | Lee Cox | 1880h | 1880h |  | PP | SI Test | 5.0 | Design, Build & Test (PIT) | Complete | COMPLETE |  |  |  |  |
| 174 | 1.3.6.2.1.2 | **Test Approach & Plan** |  | 235d | 2022-10-31 A | 2023-09-22 A |  | 100% |  | 2022-10-31 | 2023-09-22 | 235d | 2022-10-31 | 2023-07-21 |  |  | N/A | 3320h | 3320h | -0 | N/A | N/A | 5.0 | Design, Build & Test (PIT) |  |  |  |  |  |  |
| 175 | 1.3.6.2.1.2.1 | Develop Test Approach & Plan |  | 180d | 2022-10-31 A | 2023-07-07 A |  | 100% |  | 2022-10-31 | 2023-07-07 | 180d | 2022-10-31 | 2023-07-07 |  |  | Lee Cox | 1440h | 1440h |  | PP | SI Test | 5.0 | Design, Build & Test (PIT) | Complete | COMPLETE |  |  |  |  |
| 176 | 1.3.6.2.1.2.2 | Elexon Central Systems Test Approach & Plan (PIT) submitted to Programme for assurance | milestone | 0d | 2023-07-13 A | 2023-07-13 A | 175FF+4d | 100% |  | 2023-07-13 | 2023-07-13 | 0d | 2023-07-07 | 2023-07-07 |  |  | Lee Cox |  |  |  | PP | SI Test | 5.0 | Design, Build & Test (PIT) | Complete | COMPLETE |  | T3-DB-0029 | SITAG | T3 |
| 177 | 1.3.6.2.1.2.3 | Elexon Central Systems Test Approach & Plan (PIT) V2 resubmitted to Programme for assurance | milestone, manual | 0d | 2023-07-27 A | 2023-07-27 A | 176FS+9d | 100% |  | 2023-07-27 | 2023-07-27 | 0d |  |  |  |  | Lee Cox |  |  |  | PP | SI Test | 5.4 | Design, Build & Test (PIT) | Complete | COMPLETE |  |  |  |  |
| 178 | 1.3.6.2.1.2.4 | Elexon Central Systems Test Approach & Plan (PIT) V3 resubmitted to Programme for assurance | milestone | 0d | 2023-08-18 A | 2023-08-18 A | 177FS+17d | 100% |  | 2023-08-18 | 2023-08-18 | 0d |  |  |  |  | Lee Cox |  |  |  | PP | SI Test | 5.4 | Design, Build & Test (PIT) | Complete | COMPLETE |  |  |  |  |
| 179 | 1.3.6.2.1.2.5 | Elexon Central Systems Test approach and plan MHHS Review Completed | milestone | 0d | 2023-09-22 A | 2023-09-22 A | 178FS+25d | 100% |  | 2023-09-22 | 2023-09-22 | 0d | 2023-07-10 | 2023-07-21 |  |  | Lee Cox |  |  |  | SI Test | PP | 5.8 | Design, Build & Test (PIT) | Complete | COMPLETE |  | T3-DB-0106 | SITAG | T3 |
| 180 | 1.3.6.2.1.3 | **Test Readiness Report** |  | 16d | 2023-07-28 A | 2023-08-18 A |  | 100% |  | 2023-08-03 | 2023-10-12 | 51d | 2023-07-21 | 2023-09-29 |  |  | N/A | 256h | 256h |  | N/A | N/A | 5.0 | Design, Build & Test (PIT) |  |  |  |  |  |  |
| 181 | 1.3.6.2.1.3.1 | Test readiness reporting |  | 16d | 2023-07-28 A | 2023-08-18 A | 176FS+10d | 100% |  | 2023-08-03 | 2023-10-12 | 51d | 2023-07-21 | 2023-09-29 |  |  | Lee Cox | 128h | 128h |  | PP | 109 | 5.0 | Design, Build & Test (PIT) | Complete | COMPLETE |  |  |  |  |

Notes:
- 179: 1/9 - to be raised as new T3 at TMAG. Approved at TMAG on 20/9

| ID | WBS | Task | Type | Duration | Start | Finish | Predecessors | Complete | Baseline start | Baseline finish | Baseline duration | Baseline 1 start | Baseline 1 finish | Constraint | Resources | Work | Actual work | Baseline cost | Responsible | Involved | Update Version | MHHS Programme Phase | Artefact ID | Sched Status | RAG | Milestone ID | Text29 | Tier |
| --- | --- | --- | --- | --- | --- | --- | --- | --- | --- | --- | --- | --- | --- | --- | --- | --- | --- | --- | --- | --- | --- | --- | --- | --- | --- | --- | --- | --- |
| 182 | 1.3.6.2.1.4 | **Requirements to test Traceability Matrix (RTTM)** |  | 35d | 2023-08-04 A | 2023-09-22 A |  | 100% | 2023-08-04 | 2023-09-22 | 35d | 2022-10-31 | 2023-08-18 |  | N/A | 280h | 280h | -0 | N/A | N/A | 5.0 | Design, Build & Test (PIT) |  |  |  |  |  |  |
| 183 | 1.3.6.2.1.4.1 | Elexon Central Systems RTTM submitted to Programme for assurance | milestone | 0d | 2023-08-04 A | 2023-08-04 A | 176 | 100% | 2023-08-04 | 2023-08-04 | 0d | 2023-08-04 | 2023-08-04 | start no earlier than 2023-04-28 | Lee Cox |  |  |  | PP | SI Test | 5.0 | Design, Build & Test (PIT) | MHHS-ART009 | Complete | COMPLETE | T3-DB-0030 | SITAG | T3 |
| 184 | 1.3.6.2.1.4.2 | Elexon Central Systems RTTM MHHS Review Completed | milestone | 0d | 2023-09-22 A | 2023-09-22 A | 183FS+35d | 100% | 2023-09-22 | 2023-09-22 | 0d | 2023-08-07 | 2023-08-18 |  | Lee Cox |  |  |  | SI Test | PP | 5.8 | Design, Build & Test (PIT) |  | Complete | COMPLETE | T3-DB-0107 | SITAG | T3 |
| 185 | 1.3.6.2.1.5 | **Test Scenarios** |  | 35d | 2023-08-04 A | 2023-09-22 A |  | 100% | 2023-08-04 | 2023-09-22 | 35d | 2022-10-31 | 2023-08-18 |  | N/A | 280h | 280h | -0 | N/A | N/A | 5.0 | Design, Build & Test (PIT) |  |  |  |  |  |  |
| 186 | 1.3.6.2.1.5.1 | Elexon Central Systems test scenarios submitted to Programme for assurance | milestone | 0d | 2023-08-04 A | 2023-08-04 A | 176 | 100% | 2023-08-04 | 2023-08-04 | 0d | 2023-08-04 | 2023-08-04 |  | Lee Cox |  |  |  | PP | SI Test | 5.0 | Design, Build & Test (PIT) |  | Complete | COMPLETE | T3-DB-0032 | SITAG | T3 |
| 187 | 1.3.6.2.1.5.2 | Elexon Central Systems Test scenarios MHHS Review Completed | milestone | 0d | 2023-09-22 A | 2023-09-22 A | 186FS+35d | 100% | 2023-09-22 | 2023-09-22 | 0d | 2023-08-07 | 2023-08-18 |  | Lee Cox |  |  |  | SI Test | PP | 5.8 | Design, Build & Test (PIT) |  | Complete | COMPLETE | T3-DB-0108 | SITAG | T3 |
| 188 | 1.3.6.2.1.6 | **PIT Execution** |  | 38d | 2023-08-21 A | 2023-10-11 A |  | 100% | 2022-10-31 | 2023-10-11 | 248d | 2022-10-31 | 2023-09-29 |  | N/A | 672h | 672h | -0 | N/A | N/A | 5.0 | Design, Build & Test (PIT) |  |  |  |  |  |  |
| 189 | 1.3.6.2.1.6.1 | PIT Test Execution Progress Report |  | 18d | 2023-09-04 A | 2023-09-27 A | 181FS+10d | 100% | 2022-10-31 | 2023-09-22 | 235d | 2022-10-31 | 2023-09-22 |  | Lee Cox | 144h | 144h |  | PP | SI Test | 5.1 | Design, Build & Test (PIT) |  | Complete | COMPLETE |  |  |  |
| 190 | 1.3.6.2.1.6.2 | Elexon Central Systems PIT Execution |  | 28d | 2023-08-21 A | 2023-09-27 A | 181 | 100% | 2022-11-08 | 2023-10-09 | 240d | 2022-10-31 | 2023-09-29 |  | Lee Cox | 224h | 224h |  | PP | SI Test | 5.1 | Design, Build & Test (PIT) |  | Complete | COMPLETE |  |  |  |
| 191 | 1.3.6.2.1.6.3 | Elexon Central Systems PIT Completion Report submitted to Programme for assurance | milestone | 0d | 2023-09-27 A | 2023-09-27 A | 190 | 100% | 2023-09-27 | 2023-09-27 | 0d | 2024-01-05 | 2024-01-05 |  | Lee Cox |  |  |  | PP | SI Test | 5.8 | Design, Build & Test (PIT) |  | Complete | COMPLETE | T3-DB-0109 | SITAG | T3 |
| 192 | 1.3.6.2.1.6.4 | Elexon Central Systems PIT Completion Report MHHS Review Completed | milestone | 0d | 2023-10-11 A | 2023-10-11 A | 184, 187, 189, 191FS+10d, 179 | 100% | 2023-10-11 | 2023-10-11 | 0d |  |  |  | Lee Cox |  |  |  | SI Test | PP | 5.8 |  |  | Complete | COMPLETE | T3-DB-0110 | SITAG | T3 |
| 193 | 1.3.6.2.2 | **DIP DBT CIT (Entering at Interval 1)** |  | 221d | 2023-01-02 A | 2023-11-06 A |  | 100% | 2022-10-31 | 2023-11-06 | 266d | 2022-10-31 | 2023-09-29 |  | N/A | 5552h | 5552h | -0 | N/A | N/A | 5.0 | Design, Build & Test (PIT) |  |  |  |  |  |  |
| 194 | 1.3.6.2.2.1 | Design |  | 80d | 2023-01-02 A | 2023-04-21 A |  | 100% | 2023-01-02 | 2023-04-21 | 80d | 2023-01-02 | 2023-04-21 | must start on 2023-01-02 | Lee Cox | 640h | 640h |  | PP | SI Design | 5.0 | Design, Build & Test (PIT) |  | Complete | COMPLETE |  |  |  |
| 195 | 1.3.6.2.2.2 | Build |  | 155d | 2023-01-09 A | 2023-08-11 A | 194SS+5d | 100% | 2023-01-09 | 2023-08-11 | 155d | 2023-01-09 | 2023-08-11 |  | Lee Cox | 1240h | 1240h |  | PP |  | 5.5 | Design, Build & Test (PIT) |  | Complete | COMPLETE |  |  |  |
| 196 | 1.3.6.2.2.3 | **Test Approach & Plan** |  | 9d | 2023-07-07 A | 2023-07-20 A |  | 100% | 2022-10-31 | 2023-07-21 | 190d | 2022-10-31 | 2023-07-21 |  | N/A | 72h | 72h |  | N/A | N/A | 5.0 | Design, Build & Test (PIT) |  |  |  |  |  |  |
| 197 | 1.3.6.2.2.3.1 | DIP Test Approach & Plan (PIT) submitted to Programme for assurance | milestone | 0d | 2023-07-07 A | 2023-07-07 A |  | 100% | 2023-07-07 | 2023-07-07 | 0d | 2023-07-07 | 2023-07-07 |  | Lee Cox |  |  |  | PP | SI Test | 5.0 | Design, Build & Test (PIT) | MHHS-ART073 | Complete | COMPLETE | T3-DB-0026 | SITAG | T3 |
| 198 | 1.3.6.2.2.3.2 | DIP Test Approach & Plan (PIT) MHHS Review Completed | milestone | 0d | 2023-07-20 A | 2023-07-20 A | 197FS+9d | 100% | 2023-07-10 | 2023-07-21 | 10d | 2023-07-10 | 2023-07-21 |  | Lee Cox |  |  |  | SI Test | PP | 5.0 | Design, Build & Test (PIT) |  | Complete | COMPLETE |  |  |  |
| 199 | 1.3.6.2.2.4 | **PIT Test Readiness Report** |  | 31d | 2023-07-21 A | 2023-09-01 A |  | 100% | 2023-07-21 | 2023-09-29 | 51d | 2023-07-21 | 2023-09-29 |  | N/A | 496h | 496h |  | N/A | N/A | 5.0 | Design, Build & Test (PIT) |  |  |  |  |  |  |
| 200 | 1.3.6.2.2.4.1 | Test readiness reporting |  | 31d | 2023-07-21 A | 2023-09-01 A | 197FS+9d | 100% | 2023-07-21 | 2023-09-29 | 51d | 2023-07-21 | 2023-09-29 |  | Lee Cox | 248h | 248h |  | SI Test | 109 | 5.0 | Design, Build & Test (PIT) |  | Complete | COMPLETE |  |  |  |
| 201 | 1.3.6.2.2.5 | **Requirements to test Traceability Matrix (RTTM)** |  | 18d | 2023-08-04 A | 2023-08-30 A |  | 100% | 2022-10-31 | 2023-08-18 | 210d | 2022-10-31 | 2023-08-18 |  | N/A | 144h | 144h |  | N/A | N/A | 5.0 | Design, Build & Test (PIT) |  |  |  |  |  |  |
| 202 | 1.3.6.2.2.5.1 | DIP RTTM submitted to Programme for assurance | milestone | 0d | 2023-08-04 A | 2023-08-04 A | 197FS+15d | 100% | 2023-08-04 | 2023-08-04 | 0d | 2023-08-04 | 2023-08-04 |  | Lee Cox |  |  |  | PP | SI Test | 5.6 | Design, Build & Test (PIT) | MHHS-ART009 | Complete | COMPLETE | T3-DB-0034 | SITAG | T3 |
| 203 | 1.3.6.2.2.5.2 | DIP RTTM MHHS Review Completed | milestone | 0d | 2023-08-30 A | 2023-08-30 A | 202FS+18d | 100% | 2023-08-07 | 2023-08-18 | 10d | 2023-08-07 | 2023-08-18 |  | Lee Cox |  |  |  | SI Test | PP | 5.0 | Design, Build & Test (PIT) |  | Complete | COMPLETE |  |  |  |
| 204 | 1.3.6.2.2.6 | **Test Scenarios** |  | 22d | 2023-07-31 A | 2023-08-30 A |  | 100% | 2022-10-31 | 2023-08-14 | 206d | 2022-10-31 | 2023-08-18 |  | N/A | 176h | 176h |  | N/A | N/A | 5.0 | Design, Build & Test (PIT) |  |  |  |  |  |  |
| 205 | 1.3.6.2.2.6.1 | DIP PIT test scenarios submitted to Programme for assurance | milestone | 0d | 2023-07-31 A | 2023-07-31 A | 197FS+15d | 100% | 2023-07-31 | 2023-07-31 | 0d | 2023-08-04 | 2023-08-04 |  | Lee Cox |  |  |  | PP | SI Test | 5.0 | Design, Build & Test (PIT) |  | Complete | COMPLETE | T3-DB-0036 | SITAG | T3 |
| 206 | 1.3.6.2.2.6.2 | DIP Test scenarios MHHS Review Completed | milestone | 0d | 2023-08-30 A | 2023-08-30 A | 205FS+22d | 100% | 2023-08-01 | 2023-08-14 | 10d | 2023-08-07 | 2023-08-18 |  | Lee Cox |  |  |  | SI Test | PP | 5.0 | Design, Build & Test (PIT) |  | Complete | COMPLETE |  |  |  |

Notes:
- 184: 1/9 - to be raised as new T3 at TMAG. Approved at TMAG on 20/9
- 187: 1/9 - to be raised as new T3 at TMAG. Approved at TMAG on 20/9
- 191: 1/9 - to be raised as new T3 at TMAG. Approved at TMAG on 20/9
- 192: 1/9 - to be raised as new T3 at TMAG. Approved at TMAG on 20/9
- 200: Action: 14/8 - Query from RG - IS this an SI Test deliverable or expected to be a DIP deliverable if so be more specific
- 202: RG confirmed Submitted on 10/8/23

| ID | WBS | Task | Type | Duration | Start | Finish | Predecessors | Complete | Baseline start | Baseline finish | Baseline duration | Baseline 1 start | Baseline 1 finish | Constraint | Resources | Work | Actual work | Baseline cost | Responsible | Involved | Update Version | MHHS Programme Phase | Sched Status | RAG | Milestone ID | Text29 | Tier |
| --- | --- | --- | --- | --- | --- | --- | --- | --- | --- | --- | --- | --- | --- | --- | --- | --- | --- | --- | --- | --- | --- | --- | --- | --- | --- | --- | --- |
| 207 | 1.3.6.2.2.7 | **PIT execution** |  | 50d | 2023-08-29 A | 2023-11-06 A |  | 100% | 2023-09-01 | 2023-11-06 | 47d | 2022-10-31 | 2023-09-29 |  | N/A | 1016h | 1016h | -0 | N/A | N/A | 5.0 | Design, Build & Test (PIT) |  |  |  |  |  |
| 208 | 1.3.6.2.2.7.1 | PIT Test Execution Progress Report |  | 37d | 2023-09-01 A | 2023-10-23 A | 209FF, 200 | 100% | 2023-09-01 | 2023-10-23 | 37d | 2022-10-31 | 2023-09-22 | start no earlier than 2023-08-29 | Lee Cox | 296h | 296h |  | PP | SI Test | 5.6 | Design, Build & Test (PIT) | Complete | COMPLETE |  |  |  |
| 209 | 1.3.6.2.2.7.2 | PIT Execution (Interim Release 1) |  | 30d | 2023-08-29 A | 2023-10-09 A |  | 100% | 2023-09-06 | 2023-10-09 | 24d | 2022-10-31 | 2023-09-29 | start no earlier than 2023-08-29 | Lee Cox | 240h | 240h |  | PP | SI Test | 5.6 | Design, Build & Test (PIT) | Complete | COMPLETE |  |  |  |
| 210 | 1.3.6.2.2.7.3 | PIT Execution (Interim Release 2) |  | 10d | 2023-10-10 A | 2023-10-23 A | 209 | 100% | 2023-10-10 | 2023-10-23 | 10d |  |  |  | Lee Cox | 80h | 80h |  | PP | SI Test | 5.6 | Design, Build & Test (PIT) | Complete | COMPLETE |  |  |  |
| 211 | 1.3.6.2.2.7.4 | DIP PIT Completion Report (Interim Release 1) submitted to Programme for assurance | milestone | 0d | 2023-10-09 A | 2023-10-09 A | 209 | 100% | 2023-10-09 | 2023-10-09 | 0d | 2024-01-05 | 2024-01-05 |  | Lee Cox |  |  |  | PP | SI Test | 5.8 | Design, Build & Test (PIT) | Complete | COMPLETE | T3-DB-0111 | SITAG | T3 |
| 212 | 1.3.6.2.2.7.5 | DIP PIT Completion Report (Interim Release 1) MHHS Review Completed | milestone | 0d | 2023-10-23 A | 2023-10-23 A | 211FS+10d | 100% | 2023-10-23 | 2023-10-23 | 0d |  |  |  | Lee Cox |  |  |  | SI Test | SI Test | 5.10 |  | Complete | COMPLETE | T3-DB-0112 | SITAG | T3 |
| 213 | 1.3.6.2.2.7.6 | DIP PIT Completion Report (Interim Release 2) submitted to Programme for assurance | milestone | 0d | 2023-10-23 A | 2023-10-23 A | 210, 208 | 100% | 2023-10-23 | 2023-10-23 | 0d | 2024-01-05 | 2024-01-05 |  | Lee Cox |  |  |  | PP | SI Test | 5.10 | Design, Build & Test (PIT) | Complete | COMPLETE | T3-DB-0113 | SITAG | T3 |
| 214 | 1.3.6.2.2.7.7 | DIP PIT Completion Report (Interim Release 2) MHHS Review Completed | milestone | 0d | 2023-11-06 A | 2023-11-06 A | 213FS+10d | 100% | 2023-11-06 | 2023-11-06 | 0d |  |  |  | Lee Cox |  |  |  | SI Test | SI Test | 5.14 |  | Complete | COMPLETE | T3-DB-0114 | SITAG | T3 |
| 215 | 1.3.6.2.3 | **DCC (DSP) DBT SIT Functional (Entering at SIT Functional)** |  | 325d | 2022-10-31 A | 2024-01-26 A |  | 100% | 2022-10-31 | 2024-02-23 | 345d | 2022-10-31 | 2024-01-05 |  | N/A | 4128h | 4128h | -0 | N/A | N/A | 5.18 | Design, Build & Test (PIT) |  |  |  |  |  |
| 216 | 1.3.6.2.3.1 | Design |  | 67d | 2022-10-31 A | 2023-01-31 A |  | 100% | 2022-10-31 | 2023-01-31 | 67d | 2022-10-31 | 2023-01-31 |  | Lee Cox | 536h | 536h |  | PP | SI Design | 5.18 | Design, Build & Test (PIT) | Complete | COMPLETE |  |  |  |
| 217 | 1.3.6.2.3.2 | **Test Approach & Plan** |  | 20d | 2023-11-17 A | 2023-12-15 A |  | 100% | 2023-11-17 | 2023-12-15 | 20d | 2022-10-31 | 2023-10-27 |  | N/A | 160h | 160h | -0 | N/A | N/A | 5.18 | Design, Build & Test (PIT) |  |  |  |  |  |
| 218 | 1.3.6.2.3.2.1 | DCC Test Approach & Plan (PIT) submitted to Programme for assurance | milestone | 0d | 2023-11-17 A | 2023-11-17 A | 216FS+208d | 100% | 2023-11-17 | 2023-11-17 | 0d | 2023-10-13 | 2023-10-13 |  | Lee Cox |  |  |  | PP | SI Test | 5.18 | Design, Build & Test (PIT) | Complete | COMPLETE | T3-DB-0068 | SITAG | T3 |
| 219 | 1.3.6.2.3.2.2 | DCC Test Approach & Plan (PIT) MHHS Review Completed | milestone | 0d | 2023-12-15 A | 2023-12-15 A | 218FS+20d | 100% | 2023-12-15 | 2023-12-15 | 0d | 2023-10-16 | 2023-10-27 |  | Lee Cox |  |  |  | SI Test | PP | 5.18 | Design, Build & Test (PIT) | Complete | COMPLETE | T3-DB-0115 | SITAG | T3 |
| 220 | 1.3.6.2.3.3 | **Test Readiness Report** |  | 22d | 2023-12-04 A | 2024-01-02 A |  | 100% | 2023-10-27 | 2024-01-05 | 51d | 2023-10-27 | 2024-01-05 |  | N/A | 352h | 352h |  | N/A | N/A | 5.18 | Design, Build & Test (PIT) |  |  |  |  |  |
| 221 | 1.3.6.2.3.3.1 | Test readiness reporting |  | 22d | 2023-12-04 A | 2024-01-02 A | 218FS+10d | 100% | 2023-10-27 | 2024-01-05 | 51d | 2023-10-27 | 2024-01-05 |  | Lee Cox | 176h | 176h |  | PP | 109 | 5.18 | Design, Build & Test (PIT) | Complete | COMPLETE |  |  |  |
| 222 | 1.3.6.2.3.4 | **Requirements to test Traceability Matrix (RTTM)** |  | 30d | 2023-12-15 A | 2024-01-26 A |  | 100% | 2023-12-15 | 2024-01-26 | 30d | 2022-10-31 | 2023-11-24 |  | N/A | 240h | 240h | -0 | N/A | N/A | 5.18 | Design, Build & Test (PIT) |  |  |  |  |  |
| 223 | 1.3.6.2.3.4.1 | DCC RTTM submitted to Programme for assurance | milestone | 0d | 2023-12-15 A | 2023-12-15 A | 218FS+20d | 100% | 2023-12-15 | 2023-12-15 | 0d | 2023-11-10 | 2023-11-10 | start no earlier than 2023-04-28 | Lee Cox |  |  |  | PP | SI Test | 5.18 | Design, Build & Test (PIT) | Complete | COMPLETE | T3-DB-0074 | SITAG | T3 |
| 224 | 1.3.6.2.3.4.2 | DCC RTTM MHHS Review Completed | milestone | 0d | 2024-01-26 A | 2024-01-26 A | 223FS+30d | 100% | 2024-01-26 | 2024-01-26 | 0d | 2023-11-13 | 2023-11-24 |  | Lee Cox |  |  |  | SI Test | PP | 5.18 | Design, Build & Test (PIT) | Complete | COMPLETE | T3-DB-0116 | SITAG | T3 |
| 225 | 1.3.6.2.3.5 | **Test Scenarios** |  | 30d | 2023-12-15 A | 2024-01-26 A |  | 100% | 2023-12-15 | 2024-01-26 | 30d | 2022-10-31 | 2023-11-24 |  | N/A | 240h | 240h | -0 | N/A | N/A | 5.18 | Design, Build & Test (PIT) |  |  |  |  |  |
| 226 | 1.3.6.2.3.5.1 | DCC test scenarios submitted to Programme for assurance | milestone | 0d | 2023-12-15 A | 2023-12-15 A | 218FS+20d | 100% | 2023-12-15 | 2023-12-15 | 0d | 2023-11-10 | 2023-11-10 |  | Lee Cox |  |  |  | PP | SI Test | 5.18 | Design, Build & Test (PIT) | Complete | COMPLETE | T3-DB-0078 | SITAG | T3 |
| 227 | 1.3.6.2.3.5.2 | DCC Test Scenarios MHHS Review Completed | milestone | 0d | 2024-01-26 A | 2024-01-26 A | 226FS+30d | 100% | 2024-01-26 | 2024-01-26 | 0d | 2023-11-13 | 2023-11-24 |  | Lee Cox |  |  |  | SI Test | PP | 5.18 | Design, Build & Test (PIT) | Complete | COMPLETE | T3-DB-0117 | SITAG | T3 |
| 228 | 1.3.6.2.4 | **RECCo (EES) DBT CIT (Entering at Interval 6)** |  | 71d | 2023-10-13 A | 2024-01-19 A |  | 100% | 2022-10-31 | 2024-01-19 | 320d | 2022-10-31 | 2024-01-05 |  | N/A | 2272h | 2272h | -0 | N/A | N/A | 5.0 | Design, Build & Test (PIT) |  |  |  |  |  |
| 229 | 1.3.6.2.4.1 | **Test Approach & Plan** |  | 20d | 2023-10-13 A | 2023-11-09 A |  | 100% | 2023-10-13 | 2023-11-09 | 20d | 2022-10-31 | 2023-10-27 |  | N/A | 160h | 160h | -0 | N/A | N/A | 5.0 | Design, Build & Test (PIT) |  |  |  |  |  |
| 230 | 1.3.6.2.4.1.1 | EES Test Approach & Plan (PIT) submitted to Programme for assurance | milestone | 0d | 2023-10-13 A | 2023-10-13 A |  | 100% | 2023-10-13 | 2023-10-13 | 0d | 2023-10-13 | 2023-10-13 | start no earlier than 2023-10-13 | Lee Cox |  |  |  | PP | SI Test | 5.8 | Design, Build & Test (PIT) | Complete | COMPLETE | T3-DB-0066 | SITAG | T3 |
| 231 | 1.3.6.2.4.1.2 | EES Test approach and plan (PIT) MHHS Review Completed | milestone | 0d | 2023-11-09 A | 2023-11-09 A | 230FS+20d | 100% | 2023-11-09 | 2023-11-09 | 0d | 2023-10-16 | 2023-10-27 |  | Lee Cox |  |  |  | SI Test | PP | 5.8 | Design, Build & Test (PIT) | Complete | COMPLETE | T3-DB-0119 | SITAG | T3 |

Notes:
- 208: 21/8 - due to complete 9/10 - advised by RG
- 209: 21/8 - due to complete 9/10 - advised by RG
- 210: 21/8 - new line added date are 9/10 - 23/10 - advised by RG.
- 211: 1/9 - to be raised as new T3 at TMAG. Approved at TMAG on 20/9. 9/10 - RG - After discussions with DM it was decided a completion report for IR1 wasn't required as we are entering IR2 ahead of schedule & draft completion report already submitted & assured
- 212: 1/9 - to be raised as new T3 at TMAG. Approved at TMAG on 20/9
- 213: 1/9 - to be raised as new T3 at TMAG. Approved at TMAG on 20/9
- 214: 7/11- Red because further clarity aroud remaining open low severity defect work off plan requested. No impact. Completed on 8/12 / Guidance: 6/10 - LC - Successor should be SIT Component Integration Testing 1 Preparation Complete but not linked as DIP test completion plus 10 day review breaks logic. Decision will be made to proceed without a conclusion of the report review
- 218: 21/11- Red because not received. Currently no impact. 30/1 - Completed on 26/1
- 219: 1/9 - to be raised as new T3 at TMAG DCC no longer in CIT, new dates relate to SIT Functional. Approved at TMAG on 20/9. 19/12 - Red because not received
- 223: 19/12- Red because not received. 30/1 - Completed on 26/1
- 224: 23/1- Amber because of potential late delivery of RTTM. No impact. No action. 30/1 - Completed on 26/1
- 226: 5/12- Red because of late delivery of PIT approach and plan. No impact. No action. 30/1 - Completed on 26/1
- 227: 23/1- Amber because of potential late delivery of test scenrios. No impact. No action. 30/1 - Completed on 26/1
- 228: Assumption that Migration/Reverse Migration DBT is not applicable to RECCo.
- 230: 12/9 - TMAG for name change. Approved at TMAG on 20/9. 17/10 - Red because document not yet received. No impact currently. Issuance from RECCo requested
- 231: 1/9 - to be raised as new T3 at TMAG. Approved at TMAG on 20/9. 17/10 - Amber because Late delivery of document plus earlier intervals backlog. Curently no impact

| ID | WBS | Task | Type | Duration | Start | Finish | Predecessors | Complete | Baseline start | Baseline finish | Baseline duration | Baseline 1 start | Baseline 1 finish | Constraint | Resources | Work | Actual work | Baseline cost | Responsible | Involved | Update Version | MHHS Programme Phase | Sched Status | RAG | Artefact ID | Milestone ID | Text29 | Tier |
| --- | --- | --- | --- | --- | --- | --- | --- | --- | --- | --- | --- | --- | --- | --- | --- | --- | --- | --- | --- | --- | --- | --- | --- | --- | --- | --- | --- | --- |
| 232 | 1.3.6.2.4.2 | **Test Readiness Report** |  | 10d | 2023-10-27 A | 2023-11-09 A |  | 100% | 2023-10-27 | 2024-01-05 | 51d | 2023-10-27 | 2024-01-05 |  | N/A | 160h | 160h |  | N/A | N/A | 5.0 | Design, Build & Test (PIT) |  |  |  |  |  |  |
| 233 | 1.3.6.2.4.2.1 | Test readiness reporting |  | 10d | 2023-10-27 A | 2023-11-09 A | 230FS+10d | 100% | 2023-10-27 | 2024-01-05 | 51d | 2023-10-27 | 2024-01-05 |  | Lee Cox | 80h | 80h |  | PP | 109 | 5.0 | Design, Build & Test (PIT) | Complete | COMPLETE |  |  |  |  |
| 234 | 1.3.6.2.4.3 | **Requirements to test Traceability Matrix (RTTM)** |  | 20d | 2023-11-02 A | 2023-11-30 A |  | 100% | 2023-11-02 | 2023-11-30 | 20d | 2022-10-31 | 2023-11-24 |  | N/A | 160h | 160h | -0 | N/A | N/A | 5.0 | Design, Build & Test (PIT) |  |  |  |  |  |  |
| 235 | 1.3.6.2.4.3.1 | EES RTTM submitted to Programme for assurance | milestone | 0d | 2023-11-02 A | 2023-11-02 A | 230FS+15d | 100% | 2023-11-02 | 2023-11-02 | 0d | 2023-11-10 | 2023-11-10 |  | Lee Cox |  |  |  | PP | SI Test | 5.8 | Design, Build & Test (PIT) | Complete | COMPLETE | MHHS-ART009 | T3-DB-0072 | SITAG | T3 |
| 236 | 1.3.6.2.4.3.2 | EES RTTM MHHS Review Completed | milestone | 0d | 2023-11-30 A | 2023-11-30 A | 235FS+20d | 100% | 2023-11-30 | 2023-11-30 | 0d | 2023-11-13 | 2023-11-24 |  | Lee Cox |  |  |  | SI Test | PP | 5.14 | Design, Build & Test (PIT) | Complete | COMPLETE |  | T3-DB-0120 | SITAG | T3 |
| 237 | 1.3.6.2.4.4 | **Test Scenarios** |  | 20d | 2023-11-02 A | 2023-11-30 A |  | 100% | 2023-11-02 | 2023-11-30 | 20d | 2022-10-31 | 2023-11-24 |  | N/A | 160h | 160h | -0 | N/A | N/A | 5.0 | Design, Build & Test (PIT) |  |  |  |  |  |  |
| 238 | 1.3.6.2.4.4.1 | EES test scenarios submitted to Programme for assurance | milestone | 0d | 2023-11-02 A | 2023-11-02 A | 230FS+15d | 100% | 2023-11-02 | 2023-11-02 | 0d | 2023-11-10 | 2023-11-10 |  | Lee Cox |  |  |  | PP | SI Test | 5.8 | Design, Build & Test (PIT) | Complete | COMPLETE |  | T3-DB-0031 | SITAG | T3 |
| 239 | 1.3.6.2.4.4.2 | EES Test scenarios MHHS Review Completed | milestone | 0d | 2023-11-30 A | 2023-11-30 A | 238FS+20d | 100% | 2023-11-30 | 2023-11-30 | 0d | 2023-11-13 | 2023-11-24 |  | Lee Cox |  |  |  | SI Test | PP | 5.14 | Design, Build & Test (PIT) | Complete | COMPLETE |  | T3-DB-0121 | SITAG | T3 |
| 240 | 1.3.6.2.4.5 | **PIT execution** |  | 51d | 2023-11-10 A | 2024-01-19 A |  | 100% | 2022-10-31 | 2024-01-19 | 320d | 2022-10-31 | 2024-01-05 |  | N/A | 1064h | 1064h | -0 | N/A | N/A | 5.0 | Design, Build & Test (PIT) |  |  |  |  |  |  |
| 241 | 1.3.6.2.4.5.1 | PIT Test Execution Progress Report |  | 41d | 2023-11-10 A | 2024-01-05 A | 233 | 100% | 2023-11-10 | 2024-01-05 | 41d | 2022-10-31 | 2023-12-29 |  | Lee Cox | 328h | 328h |  | PP | SI Test | 5.0 | Design, Build & Test (PIT) | Complete | COMPLETE |  |  |  |  |
| 242 | 1.3.6.2.4.5.2 | PIT Execution |  | 41d | 2023-11-10 A | 2024-01-05 A | 238FS+5d | 100% | 2022-10-31 | 2024-01-05 | 310d | 2022-10-31 | 2024-01-05 |  | Lee Cox | 328h | 328h |  | PP | SI Test | 5.0 | Design, Build & Test (PIT) | Complete | COMPLETE |  |  |  |  |
| 243 | 1.3.6.2.4.5.3 | EES PIT Completion Report submitted to Programme for assurance | milestone | 0d | 2024-01-05 A | 2024-01-05 A | 241, 242 | 100% | 2024-01-05 | 2024-01-05 | 0d | 2024-01-05 | 2024-01-05 |  | Lee Cox |  |  |  | PP | SI Test | 5.14 | Design, Build & Test (PIT) | Complete | COMPLETE |  | T3-DB-0122 | SITAG | T3 |
| 244 | 1.3.6.2.4.5.4 | EES PIT Completion Report MHHS Review Completed | milestone | 0d | 2024-01-19 A | 2024-01-19 A | 231, 236, 239, 243FS+10d | 100% | 2024-01-19 | 2024-01-19 | 0d |  |  |  | Lee Cox |  |  |  | SI Test | PP | 5.14 |  | Complete | COMPLETE |  | T3-DB-0123 | SITAG | T3 |
| 245 | 1.3.6.2.5 | **Registration Services DBT CIT (Entering at Interval 2)** |  | 70d | 2023-07-28 A | 2023-11-03 A |  | 100% | 2023-07-28 | 2023-11-03 | 70d | 2022-10-31 | 2024-02-28 |  | N/A | 2344h | 2344h | -0 | N/A | N/A | 5.0 | Design, Build & Test (PIT) |  |  |  |  |  |  |
| 246 | 1.3.6.2.5.1 | **Test Approach & Plan** |  | 40d | 2023-07-28 A | 2023-09-22 A |  | 100% | 2023-07-28 | 2023-09-22 | 40d | 2022-10-31 | 2023-08-11 |  | N/A | 320h | 320h | -0 | N/A | N/A | 5.0 | Design, Build & Test (PIT) |  |  |  |  |  |  |
| 247 | 1.3.6.2.5.1.1 | Registration Services Test Approach & Plan (PIT) submitted to Programme for assurance | milestone | 0d | 2023-07-28 A | 2023-07-28 A |  | 100% | 2023-07-28 | 2023-07-28 | 0d | 2023-07-28 | 2023-07-28 |  | Lee Cox |  |  |  | PP | SI Test | 5.0 | Design, Build & Test (PIT) | Complete | COMPLETE | MHHS-ART073 | T3-DB-0028 | SITAG | T3 |
| 248 | 1.3.6.2.5.1.2 | Registration Services Test approach and plan MHHS Review Completed | milestone | 0d | 2023-09-22 A | 2023-09-22 A | 247FS+40d | 100% | 2023-09-22 | 2023-09-22 | 0d | 2023-07-31 | 2023-08-11 |  | Lee Cox |  |  |  | SI Test | PP | 5.8 | Design, Build & Test (PIT) | Complete | COMPLETE |  | T3-DB-0124 | SITAG | T3 |
| 249 | 1.3.6.2.5.2 | **Test Readiness Report** |  | 20d | 2023-08-14 A | 2023-09-08 A |  | 100% | 2023-08-11 | 2023-10-20 | 51d | 2023-08-11 | 2023-10-20 |  | N/A | 320h | 320h |  | N/A | N/A | 5.0 | Design, Build & Test (PIT) |  |  |  |  |  |  |
| 250 | 1.3.6.2.5.2.1 | Test readiness reporting |  | 20d | 2023-08-14 A | 2023-09-08 A | 247FS+10d | 100% | 2023-08-11 | 2023-10-20 | 51d | 2023-08-11 | 2023-10-20 |  | Lee Cox | 160h | 160h |  | PP | 109 | 5.0 | Design, Build & Test (PIT) | Complete | COMPLETE |  |  |  |  |
| 251 | 1.3.6.2.5.3 | **Requirements to test Traceability Matrix (RTTM)** |  | 20d | 2023-09-01 A | 2023-09-29 A |  | 100% | 2023-09-01 | 2023-09-29 | 20d | 2022-10-31 | 2023-09-15 |  | N/A | 160h | 160h | -0 | N/A | N/A | 5.0 | Design, Build & Test (PIT) |  |  |  |  |  |  |
| 252 | 1.3.6.2.5.3.1 | Registration Services RTTM submitted to Programme for assurance | milestone | 0d | 2023-09-01 A | 2023-09-01 A | 247FS+15d | 100% | 2023-09-01 | 2023-09-01 | 0d | 2023-09-01 | 2023-09-01 | start no earlier than 2023-04-28 | Lee Cox |  |  |  | PP | SI Test | 5.6 | Design, Build & Test (PIT) | Complete | COMPLETE | MHHS-ART009 | T3-DB-0042 | SITAG | T3 |
| 253 | 1.3.6.2.5.3.2 | Registration Services RTTM MHHS Review Completed | milestone | 0d | 2023-09-29 A | 2023-09-29 A | 252FS+20d | 100% | 2023-09-29 | 2023-09-29 | 0d | 2023-09-04 | 2023-09-15 |  | Lee Cox |  |  |  | SI Test | PP | 5.8 | Design, Build & Test (PIT) | Complete | COMPLETE |  | T3-DB-0125 | SITAG | T3 |
| 254 | 1.3.6.2.5.4 | **Test Scenarios** |  | 20d | 2023-09-01 A | 2023-09-29 A |  | 100% | 2023-09-01 | 2023-09-29 | 20d | 2022-10-31 | 2023-09-15 |  | N/A | 160h | 160h | -0 | N/A | N/A | 5.0 | Design, Build & Test (PIT) |  |  |  |  |  |  |
| 255 | 1.3.6.2.5.4.1 | Registration Services test scenarios submitted to Programme for assurance | milestone | 0d | 2023-09-01 A | 2023-09-01 A | 247FS+15d | 100% | 2023-09-01 | 2023-09-01 | 0d | 2023-09-01 | 2023-09-01 |  | Lee Cox |  |  |  | PP | SI Test | 5.6 | Design, Build & Test (PIT) | Complete | COMPLETE |  | T3-DB-0044 | SITAG | T3 |
| 256 | 1.3.6.2.5.4.2 | Registration Services Test scenarios MHHS Review Completed | milestone | 0d | 2023-09-29 A | 2023-09-29 A | 255FS+20d | 100% | 2023-09-29 | 2023-09-29 | 0d | 2023-09-04 | 2023-09-15 |  | Lee Cox |  |  |  | SI Test | PP | 5.8 | Design, Build & Test (PIT) | Complete | COMPLETE |  | T3-DB-0126 | SITAG | T3 |

Notes:
- 235: 7/11 - Red because not submitted. No impact. No action
- 236: 5/12- Red because Assurance conducted. Comments issued and awaiting response. No impact. No action. Completed on 15/12
- 238: 7/11 - Red because not submitted. No impact. No action
- 239: 5/12- Red because Assurance conducted. Comments issued and awaiting response. No impact. No action. Completed on 15/12
- 243: 1/9 - to be raised as new T3 at TMAG. Approved at TMAG on 20/9. 19/12 - Completed on 15/12
- 244: 1/9 - to be raised as new T3 at TMAG. Approved at TMAG on 20/9. 19/12 - Completed on 15/12
- 248: 1/9 - to be raised as new T3 at TMAG. Approved at TMAG on 20/9
- 253: 1/9 - to be raised as new T3 at TMAG. Approved at TMAG on 20/9. 4/10 - Red because small number of comments still to be resolved, will be completed no later than 3/11 ahead of Interval 2 Readiness Assessment
- 256: 1/9 - to be raised as new T3 at TMAG

| ID | WBS | Task | Type | Duration | Start | Finish | Predecessors | Complete | Remaining | Baseline start | Baseline finish | Baseline duration | Baseline 1 start | Baseline 1 finish | Total slack | Free slack | Constraint | Resources | Work | Actual work | Baseline cost | Responsible | Involved | Update Version | MHHS Programme Phase | Sched Status | RAG | Milestone ID | Text29 | Tier |
| --- | --- | --- | --- | --- | --- | --- | --- | --- | --- | --- | --- | --- | --- | --- | --- | --- | --- | --- | --- | --- | --- | --- | --- | --- | --- | --- | --- | --- | --- | --- |
| 257 | 1.3.6.2.5.5 | **PIT execution** |  | 40d | 2023-09-11 A | 2023-11-03 A |  | 100% |  | 2023-09-11 | 2023-11-03 | 40d | 2023-01-02 | 2023-10-20 |  |  |  | N/A | 824h | 824h | -0 | N/A | N/A | 5.0 | Design, Build & Test (PIT) |  |  |  |  |  |
| 258 | 1.3.6.2.5.5.1 | PIT Test Execution Progress Report |  | 33d | 2023-09-11 A | 2023-10-25 A | 250 | 100% |  | 2023-09-11 | 2023-10-20 | 30d | 2023-01-02 | 2023-10-13 |  |  |  | Lee Cox | 264h | 264h |  | PP | SI Test | 5.0 | Design, Build & Test (PIT) | Complete | COMPLETE |  |  |  |
| 259 | 1.3.6.2.5.5.2 | PIT Execution |  | 30d | 2023-09-11 A | 2023-10-20 A | 255FS+5d | 100% |  | 2023-09-11 | 2023-10-20 | 30d | 2023-01-16 | 2023-10-20 |  |  |  | Lee Cox | 240h | 240h |  | PP | SI Test | 5.0 | Design, Build & Test (PIT) | Complete | COMPLETE |  |  |  |
| 260 | 1.3.6.2.5.5.3 | Registration Services PIT (CIT interval 2) Completion Report submitted to Programme for assurance | milestone | 0d | 2023-10-25 A | 2023-10-25 A | 258, 259 | 100% |  | 2023-10-20 | 2023-10-20 | 0d | 2024-01-05 | 2024-01-05 |  |  |  | Lee Cox |  |  |  | PP | SI Test | 5.10 | Design, Build & Test (PIT) | Complete | COMPLETE | T3-DB-0127 | SITAG | T3 |
| 261 | 1.3.6.2.5.5.4 | Registration Services PIT (CIT interval 2) Completion Report MHHS Review Completed | milestone | 0d | 2023-11-03 A | 2023-11-03 A | 248, 253, 256, 260FS+7d | 100% |  | 2023-11-03 | 2023-11-03 | 0d |  |  |  |  |  | Lee Cox |  |  |  | SI Test | PP | 5.11 |  | Complete | COMPLETE | T3-DB-0128 | SITAG | T3 |
| 262 | 1.3.6.3 | **SIT Participants DBT** |  | 291d | 2023-08-11 A | 2024-09-20 |  | 73% | 77.96d | 2022-10-31 | 2024-09-20 | 495d | 2022-10-31 | 2025-03-14 | -2d | 0d |  | N/A | 25832h | 15813.4h | -0 | N/A | N/A | 5.0 | Design, Build & Test (PIT) |  |  |  |  |  |
| 263 | 1.3.6.3.1 | **All Data Services DBT CIT (Entering at Interval 3)** |  | 71d | 2023-08-11 A | 2023-11-17 A |  | 100% |  | 2022-10-31 | 2023-11-17 | 275d | 2022-10-31 | 2023-11-03 |  |  |  | N/A | 2024h | 2024h | -0 | N/A | N/A | 5.0 | Design, Build & Test (PIT) |  |  |  |  |  |
| 264 | 1.3.6.3.1.1 | **Test Approach & Plan** |  | 30d | 2023-08-11 A | 2023-09-21 A |  | 100% |  | 2023-08-11 | 2023-09-21 | 29d | 2022-10-31 | 2023-08-25 |  |  |  | N/A | 240h | 240h | -0 | N/A | N/A | 5.0 | Design, Build & Test (PIT) |  |  |  |  |  |
| 265 | 1.3.6.3.1.1.1 | All Data Services Test Approach & Plans (PIT) submitted to Programme for assurance | milestone | 0d | 2023-08-11 A | 2023-08-11 A |  | 100% |  | 2023-08-11 | 2023-08-11 | 0d | 2023-08-11 | 2023-08-11 |  |  | start no earlier than 2023-08-11 | Lee Cox |  |  |  | PP | SI Test | 5.0 | Design, Build & Test (PIT) | Complete | COMPLETE | T3-DB-0038 | SITAG | T3 |
| 266 | 1.3.6.3.1.1.2 | All Data Services Test approach and plans MHHS Review Completed | milestone | 0d | 2023-09-21 A | 2023-09-21 A | 265FS+30d | 100% |  | 2023-09-21 | 2023-09-21 | 0d | 2023-08-14 | 2023-08-25 |  |  |  | Lee Cox |  |  |  | SI Test | PP | 5.11 | Design, Build & Test (PIT) | Complete | COMPLETE | T3-DB-0129 | SITAG | T3 |
| 267 | 1.3.6.3.1.2 | **Test Readiness Report** |  | 11d | 2023-08-25 A | 2023-09-08 A |  | 100% |  | 2023-08-25 | 2023-09-08 | 11d | 2023-08-25 | 2023-11-03 |  |  |  | N/A | 176h | 176h | -0 | N/A | N/A | 5.0 | Design, Build & Test (PIT) |  |  |  |  |  |
| 268 | 1.3.6.3.1.2.1 | Test readiness reporting |  | 11d | 2023-08-25 A | 2023-09-08 A | 265FS+10d | 100% |  | 2023-08-25 | 2023-09-08 | 11d | 2023-08-25 | 2023-11-03 |  |  |  | Lee Cox | 88h | 88h |  | PP | 109 | 5.0 | Design, Build & Test (PIT) | Complete | COMPLETE |  |  |  |
| 269 | 1.3.6.3.1.3 | **Requirements to test Traceability Matrix (RTTM)** |  | 7d | 2023-09-20 A | 2023-09-29 A |  | 100% |  | 2023-09-22 | 2023-09-29 | 5d | 2022-10-31 | 2023-10-06 |  |  |  | N/A | 56h | 56h | -0 | N/A | N/A | 5.0 | Design, Build & Test (PIT) |  |  |  |  |  |
| 270 | 1.3.6.3.1.3.1 | All Data Services RTTMs submitted to Programme for assurance | milestone | 0d | 2023-09-20 A | 2023-09-20 A | 265FS+29d | 100% |  | 2023-09-22 | 2023-09-22 | 0d | 2023-09-22 | 2023-09-22 |  |  |  | Lee Cox |  |  |  | PP | SI Test | 5.7 | Design, Build & Test (PIT) | Complete | COMPLETE | T3-DB-0058 | SITAG | T3 |
| 271 | 1.3.6.3.1.3.2 | All Data Services RTTMs MHHS Review Completed | milestone | 0d | 2023-09-29 A | 2023-09-29 A | 270FS+7d | 100% |  | 2023-09-29 | 2023-09-29 | 0d | 2023-09-25 | 2023-10-06 |  |  |  | Lee Cox |  |  |  | SI Test | PP | 5.8 | Design, Build & Test (PIT) | Complete | COMPLETE | T3-DB-0130 | SITAG | T3 |
| 272 | 1.3.6.3.1.4 | **Test Scenarios** |  | 6d | 2023-09-20 A | 2023-09-28 A |  | 100% |  | 2023-09-22 | 2023-09-28 | 4d | 2022-10-31 | 2023-10-06 |  |  |  | N/A | 48h | 48h | -0 | N/A | N/A | 5.0 | Design, Build & Test (PIT) |  |  |  |  |  |
| 273 | 1.3.6.3.1.4.1 | All Data Services test scenarios' submitted to Programme for assurance | milestone | 0d | 2023-09-20 A | 2023-09-20 A | 265FS+29d | 100% |  | 2023-09-22 | 2023-09-22 | 0d | 2023-09-22 | 2023-09-22 |  |  |  | Lee Cox |  |  |  | PP | SI Test | 5.7 | Design, Build & Test (PIT) | Complete | COMPLETE | T3-DB-0056 | SITAG | T3 |
| 274 | 1.3.6.3.1.4.2 | All Data Services Test scenarios' MHHS Review Completed | milestone | 0d | 2023-09-28 A | 2023-09-28 A | 273FS+6d | 100% |  | 2023-09-28 | 2023-09-28 | 0d | 2023-09-25 | 2023-10-06 |  |  |  | Lee Cox |  |  |  | SI Test | PP | 5.11 | Design, Build & Test (PIT) | Complete | COMPLETE | T3-DB-0131 | SITAG | T3 |
| 275 | 1.3.6.3.1.5 | **PIT execution** |  | 50d | 2023-09-11 A | 2023-11-17 A |  | 100% |  | 2022-10-31 | 2023-11-17 | 275d | 2022-10-31 | 2023-11-03 |  |  |  | N/A | 936h | 936h | -0 | N/A | N/A | 5.0 | Design, Build & Test (PIT) |  |  |  |  |  |
| 276 | 1.3.6.3.1.5.1 | PIT Test Execution Progress Report |  | 40d | 2023-09-11 A | 2023-11-03 A | 268 | 100% |  | 2022-10-31 | 2023-10-27 | 260d | 2022-10-31 | 2023-10-27 |  |  |  | Lee Cox | 320h | 320h |  | PP | SI Test | 5.0 | Design, Build & Test (PIT) | Complete | COMPLETE |  |  |  |
| 277 | 1.3.6.3.1.5.2 | PIT Execution |  | 27d | 2023-09-28 A | 2023-11-03 A | 273FS+5d | 100% |  | 2022-10-31 | 2023-11-03 | 265d | 2022-10-31 | 2023-11-03 |  |  |  | Lee Cox | 216h | 216h |  | PP | SI Test | 5.0 | Design, Build & Test (PIT) | Complete | COMPLETE |  |  |  |
| 278 | 1.3.6.3.1.5.3 | All Data Services PIT Completion Reports submitted to Programme for assurance | milestone | 0d | 2023-11-03 A | 2023-11-03 A | 276, 277 | 100% |  | 2023-11-03 | 2023-11-03 | 0d | 2024-01-05 | 2024-01-05 |  |  |  | Lee Cox |  |  |  | PP | SI Test | 5.11 | Design, Build & Test (PIT) | Complete | COMPLETE | T3-DB-0132 | SITAG | T3 |
| 279 | 1.3.6.3.1.5.4 | All Data Services PIT Completion Reports MHHS Review Completed | milestone | 0d | 2023-11-17 A | 2023-11-17 A | 266, 271, 274, 278FS+10d | 100% |  | 2023-11-17 | 2023-11-17 | 0d |  |  |  |  |  | Lee Cox |  |  |  | SI Test | PP | 5.13 |  | Complete | COMPLETE | T3-DB-0133 | SITAG | T3 |
| 280 | 1.3.6.3.2 | **All Metering Services DBT CIT (Entering at Interval 4)** |  | 70d | 2023-08-25 A | 2023-12-01 A |  | 100% |  | 2022-10-31 | 2023-12-01 | 285d | 2022-10-31 | 2023-11-17 |  |  |  | N/A | 2568h | 2568h | -0 | N/A | N/A | 5.0 | Design, Build & Test (PIT) |  |  |  |  |  |
| 281 | 1.3.6.3.2.1 | **Test Approach & Plan** |  | 40d | 2023-08-25 A | 2023-10-20 A |  | 100% |  | 2023-08-25 | 2023-10-20 | 40d | 2022-10-31 | 2023-09-08 |  |  |  | N/A | 320h | 320h | -0 | N/A | N/A | 5.0 | Design, Build & Test (PIT) |  |  |  |  |  |
| 282 | 1.3.6.3.2.1.1 | All Metering Services Test Approach & Plans (PIT) submitted to Programme for assurance | milestone | 0d | 2023-08-25 A | 2023-08-25 A |  | 100% |  | 2023-08-25 | 2023-08-25 | 0d | 2023-08-25 | 2023-08-25 |  |  |  | Lee Cox |  |  |  | PP | SI Test | 5.6 | Design, Build & Test (PIT) | Complete | COMPLETE | T3-DB-0040 | SITAG | T3 |
| 283 | 1.3.6.3.2.1.2 | All Metering Services Test approach and plans MHHS Review Completed | milestone | 0d | 2023-10-20 A | 2023-10-20 A | 282FS+40d | 100% |  | 2023-10-20 | 2023-10-20 | 0d | 2023-08-28 | 2023-09-08 |  |  |  | Lee Cox |  |  |  | SI Test | PP | 5.8 | Design, Build & Test (PIT) | Complete | COMPLETE | T3-DB-0134 | SITAG | T3 |

Notes:
- 259: 17/10 - Amber because St Clements assessmsnt. No impact. Being monitored
- 260: 1/9 - to be raised as new T3 at TMAG. Approved at TMAG on 20/9. 24/10 - Red because 3 day delay to SCS PIT completion. No impact to CIT Interval 2.
- 261: 1/9 - to be raised as new T3 at TMAG. Approved at TMAG on 20/9. 17/10 - Amber because St Clements assessmsnt. No impact. Being monitored
- 266: 1/9 - to be raised as new T3 at TMAG. Approved at TMAG on 20/9. Red due to high volume to be reviewed. Date change under consideration. Review will be completed no later than 17/11 ahead of Interval 3 Readiness Assessment
- 271: 1/9 - to be raised as new T3 at TMAG Approved at TMAG on 20/9. Red due to high volume to be reviewed. Date change under consideration. Review will be completed no later than 17/11 ahead of Interval 3 Readiness Assessment
- 274: 1/9 - to be raised as new T3 at TMAG. Approved at TMAG on 20/9. Red due to high volume to be reviewed. Date change under consideration. Review will be completed no later than 17/11 ahead of Interval 3 Readiness Assessment
- 276: 10/10 - LC - red because date in the past, not all participants have provided reports. No impact. No action
- 277: 10/10 - LC - red because date in the past, acceptable for some participants to have not started PIT yet
- 278: 1/9 - to be raised as new T3 at TMAG. Approved at TMAG on 20/9
- 279: 1/9 - to be raised as new T3 at TMAG. Approved at TMAG on 20/9. 21/11-Red because 1 report remains outstanding due to close 22/11. Completed on 22/11
- 283: 7/10 - Red due to high volume to be reviewed. Date change under consideration. Review will be completed no later than 04/12 ahead of Interval 4 Readiness Assessment

| ID | WBS | Task | Type | Duration | Start | Finish | Predecessors | Complete | Remaining | Baseline start | Baseline finish | Baseline duration | Baseline 1 start | Baseline 1 finish | Total slack | Free slack | Constraint | Resources | Work | Actual work | Baseline cost | Responsible | Involved | Update Version | MHHS Programme Phase | Sched Status | RAG | Artefact ID | Milestone ID | Text29 | Tier |
| --- | --- | --- | --- | --- | --- | --- | --- | --- | --- | --- | --- | --- | --- | --- | --- | --- | --- | --- | --- | --- | --- | --- | --- | --- | --- | --- | --- | --- | --- | --- | --- |
| 284 | 1.3.6.3.2.2 | **Test Readiness Report** |  | 11d | 2023-09-11 A | 2023-09-25 A |  | 100% |  | 2023-09-08 | 2023-11-17 | 51d | 2023-09-08 | 2023-11-17 |  |  |  | N/A | 176h | 176h |  | N/A | N/A | 5.0 | Design, Build & Test (PIT) |  |  |  |  |  |  |
| 285 | 1.3.6.3.2.2.1 | Test readiness reporting |  | 11d | 2023-09-11 A | 2023-09-25 A | 282FS+10d | 100% |  | 2023-09-08 | 2023-11-17 | 51d | 2023-09-08 | 2023-11-17 |  |  |  | Lee Cox | 88h | 88h |  | PP | 109 | 5.0 | Design, Build & Test (PIT) | Complete | COMPLETE |  |  |  |  |
| 286 | 1.3.6.3.2.3 | **Requirements to test Traceability Matrix (RTTM)** |  | 30d | 2023-09-15 A | 2023-10-27 A |  | 100% |  | 2023-09-15 | 2023-10-27 | 30d | 2022-10-31 | 2023-09-29 |  |  |  | N/A | 240h | 240h | -0 | N/A | N/A | 5.0 | Design, Build & Test (PIT) |  |  |  |  |  |  |
| 287 | 1.3.6.3.2.3.1 | All Metering Services RTTMs submitted to Programme for assurance | milestone | 0d | 2023-09-15 A | 2023-09-15 A | 282FS+15d | 100% |  | 2023-09-15 | 2023-09-15 | 0d | 2023-09-15 | 2023-09-15 |  |  |  | Lee Cox |  |  |  | PP | SI Test | 5.8 | Design, Build & Test (PIT) | Complete | COMPLETE | MHHS-ART009 | T3-DB-0048 | SITAG | T3 |
| 288 | 1.3.6.3.2.3.2 | All Metering Services MHHS Reviews Completed | milestone | 0d | 2023-10-27 A | 2023-10-27 A | 287FS+30d | 100% |  | 2023-10-27 | 2023-10-27 | 0d | 2023-09-18 | 2023-09-29 |  |  |  | Lee Cox |  |  |  | SI Test | PP | 5.13 | Design, Build & Test (PIT) | Complete | COMPLETE |  | T3-DB-0135 | SITAG | T3 |
| 289 | 1.3.6.3.2.4 | **Test Scenarios** |  | 30d | 2023-09-15 A | 2023-10-27 A |  | 100% |  | 2023-09-15 | 2023-10-27 | 30d | 2022-10-31 | 2023-09-29 |  |  |  | N/A | 240h | 240h | -0 | N/A | N/A | 5.0 | Design, Build & Test (PIT) |  |  |  |  |  |  |
| 290 | 1.3.6.3.2.4.1 | All Metering Services test scenarios' submitted to Programme for assurance | milestone | 0d | 2023-09-15 A | 2023-09-15 A | 282FS+15d | 100% |  | 2023-09-15 | 2023-09-15 | 0d | 2023-09-15 | 2023-09-15 |  |  |  | Lee Cox |  |  |  | PP | SI Test | 5.8 | Design, Build & Test (PIT) | Complete | COMPLETE |  | T3-DB-0050 | SITAG | T3 |
| 291 | 1.3.6.3.2.4.2 | All Metering Services Test scenarios' MHHS Review Completed | milestone | 0d | 2023-10-27 A | 2023-10-27 A | 290FS+30d | 100% |  | 2023-10-27 | 2023-10-27 | 0d | 2023-09-18 | 2023-09-29 |  |  |  | Lee Cox |  |  |  | SI Test | PP | 5.13 | Design, Build & Test (PIT) | Complete | COMPLETE |  | T3-DB-0136 | SITAG | T3 |
| 292 | 1.3.6.3.2.5 | **PIT execution** |  | 50d | 2023-09-25 A | 2023-12-01 A |  | 100% |  | 2022-10-31 | 2023-12-01 | 285d | 2022-10-31 | 2023-11-17 |  |  |  | N/A | 1032h | 1032h | -0 | N/A | N/A | 5.0 | Design, Build & Test (PIT) |  |  |  |  |  |  |
| 293 | 1.3.6.3.2.5.1 | PIT Test Execution Progress Report |  | 39d | 2023-09-26 A | 2023-11-17 A | 285 | 100% |  | 2023-09-26 | 2023-11-17 | 39d | 2022-10-31 | 2023-11-10 |  |  |  | Lee Cox | 312h | 312h |  | PP | SI Test | 5.0 | Design, Build & Test (PIT) | Complete | COMPLETE |  |  |  |  |
| 294 | 1.3.6.3.2.5.2 | PIT Execution |  | 40d | 2023-09-25 A | 2023-11-17 A | 290FS+5d | 100% |  | 2022-10-31 | 2023-11-17 | 275d | 2022-10-31 | 2023-11-17 |  |  |  | Lee Cox | 320h | 320h |  | PP | SI Test | 5.0 | Design, Build & Test (PIT) | Complete | COMPLETE |  |  |  |  |
| 295 | 1.3.6.3.2.5.3 | All Metering Services PIT Completion Reports submitted to Programme for assurance | milestone | 0d | 2023-11-17 A | 2023-11-17 A | 293, 294 | 100% |  | 2023-11-17 | 2023-11-17 | 0d | 2024-01-05 | 2024-01-05 |  |  |  | Lee Cox |  |  |  | PP | SI Test | 5.13 | Design, Build & Test (PIT) | Complete | COMPLETE |  | T3-DB-0137 | SITAG | T3 |
| 296 | 1.3.6.3.2.5.4 | All Metering Services PIT Completion Reports MHHS Review Completed | milestone | 0d | 2023-12-01 A | 2023-12-01 A | 283, 288, 291, 295FS+10d | 100% |  | 2023-12-01 | 2023-12-01 | 0d |  |  |  |  |  | Lee Cox |  |  |  | SI Test | PP | 5.13 |  | Complete | COMPLETE |  | T3-DB-0138 | SITAG | T3 |
| 297 | 1.3.6.3.3 | **All SIT Programme Participants PIT (SIT Functional)** |  | 221d | 2023-11-17 A | 2024-09-20 |  | 41% | 130.67d | 2022-12-30 | 2024-09-20 | 451d | 2022-12-30 | 2024-02-16 | -2d | 0d |  | N/A | 11592h | 3901.44h | -0 | N/A | N/A | 5.0 | Design, Build & Test (PIT) |  |  |  |  |  |  |
| 298 | 1.3.6.3.3.1 | **Test Approach & Plans** |  | 40d | 2023-11-17 A | 2024-01-11 A |  | 100% |  | 2023-11-17 | 2024-01-11 | 40d | 2022-12-30 | 2023-11-30 |  |  |  | N/A | 320h | 320h | -0 | N/A | N/A | 5.2 | Design, Build & Test (PIT) |  |  |  |  |  |  |
| 299 | 1.3.6.3.3.1.1 | SIT Functional PIT Test Approach & Plan (PIT) submitted to Programme for assurance | milestone | 0d | 2023-11-17 A | 2023-11-17 A |  | 100% |  | 2023-11-17 | 2023-11-17 | 0d | 2023-11-16 | 2023-11-16 |  |  | start no earlier than 2023-11-17 | Lee Cox |  |  |  | PP | SI Test | 5.16 | Design, Build & Test (PIT) | Complete | COMPLETE |  | T3-DB-0093 | SITAG | T3 |
| 300 | 1.3.6.3.3.1.2 | All SIT Functional Test approach and plans MHHS Reviews Completed | milestone | 0d | 2024-01-11 A | 2024-01-11 A | 299FS+40d | 100% |  | 2024-01-11 | 2024-01-11 | 0d | 2023-11-17 | 2023-11-30 |  |  |  | Lee Cox |  |  |  | SI Test | PP | 5.8 | Design, Build & Test (PIT) | Complete | COMPLETE |  | T3-DB-0139 | SITAG | T3 |
| 301 | 1.3.6.3.3.2 | **Test Readiness Reports** |  | 11d | 2023-12-01 A | 2023-12-15 A |  | 100% |  | 2023-12-01 | 2024-02-09 | 51d | 2023-11-30 | 2024-02-08 |  |  |  | N/A | 176h | 176h |  | N/A | N/A | 5.2 | Design, Build & Test (PIT) |  |  |  |  |  |  |
| 302 | 1.3.6.3.3.2.1 | Test readiness reporting |  | 11d | 2023-12-01 A | 2023-12-15 A | 299FS+10d | 100% |  | 2023-12-01 | 2023-12-15 | 51d | 2023-11-30 | 2024-02-08 |  |  |  | Lee Cox | 88h | 88h |  | PP | 109 | 5.2 | Design, Build & Test (PIT) | Complete | COMPLETE |  |  |  |  |
| 303 | 1.3.6.3.3.3 | **Requirements to test Traceability Matrices (RTTM)** |  | 30d | 2023-12-07 A | 2024-01-18 A |  | 100% |  | 2023-12-07 | 2024-01-18 | 30d | 2023-01-06 | 2024-01-05 |  |  |  | N/A | 240h | 240h | -0 | N/A | N/A | 5.2 | Design, Build & Test (PIT) |  |  |  |  |  |  |
| 304 | 1.3.6.3.3.3.1 | SIT Functional PIT RTTM submitted to Programme for assurance | milestone | 0d | 2023-12-07 A | 2023-12-07 A | 299FS+15d | 100% |  | 2023-12-07 | 2023-12-07 | 0d | 2023-12-14 | 2023-12-14 |  |  |  | Lee Cox |  |  |  | PP | SI Test | 5.14 | Design, Build & Test (PIT) | Complete | COMPLETE |  | T3-DB-0091 | SITAG | T3 |
| 305 | 1.3.6.3.3.3.2 | All SIT Functional RTTMs MHHS Reviews Completed | milestone | 0d | 2024-01-18 A | 2024-01-18 A | 304FS+30d | 100% |  | 2024-01-18 | 2024-01-18 | 0d | 2023-12-15 | 2024-01-05 |  |  |  | Lee Cox |  |  |  | SI Test | PP | 5.14 | Design, Build & Test (PIT) | Complete | COMPLETE |  | T3-DB-0140 | SITAG | T3 |
| 306 | 1.3.6.3.3.4 | **Test Scenarios** |  | 30d | 2023-12-07 A | 2024-01-18 A |  | 100% |  | 2023-12-07 | 2024-01-18 | 30d | 2023-01-06 | 2024-01-05 |  |  |  | N/A | 240h | 240h | -0 | N/A | N/A | 5.2 | Design, Build & Test (PIT) |  |  |  |  |  |  |
| 307 | 1.3.6.3.3.4.1 | SIT Functional PIT test scenarios submitted to Programme for assurance | milestone | 0d | 2023-12-07 A | 2023-12-07 A | 299FS+15d | 100% |  | 2023-12-07 | 2023-12-07 | 0d | 2023-12-14 | 2023-12-14 |  |  |  | Lee Cox |  |  |  | PP | SI Test | 5.14 | Design, Build & Test (PIT) | Complete | COMPLETE |  | T3-DB-0089 | SITAG | T3 |
| 308 | 1.3.6.3.3.4.2 | All SIT Functional Test scenarios' MHHS Reviews Completed | milestone | 0d | 2024-01-18 A | 2024-01-18 A | 307FS+30d | 100% |  | 2024-01-18 | 2024-01-18 | 0d | 2023-12-15 | 2024-01-05 |  |  |  | Lee Cox |  |  |  | SI Test | PP | 5.14 | Design, Build & Test (PIT) | Complete | COMPLETE |  | T3-DB-0141 | SITAG | T3 |

Notes:
- 287: 13/9 - name change at TMAG. Red because 9/10 received. Approved at TMAG on 20/9
- 288: 1/9 - to be raised as new T3 at TMAG. Approved at TMAG on 20/9. 17/10 - Red because assurance reviews open comments remain outstanding. Final reviews will be completed no later than 4/12 ahead of Interval 4 Readiness Report
- 290: 13/9 - name change at TMAG Red because 9/10 . Approved at TMAG on 20/9
- 291: 1/9 - to be raised as new T3 at TMAG. Approved at TMAG on 20/9. 17/10 - Red because assurance reviews open comments remain outstanding. Final reviews will be completed no later than 4/12 ahead of Interval 4 Readiness Report
- 295: 1/9 - to be raised as new T3 at TMAG. Approved at TMAG on 20/9. 21/11-Red because not all test completion reports received. No impact. No action
- 296: 1/9 - to be raised as new T3 at TMAG. Approved at TMAG on 20/9.28/11 - Amber because late delivery of some completion reports imparing ability to conclude on time. Expediting reviews ahead of RA 4
- 299: 12/9 - name change to TMAG. Approved at TMAG on 20/9. 5/12-Red because not all test approach and plans received. Escalated at FTIG and PSG. Completed 4/1/24
- 300: 1/9 - to be raised as new T3 at TMAG. Approved at TMAG on 20/9. 16/1- All remaining / late artefacts now received and reviewed by Programme with feedback provided to PPs. Awaiting PPs final feedback. Approved complete at SITAG on 21/2/24
- 304: 12/9 - name and date change to TMAG. Approved at TMAG on 20/9. 20/02 - 1 PP artefact not yet received. Escalated at FTIG
- 305: 1/9 - to be raised as new T3 at TMAG. Approved at TMAG on 20/9. 23/01 - Late due to late delivery of PP artefacts for review
- 307: 12/9 - name and date change to TMAG. Approved at TMAG on 20/9. 20/02 - 2 PP artefacts not yet received. Escalated at FTIG
- 308: 1/9 - to be raised as new T3 at TMAG. Approved at TMAG on 20/9. 12/12 - Late due to late delivery of PP artefacts for review

| ID | WBS | Task | Type | Duration | Start | Finish | Predecessors | Complete | Remaining | Baseline start | Baseline finish | Baseline duration | Baseline 1 start | Baseline 1 finish | Total slack | Free slack | Constraint | Resources | Work | Actual work | Baseline cost | Responsible | Involved | Update Version | MHHS Programme Phase | Sched Status | RAG | Milestone ID | Text29 | Tier | Task Status |
| --- | --- | --- | --- | --- | --- | --- | --- | --- | --- | --- | --- | --- | --- | --- | --- | --- | --- | --- | --- | --- | --- | --- | --- | --- | --- | --- | --- | --- | --- | --- | --- |
| 309 | 1.3.6.3.3.5 | **PIT execution** |  | 51d | 2023-12-15 A | 2024-02-23 A |  | 100% |  | 2022-12-30 | 2024-02-23 | 301d | 2022-12-30 | 2024-02-09 |  |  |  | N/A | 1056h | 1056h | -0 | N/A | N/A | 5.0 | Design, Build & Test (PIT) |  |  |  |  |  |  |
| 310 | 1.3.6.3.3.5.1 | PIT Test Execution Progress Reports |  | 40d | 2023-12-18 A | 2024-02-09 A | 302 | 100% |  | 2023-12-18 | 2024-02-09 | 40d | 2022-12-30 | 2024-02-01 |  |  |  | Lee Cox | 320h | 320h |  | PP | SI Test | 5.0 | Design, Build & Test (PIT) | Complete | COMPLETE |  |  |  |  |
| 311 | 1.3.6.3.3.5.2 | PIT Execution |  | 41d | 2023-12-15 A | 2024-02-09 A | 307FS+5d | 100% |  | 2022-12-30 | 2024-02-09 | 290d | 2022-12-30 | 2024-02-09 |  |  |  | Lee Cox | 328h | 328h |  | PP | SI Test | 5.0 | Design, Build & Test (PIT) | Complete | COMPLETE |  |  |  |  |
| 312 | 1.3.6.3.3.5.3 | All SIT Functional PIT Completion Reports submitted to Programme for Assurance | milestone | 0d | 2024-02-09 A | 2024-02-09 A | 310, 311 | 100% |  | 2024-02-09 | 2024-02-09 | 0d | 2024-01-05 | 2024-01-05 |  |  |  | Lee Cox |  |  |  | PP | SI Test | 5.19 | Design, Build & Test (PIT) | Complete | COMPLETE | T3-DB-0087 | SITAG | T3 |  |
| 313 | 1.3.6.3.3.5.4 | All SIT Functional PIT Completion Reports MHHS Review Completed | milestone | 0d | 2024-02-23 A | 2024-02-23 A | 300, 305, 308, 312FS+10d | 100% |  | 2024-02-23 | 2024-02-23 | 0d |  |  |  |  |  | Lee Cox |  |  |  | SI Test | PP | 5.19 |  | Complete | COMPLETE | T3-DB-0142 | SITAG | T3 |  |
| 314 | 1.3.6.3.3.6 | **All SIT Programme Participants PIT (SIT Migration)** |  | 71d | 2024-02-16 A | 2024-05-24 |  | 63% | 26.24d | 2023-03-31 | 2024-05-24 | 301d |  |  | 5d |  |  | N/A | 2600h | 1146.83h | -0 | N/A | N/A | 5.1 | Design, Build & Test (PIT) |  |  |  |  |  |  |
| 315 | 1.3.6.3.3.6.1 | **Test Approach & Plans** |  | 40d | 2024-02-16 A | 2024-04-11 |  |  | 40d | 2024-02-16 | 2024-04-11 | 40d |  |  | 36d |  |  | N/A | 320h |  | -0 | N/A | N/A | 5.2 | Design, Build & Test (PIT) |  |  |  |  |  |  |
| 316 | 1.3.6.3.3.6.1.1 | All SIT Migration PIT Test Approach & Plans submitted to Programme for assurance | milestone | 0d | 2024-02-16 A | 2024-02-16 A |  | 100% |  | 2024-02-16 | 2024-02-16 | 0d |  |  |  |  | start no earlier than 2024-02-16 | Lee Cox |  |  |  | PP | SI Test | 5.8 | Design, Build & Test (PIT) | Complete | COMPLETE | T3-DB-0143 | SITAG | T3 |  |
| 317 | 1.3.6.3.3.6.1.2 | All SIT Migration PIT Test approach and plans MHHS Reviews Completed | milestone | 0d | 2024-04-11 | 2024-04-11 | 316FS+40d |  |  | 2024-04-11 | 2024-04-11 | 0d |  |  | 36d | 31d |  | Lee Cox |  |  |  | SI Test | PP | 5.8 | Design, Build & Test (PIT) | Overdue Start | RED | T3-DB-0144 | SITAG | T3 | -6.29 |
| 318 | 1.3.6.3.3.6.2 | **Test Readiness Reports** |  | 11d | 2024-03-01 A | 2024-03-15 A |  | 100% |  | 2024-03-01 | 2024-05-10 | 51d |  |  |  |  |  | N/A | 176h | 176h |  | N/A | N/A | 5.2 | Design, Build & Test (PIT) |  |  |  |  |  |  |
| 319 | 1.3.6.3.3.6.2.1 | Test readiness reporting |  | 11d | 2024-03-01 A | 2024-03-15 A | 316FS+10d | 100% |  | 2024-03-01 | 2024-05-10 | 51d |  |  |  |  |  | Lee Cox | 88h | 88h |  | PP | 109 | 5.2 | Design, Build & Test (PIT) | Complete | COMPLETE |  |  |  |  |
| 320 | 1.3.6.3.3.6.3 | **Requirements to test Traceability Matrices (RTTM)** |  | 30d | 2024-03-07 | 2024-04-18 |  |  |  | 2024-03-07 | 2024-04-18 | 30d |  |  | 31d |  |  | N/A | 240h |  | -0 | N/A | N/A | 5.2 | Design, Build & Test (PIT) |  |  |  |  |  |  |
| 321 | 1.3.6.3.3.6.3.1 | All SIT Migration PIT RTTMs submitted to Programme for assurance | milestone | 0d | 2024-03-07 | 2024-03-07 | 316FS+15d |  |  | 2024-03-07 | 2024-03-07 | 0d |  |  | 31d | 0d |  | Lee Cox |  |  |  | PP | SI Test | 5.8 | Design, Build & Test (PIT) | Overdue Start | RED | T3-DB-0145 | SITAG | T3 | -41.29 |
| 322 | 1.3.6.3.3.6.3.2 | All SIT Migration RTTMs MHHS Reviews Completed | milestone | 0d | 2024-04-18 | 2024-04-18 | 321FS+30d |  |  | 2024-04-18 | 2024-04-18 | 0d |  |  | 31d | 26d |  | Lee Cox |  |  |  | SI Test | PP | 5.8 | Design, Build & Test (PIT) | Green | AMBER | T3-DB-0146 | SITAG | T3 | 0.71 |
| 323 | 1.3.6.3.3.6.4 | **Test Scenarios** |  | 30d | 2024-03-07 | 2024-04-18 |  |  |  | 2024-03-07 | 2024-04-18 | 30d |  |  | 24d |  |  | N/A | 240h |  | -0 | N/A | N/A | 5.2 | Design, Build & Test (PIT) |  |  |  |  |  |  |
| 324 | 1.3.6.3.3.6.4.1 | All SIT Migration PIT test scenarios submitted to Programme for assurance | milestone | 0d | 2024-03-07 | 2024-03-07 | 316FS+15d |  |  | 2024-03-07 | 2024-03-07 | 0d |  |  | 24d | 0d |  | Lee Cox |  |  |  | PP | SI Test | 5.8 | Design, Build & Test (PIT) | Overdue Start | RED | T3-DB-0147 | SITAG | T3 | -41.29 |
| 325 | 1.3.6.3.3.6.4.2 | All SIT Migration Test scenarios MHHS Reviews Completed | milestone | 0d | 2024-04-18 | 2024-04-18 | 324FS+30d |  |  | 2024-04-18 | 2024-04-18 | 0d |  |  | 31d | 26d |  | Lee Cox |  |  |  | SI Test | PP | 5.8 | Design, Build & Test (PIT) | Green | AMBER | T3-DB-0148 | SITAG | T3 | 0.71 |
| 326 | 1.3.6.3.3.6.5 | **PIT execution** |  | 51d | 2024-03-15 A | 2024-05-24 |  | 58% | 21.41d | 2023-03-31 | 2024-05-24 | 301d |  |  | 5d |  |  | N/A | 1056h | 612.74h | -0 | N/A | N/A | 5.1 | Design, Build & Test (PIT) |  |  |  |  |  |  |
| 327 | 1.3.6.3.3.6.5.1 | PIT Test Execution Progress Reports |  | 40d | 2024-03-18 A | 2024-05-10 | 319 | 58% | 17d | 2024-03-18 | 2024-05-10 | 40d |  |  | 5d | 0d |  | Lee Cox | 320h | 184h |  | PP | SI Test | 5.1 | Design, Build & Test (PIT) | Green | GREEN |  |  |  |  |
| 328 | 1.3.6.3.3.6.5.2 | PIT Execution |  | 41d | 2024-03-15 A | 2024-05-10 | 324FS+5d | 59% | 17d | 2023-03-31 | 2024-05-10 | 290d |  |  | 5d | 0d |  | Lee Cox | 328h | 192h |  | PP | SI Test | 5.1 | Design, Build & Test (PIT) | yellow | GREEN |  |  |  |  |
| 329 | 1.3.6.3.3.6.5.3 | All SIT Migration PIT Completion Reports submitted to Programme for assurance | milestone | 0d | 2024-05-10 | 2024-05-10 | 327, 328 |  |  | 2024-05-10 | 2024-05-10 | 0d | 2024-01-05 | 2024-01-05 | 5d | 0d |  | Lee Cox |  |  |  | PP | SI Test | 5.8 | Design, Build & Test (PIT) | Green | GREEN | T3-DB-0149 | SITAG | T3 | 22.71 |
| 330 | 1.3.6.3.3.6.5.4 | All SIT Migration PIT Completion Reports MHHS Review Completed | milestone | 0d | 2024-05-24 | 2024-05-24 | 317, 322, 325, 329FS+10d |  |  | 2024-05-24 | 2024-05-24 | 0d |  |  | 5d |  |  | Lee Cox |  |  |  | SI Test | PP | 5.8 |  | Green | GREEN | T3-DB-0150 | SITAG | T3 | 36.71 |
| 331 | 1.3.6.3.3.7 | **All SIT Programme Participants PIT (SIT Non Functional)** |  | 71d | 2024-05-10 | 2024-08-16 |  |  |  | 2023-06-23 | 2024-08-16 | 301d |  |  | 5d |  |  | N/A | 2592h |  | -0 | N/A | N/A | 5.1 | Design, Build & Test (PIT) |  |  |  |  |  |  |
| 332 | 1.3.6.3.3.7.1 | **Test Approach & Plan** |  | 40d | 2024-05-10 | 2024-07-04 |  |  |  | 2024-05-10 | 2024-07-04 | 40d |  |  | 5d |  |  | N/A | 320h |  | -0 | N/A | N/A | 5.2 | Design, Build & Test (PIT) |  |  |  |  |  |  |
| 333 | 1.3.6.3.3.7.1.1 | SIT Non-Functional PIT Test Approach & Plan (PIT) submitted to Programme for assurance | milestone | 0d | 2024-05-10 | 2024-05-10 |  |  |  | 2024-05-10 | 2024-05-10 | 0d |  |  | 5d | 0d | start no earlier than 2024-05-10 | Lee Cox |  |  |  | PP | SI Test | 5.8 | Design, Build & Test (PIT) | Green | GREEN | T3-DB-0151 | SITAG | T3 | 22.33 |
| 334 | 1.3.6.3.3.7.1.2 | SIT Non-Functional Test approach and plan MHHS Review Completed | milestone | 0d | 2024-07-04 | 2024-07-04 | 333FS+40d |  |  | 2024-07-04 | 2024-07-04 | 0d |  |  | 36d | 31d |  | Lee Cox |  |  |  | SI Test | PP | 5.8 | Design, Build & Test (PIT) | Green | GREEN | T3-DB-0152 | SITAG | T3 | 77.71 |

Notes:
- 310: 16/4: completed 12/4
- 311: 16/4: completed 12/4
- 312: 1/9 - name change at TMAG. Approved at TMAG on 20/9. 20/2 - 23 reports received. The majority of late deliveries have been discussed and agreed with the Programme.5/3 - Approved 1/3 SITAG with workoff
- 313: 1/9 - to be raised as new T3 at TMAG. Approved at TMAG on 20/9. 27/2 - Target date missed due to late delivery of some reports. 5/3 - Approved 1/3 SITAG with workoff
- 316: 1/9 - to be raised as new T3 at TMAG. Approved at TMAG on 20/9.. 19/3 - 33/35 received
- 317: 1/9 - to be raised as new T3 at TMAG. Approved at TMAG on 20/9. 26/3: At risk because of late delivery of PIT test approach and plans by PPs. 16/4: All received. All but 1 reviewed
- 321: 1/9 - to be raised as new T3 at TMAG. Approved at TMAG on 20/9. 16/04: 27/35 received. Remainder to be chased
- 322: 1/9 - to be raised as new T3 at TMAG. Approved at TMAG on 20/9. 26/3: At risk because of late delivery of RTTMs by PPs
- 324: 1/9 - to be raised as new T3 at TMAG. Approved at TMAG on 20/9. 16/04: 25/35 received. Remainder to be chased
- 325: 1/9 - to be raised as new T3 at TMAG. Approved at TMAG on 20/9. 26/3: At risk because of late delivery of PIT test scenarios by PPs
- 329: 1/9 - to be raised as new T3 at TMAG. Approved at TMAG on 20/9. 9/4/24: Sufficinet PIT completion reports on track, some are known to be late
- 330: 1/9 - to be raised as new T3 at TMAG. Approved at TMAG on 20/9.
- 333: 1/9 - to be raised as new T3 at TMAG. Approved at TMAG on 20/9.
- 334: 1/9 - to be raised as new T3 at TMAG. Approved at TMAG on 20/9.

| ID | WBS | Task | Type | Duration | Start | Finish | Predecessors | Baseline start | Baseline finish | Baseline duration | Baseline 1 start | Baseline 1 finish | Total slack | Free slack | Constraint | Resources | Work | Baseline cost | Responsible | Involved | Update Version | MHHS Programme Phase | Task Status | Sched Status | RAG | Milestone ID | Text29 | Tier |
| --- | --- | --- | --- | --- | --- | --- | --- | --- | --- | --- | --- | --- | --- | --- | --- | --- | --- | --- | --- | --- | --- | --- | --- | --- | --- | --- | --- | --- |
| 335 | 1.3.6.3.3.7.2 | **Test Readiness Report** |  | 11d | 2024-05-24 | 2024-06-07 |  | 2024-05-24 | 2024-08-02 | 51d |  |  | 6d |  |  | N/A | 176h |  | N/A | N/A | 5.2 | Design, Build & Test (PIT) |  |  |  |  |  |  |
| 336 | 1.3.6.3.3.7.2.1 | Test readiness reporting |  | 11d | 2024-05-24 | 2024-06-07 | 333FS+10d | 2024-05-24 | 2024-08-02 | 51d |  |  | 6d | 0d |  | Lee Cox | 88h |  | PP | 109 | 5.2 | Design, Build & Test (PIT) | 36.33 | Green | GREEN |  |  |  |
| 337 | 1.3.6.3.3.7.3 | **Requirements to test Traceability Matrix (RTTM)** |  | 30d | 2024-05-30 | 2024-07-11 |  | 2024-05-30 | 2024-07-11 | 30d |  |  | 31d |  |  | N/A | 240h | -0 | N/A | N/A | 5.2 | Design, Build & Test (PIT) |  |  |  |  |  |  |
| 338 | 1.3.6.3.3.7.3.1 | SIT Non-Functional PIT RTTM submitted to Programme for assurance | milestone | 0d | 2024-05-30 | 2024-05-30 | 333FS+15d | 2024-05-30 | 2024-05-30 | 0d |  |  | 31d | 0d |  | Lee Cox |  |  | PP | SI Test | 5.8 | Design, Build & Test (PIT) | 42.71 | Green | GREEN | T3-DB-0153 | SITAG | T3 |
| 339 | 1.3.6.3.3.7.3.2 | SIT Non-Functional RTTM MHHS Review Completed | milestone | 0d | 2024-07-11 | 2024-07-11 | 338FS+30d | 2024-07-11 | 2024-07-11 | 0d |  |  | 31d | 26d |  | Lee Cox |  |  | SI Test | PP | 5.8 | Design, Build & Test (PIT) | 84.71 | Green | GREEN | T3-DB-0154 | SITAG | T3 |
| 340 | 1.3.6.3.3.7.4 | **Test Scenarios** |  | 30d | 2024-05-30 | 2024-07-11 |  | 2024-05-30 | 2024-07-11 | 30d |  |  | 5d |  |  | N/A | 240h | -0 | N/A | N/A | 5.2 | Design, Build & Test (PIT) |  |  |  |  |  |  |
| 341 | 1.3.6.3.3.7.4.1 | SIT Non-Functional PIT test scenarios submitted to Programme for assurance | milestone | 0d | 2024-05-30 | 2024-05-30 | 333FS+15d | 2024-05-30 | 2024-05-30 | 0d |  |  | 5d | 0d |  | Lee Cox |  |  | PP | SI Test | 5.8 | Design, Build & Test (PIT) | 42.71 | Green | GREEN | T3-DB-0155 | SITAG | T3 |
| 342 | 1.3.6.3.3.7.4.2 | SIT Non-Functional Test scenarios MHHS Review Completed | milestone | 0d | 2024-07-11 | 2024-07-11 | 341FS+30d | 2024-07-11 | 2024-07-11 | 0d |  |  | 31d | 26d |  | Lee Cox |  |  | SI Test | PP | 5.8 | Design, Build & Test (PIT) | 84.71 | Green | GREEN | T3-DB-0156 | SITAG | T3 |
| 343 | 1.3.6.3.3.7.5 | **PIT execution** |  | 51d | 2024-06-07 | 2024-08-16 |  | 2023-06-23 | 2024-08-16 | 301d |  |  | 5d |  |  | N/A | 1048h | -0 | N/A | N/A | 5.1 | Design, Build & Test (PIT) |  |  |  |  |  |  |
| 344 | 1.3.6.3.3.7.5.1 | PIT Test Execution Progress Report |  | 39d | 2024-06-10 | 2024-08-01 | 336 | 2024-06-10 | 2024-08-01 | 39d |  |  | 6d | 1d |  | Lee Cox | 312h |  | PP | SI Test | 5.1 | Design, Build & Test (PIT) | 53.33 | Green | GREEN |  |  |  |
| 345 | 1.3.6.3.3.7.5.2 | PIT Execution |  | 41d | 2024-06-07 | 2024-08-02 | 341FS+5d | 2023-06-23 | 2024-08-02 | 290d |  |  | 5d | 0d |  | Lee Cox | 328h |  | PP | SI Test | 5.1 | Design, Build & Test (PIT) | 50.33 | yellow | GREEN |  |  |  |
| 346 | 1.3.6.3.3.7.5.3 | SIT Non-Functional PIT Completion Report submitted to Programme for assurance | milestone | 0d | 2024-08-02 | 2024-08-02 | 344, 345 | 2024-08-02 | 2024-08-02 | 0d | 2024-01-05 | 2024-01-05 | 5d | 0d |  | Lee Cox |  |  | PP | SI Test | 5.10 | Design, Build & Test (PIT) | 106.71 | Green | GREEN | T3-DB-0157 | SITAG | T3 |
| 347 | 1.3.6.3.3.7.5.4 | SIT Non-Functional PIT Completion Report MHHS Review Completed | milestone | 0d | 2024-08-16 | 2024-08-16 | 334, 339, 342, 346FS+10d | 2024-08-16 | 2024-08-16 | 0d |  |  | 5d |  |  | Lee Cox |  |  | SI Test | PP | 5.8 |  | 120.71 | Green | GREEN | T3-DB-0158 | SITAG | T3 |
| 348 | 1.3.6.3.3.8 | **All SIT Programme Participants PIT (SIT Operational)** |  | 71d | 2024-06-14 | 2024-09-20 |  | 2023-07-28 | 2024-09-20 | 301d |  |  | -2d | 0d |  | N/A | 2600h | -0 | N/A | N/A | 5.1 | Design, Build & Test (PIT) |  |  |  |  |  |  |
| 349 | 1.3.6.3.3.8.1 | **Test Approach & Plan** |  | 40d | 2024-06-14 | 2024-08-08 |  | 2024-06-14 | 2024-08-08 | 40d |  |  | -2d | 0d |  | N/A | 320h | -0 | N/A | N/A | 5.2 | Design, Build & Test (PIT) |  |  |  |  |  |  |
| 350 | 1.3.6.3.3.8.1.1 | SIT Operational PIT Test Approach & Plan (PIT) submitted to Programme for assurance | milestone | 0d | 2024-06-14 | 2024-06-14 |  | 2024-06-14 | 2024-06-14 | 0d |  |  | -2d | 0d | start no earlier than 2024-06-14 | Lee Cox |  |  | PP | SI Test | 5.8 | Design, Build & Test (PIT) | 57.33 | Green | GREEN | T3-DB-0159 | SITAG | T3 |
| 351 | 1.3.6.3.3.8.1.2 | SIT Operational Test approach and plan MHHS Review Completed | milestone | 0d | 2024-08-08 | 2024-08-08 | 350FS+40d | 2024-08-08 | 2024-08-08 | 0d |  |  | 29d |  |  | Lee Cox |  |  | SI Test | PP | 5.8 | Design, Build & Test (PIT) | 112.71 | Green | GREEN | T3-DB-0160 | SITAG | T3 |
| 352 | 1.3.6.3.3.8.2 | **Test Readiness Report** |  | 11d | 2024-06-28 | 2024-07-12 |  | 2024-06-28 | 2024-09-06 | 51d |  |  | -2d | 0d |  | N/A | 176h |  | N/A | N/A | 5.2 | Design, Build & Test (PIT) |  |  |  |  |  |  |
| 353 | 1.3.6.3.3.8.2.1 | Test readiness reporting |  | 11d | 2024-06-28 | 2024-07-12 | 350FS+10d | 2024-06-28 | 2024-09-06 | 51d |  |  | -2d | 0d |  | Lee Cox | 88h |  | PP | 109 | 5.2 | Design, Build & Test (PIT) | 71.33 | Green | GREEN |  |  |  |
| 354 | 1.3.6.3.3.8.3 | **Requirements to test Traceability Matrix (RTTM)** |  | 30d | 2024-07-04 | 2024-08-15 |  | 2024-07-04 | 2024-08-15 | 30d |  |  | 24d |  |  | N/A | 240h | -0 | N/A | N/A | 5.2 | Design, Build & Test (PIT) |  |  |  |  |  |  |
| 355 | 1.3.6.3.3.8.3.1 | SIT Operational PIT RTTM submitted to Programme for assurance | milestone | 0d | 2024-07-04 | 2024-07-04 | 350FS+15d | 2024-07-04 | 2024-07-04 | 0d |  |  | 24d | 0d |  | Lee Cox |  |  | PP | SI Test | 5.8 | Design, Build & Test (PIT) | 77.71 | Green | GREEN | T3-DB-0161 | SITAG | T3 |
| 356 | 1.3.6.3.3.8.3.2 | SIT Operational RTTM MHHS Review Completed | milestone | 0d | 2024-08-15 | 2024-08-15 | 355FS+30d | 2024-08-15 | 2024-08-15 | 0d |  |  | 24d |  |  | Lee Cox |  |  | SI Test | PP | 5.8 | Design, Build & Test (PIT) | 119.71 | Green | GREEN | T3-DB-0162 | SITAG | T3 |
| 357 | 1.3.6.3.3.8.4 | **Test Scenarios** |  | 30d | 2024-07-04 | 2024-08-15 |  | 2024-07-04 | 2024-08-15 | 30d |  |  | -2d | 0d |  | N/A | 240h | -0 | N/A | N/A | 5.2 | Design, Build & Test (PIT) |  |  |  |  |  |  |
| 358 | 1.3.6.3.3.8.4.1 | SIT Operational PIT test scenarios submitted to Programme for assurance | milestone | 0d | 2024-07-04 | 2024-07-04 | 350FS+15d | 2024-07-04 | 2024-07-04 | 0d |  |  | -2d | 0d |  | Lee Cox |  |  | PP | SI Test | 5.8 | Design, Build & Test (PIT) | 77.71 | Green | GREEN | T3-DB-0163 | SITAG | T3 |
| 359 | 1.3.6.3.3.8.4.2 | SIT Operational Test scenarios MHHS Review Completed | milestone | 0d | 2024-08-15 | 2024-08-15 | 358FS+30d | 2024-08-15 | 2024-08-15 | 0d |  |  | 24d |  |  | Lee Cox |  |  | SI Test | PP | 5.8 | Design, Build & Test (PIT) | 119.71 | Green | GREEN | T3-DB-0164 | SITAG | T3 |

Notes:
- 338: 1/9 - to be raised as new T3 at TMAG. Approved at TMAG on 20/9.
- 339: 1/9 - to be raised as new T3 at TMAG. Approved at TMAG on 20/9.
- 341: 1/9 - to be raised as new T3 at TMAG. Approved at TMAG on 20/9.
- 342: 1/9 - to be raised as new T3 at TMAG. Approved at TMAG on 20/9.
- 346: 1/9 - to be raised as new T3 at TMAG. Approved at TMAG on 20/9. 6/10 - Submit to TMAG for name change to remove IT. Approved for date change at TMAG on 23/10/23
- 347: 1/9 - to be raised as new T3 at TMAG. Approved at TMAG on 20/9.
- 350: 1/9 - to be raised as new T3 at TMAG. Approved at TMAG on 20/9.
- 351: 1/9 - to be raised as new T3 at TMAG. Approved at TMAG on 20/9.
- 355: 1/9 - to be raised as new T3 at TMAG. Approved at TMAG on 20/9.
- 356: 1/9 - to be raised as new T3 at TMAG. Approved at TMAG on 20/9.
- 358: 1/9 - to be raised as new T3 at TMAG. Approved at TMAG on 20/9.
- 359: 1/9 - to be raised as new T3 at TMAG. Approved at TMAG on 20/9.

| ID | WBS | Task | Type | Duration | Start | Finish | Predecessors | Complete | Baseline start | Baseline finish | Baseline duration | Baseline 1 start | Baseline 1 finish | Total slack | Free slack | Constraint | Resources | Work | Actual work | Baseline cost | Responsible | Involved | Update Version | MHHS Programme Phase | Task Status | Sched Status | RAG | Milestone ID | Text29 | Tier | Artefact ID |
| --- | --- | --- | --- | --- | --- | --- | --- | --- | --- | --- | --- | --- | --- | --- | --- | --- | --- | --- | --- | --- | --- | --- | --- | --- | --- | --- | --- | --- | --- | --- | --- |
| 360 | 1.3.6.3.3.8.5 | **PIT execution** |  | 51d | 2024-07-12 | 2024-09-20 |  |  | 2023-07-28 | 2024-09-20 | 301d |  |  | -2d | 0d |  | N/A | 1056h |  | -0 | N/A | N/A | 5.1 | Design, Build & Test (PIT) |  |  |  |  |  |  |  |
| 361 | 1.3.6.3.3.8.5.1 | PIT Test Execution Progress Report |  | 40d | 2024-07-15 | 2024-09-06 | 353 |  | 2024-07-15 | 2024-09-06 | 40d |  |  | -2d | 0d |  | Lee Cox | 320h |  |  | PP | SI Test | 5.1 | Design, Build & Test (PIT) | 88.33 | Green | GREEN |  |  |  |  |
| 362 | 1.3.6.3.3.8.5.2 | PIT Execution |  | 41d | 2024-07-12 | 2024-09-06 | 358FS+5d |  | 2023-07-28 | 2024-09-06 | 290d |  |  | -2d | 0d |  | Lee Cox | 328h |  |  | PP | SI Test | 5.1 | Design, Build & Test (PIT) | 85.33 | yellow | GREEN |  |  |  |  |
| 363 | 1.3.6.3.3.8.5.3 | SIT Operational PIT Completion Report submitted to Programme for assurance | milestone | 0d | 2024-09-06 | 2024-09-06 | 361, 362 |  | 2024-09-06 | 2024-09-06 | 0d | 2024-01-05 | 2024-01-05 | -2d | 0d |  | Lee Cox |  |  |  | PP | SI Test | 5.10 | Design, Build & Test (PIT) | 141.71 | Green | GREEN | T3-DB-0165 | SITAG | T3 |  |
| 364 | 1.3.6.3.3.8.5.4 | SIT Operational PIT Completion Report MHHS Review Completed | milestone | 0d | 2024-09-20 | 2024-09-20 | 351, 356, 359, 363FS+10d |  | 2024-09-20 | 2024-09-20 | 0d |  |  | -2d | 0d |  | Lee Cox |  |  |  | SI Test | PP | 5.8 |  | 155.71 | Green | GREEN | T3-DB-0166 | SITAG | T3 |  |
| 365 | 1.3.6.3.4 | **All Suppliers DBT CIT (Entering at Interval 5)** |  | 71d | 2023-09-15 A | 2023-12-22 A |  | 100% | 2022-10-31 | 2023-12-22 | 300d | 2022-10-31 | 2025-03-14 |  |  |  | N/A | 2280h | 2280h | -0 | N/A | N/A | 5.0 | Design, Build & Test (PIT) |  |  |  |  |  |  |  |
| 366 | 1.3.6.3.4.1 | **Test Approach & Plan** |  | 20d | 2023-09-15 A | 2023-10-12 A |  | 100% | 2023-09-15 | 2023-10-12 | 19d | 2022-10-31 | 2023-09-29 |  |  |  | N/A | 160h | 160h | -0 | N/A | N/A | 5.0 | Design, Build & Test (PIT) |  |  |  |  |  |  |  |
| 367 | 1.3.6.3.4.1.1 | All SIT Suppliers Test Approach & Plans (PIT) submitted to Programme for assurance | milestone | 0d | 2023-09-15 A | 2023-09-15 A |  | 100% | 2023-09-15 | 2023-09-15 | 0d | 2023-09-15 | 2023-09-15 |  |  | start no earlier than 2023-09-15 | Lee Cox |  |  |  | PP | SI Test | 5.8 | Design, Build & Test (PIT) |  | Complete | COMPLETE | T3-DB-0046 | SITAG | T3 |  |
| 368 | 1.3.6.3.4.1.2 | All SIT Suppliers Test Approach & Plans MHHS Review Completed | milestone | 0d | 2023-10-12 A | 2023-10-12 A | 367FS+20d | 100% | 2023-10-12 | 2023-10-12 | 0d | 2023-09-18 | 2023-09-29 |  |  |  | Lee Cox |  |  |  | SI Test | PP | 5.8 | Design, Build & Test (PIT) |  | Complete | COMPLETE | T3-DB-0167 | SITAG | T3 |  |
| 369 | 1.3.6.3.4.2 | **Test Readiness Report** |  | 11d | 2023-09-29 A | 2023-10-13 A |  | 100% | 2023-09-29 | 2023-12-08 | 51d | 2023-09-29 | 2023-12-08 |  |  |  | N/A | 176h | 176h |  | N/A | N/A | 5.0 | Design, Build & Test (PIT) |  |  |  |  |  |  |  |
| 370 | 1.3.6.3.4.2.1 | Test readiness reporting |  | 11d | 2023-09-29 A | 2023-10-13 A | 367FS+10d | 100% | 2023-09-29 | 2023-12-08 | 51d | 2023-09-29 | 2023-12-08 |  |  |  | Lee Cox | 88h | 88h |  | PP | 109 | 5.0 | Design, Build & Test (PIT) |  | Complete | COMPLETE |  |  |  |  |
| 371 | 1.3.6.3.4.3 | **Requirements to test Traceability Matrix (RTTM)** |  | 20d | 2023-10-06 A | 2023-11-03 A |  | 100% | 2023-10-06 | 2023-11-03 | 21d | 2022-10-31 | 2023-10-20 |  |  |  | N/A | 160h | 160h | -0 | N/A | N/A | 5.0 | Design, Build & Test (PIT) |  |  |  |  |  |  |  |
| 372 | 1.3.6.3.4.3.1 | All SIT Suppliers RTTMs submitted to Programme for assurance | milestone | 0d | 2023-10-06 A | 2023-10-06 A | 367FS+16d | 100% | 2023-10-06 | 2023-10-06 | 1d | 2023-10-06 | 2023-10-06 |  |  |  | Lee Cox |  |  |  | PP | SI Test | 5.8 | Design, Build & Test (PIT) |  | Complete | COMPLETE | T3-DB-0064 | SITAG | T3 | MHHS-ART009 |
| 373 | 1.3.6.3.4.3.2 | All SIT Suppliers RTTMs MHHS Review Completed | milestone | 0d | 2023-11-03 A | 2023-11-03 A | 372FS+20d | 100% | 2023-11-03 | 2023-11-03 | 0d | 2023-10-09 | 2023-10-20 |  |  |  | Lee Cox |  |  |  | SI Test | PP | 5.14 | Design, Build & Test (PIT) |  | Complete | COMPLETE | T3-DB-0168 | SITAG | T3 |  |
| 374 | 1.3.6.3.4.4 | **Test Scenarios** |  | 20d | 2023-10-05 A | 2023-11-02 A |  | 100% | 2023-10-05 | 2023-11-02 | 20d | 2022-10-31 | 2023-10-20 |  |  |  | N/A | 160h | 160h | -0 | N/A | N/A | 5.0 | Design, Build & Test (PIT) |  |  |  |  |  |  |  |
| 375 | 1.3.6.3.4.4.1 | All SIT Suppliers test scenarios' submitted to Programme for assurance | milestone | 0d | 2023-10-05 A | 2023-10-05 A | 367FS+15d | 100% | 2023-10-05 | 2023-10-05 | 0d | 2023-10-06 | 2023-10-06 |  |  |  | Lee Cox |  |  |  | PP | SI Test | 5.8 | Design, Build & Test (PIT) |  | Complete | COMPLETE | T3-DB-0037 | SITAG | T3 |  |
| 376 | 1.3.6.3.4.4.2 | All SIT Suppliers Test scenarios' MHHS Review Completed | milestone | 0d | 2023-11-02 A | 2023-11-02 A | 375FS+20d | 100% | 2023-11-02 | 2023-11-02 | 0d | 2023-10-09 | 2023-10-20 |  |  |  | Lee Cox |  |  |  | SI Test | PP | 5.14 | Design, Build & Test (PIT) |  | Complete | COMPLETE | T3-DB-0169 | SITAG | T3 |  |
| 377 | 1.3.6.3.4.5 | **PIT execution** |  | 51d | 2023-10-13 A | 2023-12-22 A |  | 100% | 2022-10-31 | 2023-12-22 | 300d | 2022-10-31 | 2023-12-08 |  |  |  | N/A | 1056h | 1056h | -0 | N/A | N/A | 5.0 | Design, Build & Test (PIT) |  |  |  |  |  |  |  |
| 378 | 1.3.6.3.4.5.1 | PIT Test Execution Progress Report |  | 40d | 2023-10-16 A | 2023-12-08 A | 375FS+5d, 370 | 100% | 2023-10-16 | 2023-12-08 | 40d | 2022-10-31 | 2023-12-01 |  |  |  | Lee Cox | 320h | 320h |  | PP | SI Test | 5.0 | Design, Build & Test (PIT) |  | Complete | COMPLETE |  |  |  |  |
| 379 | 1.3.6.3.4.5.2 | PIT Execution |  | 41d | 2023-10-13 A | 2023-12-08 A | 375FS+5d | 100% | 2022-10-31 | 2023-12-08 | 290d | 2022-10-31 | 2023-12-08 |  |  |  | Lee Cox | 328h | 328h |  | PP | SI Test | 5.0 | Design, Build & Test (PIT) |  | Complete | COMPLETE |  |  |  |  |
| 380 | 1.3.6.3.4.5.3 | All SIT Suppliers PIT Completion Reports submitted to Programme for assurance | milestone | 0d | 2023-12-08 A | 2023-12-08 A | 379, 378 | 100% | 2023-12-08 | 2023-12-08 | 0d | 2024-01-05 | 2024-01-05 |  |  |  | Lee Cox |  |  |  | PP | SI Test | 5.14 | Design, Build & Test (PIT) |  | Complete | COMPLETE | T3-DB-0170 | SITAG | T3 |  |
| 381 | 1.3.6.3.4.5.4 | All SIT Suppliers PIT Completion Reports MHHS Review Completed | milestone | 0d | 2023-12-22 A | 2023-12-22 A | 380FS+10d, 368, 373, 376 | 100% | 2023-12-22 | 2023-12-22 | 0d |  |  |  |  |  | Lee Cox |  |  |  | SI Test | PP | 5.14 |  |  | Complete | COMPLETE | T3-DB-0171 | SITAG | T3 |  |
| 382 | 1.3.6.3.5 | **All LDSO Network Operations DBT CIT (Entering at Interval 5)** |  | 71d | 2023-09-15 A | 2023-12-22 A |  | 100% | 2022-10-31 | 2024-01-05 | 310d | 2022-10-31 | 2025-03-14 |  |  |  | N/A | 2688h | 2688h | -0 | N/A | N/A | 5.0 | Design, Build & Test (PIT) |  |  |  |  |  |  |  |
| 383 | 1.3.6.3.5.1 | **Test Approach & Plan** |  | 71d | 2023-09-15 A | 2023-12-22 A |  | 100% | 2022-10-31 | 2024-01-05 | 310d | 2022-10-31 | 2023-08-11 |  |  |  | N/A | 2120h | 2120h | -0 | N/A | N/A | 5.0 | Design, Build & Test (PIT) |  |  |  |  |  |  |  |
| 384 | 1.3.6.3.5.1.1 | All Network Operation Test Approach & Plans (PIT) submitted to Programme for assurance | milestone | 0d | 2023-09-15 A | 2023-09-15 A |  | 100% | 2023-09-15 | 2023-09-15 | 0d | 2023-07-28 | 2023-07-28 |  |  | start no earlier than 2023-09-15 | Lee Cox |  |  |  | PP | SI Test | 5.8 | Design, Build & Test (PIT) |  | Complete | COMPLETE | T3-DB-0054 | SITAG | T3 |  |
| 385 | 1.3.6.3.5.1.2 | All Network Operation Test Approach & Plans MHHS Review Completed | milestone | 0d | 2023-10-12 A | 2023-10-12 A | 384FS+20d | 100% | 2023-10-12 | 2023-10-12 | 0d | 2023-07-31 | 2023-08-11 |  |  |  | Lee Cox |  |  |  | SI Test | PP | 5.8 | Design, Build & Test (PIT) |  | Complete | COMPLETE | T3-DB-0172 | SITAG | T3 |  |

Notes:
- 363: 1/9 - to be raised as new T3 at TMAG. Approved at TMAG on 20/9. 9/10 - Submit to TMAG for name change to remove IT. Approved for date change at TMAG on 23/10/23
- 364: 1/9 - to be raised as new T3 at TMAG. Approved at TMAG on 20/9.
- 367: 12/9 - TMAG for name change Red because 7/9 received. Approved at TMAG on 20/9
- 368: 7/11 - Red due to high volume to be reviewed. Date change under consideration. Initial reviews complete. Final review will be completed no later than 08/01/24 ahead of Interval 5 Readiness Assessment
- 372: 12/9 - TMAG for name change. Approved at TMAG on 20/9. 10/10 - Red because small number of RTTMs still outstanding
- 373: 17/10 - Red because open comments still outstanding. Assurance reviews complete. Review will be completed no later than 08/01/24 ahead of Interval 5 Readiness Report . Completed on 14/12
- 375: 12/9 - TMAG for name change. Approved at TMAG on 20/9. 10/10 - Red because small number of Test Scenarios still outstanding
- 376: 1/9 - to be raised as new T3 at TMAG. Approved at TMAG on 20/9. 17/10 - Red due to high volume and backlog to be reviewed. Review will be completed no later than 08/01/24 ahead of Interval 5 Readiness Report. Completed 14/12
- 380: 1/9 - to be raised as new T3 at TMAG. Approved at TMAG on 20/9. 12/12 - Red because not all received. No impact as of yet. No action. Completed 12/12
- 381: 1/9 - to be raised as new T3 at TMAG. Approved at TMAG on 20/9. 12/12 - Amber because not all artefacts received. No impact. No action. Completed 15/12
- 384: 12/9 - TMAG for name and date change Red because only received 1/2 test approach and plans. Approved at TMAG on 20/9
- 385: 11/9 - to be raised as new T3 at TMAG. Approved at TMAG on 20/9. Red due to high volume to be reviewed. Date change under consideration. Review will be completed no later than 08/01/24 ahead of Interval 5 Readiness Assessment

| ID | WBS | Task | Type | Duration | Start | Finish | Predecessors | Complete | Actual finish | Baseline start | Baseline finish | Baseline duration | Baseline 1 start | Baseline 1 finish | Constraint | Resources | Work | Actual work | Baseline cost | Responsible | Involved | Update Version | MHHS Programme Phase | Sched Status | RAG | Artefact ID | Milestone ID | Text29 | Tier |
| --- | --- | --- | --- | --- | --- | --- | --- | --- | --- | --- | --- | --- | --- | --- | --- | --- | --- | --- | --- | --- | --- | --- | --- | --- | --- | --- | --- | --- | --- |
| 386 | 1.3.6.3.5.1.3 | **Test Readiness Report** |  | 11d | 2023-09-29 A | 2023-10-13 A |  | 100% |  | 2023-08-11 | 2023-10-20 | 51d | 2023-08-11 | 2023-10-20 |  | N/A | 176h | 176h |  | N/A | N/A | 5.0 | Design, Build & Test (PIT) |  |  |  |  |  |  |
| 387 | 1.3.6.3.5.1.3.1 | Test readiness reporting |  | 11d | 2023-09-29 A | 2023-10-13 A | 384FS+10d | 100% |  | 2023-08-11 | 2023-10-20 | 51d | 2023-08-11 | 2023-10-20 |  | Lee Cox | 88h | 88h |  | PP | 109 | 5.0 | Design, Build & Test (PIT) | Complete | COMPLETE |  |  |  |  |
| 388 | 1.3.6.3.5.1.4 | **Requirements to test Traceability Matrix (RTTM)** |  | 20d | 2023-10-05 A | 2023-11-02 A |  | 100% |  | 2023-10-05 | 2023-11-02 | 20d | 2022-10-31 | 2023-09-15 |  | N/A | 160h | 160h | -0 | N/A | N/A | 5.0 | Design, Build & Test (PIT) |  |  |  |  |  |  |
| 389 | 1.3.6.3.5.1.4.1 | All Network Operation RTTMs submitted to Programme for assurance | milestone | 0d | 2023-10-05 A | 2023-10-05 A | 384FS+15d | 100% |  | 2023-10-05 | 2023-10-05 | 0d | 2023-09-01 | 2023-09-01 | start no earlier than 2023-04-28 | Lee Cox |  |  |  | PP | SI Test | 5.8 | Design, Build & Test (PIT) | Complete | COMPLETE | MHHS-ART009 | T3-DB-0062 | SITAG | T3 |
| 390 | 1.3.6.3.5.1.4.2 | All Network Operation RTTMs MHHS Review Completed | milestone | 0d | 2023-11-02 A | 2023-11-02 A | 389FS+20d | 100% |  | 2023-11-02 | 2023-11-02 | 0d | 2023-09-04 | 2023-09-15 |  | Lee Cox |  |  |  | SI Test | PP | 5.14 | Design, Build & Test (PIT) | Complete | COMPLETE |  | T3-DB-0173 | SITAG | T3 |
| 391 | 1.3.6.3.5.1.5 | **Test Scenarios** |  | 20d | 2023-10-05 A | 2023-11-02 A |  | 100% |  | 2023-10-05 | 2023-11-02 | 20d | 2022-10-31 | 2023-09-15 |  | N/A | 160h | 160h | -0 | N/A | N/A | 5.0 | Design, Build & Test (PIT) |  |  |  |  |  |  |
| 392 | 1.3.6.3.5.1.5.1 | All Network Operation test scenarios' submitted to Programme for assurance | milestone | 0d | 2023-10-05 A | 2023-10-05 A | 384FS+15d | 100% |  | 2023-10-05 | 2023-10-05 | 0d | 2023-09-01 | 2023-09-01 |  | Lee Cox |  |  |  | PP | SI Test | 5.8 | Design, Build & Test (PIT) | Complete | COMPLETE |  | T3-DB-0011 | SITAG | T3 |
| 393 | 1.3.6.3.5.1.5.2 | All Network Operation test scenarios' MHHS Review Completed | milestone | 0d | 2023-11-02 A | 2023-11-02 A | 392FS+20d | 100% |  | 2023-11-02 | 2023-11-02 | 0d | 2023-09-04 | 2023-09-15 |  | Lee Cox |  |  |  | SI Test | PP | 5.14 | Design, Build & Test (PIT) | Complete | COMPLETE |  | T3-DB-0174 | SITAG | T3 |
| 394 | 1.3.6.3.5.1.6 | **PIT execution** |  | 51d | 2023-10-13 A | 2023-12-22 A |  | 100% |  | 2022-10-31 | 2024-01-05 | 310d | 2022-10-31 | 2024-01-05 |  | N/A | 1056h | 1056h | -0 | N/A | N/A | 5.0 | Design, Build & Test (PIT) |  |  |  |  |  |  |
| 395 | 1.3.6.3.5.1.6.1 | PIT Test Execution Progress Report |  | 40d | 2023-10-16 A | 2023-12-08 A | 392FS+5d, 387 | 100% |  | 2022-10-31 | 2023-12-29 | 305d | 2022-10-31 | 2023-12-29 |  | Lee Cox | 320h | 320h |  | PP | SI Test | 5.0 | Design, Build & Test (PIT) | Complete | COMPLETE |  |  |  |  |
| 396 | 1.3.6.3.5.1.6.2 | PIT Execution |  | 41d | 2023-10-13 A | 2023-12-08 A | 392FS+5d | 100% |  | 2022-10-31 | 2024-01-05 | 310d | 2022-10-31 | 2024-01-05 |  | Lee Cox | 328h | 328h |  | PP | SI Test | 5.0 | Design, Build & Test (PIT) | Complete | COMPLETE |  |  |  |  |
| 397 | 1.3.6.3.5.1.6.3 | All Network Operation PIT (CIT interval 5) Completion Reports submitted to Programme for assurance | milestone | 0d | 2023-12-08 A | 2023-12-08 A | 396, 395 | 100% |  | 2023-12-08 | 2023-12-08 | 0d | 2024-01-05 | 2024-01-05 |  | Lee Cox |  |  |  | PP | SI Test | 5.0 | Design, Build & Test (PIT) | Complete | COMPLETE |  | T3-DB-0175 | SITAG | T3 |
| 398 | 1.3.6.3.5.1.6.4 | All Network Operation PIT (CIT interval 5) Completion Reports MHHS Review Completed | milestone | 0d | 2023-12-22 A | 2023-12-22 A | 397FS+10d, 385, 390, 393 | 100% |  | 2023-12-22 | 2023-12-22 | 0d |  |  |  | Lee Cox |  |  |  | SI Test | PP | 5.15 |  | Complete | COMPLETE |  | T3-DB-0176 | SITAG | T3 |
| 399 | 1.3.6.3.6 | **All UMSO DBT CIT (Entering at Interval 6)** |  | 81d | 2023-09-29 A | 2024-01-19 A |  | 100% |  | 2022-10-31 | 2024-01-19 | 320d | 2022-10-31 | 2024-05-13 |  | N/A | 2352h | 2352h | -0 | N/A | N/A | 5.0 | Design, Build & Test (PIT) |  |  |  |  |  |  |
| 400 | 1.3.6.3.6.1 | **Test Approach & Plan** |  | 20d | 2023-10-13 A | 2023-11-09 A |  | 100% |  | 2023-09-15 | 2023-11-09 | 40d | 2022-10-31 | 2023-09-29 |  | N/A | 160h | 160h | -0 | N/A | N/A | 5.0 | Design, Build & Test (PIT) |  |  |  |  |  |  |
| 401 | 1.3.6.3.6.1.1 | All UMSO Test Approach & Plans (PIT) submitted to Programme for assurance | milestone | 0d | 2023-10-13 A | 2023-10-13 A |  | 100% |  | 2023-09-15 | 2023-09-15 | 0d | 2023-09-15 | 2023-09-15 | start no earlier than 2023-10-13 | Lee Cox |  |  |  | PP | SI Test | 5.11 | Design, Build & Test (PIT) | Complete | COMPLETE |  | T3-DB-0052 | SITAG | T3 |
| 402 | 1.3.6.3.6.1.2 | All UMSO Test Approach & Plans MHHS Review Completed | milestone | 0d | 2023-11-09 A | 2023-11-09 A | 401FS+20d | 100% |  | 2023-11-09 | 2023-11-09 | 0d | 2023-09-18 | 2023-09-29 |  | Lee Cox |  |  |  | SI Test | PP | 5.10 | Design, Build & Test (PIT) | Complete | COMPLETE |  | T3-DB-0177 | SITAG | T3 |
| 403 | 1.3.6.3.6.2 | **Test Readiness Report** |  | 11d | 2023-09-29 A | 2023-10-13 |  | 100% | 2023-11-10 | 2023-10-27 | 2023-11-10 | 11d | 2023-09-29 | 2023-12-08 |  | N/A | 176h | 176h | -0 | N/A | N/A | 5.0 | Design, Build & Test (PIT) |  |  |  |  |  |  |
| 404 | 1.3.6.3.6.2.1 | Test readiness reporting |  | 11d | 2023-10-27 A | 2023-11-10 A | 401FS+10d | 100% |  | 2023-10-27 | 2023-11-10 | 11d | 2023-09-29 | 2023-12-08 |  | Lee Cox | 88h | 88h |  | PP | 109 | 5.0 | Design, Build & Test (PIT) | Complete | COMPLETE |  |  |  |  |
| 405 | 1.3.6.3.6.3 | **Requirements to test Traceability Matrix (RTTM)** |  | 20d | 2023-10-05 A | 2023-11-01 |  | 100% | 2023-11-30 | 2023-11-02 | 2023-11-30 | 20d | 2022-10-31 | 2023-10-20 |  | N/A | 160h | 160h | -0 | N/A | N/A | 5.0 | Design, Build & Test (PIT) |  |  |  |  |  |  |
| 406 | 1.3.6.3.6.3.1 | All UMSO RTTMs submitted to Programme for assurance | milestone | 0d | 2023-11-02 A | 2023-11-02 A | 401FS+15d | 100% |  | 2023-11-02 | 2023-11-02 | 0d | 2023-10-06 | 2023-10-06 |  | Lee Cox |  |  |  | PP | SI Test | 5.12 | Design, Build & Test (PIT) | Complete | COMPLETE | MHHS-ART009 | T3-DB-0060 | SITAG | T3 |
| 407 | 1.3.6.3.6.3.2 | All UMSO RTTMs MHHS Review Completed | milestone | 0d | 2023-11-30 A | 2023-11-30 A | 406FS+20d | 100% |  | 2023-11-30 | 2023-11-30 | 0d | 2023-10-09 | 2023-10-20 |  | Lee Cox |  |  |  | SI Test | PP | 5.12 | Design, Build & Test (PIT) | Complete | COMPLETE |  | T3-DB-0178 | SITAG | T3 |
| 408 | 1.3.6.3.6.4 | **Test Scenarios** |  | 20d | 2023-10-05 A | 2023-11-01 |  | 100% | 2023-11-30 | 2023-11-02 | 2023-11-30 | 20d | 2022-10-31 | 2023-10-20 |  | N/A | 160h | 160h | -0 | N/A | N/A | 5.0 | Design, Build & Test (PIT) |  |  |  |  |  |  |
| 409 | 1.3.6.3.6.4.1 | All UMSO test scenarios' submitted to Programme for assurance | milestone | 0d | 2023-11-02 A | 2023-11-02 A | 401FS+15d | 100% |  | 2023-11-02 | 2023-11-02 | 0d | 2023-10-06 | 2023-10-06 |  | Lee Cox |  |  |  | PP | SI Test | 5.12 | Design, Build & Test (PIT) | Complete | COMPLETE |  | T3-DB-0025 | SITAG | T3 |
| 410 | 1.3.6.3.6.4.2 | All UMSO Test scenarios' MHHS Review Completed | milestone | 0d | 2023-11-30 A | 2023-11-30 A | 409FS+20d | 100% |  | 2023-11-30 | 2023-11-30 | 0d | 2023-10-09 | 2023-10-20 |  | Lee Cox |  |  |  | SI Test | PP | 5.10 | Design, Build & Test (PIT) | Complete | COMPLETE |  | T3-DB-0179 | SITAG | T3 |

Notes:
- 389: 12/9 - TMAG for name and date change Approved at TMAG on 20/9. 10/10 - Red because 50% of RTTMs outstanding
- 390: 17/10 - Red because open comments still outstanding. Assurance reviews complete. Review will be completed no later than 08/01/24 ahead of Interval 5 Readiness Report . 19/12 - completed 14/12
- 392: 12/9 - TMAG for name and date change. Approved at TMAG on 20/9. 17/10 - Red because cuurently 50% have been received. Date change under consideration.
- 393: 17/10 - Red because open comments still outstanding. Assurance reviews complete. Review will be completed no later than 08/01/24 ahead of Interval 5 Readiness Assessment . 19/12 - completed 14/12
- 397: 11/9 - to be raised as new T3 at TMAG. Approved at TMAG on 20/9. 19/12 - completed 14/12
- 398: 11/9 - to be raised as new T3 at TMAG. Approved at TMAG on 20/9. 12/12 - Amber because all reviews complete, clarifications are requested
- 401: 12/9 - TMAG for name and date change. Approved at TMAG on 20/9. 17/10 - Red because not all received. Currently no impact. Issuance request sent. Complete 1/11
- 402: To go to TMAG for date change. Approved for date change at TMAG on 23/10/23. 7/11-Amber because of high volume and backlog to be reviewed. Review will be completed no later than 22/01/24 ahead of Interval 6 Readiness Assessment
- 406: 4/10 - Red because baseline date incorrect. To go to TMAG for date change. Approved for date change at TMAG on 23/10/23. 14/11-Red because up to 50% not received. No impact. No action
- 407: 1/9 - to be raised as new T3 at TMAG. Approved at TMAG on 20/9. 4/10 - Red because baseline date incorrect. To go to TMAG for date change. Approved for date change at TMAG on 23/10/23
- 409: Approved at TMAG on 20/9. 4/10 - Red because baseline date incorrect. To go to TMAG for date change. Approved for date change at TMAG on 23/10/23. 7/11-Red because not received. Expected 10/11. No imact No action
- 410: 1/9 - to be raised as new T3 at TMAG. Approved at TMAG on 20/9. 5/12 - Assurance review conducted, but outstanding comments to be addressed

| ID | WBS | Task | Type | Duration | Start | Finish | Predecessors | Complete | Remaining | Baseline start | Baseline finish | Baseline duration | Baseline 1 start | Baseline 1 finish | Total slack | Constraint | Resources | Work | Actual work | Baseline cost | Responsible | Involved | Update Version | MHHS Programme Phase | Sched Status | RAG | Milestone ID | Text29 | Tier | Task Status | Artefact ID |
| --- | --- | --- | --- | --- | --- | --- | --- | --- | --- | --- | --- | --- | --- | --- | --- | --- | --- | --- | --- | --- | --- | --- | --- | --- | --- | --- | --- | --- | --- | --- | --- |
| 411 | 1.3.6.3.6.5 | **PIT execution** |  | 51d | 2023-11-10 A | 2024-01-19 A |  | 100% |  | 2022-10-31 | 2024-01-19 | 320d | 2022-10-31 | 2023-12-08 |  |  | N/A | 1048h | 1048h | -0 | N/A | N/A | 5.0 | Design, Build & Test (PIT) |  |  |  |  |  |  |  |
| 412 | 1.3.6.3.6.5.1 | PIT Test Execution Progress Report |  | 40d | 2023-11-13 A | 2024-01-05 A | 409FS+5d, 404 | 100% |  | 2023-11-13 | 2024-01-05 | 40d | 2022-10-31 | 2023-12-01 |  |  | Lee Cox | 320h | 320h |  | PP | SI Test | 5.0 | Design, Build & Test (PIT) | Complete | COMPLETE |  |  |  |  |  |
| 413 | 1.3.6.3.6.5.2 | PIT Execution |  | 40d | 2023-11-10 A | 2024-01-04 A | 409FS+5d | 100% |  | 2022-10-31 | 2024-01-05 | 290d | 2022-10-31 | 2023-12-08 |  |  | Lee Cox | 320h | 320h |  | PP | SI Test | 5.0 | Design, Build & Test (PIT) | Complete | COMPLETE |  |  |  |  |  |
| 414 | 1.3.6.3.6.5.3 | All UMSO PIT (CIT interval 6) Completion Reports submitted to Programme for assurance | milestone | 0d | 2024-01-05 A | 2024-01-05 A | 413, 412 | 100% |  | 2024-01-05 | 2024-01-05 | 0d | 2024-01-05 | 2024-01-05 |  |  | Lee Cox |  |  |  | PP | SI Test | 5.10 | Design, Build & Test (PIT) | Complete | COMPLETE | T3-DB-0180 | SITAG | T3 |  |  |
| 415 | 1.3.6.3.6.5.4 | All UMSO PIT (CIT interval 6) Completion Reports MHHS Review Completed | milestone | 0d | 2024-01-19 A | 2024-01-19 A | 402, 407, 410, 414FS+10d | 100% |  | 2024-01-19 | 2024-01-19 | 0d |  |  |  |  | Lee Cox |  |  |  | SI Test | PP | 5.10 |  | Complete | COMPLETE | T3-DB-0181 | SITAG | T3 |  |  |
| 416 | 1.3.7 | **DBT Monitoring and Assurance** |  | 842d | 2022-10-31 A | 2026-01-20 |  | 55% | 382.49d | 2022-10-31 | 2026-01-20 | 842d | 2022-10-31 | 2026-01-19 | 353d |  | N/A | 61912h | 23922.4h |  | N/A | N/A | 5.0 | Design, Build & Test (PIT) |  |  |  |  |  |  |  |
| 417 | 1.3.7.1 | **Planning and DBT Progress Monitoring of PPs** |  | 696d | 2022-10-31 A | 2025-06-30 |  | 55% | 313d | 2022-10-31 | 2025-06-30 | 696d | 2022-10-31 | 2025-06-30 | 499d |  | N/A | 11136h | 6128h |  | N/A | N/A | 5.0 | Design, Build & Test (PIT) |  |  |  |  |  | M9 |  |
| 418 | 1.3.7.1.1 | Monitor Non-SIT PPs Planning and DBT1 progress (to inform confirmation of Qualification Testing Tranche participants milestones) |  | 696d | 2022-10-31 A | 2025-06-30 | 164SS | 55% | 313d | 2022-10-31 | 2025-06-30 | 696d | 2022-10-31 | 2025-06-30 | 499d |  | Lee Cox | 5568h | 3064h |  | Code Bodies | SI Test,PPC | 5.0 | Design, Build & Test (PIT) | Green | GREEN |  |  |  |  |  |
| 419 | 1.3.7.2 | **DBT Progress Monitoring of Consequential Change** |  | 774d | 2023-02-02 A | 2026-01-20 |  | 41% | 459d | 2023-02-02 | 2026-01-20 | 774d | 2023-02-01 | 2026-01-19 | 353d |  | N/A | 12384h | 5040h |  | N/A | N/A | 5.0 | Design, Build & Test (PIT) |  |  |  |  |  | M9 |  |
| 420 | 1.3.7.2.1 | Monitor & report data cleanse progress |  | 774d | 2023-02-02 A | 2026-01-20 |  | 41% | 459d | 2023-02-02 | 2026-01-20 | 774d | 2023-02-01 | 2026-01-19 | 353d |  | Matthew Breen | 6192h | 2520h |  | SI Test | PPC | 5.0 | Design, Build & Test (PIT) | Green | GREEN |  |  |  |  |  |
| 421 | 1.3.7.3 | **Design Assurance** |  | 713d | 2022-11-14 A | 2025-08-06 |  | 64% | 254.4d | 2022-11-14 | 2025-08-06 | 713d | 2022-11-14 | 2025-08-06 | 472d |  | N/A | 20520h | 9056h |  | N/A | N/A | 5.0 | Design, Build & Test (PIT) |  |  |  |  |  | M9 |  |
| 422 | 1.3.7.3.1 | **Design Assurance Readiness Assessment Preparation** |  | 39d | 2023-02-28 A | 2023-04-21 A |  | 100% |  | 2023-02-28 | 2023-04-21 | 39d | 2023-02-28 | 2023-04-21 |  |  | N/A | 728h | 728h |  | N/A | N/A | 5.0 | Design, Build & Test (PIT) |  |  |  |  |  |  |  |
| 423 | 1.3.7.3.1.1 | Set up FTIG |  | 15d | 2023-04-03 A | 2023-04-21 A |  | 100% |  | 2023-04-03 | 2023-04-21 | 15d | 2023-04-03 | 2023-04-21 |  | must start on 2023-04-03 | Paul Pettitt | 120h | 120h |  | SI Design |  | 5.0 | Design, Build & Test (PIT) | Complete | COMPLETE |  |  |  |  |  |
| 424 | 1.3.7.3.1.2 | Produce Draft Questions |  | 10d | 2023-02-28 A | 2023-03-13 A |  | 100% |  | 2023-02-28 | 2023-03-13 | 10d | 2023-02-28 | 2023-03-13 |  | must start on 2023-02-28 | Paul Pettitt | 80h | 80h |  | SI Design |  | 5.0 | Design, Build & Test (PIT) | Complete | COMPLETE |  |  |  |  |  |
| 425 | 1.3.7.3.1.3 | Pilot with SRO |  | 1d | 2023-03-14 A | 2023-03-14 A | 424 | 100% |  | 2023-03-14 | 2023-03-14 | 1d | 2023-03-14 | 2023-03-14 |  |  | Paul Pettitt | 8h | 8h |  | SI Design |  | 5.0 | Design, Build & Test (PIT) | Complete | COMPLETE |  |  |  |  |  |
| 426 | 1.3.7.3.1.4 | Finalise questions |  | 10d | 2023-03-15 A | 2023-03-28 A | 425 | 100% |  | 2023-03-15 | 2023-03-28 | 10d | 2023-03-15 | 2023-03-28 |  |  | Paul Pettitt | 80h | 80h |  | SI Design |  | 5.0 | Design, Build & Test (PIT) | Complete | COMPLETE |  |  |  |  |  |
| 427 | 1.3.7.3.1.5 | Prepare on-line RA tooling |  | 10d | 2023-03-29 A | 2023-04-11 A | 426 | 100% |  | 2023-03-29 | 2023-04-11 | 10d | 2023-03-29 | 2023-04-11 |  |  | Paul Pettitt | 80h | 80h |  | SI Design |  | 5.0 | Design, Build & Test (PIT) | Complete | COMPLETE |  |  |  |  |  |
| 428 | 1.3.7.3.1.6 | Prepare webinar content |  | 5d | 2023-03-20 A | 2023-03-24 A | 424FS+4d | 100% |  | 2023-03-20 | 2023-03-24 | 5d | 2023-03-20 | 2023-03-24 |  |  | Paul Pettitt | 40h | 40h |  | SI Design |  | 5.0 | Design, Build & Test (PIT) | Complete | COMPLETE |  |  |  |  |  |
| 429 | 1.3.7.3.1.7 | Conduct webinar |  | 1d | 2023-03-30 A | 2023-03-30 A | 428FS+3d | 100% |  | 2023-03-30 | 2023-03-30 | 1d | 2023-03-30 | 2023-03-30 |  |  | Paul Pettitt | 8h | 8h |  | SI Design | PP | 5.0 | Design, Build & Test (PIT) | Complete | COMPLETE |  |  |  |  |  |
| 430 | 1.3.7.3.2 | **Participant Design Assurance Approach** |  | 43d | 2022-11-14 A | 2023-01-11 A |  | 100% |  | 2022-11-14 | 2023-01-11 | 43d | 2022-11-14 | 2023-01-11 |  |  | N/A | 648h | 648h |  | N/A | N/A | 5.0 | Design, Build & Test (PIT) |  |  |  |  |  |  |  |
| 431 | 1.3.7.3.2.1 | Develop document |  | 20d | 2022-11-14 A | 2022-12-09 A | 48FS+10d | 100% |  | 2022-11-14 | 2022-12-09 | 20d | 2022-11-14 | 2022-12-09 |  | start no earlier than 2022-11-14 | Paul Pettitt | 160h | 160h |  | SI Design | PP | 5.0 | Design, Build & Test (PIT) | Complete | COMPLETE |  |  |  |  |  |
| 432 | 1.3.7.3.2.2 | Review document |  | 18d | 2022-12-12 A | 2023-01-04 A | 431 | 100% |  | 2022-12-12 | 2023-01-04 | 18d | 2022-12-12 | 2023-01-04 |  |  | Paul Pettitt | 144h | 144h |  | PP | SI Design,IPA | 5.0 | Design, Build & Test (PIT) | Complete | COMPLETE |  |  |  |  |  |
| 433 | 1.3.7.3.2.3 | Participant Design Assurance Approach approved | milestone | 0d | 2023-01-11 A | 2023-01-11 A | 432FF+5d | 100% |  | 2023-01-11 | 2023-01-11 | 0d | 2023-01-11 | 2023-01-11 |  |  | Paul Pettitt |  |  |  | SI Design | PP | 5.0 | Design, Build & Test (PIT) | Complete | COMPLETE | T3-DB-0012 | DAG | T3 |  |  |
| 434 | 1.3.7.3.3 | **Phase 1 - SIT Volunteers (Core Providers)** |  | 145d | 2023-04-10 A | 2023-10-27 A |  | 100% |  | 2023-04-10 | 2023-10-27 | 145d | 2023-04-10 | 2023-10-27 |  |  | N/A | 2768h | 2768h |  | N/A | N/A | 5.0 | Design, Build & Test (PIT) |  |  |  |  |  |  |  |
| 435 | 1.3.7.3.3.1 | Send on-line questionnaire to core capability providers and current SIT volunteers (from Round 3 consultation) |  | 1d | 2023-04-10 A | 2023-04-10 A |  | 100% |  | 2023-04-10 | 2023-04-10 | 1d | 2023-04-10 | 2023-04-10 |  | must start on 2023-04-10 | Paul Pettitt | 8h | 8h |  | SI Design | PP | 5.0 | Design, Build & Test (PIT) | Complete | COMPLETE |  |  |  |  |  |
| 436 | 1.3.7.3.3.2 | Participants Provide Responses to questionnaires |  | 15d | 2023-04-11 A | 2023-05-01 A | 435 | 100% |  | 2023-04-11 | 2023-05-01 | 15d | 2023-04-11 | 2023-05-01 |  |  | Paul Pettitt | 120h | 120h |  | PP |  | 5.0 | Design, Build & Test (PIT) | Complete | COMPLETE |  |  |  |  |  |
| 437 | 1.3.7.3.3.3 | Assess on-line responses and provided evidence |  | 5d | 2023-05-02 A | 2023-05-08 A | 436 | 100% |  | 2023-05-02 | 2023-05-08 | 5d | 2023-05-02 | 2023-05-08 |  |  | Paul Pettitt | 40h | 40h |  | SI Design |  | 5.0 | Design, Build & Test (PIT) | Complete | COMPLETE |  |  |  |  |  |
| 438 | 1.3.7.3.3.4 | Bi-lateral meeting with each responder, to walk and navigate through provided materials |  | 31d | 2023-05-09 A | 2023-06-20 A | 437 | 100% |  | 2023-05-09 | 2023-06-20 | 31d | 2023-05-09 | 2023-06-20 |  |  | Paul Pettitt | 248h | 248h |  | SI Design | PP | 5.0 | Design, Build & Test (PIT) | Complete | COMPLETE |  |  |  |  |  |
| 439 | 1.3.7.3.3.5 | Plan for, create and execute deep dive assurance interviews based on agreed priorities (participants, design areas) |  | 62d | 2023-06-07 A | 2023-08-31 A | 438FS-10d | 100% |  | 2023-06-07 | 2023-08-31 | 62d | 2023-06-07 | 2023-08-01 |  |  | Paul Pettitt | 496h | 496h |  | SI Design |  | 5.2 | Design, Build & Test (PIT) | Complete | COMPLETE |  |  |  |  |  |
| 440 | 1.3.7.3.3.6 | SI endorsement of participants’ design – assurance reports |  | 43d | 2023-08-02 A | 2023-09-29 A | 439FS-22d | 100% |  | 2023-08-02 | 2023-09-29 | 43d | 2023-08-02 | 2023-08-15 |  |  | Paul Pettitt | 344h | 344h |  | SI Design |  | 5.2 | Design, Build & Test (PIT) | Complete | COMPLETE |  |  |  |  |  |
| 441 | 1.3.7.3.3.7 | Post-assurance review of recommendations take-up by assured participants |  | 44d | 2023-08-29 A | 2023-10-27 A | 440SS+19d | 100% |  | 2023-10-02 | 2023-10-27 | 20d | 2023-08-16 | 2023-10-27 |  |  | Paul Pettitt | 352h | 352h |  | SI Design |  | 5.2 | Design, Build & Test (PIT) | Complete | COMPLETE |  |  |  |  |  |
| 442 | 1.3.7.3.3.8 | Phase 1 - SIT Volunteers (Core Providers) complete | milestone | 0d | 2023-10-27 A | 2023-10-27 A | 441 | 100% |  | 2023-10-27 | 2023-10-27 | 0d | 2023-10-27 | 2023-10-27 |  |  | Paul Pettitt |  |  |  | SI Design |  | 5.11 | Design, Build & Test (PIT) | Complete | COMPLETE | T2-DB-0100 | DAG | T2 |  | MHHS-ART002 |

Notes:
- 414: . 4/10 - Red because baseline date incorrect. To go to TMAG for date change. Approved for date change at TMAG on 23/10/23. 16/1 - Not all completion reports yet received. Completed on 21/2
- 415: Red because baseline date incorrect. To go to TMAG for date change. Approved for date change at TMAG on 23/10/23. 16/01 - Late due to late delivery of PP artefacts for review. Completed on 21/2
- 418: 15/9 - hold in plan until qualification sections updated
- 420: 15/9 - query with John Wiggins where this sits
- 442: 16/10 Awaiting the issuing of backlog reports. But no significant design impacts identified. No impact to commencing SIT

| ID | WBS | Task | Type | Duration | Start | Finish | Predecessors | Complete | Remaining | Baseline start | Baseline finish | Baseline duration | Baseline 1 start | Baseline 1 finish | Total slack | Constraint | Resources | Work | Actual work | Baseline cost | Responsible | Involved | Update Version | MHHS Programme Phase | Sched Status | RAG | Artefact ID | Milestone ID | Text29 | Tier | Task Status | Text3 |
| --- | --- | --- | --- | --- | --- | --- | --- | --- | --- | --- | --- | --- | --- | --- | --- | --- | --- | --- | --- | --- | --- | --- | --- | --- | --- | --- | --- | --- | --- | --- | --- | --- |
| 443 | 1.3.7.3.4 | **Phase 2 - SIT all other participants** |  | 143d | 2023-05-08 A | 2023-11-22 A |  | 100% |  | 2023-05-08 | 2023-11-22 | 143d | 2023-05-08 | 2023-11-22 |  |  | N/A | 3552h | 3552h |  | N/A | N/A | 5.0 | Design, Build & Test (PIT) |  |  |  |  |  |  |  |  |
| 444 | 1.3.7.3.4.1 | Send on-line questionnaire to core capability providers and current SIT volunteers (from Round 3 consultation) |  | 1d | 2023-05-08 A | 2023-05-08 A |  | 100% |  | 2023-05-08 | 2023-05-08 | 1d | 2023-05-08 | 2023-05-08 |  | must start on 2023-05-08 | Paul Pettitt | 8h | 8h |  | SI Design | PP | 5.0 | Design, Build & Test (PIT) | Complete | COMPLETE |  |  |  |  |  |  |
| 445 | 1.3.7.3.4.2 | Participants Provide Responses to questionnaires |  | 15d | 2023-05-09 A | 2023-05-29 A | 444 | 100% |  | 2023-05-09 | 2023-05-29 | 15d | 2023-05-09 | 2023-05-29 |  |  | Paul Pettitt | 120h | 120h |  | PP |  | 5.0 | Design, Build & Test (PIT) | Complete | COMPLETE |  |  |  |  |  |  |
| 446 | 1.3.7.3.4.3 | Assess on-line responses and provided evidence |  | 5d | 2023-05-30 A | 2023-06-05 A | 445 | 100% |  | 2023-05-30 | 2023-06-05 | 5d | 2023-05-30 | 2023-06-05 |  |  | Paul Pettitt | 40h | 40h |  | SI Design |  | 5.0 | Design, Build & Test (PIT) | Complete | COMPLETE |  |  |  |  |  |  |
| 447 | 1.3.7.3.4.4 | Bi-lateral meeting with each responder, to walk and navigate through provided materials |  | 84d | 2023-06-06 A | 2023-09-29 A | 446 | 100% |  | 2023-06-06 | 2023-09-29 | 84d | 2023-06-06 | 2023-07-18 |  |  | Paul Pettitt | 672h | 672h |  | SI Design | PP | 5.2 | Design, Build & Test (PIT) | Complete | COMPLETE |  |  |  |  |  |  |
| 448 | 1.3.7.3.4.5 | Plan for, create and execute deep dive assurance interviews based on agreed priorities (participants, design areas) |  | 69d | 2023-06-27 A | 2023-09-29 A | 447SS+15d | 100% |  | 2023-06-27 | 2023-09-29 | 69d | 2023-07-05 | 2023-08-29 |  |  | Paul Pettitt | 552h | 552h |  | SI Design |  | 5.2 | Design, Build & Test (PIT) | Complete | COMPLETE |  |  |  |  |  |  |
| 449 | 1.3.7.3.4.6 | SI endorsement of participants’ design – assurance reports |  | 54d | 2023-07-18 A | 2023-09-29 A | 448SS+15d | 100% |  | 2023-07-18 | 2023-09-29 | 54d | 2023-08-30 | 2023-09-12 |  |  | Paul Pettitt | 432h | 432h |  | SI Design |  | 5.2 | Design, Build & Test (PIT) | Complete | COMPLETE |  |  |  |  |  |  |
| 450 | 1.3.7.3.4.7 | Post-assurance review of recommendations take-up by assured participants |  | 73d | 2023-08-14 A | 2023-11-22 A | 449SS+19d | 100% |  | 2023-10-02 | 2023-11-22 | 38d | 2023-09-13 | 2023-11-22 |  |  | Paul Pettitt | 584h | 584h |  | SI Design |  | 5.2 | Design, Build & Test (PIT) | Complete | COMPLETE |  |  |  |  |  |  |
| 451 | 1.3.7.3.4.8 | SIT PPs design assurance (excl Migration/Reverse Migration) complete | milestone | 0d | 2023-11-22 A | 2023-11-22 A | 450 | 100% |  | 2023-11-22 | 2023-11-22 | 0d | 2023-11-22 | 2023-11-22 |  |  | Paul Pettitt |  |  |  | SI Design |  | 5.11 | Design, Build & Test (PIT) | Complete | COMPLETE | MHHS-ART002 | T2-DB-0200 | DAG | T2 |  |  |
| 452 | 1.3.7.3.5 | **Non-SIT PPs design assurance** |  | 445d | 2023-11-23 A | 2025-08-06 |  | 17% | 370d | 2023-11-23 | 2025-08-06 | 445d | 2023-11-23 | 2025-08-06 | 472d |  | N/A | 7120h | 1200h |  | N/A | N/A | 5.0 | Design, Build & Test (PIT) |  |  |  |  |  |  |  |  |
| 453 | 1.3.7.3.5.1 | Non-SIT PPs design assurance (risk-based sample) |  | 445d | 2023-11-23 A | 2025-08-06 | 451 | 17% | 370d | 2023-11-23 | 2025-08-06 | 445d | 2023-11-23 | 2025-08-06 | 472d |  | Paul Pettitt | 3560h | 600h |  | SI Design | PPC | 5.0 | Design, Build & Test (PIT) | Green | GREEN |  |  |  |  |  |  |
| 454 | 1.3.7.4 | **Test Assurance** |  | 629d | 2023-02-01 A | 2025-06-30 |  | 50% | 313d | 2022-10-31 | 2025-06-30 | 696d | 2022-10-31 | 2025-06-30 | 499d |  | N/A | 10064h | 2626.4h |  | N/A | N/A | 5.0 | Design, Build & Test (PIT) |  |  |  |  |  |  | M9 |  |
| 455 | 1.3.7.4.1 | Non-SIT PPs test assurance |  | 629d | 2023-02-01 A | 2025-06-30 |  | 50% | 313d | 2023-02-01 | 2025-06-30 | 629d | 2023-02-01 | 2025-06-30 | 499d |  | Lee Cox | 5032h | 2528h |  | Code Bodies | PP,PPC,SI Test | 5.0 | Design, Build & Test (PIT) | Green | GREEN |  |  |  |  |  |  |
| 456 | 1.3.7.5 | **Pre-Qualification Guidance (PIT Guidance)** |  | 67d | 2022-10-31 A | 2023-01-31 A |  | 100% |  | 2022-10-31 | 2023-01-31 | 67d | 2022-10-31 | 2023-01-31 |  |  | N/A | 1072h | 1072h |  | N/A | N/A | 5.0 | Design, Build & Test (PIT) |  |  |  |  |  |  |  |  |
| 457 | 1.3.7.5.1 | Develop document (incl. collaboration with code bodies, as required) |  | 56d | 2022-10-31 A | 2023-01-16 A |  | 100% |  | 2022-10-31 | 2023-01-16 | 56d | 2022-10-31 | 2023-01-16 |  |  | Lee Cox | 448h | 448h |  | SI Test | Code Bodies | 5.0 | Design, Build & Test (PIT) | Complete | COMPLETE |  |  |  |  |  |  |
| 458 | 1.3.7.5.2 | Review, update and agree Pre-Qualification Guidance internally |  | 11d | 2023-01-17 A | 2023-01-31 A | 457 | 100% |  | 2023-01-17 | 2023-01-31 | 11d | 2023-01-17 | 2023-01-31 |  |  | Lee Cox | 88h | 88h |  | SRO Function | IPA,SI Test | 5.0 | Design, Build & Test (PIT) | Complete | COMPLETE |  |  |  |  |  |  |
| 459 | 1.3.7.6 | **External Programme Dependency Management** |  | 0d | 2022-11-03 A | 2022-11-03 A |  | 100% |  | 2022-11-03 | 2022-11-03 | 0d | 2022-11-03 | 2022-11-03 |  |  | N/A |  |  |  | N/A | N/A | 5.0 | Design, Build & Test (PIT) |  |  |  |  |  |  |  |  |
| 460 | 1.3.7.6.1 | **SLC47** |  | 0d | 2022-11-03 A | 2022-11-03 A |  | 100% |  | 2022-11-03 | 2022-11-03 | 0d | 2022-11-03 | 2022-11-03 |  |  | N/A |  |  |  | N/A | N/A | 5.0 | Design, Build & Test (PIT) |  |  |  |  |  |  |  |  |
| 461 | 1.3.7.6.1.1 | SLC47 implementation date | milestone | 0d | 2022-11-03 A | 2022-11-03 A |  | 100% |  | 2022-11-03 | 2022-11-03 | 0d | 2022-11-03 | 2022-11-03 |  | start no earlier than 2022-11-03 | Lee Cox |  |  |  | Ofgem |  | 5.0 | Design, Build & Test (PIT) | Complete | COMPLETE |  |  |  |  |  |  |
| 462 | 1.4 | **SYSTEMS INTEGRATION TESTING (SIT)** |  | 841d | 2022-10-31 A | 2026-01-19 |  | 49% | 430.24d | 2022-10-31 | 2026-01-19 | 841d | 2022-10-31 | 2026-01-19 | 354d |  | N/A | 296354h | 127781h | -0 | N/A | N/A |  | Systems Integration Testing (SIT) |  |  |  |  |  |  |  | 1 Aug 2023 - 30 Sep 2024 |
| 463 | 1.4.1 | **SIT Preparation** |  | 520d | 2022-10-31 A | 2024-10-25 |  | 88% | 63.3d | 2022-10-31 | 2025-03-03 | 611d | 2022-10-31 | 2025-03-10 | 675d |  | N/A | 147098h | 103873h | -0 | N/A | N/A | 5.0 | Systems Integration Testing (SIT) |  |  |  |  |  |  |  |  |
| 464 | 1.4.1.1 | **Test Artefact Development** |  | 472d | 2022-10-31 A | 2024-08-21 |  | 99% | 2.69d | 2022-10-31 | 2024-08-21 | 472d | 2022-10-31 | 2023-09-01 | 723d |  | N/A | 18208h | 11424h | -0 | N/A | N/A | 5.0 | Systems Integration Testing (SIT) |  |  |  |  |  |  | M9 |  |
| 465 | 1.4.1.1.1 | **Environment Approach & Plan** |  | 460d | 2022-11-16 A | 2024-08-21 |  | 99% | 0d | 2022-11-16 | 2024-08-21 | 460d | 2022-11-16 | 2023-06-30 | 723d |  | N/A | 4056h | 1256h | -0 | N/A | N/A | 5.0 | Systems Integration Testing (SIT) |  |  |  |  |  |  |  |  |
| 466 | 1.4.1.1.1.1 | Environment Approach & Plan approved | milestone | 0d | 2022-11-16 A | 2022-11-16 A |  | 100% |  | 2022-11-16 | 2022-11-16 | 0d | 2022-11-16 | 2022-11-16 |  | start no earlier than 2022-11-16 | Simon Berry |  |  |  | SI Test | PP | 5.0 | Systems Integration Testing (SIT) | Complete | COMPLETE | MHHS-ART139 | T3-TE-0010 | SITAG | T3 |  |  |
| 467 | 1.4.1.1.1.2 | Environment Approach & Plan - Work Off |  | 157d | 2022-11-17 A | 2023-06-23 A | 466FS+1d | 100% |  | 2022-11-17 | 2023-06-23 | 157d | 2022-11-17 | 2023-06-23 |  |  | Simon Berry | 1256h | 1256h |  | SI Test | PP | 5.0 | Systems Integration Testing (SIT) | Complete | COMPLETE |  |  |  |  |  |  |
| 468 | 1.4.1.1.1.3 | Environment Approach & Plan - Work Off Approved | milestone | 0d | 2023-08-16 A | 2023-08-16 A | 467FS+5d | 100% |  | 2023-08-16 | 2023-08-16 | 0d | 2023-06-30 | 2023-06-30 |  | start no earlier than 2023-08-16 | Simon Berry |  |  |  | SI Test | PP | 5.0 | Systems Integration Testing (SIT) | Complete | COMPLETE | MHHS-ART139 | T3-TE-0068 | SITAG | T3 |  |  |
| 469 | 1.4.1.1.1.4 | Environment Approach and Plan - SIT Functional | milestone | 0d | 2023-11-20 A | 2023-11-20 A |  | 100% |  | 2023-11-15 | 2023-11-15 | 0d |  |  |  | start no earlier than 2023-11-20 | Simon Berry |  |  |  | SI Test | PP | 5.12 | Systems Integration Testing (SIT) | Complete | COMPLETE | MHHS-DEL 618 | T3-TE-0090 | SITAG | T3 |  |  |
| 470 | 1.4.1.1.1.5 | Define Approach to Simulator for Non-SIT LDSO | milestone | 0d | 2023-11-15 A | 2023-11-15 A |  | 100% |  | 2023-11-15 | 2023-11-15 | 0d |  |  |  | start no earlier than 2023-11-15 | Simon Berry |  |  |  | SI Test | PP | 5.12 |  | Complete | COMPLETE |  |  |  |  |  |  |
| 471 | 1.4.1.1.1.6 | Environment Approach and Plan - Non SIT LDSO Testing | milestone | 0d | 2024-04-17 A | 2024-04-17 A |  | 100% |  | 2024-04-17 | 2024-04-17 | 0d |  |  |  | start no earlier than 2024-04-17 | Simon Berry |  |  |  | SI Test | PP | 5.22 | Systems Integration Testing (SIT) | Complete | COMPLETE | MHHS-DEL 619 | T3-TE-0091 | SITAG/QAG | T3 |  |  |
| 472 | 1.4.1.1.1.7 | Environment Approach and Plan - S and A Testing | milestone | 0d | 2024-07-17 | 2024-07-17 |  |  |  | 2024-07-17 | 2024-07-17 | 0d |  |  | 748d | start no earlier than 2024-07-17 | Simon Berry |  |  |  | SI Test | PP | 5.22 | Systems Integration Testing (SIT) | Green | GREEN | MHHS-DEL 619 | T3-TE-0120 | SITAG/QAG | T3 | 90.33 |  |
| 473 | 1.4.1.1.1.8 | Environment Approach and Plan - SIT Non Functional | milestone | 0d | 2024-06-19 | 2024-06-19 |  |  |  | 2024-06-19 | 2024-06-19 | 0d |  |  | 768d | start no earlier than 2024-06-19 | Simon Berry |  |  |  | SI Test | PP | 5.22 | Systems Integration Testing (SIT) | Green | GREEN | MHHS-DEL 620 | T3-TE-0092 | SITAG | T3 | 62.33 |  |
| 474 | 1.4.1.1.1.9 | Environment Approach and Plan - Sandbox | milestone | 0d | 2024-08-21 | 2024-08-21 |  |  |  | 2024-08-21 | 2024-08-21 | 0d |  |  | 723d | start no earlier than 2024-08-21 | Simon Berry |  |  |  | SI Test | PP | 5.21 | Systems Integration Testing (SIT) | Green | GREEN | MHHS-DEL 621 | T3-TE-0093 | SITAG/QAG | T3 | 125.33 |  |

Notes:
- 450: 6/11 - last report sent out 27/10
- 451: 6/11 - last report sent out 27/10
- 455: 15/9 - keep in plan until qualification reviewed
- 463: Action: 11/3: Ask simon B for the link (line 1312) dip onboarding to non sit ldso
- 465: Action: 16/8 - add to milestone register. Build out detail further
- 466: Action: 25/7 - Simon to provide update
- 467: Action: 25/7 - Simon to provide update
- 468: Action: 25/7 - Simon to provide update
- 469: The LDSO element is on hold whilst discussions are being held between Programme and Code Bodies re: LDSO testing. When concluded, that update will be re-planned by agreement with TMAG. 20/11- Approved at TMAG / Action: 16/8 - add to milestone register. Build out detail further
- 471: 25/3: Name and date change approved at QAG on 21/3/24. 25/03: To go to Apr QAG for name change as Non-SIT LDSO and S and A will deliver on different timelines so '& S and A' will be removed. 17/4: Approved for name change at SITAG on 17/4/24 / Action: 16/8 - add to milestone register. Build out detail further
- 472: 25/3: Name and date change approved at QAG on 21/3/24. 25/03: New milestone to go to Apr QAG as Non-SIT LDSO and S and A will deliver on different timelines so need to create a new milestone for S and A. 17/4: Approved as new mileston at SITAG on 17/4/24 / Action: 16/8 - add to milestone register. Build out detail further
- 473: 26/3/24: To go to April SITAG for date change approval. Because of dependency on NF test approach and plan. Currently under PP review 17/4: Approved date change at SITAG on 17/4/24 / Action: 16/8 - add to milestone register. Build out detail further
- 474: 30/1 - Qualification Testing approach being developed. Environment requirements will follow that test approach. Name change to remove 'qualification and' to reflect sandbox only scope. Name and date change approved at QAG on 21/3/24 / Action: 16/8 - add to milestone register. Build out detail further

| ID | WBS | Task | Type | Duration | Start | Finish | Predecessors | Complete | Remaining | Baseline start | Baseline finish | Baseline duration | Baseline 1 start | Baseline 1 finish | Total slack | Free slack | Constraint | Resources | Work | Actual work | Baseline cost | Responsible | Involved | Update Version | MHHS Programme Phase | Sched Status | RAG | Action | Task Status | Milestone ID | Text29 | Tier |
| --- | --- | --- | --- | --- | --- | --- | --- | --- | --- | --- | --- | --- | --- | --- | --- | --- | --- | --- | --- | --- | --- | --- | --- | --- | --- | --- | --- | --- | --- | --- | --- | --- |
| 475 | 1.4.1.1.2 | **Overarching Test Scope (for all stages)** |  | 65d | 2022-10-31 A | 2023-01-27 A |  | 100% |  | 2022-10-31 | 2023-06-30 | 175d | 2022-10-31 | 2023-06-30 |  |  |  | N/A | 1560h | 1560h |  | N/A | N/A | 5.0 | Systems Integration Testing (SIT) |  |  |  |  |  |  |  |
| 476 | 1.4.1.1.2.1 | **Overarching Test Scope (excl. Migration/Reverse Migration, NFT and Ops components)** |  | 65d | 2022-10-31 A | 2023-01-27 A |  | 100% |  | 2022-10-31 | 2023-01-27 | 65d | 2022-10-31 | 2023-01-27 |  |  |  | N/A | 1040h | 1040h |  | N/A | N/A | 5.0 | Systems Integration Testing (SIT) |  |  |  |  |  |  |  |
| 477 | 1.4.1.1.2.1.1 | Develop document (excl Migration/Reverse Migration, NFT and Ops components) |  | 55d | 2022-10-31 A | 2023-01-13 A | 48 | 100% |  | 2022-10-31 | 2023-01-13 | 55d | 2022-10-31 | 2023-01-13 |  |  |  | Lee Cox | 440h | 440h |  | SI Test |  | 5.0 | Systems Integration Testing (SIT) | Complete | COMPLETE |  |  |  |  |  |
| 478 | 1.4.1.1.2.1.2 | Review, update & agree document (excl Migration/Reverse Migration, NFT and Ops components) |  | 10d | 2023-01-16 A | 2023-01-27 A | 477 | 100% |  | 2023-01-16 | 2023-01-27 | 10d | 2023-01-16 | 2023-01-27 |  |  |  | Lee Cox | 80h | 80h |  | SI Test | IPA,Code Bodies,PP | 5.0 | Systems Integration Testing (SIT) | Complete | COMPLETE |  |  |  |  |  |
| 479 | 1.4.1.1.2.2 | **Updated Overarching Test Scope (incl. Migration/Reverse Migration, NFT and Ops components)** | inactive | 45d | 2023-05-01 | 2023-06-30 |  |  |  | 2023-05-01 | 2023-06-30 | 45d | 2023-05-01 | 2023-06-30 | 1020d |  |  | N/A | 720h |  |  | N/A | N/A | 5.21 | Systems Integration Testing (SIT) |  |  |  |  |  |  |  |
| 480 | 1.4.1.1.2.2.1 | Develop Migration/Reverse Migration, NFT and Ops components of document | inactive | 40d | 2023-05-01 | 2023-06-23 | 1806 |  |  | 2023-05-01 | 2023-06-23 | 40d | 2023-05-01 | 2023-06-23 | 1020d | 0d |  | Lee Cox | 320h |  |  | SI Test |  | 5.21 | Systems Integration Testing (SIT) |  | RED | 25/7 - Kate goodman gave SIT doc to Kevin? | -352.67 |  |  |  |
| 481 | 1.4.1.1.2.2.2 | Review, update & agree Migration/Reverse Migration, NFT and Ops components of document | inactive | 5d | 2023-06-26 | 2023-06-30 | 480 |  |  | 2023-06-26 | 2023-06-30 | 5d | 2023-06-26 | 2023-06-30 | 1020d |  |  | Lee Cox | 40h |  |  | SI Test | IPA,Code Bodies,PP | 5.21 | Systems Integration Testing (SIT) |  | RED | 25/7 - Kate goodman gave SIT doc to Kevin? | -296.67 |  |  |  |
| 482 | 1.4.1.1.3 | **Configuration and Release Management Approach & Plan** |  | 164d | 2022-11-01 A | 2023-06-16 A |  | 100% |  | 2022-11-01 | 2023-06-16 | 164d | 2022-11-01 | 2023-04-28 |  |  |  | N/A | 2368h | 2368h |  | N/A | N/A | 5.0 | Systems Integration Testing (SIT) |  |  |  | M9 |  |  |  |
| 483 | 1.4.1.1.3.1 | Develop document |  | 69d | 2022-11-01 A | 2023-06-16 A |  | 100% |  | 2022-11-01 | 2023-06-16 | 69d | 2022-11-01 | 2023-01-31 |  |  | start no earlier than 2022-11-01 | Simon Berry | 552h | 552h |  | SI Test |  | 5.0 | Systems Integration Testing (SIT) | Complete | COMPLETE |  |  |  |  |  |
| 484 | 1.4.1.1.3.2 | Review, update and agree Configuration and Release Management Approach & Plan internally |  | 63d | 2023-02-01 A | 2023-04-28 A | 483 | 100% |  | 2023-02-01 | 2023-04-28 | 63d | 2023-02-01 | 2023-04-28 |  |  |  | Simon Berry | 504h | 504h |  | SRO Function | IPA,SI Test | 5.0 | Systems Integration Testing (SIT) | Complete | COMPLETE |  |  |  |  |  |
| 485 | 1.4.1.1.4 | **Test Data Overarching Approach & Plan** |  | 179d | 2022-11-14 A | 2023-07-20 A |  | 100% |  | 2022-11-14 | 2023-07-20 | 179d | 2022-11-14 | 2023-05-18 |  |  |  | N/A | 2840h | 2840h |  | N/A | N/A | 5.0 | Systems Integration Testing (SIT) |  |  |  | M9 |  |  |  |
| 486 | 1.4.1.1.4.1 | Develop document |  | 20d | 2022-11-14 A | 2022-12-09 A |  | 100% |  | 2022-11-14 | 2022-12-09 | 20d | 2022-11-14 | 2022-12-09 |  |  | start no earlier than 2022-11-14 | Cesar Lopes | 160h | 160h |  | SI Test | PP | 5.0 | Systems Integration Testing (SIT) | Complete | COMPLETE |  |  |  |  |  |
| 487 | 1.4.1.1.4.2 | Document review and update |  | 155d | 2022-12-12 A | 2023-07-14 A | 486 | 100% |  | 2022-12-12 | 2023-07-14 | 155d | 2022-12-12 | 2023-05-17 |  |  |  | Cesar Lopes | 1240h | 1240h |  | PP | SI Test,IPA | 5.0 | Systems Integration Testing (SIT) | Complete | COMPLETE |  |  |  |  |  |
| 488 | 1.4.1.1.4.3 | Test Data Overarching Approach & Plan approved by TMAG | milestone | 0d | 2023-07-19 A | 2023-07-19 A | 487FS+3d | 100% |  | 2023-07-19 | 2023-07-19 | 0d | 2023-05-17 | 2023-05-17 |  |  |  | Cesar Lopes |  |  |  | SRO Test | PP,IPA,Code Bodies | 5.0 | Systems Integration Testing (SIT) | Complete | COMPLETE |  |  | T3-TE-0072 | SITAG | T3 |
| 489 | 1.4.1.1.4.4 | Document publication final version |  | 1d | 2023-07-20 A | 2023-07-20 A | 488 | 100% |  | 2023-07-20 | 2023-07-20 | 1d | 2023-05-18 | 2023-05-18 |  |  |  | Cesar Lopes | 8h | 8h |  | SI Test |  | 5.0 | Systems Integration Testing (SIT) | Complete | COMPLETE |  |  |  |  |  |
| 490 | 1.4.1.1.5 | **Interface Code of Connection (dates subject to DIP Service Provider's plan)** |  | 48d | 2023-03-01 A | 2023-05-05 A |  | 100% |  | 2023-03-01 | 2023-05-05 | 48d | 2023-03-01 | 2023-05-05 |  |  |  | N/A | 728h | 728h |  | N/A | N/A | 5.0 | Systems Integration Testing (SIT) |  |  |  |  |  |  |  |
| 491 | 1.4.1.1.5.1 | Develop Interface Code of Connection with DIP Service Provider |  | 43d | 2023-03-01 A | 2023-04-28 A |  | 100% |  | 2023-03-01 | 2023-04-28 | 43d | 2023-03-01 | 2023-04-28 |  |  | must start on 2023-03-01 | Lee Cox | 344h | 344h |  | DIP Provider | SI Test | 5.0 | Systems Integration Testing (SIT) | Complete | COMPLETE |  |  |  |  |  |
| 492 | 1.4.1.1.5.2 | Interface Code of Connection approved at SDWG | milestone | 0d | 2023-05-05 A | 2023-05-05 A | 491FS+5d | 100% |  | 2023-05-05 | 2023-05-05 | 0d | 2023-05-05 | 2023-05-05 |  |  |  | Lee Cox |  |  |  | SI Test | PP | 5.0 | Systems Integration Testing (SIT) | Complete | COMPLETE |  |  |  |  |  |
| 493 | 1.4.1.1.6 | **Test Traceability** |  | 165d | 2023-06-01 A | 2024-01-17 |  | 98% | 2.71d | 2023-06-01 | 2024-01-17 | 165d | 2023-06-01 | 2023-09-01 | 813d |  |  | N/A | 3760h | 2576h | -0 | N/A | N/A | 5.0 | Systems Integration Testing (SIT) |  |  |  |  |  |  |  |
| 494 | 1.4.1.1.6.1 | RTM containing Method Statement Implied Requirements into Azure DevOps |  | 22d | 2023-06-01 A | 2023-06-30 A |  | 100% |  | 2023-06-01 | 2023-06-30 | 22d | 2023-06-01 | 2023-06-30 |  |  | must start on 2023-06-01 | Lee Cox | 176h | 176h |  | SI Test |  | 5.0 | Systems Integration Testing (SIT) | Complete | COMPLETE |  |  |  |  |  |
| 495 | 1.4.1.1.6.2 | RTM Containing Interface Catalogue Implied Requirements |  | 27d | 2023-06-01 A | 2023-07-07 A |  | 100% |  | 2023-06-01 | 2023-07-07 | 27d | 2023-06-01 | 2023-07-07 |  |  | must start on 2023-06-01 | Lee Cox | 216h | 216h |  | SI Test |  | 5.0 | Systems Integration Testing (SIT) | Complete | COMPLETE |  |  |  |  |  |
| 496 | 1.4.1.1.6.3 | SIT CIT Full Traceability & Coverage complete |  | 118d | 2023-07-10 A | 2023-12-20 A | 495, 494 | 100% |  | 2023-07-10 | 2023-12-08 | 110d | 2023-07-10 | 2023-07-28 |  |  |  | Lee Cox | 944h | 944h |  | SI Test |  | 5.0 | Systems Integration Testing (SIT) | Complete | COMPLETE |  |  |  |  |  |
| 497 | 1.4.1.1.6.4 | SIT Functional Full Traceability & Coverage complete |  | 138d | 2023-07-10 A | 2024-01-17 | 495, 494 | 96% | 5d | 2023-07-10 | 2024-01-17 | 138d | 2023-07-10 | 2023-09-01 | 813d | 0d |  | Lee Cox | 1104h | 1064h |  | SI Test |  | 5.0 | Systems Integration Testing (SIT) | Overdue | RED | 25/7 - Activity to be replanned |  |  |  |  |
| 498 | 1.4.1.2 | **Test Tool Development** |  | 256d | 2022-10-31 A | 2023-10-23 A |  | 100% |  | 2022-10-31 | 2023-06-30 | 175d | 2022-10-31 | 2023-06-30 |  |  |  | N/A | 11272h | 11272h |  | N/A | N/A | 5.0 | Systems Integration Testing (SIT) |  |  | 25/7 - replan from start |  |  |  |  |
| 499 | 1.4.1.2.1 | **Test Management Tool** |  | 256d | 2022-10-31 A | 2023-10-23 A |  | 100% |  | 2022-10-31 | 2023-06-30 | 175d | 2022-10-31 | 2023-06-30 |  |  |  | N/A | 9224h | 9224h |  | N/A | N/A | 5.0 | Systems Integration Testing (SIT) |  |  | 25/7 - replan from start |  |  |  |  |
| 500 | 1.4.1.2.1.1 | **Test Management Tool Implementation** |  | 256d | 2022-10-31 A | 2023-10-23 A |  | 100% |  | 2022-10-31 | 2023-06-30 | 175d | 2022-10-31 | 2023-06-30 |  |  |  | N/A | 4376h | 4376h |  | N/A | N/A | 5.0 | Systems Integration Testing (SIT) |  |  | 25/7 - replan from start |  |  |  |  |
| 501 | 1.4.1.2.1.1.1 | Requirements identification |  | 40d | 2022-10-31 A | 2022-12-23 A |  | 100% |  | 2022-10-31 | 2022-12-23 | 40d | 2022-10-31 | 2022-12-23 |  |  |  | Simon Berry | 320h | 320h |  | SI DevOps | SI Test | 5.0 | Systems Integration Testing (SIT) | Complete | COMPLETE | 25/7 - replan from start |  |  |  |  |
| 502 | 1.4.1.2.1.1.2 | Development |  | 125d | 2023-01-02 A | 2023-06-23 A | 501FS+5d | 100% |  | 2023-01-02 | 2023-06-23 | 125d | 2023-01-02 | 2023-06-23 |  |  |  | Simon Berry | 1000h | 1000h |  | SI DevOps | SI Test | 5.0 | Systems Integration Testing (SIT) | Complete | COMPLETE | 25/7 - replan from start |  |  |  |  |
| 503 | 1.4.1.2.1.1.3 | Testing |  | 125d | 2023-01-02 A | 2023-06-23 A | 502FF | 100% |  | 2023-01-02 | 2023-06-23 | 125d | 2023-01-02 | 2023-06-23 |  |  |  | Simon Berry | 1000h | 1000h |  | SI DevOps | SI Test | 5.0 | Systems Integration Testing (SIT) | Complete | COMPLETE | 25/7 - replan from start |  |  |  |  |
| 504 | 1.4.1.2.1.1.4 | Accept tool | milestone | 0d | 2023-06-23 A | 2023-06-23 A | 503FF | 100% |  | 2023-06-23 | 2023-06-23 | 0d | 2023-06-23 | 2023-06-23 |  |  |  | Simon Berry |  |  |  | SI DevOps | SI Test | 5.0 | Systems Integration Testing (SIT) | Complete | COMPLETE | 25/7 - replan from start |  |  |  |  |
| 505 | 1.4.1.2.1.1.5 | Implementation |  | 1d | 2023-10-23 A | 2023-10-23 A | 504FS+85d | 100% |  | 2023-06-30 | 2023-06-30 | 1d | 2023-06-30 | 2023-06-30 |  |  |  | Simon Berry | 8h | 8h |  | SI DevOps | PPC | 5.0 | Systems Integration Testing (SIT) | Complete | COMPLETE | 25/7 - replan from start |  |  |  |  |

Notes:
- 480: 2/4 - to be removed - All SIT test approach and plans created and socialised with Industry
- 481: 2/4 - to be removed - All SIT test approach and plans created and socialised with Industry
- 497: 4/0 - stays red till delivery plan agreed at TMAG

| ID | WBS | Task | Type | Duration | Start | Finish | Predecessors | Complete | Baseline start | Baseline finish | Baseline duration | Baseline 1 start | Baseline 1 finish | Total slack | Free slack | Constraint | Resources | Work | Actual work | Responsible | Involved | Action | Update Version | MHHS Programme Phase | Sched Status | RAG | Task Status | Milestone ID | Text29 | Tier |
| --- | --- | --- | --- | --- | --- | --- | --- | --- | --- | --- | --- | --- | --- | --- | --- | --- | --- | --- | --- | --- | --- | --- | --- | --- | --- | --- | --- | --- | --- | --- |
| 506 | 1.4.1.2.1.2 | **Test Management Tool User Guide** |  | 115d | 2023-01-02 A | 2023-06-09 A |  | 100% | 2023-01-02 | 2023-06-09 | 115d | 2023-01-02 | 2023-06-09 |  |  |  | N/A | 1840h | 1840h | N/A | N/A | 25/7 - replan from start | 5.0 | Systems Integration Testing (SIT) |  |  |  |  |  |  |
| 507 | 1.4.1.2.1.2.1 | Develop document |  | 100d | 2023-01-02 A | 2023-05-19 A | 502SS, 503SS | 100% | 2023-01-02 | 2023-05-19 | 100d | 2023-01-02 | 2023-05-19 |  |  | start no earlier than 2023-01-02 | Lee Cox | 800h | 800h | SI DevOps |  | 25/7 - replan from start | 5.0 | Systems Integration Testing (SIT) | Complete | COMPLETE |  |  |  |  |
| 508 | 1.4.1.2.1.2.2 | Review, update and agree Test Management Tool User Guide internally |  | 15d | 2023-05-22 A | 2023-06-09 A | 507 | 100% | 2023-05-22 | 2023-06-09 | 15d | 2023-05-22 | 2023-06-09 |  |  |  | Lee Cox | 120h | 120h | SRO Function | SI DevOps,SI Test,IPA,PPC | 25/7 - replan from start | 5.0 | Systems Integration Testing (SIT) | Complete | COMPLETE |  |  |  |  |
| 509 | 1.4.1.2.1.3 | **Test Management Tool Configuration Guide** |  | 60d | 2023-01-02 A | 2023-03-24 A |  | 100% | 2023-01-02 | 2023-03-24 | 60d | 2023-01-02 | 2023-03-24 |  |  |  | N/A | 960h | 960h | N/A | N/A | 25/7 - replan from start | 5.0 | Systems Integration Testing (SIT) |  |  |  |  |  |  |
| 510 | 1.4.1.2.1.3.1 | Develop document |  | 45d | 2023-01-02 A | 2023-03-03 A | 501 | 100% | 2023-01-02 | 2023-03-03 | 45d | 2023-01-02 | 2023-03-03 |  |  | start no earlier than 2023-01-02 | Lee Cox | 360h | 360h | SI DevOps | SI Test,IPA | 25/7 - replan from start | 5.0 | Systems Integration Testing (SIT) | Complete | COMPLETE |  |  |  |  |
| 511 | 1.4.1.2.1.3.2 | Review, update and agree Test Management Tool Configuration Guide internally |  | 15d | 2023-03-06 A | 2023-03-24 A | 510 | 100% | 2023-03-06 | 2023-03-24 | 15d | 2023-03-06 | 2023-03-24 |  |  |  | Lee Cox | 120h | 120h | SRO Function | SI DevOps,SI Test,IPA | 25/7 - replan from start | 5.0 | Systems Integration Testing (SIT) | Complete | COMPLETE |  |  |  |  |
| 512 | 1.4.1.2.2 | **Test Query Tool** | inactive | 130d | 2022-10-31 | 2023-04-28 |  |  | 2022-10-31 | 2023-04-28 | 130d | 2022-10-31 | 2023-04-28 | 96d |  |  | N/A | 2592h |  | N/A | N/A | 25/7 - replan from start | 5.0 | Systems Integration Testing (SIT) |  |  |  |  |  |  |
| 513 | 1.4.1.2.2.1 | **Test Query Tool Implementation** | inactive | 130d | 2022-10-31 | 2023-04-28 |  |  | 2022-10-31 | 2023-04-28 | 130d | 2022-10-31 | 2023-04-28 | 96d |  |  | N/A | 1328h |  | N/A | N/A | 25/7 - replan from start | 5.0 | Systems Integration Testing (SIT) |  |  |  |  |  |  |
| 514 | 1.4.1.2.2.1.1 | Requirements identification | inactive | 20d | 2022-10-31 | 2022-11-25 |  |  | 2022-10-31 | 2022-11-25 | 20d | 2022-10-31 | 2022-11-25 | 96d |  |  | Lee Cox | 160h |  | SI DevOps | SI Test | 25/7 - replan from start | 5.0 | Systems Integration Testing (SIT) |  | RED | -534.67 |  |  |  |
| 515 | 1.4.1.2.2.1.2 | Development | inactive | 10d | 2023-04-11 | 2023-04-24 | 514 |  | 2023-04-11 | 2023-04-24 | 10d | 2023-04-11 | 2023-04-24 | 0d |  | must start on 2023-04-11 | Lee Cox | 80h |  | SI DevOps | SI Test | 25/7 - replan from start | 5.0 | Systems Integration Testing (SIT) |  | RED | -372.67 |  |  |  |
| 516 | 1.4.1.2.2.1.3 | Testing | inactive | 5d | 2023-04-18 | 2023-04-24 | 515FF |  | 2023-04-18 | 2023-04-24 | 5d | 2023-04-18 | 2023-04-24 | 1065d | 0d |  | Lee Cox | 40h |  | SI DevOps | SI Test | 25/7 - replan from start | 5.0 | Systems Integration Testing (SIT) |  | RED | -365.67 |  |  |  |
| 517 | 1.4.1.2.2.1.4 | Accept tool | milestone, inactive | 0d | 2023-04-24 | 2023-04-24 | 516FF |  | 2023-04-24 | 2023-04-24 | 0d | 2023-04-24 | 2023-04-24 | 1065d | 0d |  | Lee Cox |  |  | SI DevOps | SI Test | 25/7 - replan from start | 5.0 | Systems Integration Testing (SIT) |  | RED | -359.29 |  |  |  |
| 518 | 1.4.1.2.2.1.5 | Implementation | inactive | 1d | 2023-04-28 | 2023-04-28 | 517FS+3d |  | 2023-04-28 | 2023-04-28 | 1d | 2023-04-28 | 2023-04-28 | 1065d |  |  | Lee Cox | 8h |  | SI DevOps | PPC | 25/7 - replan from start | 5.0 | Systems Integration Testing (SIT) |  | RED | -355.67 |  |  |  |
| 519 | 1.4.1.2.2.2 | **Test Query Tool User Guide** | inactive | 14d | 2023-04-11 | 2023-04-28 |  |  | 2023-04-11 | 2023-04-28 | 14d | 2023-04-11 | 2023-04-28 | 1065d |  |  | N/A | 224h |  | N/A | N/A | 25/7 - replan from start | 5.0 | Systems Integration Testing (SIT) |  |  |  |  |  |  |
| 520 | 1.4.1.2.2.2.1 | Develop document | inactive | 10d | 2023-04-11 | 2023-04-24 | 515SS |  | 2023-04-11 | 2023-04-24 | 10d | 2023-04-11 | 2023-04-24 | 1065d | 0d | start no earlier than 2022-11-28 | Lee Cox | 80h |  | SI DevOps |  | 25/7 - replan from start | 5.0 | Systems Integration Testing (SIT) |  | RED | -372.67 |  |  |  |
| 521 | 1.4.1.2.2.2.2 | Review, update and agree Test Query Tool User Guide internally | inactive | 4d | 2023-04-25 | 2023-04-28 | 520 |  | 2023-04-25 | 2023-04-28 | 4d | 2023-04-25 | 2023-04-28 | 1065d |  |  | Lee Cox | 32h |  | SRO Function | IPA,SI Test | 25/7 - replan from start | 5.0 | Systems Integration Testing (SIT) |  | RED | -358.67 |  |  |  |
| 522 | 1.4.1.3 | **SIT Participation** |  | 147d | 2022-10-31 A | 2023-05-23 A |  | 100% | 2022-10-31 | 2023-05-23 | 147d | 2022-10-31 | 2023-05-23 |  |  |  | N/A | 2968h | 2968h | N/A | N/A |  | 5.0 | Systems Integration Testing (SIT) |  |  |  |  |  |  |
| 523 | 1.4.1.3.1 | PPs decide whether to volunteer to participate in SIT and inform Programme of decision via Round 3 Replan consultation |  | 67d | 2022-10-31 A | 2023-01-31 A | 34FF | 100% | 2022-10-31 | 2023-01-31 | 67d | 2022-10-31 | 2023-01-31 |  |  |  | Lee Cox | 536h | 536h | PP | SI Test,PMO |  | 5.0 | Systems Integration Testing (SIT) | Complete | COMPLETE |  |  |  |  |
| 524 | 1.4.1.3.2 | Assurance of SIT volunteers' plans (submitted via Round 3 Replan Consultation) |  | 10d | 2023-02-01 A | 2023-02-14 A | 523, 34 | 100% | 2023-02-01 | 2023-02-14 | 10d | 2023-02-01 | 2023-02-14 |  |  |  | Lee Cox | 80h | 80h | SI Test | PP |  | 5.0 | Systems Integration Testing (SIT) | Complete | COMPLETE |  |  |  |  |
| 525 | 1.4.1.3.3 | SIT Participant Volunteers Identified | milestone | 0d | 2023-02-14 A | 2023-02-14 A | 524FF | 100% | 2023-02-14 | 2023-02-14 | 0d | 2023-02-14 | 2023-02-14 |  |  |  | Lee Cox |  |  | SI Test | PP |  | 5.0 | Systems Integration Testing (SIT) | Complete | COMPLETE |  | T2-TE-0100 | SITAG | T2 |
| 526 | 1.4.1.3.4 | Engagement with SIT volunteers |  | 147d | 2022-10-31 A | 2023-05-23 A |  | 100% | 2022-10-31 | 2023-05-23 | 147d | 2022-10-31 | 2023-05-23 |  |  |  | Lee Cox | 1176h | 1176h | SI Test | PP |  | 5.0 | Systems Integration Testing (SIT) | Complete | COMPLETE |  |  |  |  |
| 527 | 1.4.1.3.5 | SIT Participants Agreed | milestone | 0d | 2023-05-23 A | 2023-05-23 A | 526, 584FS-74d | 100% | 2023-05-23 | 2023-05-23 | 0d | 2023-05-23 | 2023-05-23 |  |  |  | Lee Cox |  |  | SI Test | PP |  | 5.0 | Systems Integration Testing (SIT) | Complete | COMPLETE |  | T2-TE-0150 | SITAG | T2 |
| 528 | 1.4.1.4 | **Data Protection Impact Assessment (DPIA)** |  | 32d | 2023-06-01 A | 2023-07-14 A |  | 100% | 2023-06-01 | 2023-07-14 | 32d | 2023-06-01 | 2023-07-14 |  |  |  | N/A | 512h | 512h | N/A | N/A |  | 5.0 | Systems Integration Testing (SIT) |  |  |  |  |  |  |
| 529 | 1.4.1.4.1 | Conduct DPIA on Overall Test Data Approach |  | 22d | 2023-06-01 A | 2023-06-30 A | 488 | 100% | 2023-06-01 | 2023-06-30 | 22d | 2023-06-01 | 2023-06-30 |  |  | start no earlier than 2023-06-01 | Cesar Lopes | 176h | 176h | PP | SI Test |  | 5.0 | Systems Integration Testing (SIT) | Complete | COMPLETE |  |  |  |  |
| 530 | 1.4.1.4.2 | Revise Overarching Test Data Approach & plan for DPIA (if required), including engagement with DWG |  | 9d | 2023-07-03 A | 2023-07-13 A | 529 | 100% | 2023-07-03 | 2023-07-13 | 9d | 2023-07-03 | 2023-07-13 |  |  |  | Cesar Lopes | 72h | 72h | SI Test Data |  |  | 5.0 | Systems Integration Testing (SIT) | Complete | COMPLETE |  |  |  |  |
| 531 | 1.4.1.4.3 | Review (internal), update and approve revised Overarching Test Data Approach & Plan (if required) |  | 1d | 2023-07-14 A | 2023-07-14 A | 530 | 100% | 2023-07-14 | 2023-07-14 | 1d | 2023-07-14 | 2023-07-14 |  |  |  | Cesar Lopes | 8h | 8h | SI Test Data | PP,IPA |  | 5.0 | Systems Integration Testing (SIT) | Complete | COMPLETE |  |  |  |  |

| ID | WBS | Task | Type | Duration | Start | Finish | Predecessors | Complete | Remaining | Baseline start | Baseline finish | Baseline duration | Baseline 1 start | Baseline 1 finish | Total slack | Constraint | Resources | Work | Actual work | Baseline cost | Responsible | Involved | Task Status | Update Version | MHHS Programme Phase | Sched Status | RAG | Milestone ID | Text29 | Tier | Guidance | Artefact ID |
| --- | --- | --- | --- | --- | --- | --- | --- | --- | --- | --- | --- | --- | --- | --- | --- | --- | --- | --- | --- | --- | --- | --- | --- | --- | --- | --- | --- | --- | --- | --- | --- | --- |
| 532 | 1.4.1.5 | **Data Sharing Agreements** |  | 44d | 2023-07-17 A | 2023-09-14 A |  | 100% |  | 2023-07-17 | 2023-09-14 | 44d |  |  |  |  | N/A | 704h | 704h |  | N/A | N/A | -275.67 | 5.5 | Systems Integration Testing (SIT) |  |  |  |  |  |  |  |
| 533 | 1.4.1.5.1 | Produce Data Sharing Agreement for Industry Review |  | 15d | 2023-07-17 A | 2023-08-04 A | 531 | 100% |  | 2023-07-17 | 2023-08-04 | 15d |  |  |  |  | Cesar Lopes | 120h | 120h |  | SI Test Data | PPC, Elexon |  | 5.5 | Systems Integration Testing (SIT) | Complete | COMPLETE |  |  |  |  |  |
| 534 | 1.4.1.5.2 | Manage Participant Queries and Contract Agreement Execution |  | 29d | 2023-08-07 A | 2023-09-14 A | 533 | 100% |  | 2023-08-07 | 2023-09-14 | 29d |  |  |  |  | Cesar Lopes | 232h | 232h |  | SI Test Data | PPC, Elexon |  | 5.5 | Systems Integration Testing (SIT) | Complete | COMPLETE |  |  |  |  |  |
| 535 | 1.4.1.5.3 | Data Sharing Agreements Complete | milestone | 0d | 2023-09-14 A | 2023-09-14 A | 534 | 100% |  | 2023-09-14 | 2023-09-14 | 0d |  |  |  |  | Cesar Lopes |  |  |  | SI Test Data | PPC, Elexon |  | 5.5 | Systems Integration Testing (SIT) | Complete | COMPLETE | T3-TE-0086 | SITAG | T3 |  |  |
| 536 | 1.4.1.6 | **Production Data Cut & Data Obfuscation** |  | 109d | 2023-04-04 A | 2023-09-01 A |  | 100% |  | 2023-04-04 | 2023-09-01 | 109d | 2023-04-04 | 2023-09-01 |  |  | N/A | 3312h | 3312h |  | N/A | N/A |  | 5.0 | Systems Integration Testing (SIT) |  |  |  |  |  |  |  |
| 537 | 1.4.1.6.1 | **SI Data Cut Preparation & Infrastructure** |  | 99d | 2023-04-04 A | 2023-08-18 A |  | 100% |  | 2023-04-04 | 2023-08-18 | 99d | 2023-04-04 | 2023-07-31 |  |  | N/A | 1592h | 1592h |  | N/A | N/A |  | 5.0 | Systems Integration Testing (SIT) |  |  |  |  |  |  |  |
| 538 | 1.4.1.6.1.1 | SI Data Cut Planning activities (incl. pre-cut and post-cut cleansing and population approach) |  | 55d | 2023-04-04 A | 2023-06-19 A |  | 100% |  | 2023-04-04 | 2023-06-19 | 55d | 2023-04-04 | 2023-06-19 |  | must start on 2023-04-04 | Cesar Lopes | 440h | 440h |  | SI Test Data | SI Test |  | 5.0 | Systems Integration Testing (SIT) | Complete | COMPLETE |  |  |  |  |  |
| 539 | 1.4.1.6.1.2 | Set up SI database and transmission structure |  | 44d | 2023-06-19 A | 2023-08-17 A | 538 | 100% |  | 2023-06-19 | 2023-08-17 | 44d | 2023-06-19 | 2023-07-31 |  | must start on 2023-06-19 | Cesar Lopes | 352h | 352h |  | SI Test Data | SI Test |  | 5.0 | Systems Integration Testing (SIT) | Complete | COMPLETE |  |  |  |  |  |
| 540 | 1.4.1.6.1.3 | Mechanism for transfer of data in place |  | 1d | 2023-08-18 A | 2023-08-18 A | 539 | 100% |  | 2023-08-18 | 2023-08-18 | 1d | 2023-07-31 | 2023-07-31 |  |  | Cesar Lopes | 8h | 8h |  | SI Test Data | SI Test |  | 5.0 | Systems Integration Testing (SIT) | Complete | COMPLETE |  |  |  |  |  |
| 541 | 1.4.1.6.1.4 | SI Data Cut Preparation & Infrastructure Complete | milestone | 0d | 2023-08-18 A | 2023-08-18 A | 540 | 100% |  | 2023-08-18 | 2023-08-18 | 0d |  |  |  |  | Cesar Lopes |  |  |  | SI Test Data | SI Test |  | 5.5 | Systems Integration Testing (SIT) | Complete | COMPLETE | T3-TE-0087 | SITAG | T3 |  |  |
| 542 | 1.4.1.6.2 | **Production Data Cut** |  | 55d | 2023-06-19 A | 2023-09-01 A |  | 100% |  | 2023-06-19 | 2023-09-01 | 55d | 2023-06-19 | 2023-09-01 |  |  | N/A | 848h | 848h |  | N/A | N/A |  | 5.0 | Systems Integration Testing (SIT) |  |  |  |  |  |  |  |
| 543 | 1.4.1.6.2.1 | Notification of Production Data Cut issued to relevant participants | milestone | 0d | 2023-06-19 A | 2023-06-19 A | 488 | 100% |  | 2023-06-19 | 2023-06-19 | 0d | 2023-06-19 | 2023-06-19 |  |  | Cesar Lopes |  |  |  | SI Test Data | PP |  | 5.0 | Systems Integration Testing (SIT) | Complete | COMPLETE | T3-TE-0011 | SITAG | T3 |  |  |
| 544 | 1.4.1.6.2.2 | Coordinate relevant participants taking data cut from production systems |  | 40d | 2023-06-19 A | 2023-08-11 A | 543 | 100% |  | 2023-06-19 | 2023-08-11 | 40d | 2023-06-19 | 2023-08-11 |  |  | Cesar Lopes | 320h | 320h |  | SI Test Data | PP |  | 5.0 | Systems Integration Testing (SIT) | Complete | COMPLETE |  |  |  |  |  |
| 545 | 1.4.1.6.2.3 | Production data cut GONG decision | milestone | 0d | 2023-08-16 A | 2023-08-16 A | 544FS+3d | 100% |  | 2023-08-16 | 2023-08-16 | 0d | 2023-08-16 | 2023-08-16 |  |  | Cesar Lopes |  |  |  | SI Test Data | PP |  | 5.0 | Systems Integration Testing (SIT) | Complete | COMPLETE | T3-TE-0017 | SITAG | T3 |  |  |
| 546 | 1.4.1.6.2.4 | Relevant participants take data cut from production systems (Saturday 19 August) |  | 1d | 2023-08-21 A | 2023-08-21 A | 545FS+2d | 100% |  | 2023-08-21 | 2023-08-21 | 1d | 2023-08-21 | 2023-08-21 |  |  | Cesar Lopes | 8h | 8h |  | SI Test Data | SI Test |  | 5.0 | Systems Integration Testing (SIT) | Complete | COMPLETE |  |  |  |  |  |
| 547 | 1.4.1.6.2.5 | EES transmit request data to SI |  | 5d | 2023-08-21 A | 2023-08-25 A | 546SS | 100% |  | 2023-08-21 | 2023-08-25 | 5d | 2023-08-21 | 2023-08-25 |  |  | Cesar Lopes | 40h | 40h |  | SI Test Data | SI Test |  | 5.0 | Systems Integration Testing (SIT) | Complete | COMPLETE |  |  |  |  |  |
| 548 | 1.4.1.6.2.6 | Check data alignment and integrity of data cut |  | 5d | 2023-08-28 A | 2023-09-01 A | 547 | 100% |  | 2023-08-28 | 2023-09-01 | 5d | 2023-08-28 | 2023-09-01 |  |  | Cesar Lopes | 40h | 40h |  | SI Test Data | PP |  | 5.0 | Systems Integration Testing (SIT) | Complete | COMPLETE |  |  |  |  |  |
| 549 | 1.4.1.6.2.7 | Data cut from relevant participants' production systems completed (Saturday 19 August) | milestone | 0d | 2023-08-21 A | 2023-08-21 A | 546, 529 | 100% |  | 2023-08-21 | 2023-08-21 | 0d | 2023-08-21 | 2023-08-21 |  |  | Cesar Lopes |  |  |  | SI Test Data | PP |  | 5.0 | Systems Integration Testing (SIT) | Complete | COMPLETE | T2-TE-0200 | SITAG | T2 | 28/07 - Starts on Sat 19th Aug |  |
| 550 | 1.4.1.6.2.8 | Production Data Cut Complete | milestone | 0d | 2023-08-21 A | 2023-08-21 A | 549 | 100% |  | 2023-08-21 | 2023-08-21 | 0d |  |  |  |  | Cesar Lopes |  |  |  | SI Test Data | PP |  | 5.4 | Systems Integration Testing (SIT) | Complete | COMPLETE |  |  |  | 28/07 - Starts on Sat 19th Aug |  |
| 551 | 1.4.1.7 | **SIT Stage-Specific Preparation** |  | 520d | 2022-10-31 A | 2024-10-25 |  | 83% | 86.67d | 2022-10-31 | 2025-03-03 | 611d | 2022-10-31 | 2025-03-10 | 675d |  | N/A | 105962h | 73585.1h | -0 | N/A | N/A |  | 5.0 | Systems Integration Testing (SIT) |  |  |  |  |  |  |  |
| 552 | 1.4.1.7.1 | **SIT Component Integration Preparation** |  | 320d | 2022-10-31 A | 2024-01-19 |  | 98% | 6.25d | 2022-10-31 | 2024-01-22 | 321d | 2022-10-31 | 2024-01-22 | 875d |  | N/A | 40384h | 37240.4h | -0 | N/A | N/A |  | 5.0 | Systems Integration Testing (SIT) |  |  |  |  |  |  |  |
| 553 | 1.4.1.7.1.1 | **Test Approach & Plan** |  | 188d | 2022-10-31 A | 2023-07-19 A |  | 100% |  | 2022-10-31 | 2023-07-19 | 188d | 2022-10-31 | 2023-07-19 |  |  | N/A | 3008h | 3008h |  | N/A | N/A |  | 5.0 | Systems Integration Testing (SIT) |  |  |  |  |  |  |  |
| 554 | 1.4.1.7.1.1.1 | Develop document with SITWG |  | 159d | 2022-10-31 A | 2023-06-08 A |  | 100% |  | 2022-10-31 | 2023-06-08 | 159d | 2022-10-31 | 2023-05-12 |  |  | Lee Cox | 1272h | 1272h |  | SI Test |  |  | 5.0 | Systems Integration Testing (SIT) | Complete | COMPLETE |  |  |  |  |  |
| 555 | 1.4.1.7.1.1.2 | Industry consultation |  | 10d | 2023-06-09 A | 2023-06-22 A | 554 | 100% |  | 2023-06-09 | 2023-06-22 | 10d |  |  |  |  | Lee Cox | 80h | 80h |  | PP |  |  | 5.1 | Systems Integration Testing (SIT) | Complete | COMPLETE |  |  |  |  |  |
| 556 | 1.4.1.7.1.1.3 | Artefact review (via TMAG) and updates |  | 19d | 2023-06-23 A | 2023-07-19 A | 555 | 100% |  | 2023-06-23 | 2023-07-19 | 19d | 2023-06-09 | 2023-07-06 |  | finish no earlier than 2023-07-06 | Lee Cox | 152h | 152h |  | SI Test | PP,IPA,Code Bodies |  | 5.0 | Systems Integration Testing (SIT) | Complete | COMPLETE |  |  |  |  |  |
| 557 | 1.4.1.7.1.1.4 | SIT Component Integration Testing Test Approach & Plan approved | milestone | 0d | 2023-07-19 A | 2023-07-19 A | 556 | 100% |  | 2023-07-19 | 2023-07-19 | 0d | 2023-07-19 | 2023-07-19 |  | finish no earlier than 2023-07-19 | Lee Cox |  |  |  | SI Test | PP |  | 5.0 | Systems Integration Testing (SIT) | Complete | COMPLETE | T3-TE-0012 | SITAG | T3 |  | MHHS-ART073 |

Notes:
- 532: 3/8 - JW and CL Meeting - Added in to align with FTIG plan as critical programme activity
- 533: 3/8 - JW and CL - Added in to align with FTIG plan as critical programme activity
- 534: 3/8 - JW and CL - Added in to align with FTIG plan as critical programme activity
- 535: 22/8 - no issue as long as ready by 14/9 when data starts to be transmitted to Helix / Action: 3/8 - add as t3 milestones. Awaiting approval at TMAG
- 541: 3/8 - JW and CL Meeting - added in as new T3 milestone / Action: 3/8 - add as t3 milestones. Awaiting approval at TMAG. 8/8 - update name in register
- 550: Action: 2/8 - check isn't a duplicate of t2-te-0200

| ID | WBS | Task | Type | Duration | Start | Finish | Predecessors | Complete | Baseline start | Baseline finish | Baseline duration | Baseline 1 start | Baseline 1 finish | Constraint | Resources | Work | Actual work | Baseline cost | Responsible | Involved | Update Version | MHHS Programme Phase | Sched Status | RAG | Artefact ID | Milestone ID | Text29 | Tier | Task Status |
| --- | --- | --- | --- | --- | --- | --- | --- | --- | --- | --- | --- | --- | --- | --- | --- | --- | --- | --- | --- | --- | --- | --- | --- | --- | --- | --- | --- | --- | --- |
| 558 | 1.4.1.7.1.2 | **Test Data Approach & Plan** |  | 29d | 2023-06-09 A | 2023-07-19 A |  | 100% | 2023-06-09 | 2023-07-19 | 29d | 2023-06-09 | 2023-07-19 |  | N/A | 464h | 464h |  | N/A | N/A | 5.0 | Systems Integration Testing (SIT) |  |  |  |  |  |  |  |
| 559 | 1.4.1.7.1.2.1 | Industry consultation |  | 10d | 2023-06-09 A | 2023-06-22 A | 555SS | 100% | 2023-06-09 | 2023-06-22 | 10d |  |  |  | Cesar Lopes | 80h | 80h |  | PP |  | 5.1 | Systems Integration Testing (SIT) | Complete | COMPLETE |  |  |  |  |  |
| 560 | 1.4.1.7.1.2.2 | Artefact review (via TMAG) and updates |  | 19d | 2023-06-23 A | 2023-07-19 A | 559 | 100% | 2023-06-23 | 2023-07-19 | 19d | 2023-06-09 | 2023-07-06 |  | Cesar Lopes | 152h | 152h |  | SI Test | PP | 5.0 | Systems Integration Testing (SIT) | Complete | COMPLETE |  |  |  |  |  |
| 561 | 1.4.1.7.1.2.3 | SIT Component Integration Testing Test Data Approach & Plan approved | milestone | 0d | 2023-07-19 A | 2023-07-19 A | 560 | 100% | 2023-07-19 | 2023-07-19 | 0d | 2023-07-19 | 2023-07-19 |  | Cesar Lopes |  |  |  | SI Test | IPA | 5.0 | Systems Integration Testing (SIT) | Complete | COMPLETE |  |  |  |  |  |
| 562 | 1.4.1.7.1.3 | **Test scenarios** |  | 173d | 2023-01-02 A | 2023-08-30 A |  | 100% | 2023-01-02 | 2023-08-30 | 173d | 2023-01-02 | 2023-06-02 |  | N/A | 1472h | 1472h |  | N/A | N/A | 5.0 | Systems Integration Testing (SIT) |  |  |  |  |  |  |  |
| 563 | 1.4.1.7.1.3.1 | Development of test scenarios | milestone | 0d | 2023-01-02 A | 2023-04-28 A | 554SS+45d | 100% | 2023-01-02 | 2023-04-28 | 85d | 2023-01-02 | 2023-04-28 |  | Lee Cox |  |  |  | SI Test | PP, Code Bodies | 5.0 | Systems Integration Testing (SIT) | Complete | COMPLETE |  |  |  |  |  |
| 564 | 1.4.1.7.1.3.2 | Review test scenarios with SIT Working Group |  | 11d | 2023-02-01 A | 2023-08-09 A | 563SS+22d | 100% | 2023-02-01 | 2023-08-09 | 136d | 2023-02-01 | 2023-05-26 |  | Lee Cox | 88h | 88h |  | SI Test | PP, Code Bodies, IPA | 5.0 | Systems Integration Testing (SIT) | Complete | COMPLETE |  |  |  |  |  |
| 565 | 1.4.1.7.1.3.3 | SIT Component Integration Testing Test scenarios approved | milestone | 0d | 2023-08-30 A | 2023-08-30 A | 564FS+15d | 100% | 2023-08-30 | 2023-08-30 | 0d | 2023-06-02 | 2023-06-02 |  | Lee Cox |  |  |  | SI Test | PP | 5.6 | Systems Integration Testing (SIT) | Complete | COMPLETE | MHHS-ART148 | T3-TE-0014 | SITAG | T3 |  |
| 566 | 1.4.1.7.1.4 | **Test cases** |  | 160d | 2023-05-01 A | 2023-12-08 A |  | 100% | 2023-05-01 | 2023-12-08 | 160d | 2023-05-01 | 2023-09-01 |  | N/A | 4240h | 4240h |  | N/A | N/A | 5.6 | Systems Integration Testing (SIT) |  |  |  |  |  |  |  |
| 567 | 1.4.1.7.1.4.1 | **SI Test cases** |  | 160d | 2023-05-01 A | 2023-12-08 A |  | 100% | 2023-05-01 | 2023-12-08 | 160d | 2023-05-01 | 2023-09-01 |  | N/A | 2960h | 2960h |  | N/A | N/A | 5.6 | Systems Integration Testing (SIT) |  |  |  |  |  |  |  |
| 568 | 1.4.1.7.1.4.1.1 | **Batch 1 (CIT Intervals 1 and 2)** |  | 110d | 2023-05-01 A | 2023-09-29 A |  | 100% | 2023-05-01 | 2023-09-29 | 110d |  |  |  | N/A | 1256h | 1256h |  | N/A | N/A | 5.6 | Systems Integration Testing (SIT) |  |  |  |  |  |  | -290.67 |
| 569 | 1.4.1.7.1.4.1.1.1 | Develop Test cases |  | 100d | 2023-05-01 A | 2023-09-15 A | 563 | 100% | 2023-05-01 | 2023-09-15 | 100d | 2023-05-01 | 2023-07-28 |  | Lee Cox | 304h | 304h |  | SI Test |  | 5.6 | Systems Integration Testing (SIT) | Complete | COMPLETE |  |  |  |  |  |
| 570 | 1.4.1.7.1.4.1.1.2 | Review Test cases with SIT Working Group |  | 9d | 2023-09-18 A | 2023-09-28 A | 569 | 100% | 2023-09-18 | 2023-09-28 | 9d | 2023-05-26 | 2023-08-25 |  | Lee Cox | 72h | 72h |  | SI Test | PP,IPA | 5.6 | Systems Integration Testing (SIT) | Complete | COMPLETE |  |  |  |  |  |
| 571 | 1.4.1.7.1.4.1.1.3 | SIT Component Integration Testing Test cases Batch 1 (CIT Intervals 1 and 2) approved at ETMAG | milestone | 0d | 2023-09-29 A | 2023-09-29 A | 570FS+1d | 100% | 2023-09-29 | 2023-09-29 | 0d | 2023-09-01 | 2023-09-01 |  | Lee Cox |  |  |  | SI Test | PP | 5.6 | Systems Integration Testing (SIT) | Complete | COMPLETE | MHHS-ART073 | T3-TE-0069 | SITAG | T3 |  |
| 572 | 1.4.1.7.1.4.1.2 | **Batch 2 (CIT Intervals 3 and 4)** |  | 25d | 2023-10-02 A | 2023-11-03 A |  | 100% | 2023-10-02 | 2023-11-03 | 25d |  |  |  | N/A | 320h | 320h |  | N/A | N/A | 5.6 | Systems Integration Testing (SIT) |  |  |  |  |  |  | -290.67 |
| 573 | 1.4.1.7.1.4.1.2.1 | Develop Test cases |  | 15d | 2023-10-02 A | 2023-10-20 A | 571 | 100% | 2023-10-02 | 2023-10-20 | 15d | 2023-05-01 | 2023-07-28 |  | Lee Cox | 48h | 48h |  | SI Test |  | 5.6 | Systems Integration Testing (SIT) | Complete | COMPLETE |  |  |  |  |  |
| 574 | 1.4.1.7.1.4.1.2.2 | Review Test cases with SIT Working Group |  | 9d | 2023-10-23 A | 2023-11-02 A | 573 | 100% | 2023-10-23 | 2023-11-02 | 9d | 2023-05-26 | 2023-08-25 |  | Lee Cox | 72h | 72h |  | SI Test | PP,IPA | 5.6 | Systems Integration Testing (SIT) | Complete | COMPLETE |  |  |  |  |  |
| 575 | 1.4.1.7.1.4.1.2.3 | SIT Component Integration Testing Test cases Batch 2 (CIT Intervals 3 and 4) approved at ETMAG | milestone | 0d | 2023-11-03 A | 2023-11-03 A | 574FS+1d | 100% | 2023-11-03 | 2023-11-03 | 0d | 2023-09-01 | 2023-09-01 |  | Lee Cox |  |  |  | SI Test | PP | 5.11 | Systems Integration Testing (SIT) | Complete | COMPLETE |  | T3-TE-0104 | SITAG | T3 |  |
| 576 | 1.4.1.7.1.4.1.3 | **Batch 3 (CIT Intervals 5 and 6)** |  | 25d | 2023-11-03 A | 2023-12-08 A |  | 100% | 2023-11-03 | 2023-12-08 | 25d |  |  |  | N/A | 104h | 104h |  | N/A | N/A | 5.6 | Systems Integration Testing (SIT) |  |  |  |  |  |  | -290.67 |
| 577 | 1.4.1.7.1.4.1.3.1 | Develop Test cases |  | 15d | 2023-11-03 A | 2023-11-24 A | 575 | 100% | 2023-11-03 | 2023-11-24 | 15d | 2023-05-01 | 2023-07-28 |  | Lee Cox |  |  |  | SI Test |  | 5.6 | Systems Integration Testing (SIT) | Complete | COMPLETE |  |  |  |  |  |
| 578 | 1.4.1.7.1.4.1.3.2 | Review Test cases with SIT Working Group |  | 9d | 2023-11-27 A | 2023-12-07 A | 577 | 100% | 2023-11-27 | 2023-12-07 | 9d | 2023-05-26 | 2023-08-25 |  | Lee Cox | 72h | 72h |  | SI Test | PP,IPA | 5.6 | Systems Integration Testing (SIT) | Complete | COMPLETE |  |  |  |  |  |
| 579 | 1.4.1.7.1.4.1.3.3 | SIT Component Integration Testing Test cases Batch 3 (CIT Intervals 5 and 6) approved at ETMAG | milestone | 0d | 2023-12-08 A | 2023-12-08 A | 578FS+1d | 100% | 2023-12-08 | 2023-12-08 | 0d | 2023-09-01 | 2023-09-01 |  | Lee Cox |  |  |  | SI Test | PP | 5.14 | Systems Integration Testing (SIT) | Complete | COMPLETE |  | T3-TE-0105 | SITAG | T3 |  |
| 580 | 1.4.1.7.1.5 | **CIT Interval 1 Preparation** |  | 283d | 2022-11-16 A | 2023-12-15 A |  | 100% | 2022-11-16 | 2023-12-08 | 278d | 2022-11-16 | 2023-10-23 |  | N/A | 14632h | 14632h | -0 | N/A | N/A | 5.6 | Systems Integration Testing (SIT) |  |  |  |  |  |  |  |
| 581 | 1.4.1.7.1.5.1 | **Environments (SIT A)** |  | 246d | 2022-11-16 A | 2023-10-25 A |  | 100% | 2022-11-16 | 2023-10-16 | 239d | 2022-11-16 | 2023-10-06 |  | N/A | 6616h | 6616h |  | N/A | N/A | 5.0 | Systems Integration Testing (SIT) |  |  |  |  |  |  |  |
| 582 | 1.4.1.7.1.5.1.1 | PPs register PKI Officers and request PKI certificates |  | 5d | 2023-10-09 A | 2023-10-13 A |  | 100% | 2023-10-09 | 2023-10-13 | 5d | 2023-08-28 | 2023-09-01 | start no earlier than 2023-10-09 | Simon Berry | 40h | 40h |  | PP | DIP Provider | 5.5 | Systems Integration Testing (SIT) | Complete | COMPLETE |  |  |  |  |  |
| 583 | 1.4.1.7.1.5.1.2 | PPs register PKI Officers and request PKI certificates Complete - Interval 1 | milestone | 0d | 2023-10-25 A | 2023-10-25 A | 582FS+8d | 100% | 2023-10-13 | 2023-10-13 | 0d |  |  |  | Simon Berry |  |  |  | PP | DIP Provider | 5.10 | Systems Integration Testing (SIT) | Complete | COMPLETE |  | T3-TE-0094 | SITAG | T3 |  |
| 584 | 1.4.1.7.1.5.1.3 | PP SIT A environment preparation (incl. security certificates and security compliance) |  | 238d | 2022-11-16 A | 2023-10-13 A | 466 | 100% | 2022-11-16 | 2023-09-01 | 208d | 2022-11-16 | 2023-09-01 |  | Simon Berry | 1904h | 1904h |  | PP | SI Test | 5.8 | Systems Integration Testing (SIT) | Complete | COMPLETE |  |  |  |  |  |
| 585 | 1.4.1.7.1.5.1.4 | SI coordinate SIT Participants' SIT A environment preparation |  | 238d | 2022-11-16 A | 2023-10-13 A | 584SS | 100% | 2022-11-16 | 2023-09-01 | 208d | 2022-11-16 | 2023-09-01 |  | Simon Berry | 1904h | 1904h |  | SI Test | PP | 5.8 | Systems Integration Testing (SIT) | Complete | COMPLETE |  |  |  |  |  |
| 586 | 1.4.1.7.1.5.1.5 | PP submit self-declaration of environment preparation complete (incl. security certificates and security compliance) to Programme for assurance | milestone | 0d | 2023-10-13 A | 2023-10-13 A | 584FF | 100% | 2023-09-01 | 2023-09-01 | 0d | 2023-09-01 | 2023-09-01 | start no earlier than 2023-10-13 | Simon Berry |  |  |  | PP | SI Test | 5.8 | Systems Integration Testing (SIT) | Complete | COMPLETE |  |  |  |  |  |
| 587 | 1.4.1.7.1.5.1.6 | SI assure PPs' self-declaration of environment preparation complete (incl. security certificates and security compliance) |  | 5d | 2023-10-16 A | 2023-10-20 A | 586FF+5d | 100% | 2023-09-04 | 2023-09-08 | 5d | 2023-09-04 | 2023-09-08 |  | Simon Berry | 40h | 40h |  | SI Test | PP | 5.8 | Systems Integration Testing (SIT) | Complete | COMPLETE |  |  |  |  |  |
| 588 | 1.4.1.7.1.5.1.7 | SIT Participants' SIT A environments ready to start connectivity proving CIT Interval 1 | milestone | 0d | 2023-09-01 A | 2023-09-01 A | 586SS | 100% | 2023-09-01 | 2023-09-01 | 0d | 2023-09-01 | 2023-09-01 |  | Simon Berry |  |  |  | PP | PP,IPA | 5.6 | Systems Integration Testing (SIT) | Complete | COMPLETE | MHHS-ART139 | T3-TE-0019 | SITAG | T3 |  |
| 589 | 1.4.1.7.1.5.1.8 | PP SIT A environment connectivity proving |  | 10d | 2023-09-04 A | 2023-09-15 A | 588 | 100% | 2023-09-12 | 2023-10-09 | 20d | 2023-09-04 | 2023-09-29 |  | Simon Berry | 80h | 80h |  | PP | SI Test | 5.8 | Systems Integration Testing (SIT) | Complete | COMPLETE |  |  |  |  |  |
| 590 | 1.4.1.7.1.5.1.9 | SI coordinate SIT Participants' SIT A environment connectivity proving |  | 10d | 2023-09-04 A | 2023-09-15 A | 589SS | 100% | 2023-09-12 | 2023-10-09 | 20d | 2023-09-04 | 2023-09-29 |  | Simon Berry | 80h | 80h |  | SI Test | PP | 5.8 | Systems Integration Testing (SIT) | Complete | COMPLETE |  |  |  |  |  |
| 591 | 1.4.1.7.1.5.1.10 | PP deployment of MHHS solution code to SIT A environments |  | 10d | 2023-09-25 A | 2023-10-06 A | 632FF | 100% | 2023-09-26 | 2023-10-09 | 10d | 2023-09-18 | 2023-09-29 |  | Simon Berry | 80h | 80h |  | PP | SI Test | 5.0 | Systems Integration Testing (SIT) | Complete | COMPLETE |  |  |  |  |  |
| 592 | 1.4.1.7.1.5.1.11 | SI coordinate deployment of MHHS solution code to SIT Participants' SIT A environments |  | 10d | 2023-09-25 A | 2023-10-06 A | 632FF | 100% | 2023-09-26 | 2023-10-09 | 10d | 2023-09-18 | 2023-09-29 |  | Simon Berry | 80h | 80h |  | SI Test | PP | 5.0 | Systems Integration Testing (SIT) | Complete | COMPLETE |  |  |  |  |  |
| 593 | 1.4.1.7.1.5.1.12 | PP submit evidence of SIT A environment connectivity proving and code deployment completion to Programme for assurance |  | 30d | 2023-09-04 A | 2023-10-13 A | 589SS | 100% | 2023-09-12 | 2023-10-09 | 20d | 2023-09-04 | 2023-09-29 |  | Simon Berry | 240h | 240h |  | PP | SI Test | 5.8 | Systems Integration Testing (SIT) | Complete | COMPLETE |  |  |  |  |  |
| 594 | 1.4.1.7.1.5.1.13 | SI assurance of SIT Participants' SIT A environment connectivity proving and code deployment completion |  | 25d | 2023-09-18 A | 2023-10-20 A | 593FF+5d | 100% | 2023-09-12 | 2023-10-16 | 25d | 2023-09-04 | 2023-10-06 |  | Simon Berry | 200h | 200h |  | SI Test | PP | 5.8 | Systems Integration Testing (SIT) | Complete | COMPLETE |  |  |  |  |  |

Notes:
- 565: 17/8 - to go to ETMAG on 30/8
- 566: 18/8 - added in with LC to reflect his ppt slide
- 567: 18/8 - added in with LC to reflect his ppt slide
- 568: 18/8 - added in with LC to reflect his ppt slide
- 569: 18/8 - added in with LC to reflect his ppt slide
- 570: 18/8 - added in with LC to reflect his ppt slide
- 571: 18/8 - added in with LC to reflect his ppt slide / Guidance: 18/8 - needs to finish on 29/9 for ETWAG / Action: 18/8 - needs to finish on 29/9 for ETWAG. Update Milestone register after approval
- 572: 18/8 - added in with LC to reflect his ppt slide
- 573: 18/8 - added in with LC to reflect his ppt slide
- 574: 18/8 - added in with LC to reflect his ppt slide
- 575: 18/8 - added in with LC to reflect his ppt slide / Guidance: 18/8 - needs to finish on 3/11 for ETWAG / Action: 18/8 - needs to finish on 29/9 for ETWAG
- 576: 18/8 - added in with LC to reflect his ppt slide
- 577: 18/8 - added in with LC to reflect his ppt slide
- 578: 18/8 - added in with LC to reflect his ppt slide
- 579: 18/8 - added in with LC to reflect his ppt slide. 28/11 - Red bacause TMAG date has moved from 8/12 to 20/12 due to reduction in Dec TMAGs. No impact. No action. 20/12 - Approved at TMAG on 20/12 / Guidance: 28/11 - Red bacause TMAG date has moved from 8/12 to 20/12 due to reduction in Dec TMAGs. No impact. No action
- 583: 16/8- new milestones added in and date change. Approved at TMAG on 16/8. 18/10 - Red because there is an issue that is preventing the issue of PKI certificates. ~Avanade are working with GlobalSign to resolve.~A fix is in the process of being tested

| ID | WBS | Task | Type | Duration | Start | Finish | Predecessors | Complete | Baseline start | Baseline finish | Baseline duration | Resources | Work | Actual work | Baseline cost | Responsible | Involved | Task Status | Update Version | MHHS Programme Phase | Sched Status | RAG | Action | Milestone ID | Text29 | Tier | Artefact ID |
| --- | --- | --- | --- | --- | --- | --- | --- | --- | --- | --- | --- | --- | --- | --- | --- | --- | --- | --- | --- | --- | --- | --- | --- | --- | --- | --- | --- |
| 595 | 1.4.1.7.1.5.2 | **Test Data - ISD Creation** |  | 9d | 2023-08-22 A | 2023-09-01 A |  | 100% | 2023-08-22 | 2023-09-01 | 9d | N/A | 144h | 144h |  | N/A | N/A | -275.67 | 5.5 | Systems Integration Testing (SIT) |  |  |  |  |  |  |  |
| 596 | 1.4.1.7.1.5.2.1 | Set-up Market Participants and DIP ID Data |  | 8d | 2023-08-22 A | 2023-08-31 A | 550 | 100% | 2023-08-22 | 2023-08-31 | 8d | Cesar Lopes | 64h | 64h |  | SI Test Data | SI Test, DIP, Helix |  | 5.5 | Systems Integration Testing (SIT) | Complete | COMPLETE |  |  |  |  |  |
| 597 | 1.4.1.7.1.5.2.2 | Distribute ISD Data to Participants |  | 1d | 2023-09-01 A | 2023-09-01 A | 596 | 100% | 2023-09-01 | 2023-09-01 | 1d | Cesar Lopes | 8h | 8h |  | SI Test Data | SI Test, DIP, Helix |  | 5.5 | Systems Integration Testing (SIT) | Complete | COMPLETE |  |  |  |  |  |
| 598 | 1.4.1.7.1.5.2.3 | Test Data - ISD Creation Complete | milestone | 0d | 2023-09-01 A | 2023-09-01 A | 597 | 100% | 2023-09-01 | 2023-09-01 | 0d | Cesar Lopes |  |  |  | SI Test Data | SI Test, DIP, Helix |  | 5.5 | Systems Integration Testing (SIT) | Complete | COMPLETE | 3/8 - add as t3 milestones. Awaiting approval at TMAG | T3-TE-0083 | SITAG | T3 |  |
| 599 | 1.4.1.7.1.5.3 | **Test Data - SFTP Onboarding** |  | 70d | 2023-08-21 A | 2023-11-24 A |  | 100% | 2023-08-21 | 2023-11-24 | 70d | N/A | 664h | 664h | -0 | N/A | N/A | -275.67 | 5.5 | Systems Integration Testing (SIT) |  |  |  |  |  |  |  |
| 600 | 1.4.1.7.1.5.3.1 | Create Containers and Keys for Participants |  | 3d | 2023-08-21 A | 2023-08-23 A | 541 | 100% | 2023-08-21 | 2023-08-23 | 3d | Cesar Lopes | 24h | 24h |  | SI Test Data | SI Test |  | 5.5 | Systems Integration Testing (SIT) | Complete | COMPLETE |  |  |  |  |  |
| 601 | 1.4.1.7.1.5.3.2 | Share SFTP Access with Participants |  | 5d | 2023-08-24 A | 2023-08-30 A | 600 | 100% | 2023-08-24 | 2023-08-30 | 5d | Cesar Lopes | 40h | 40h |  | SI Test Data | SI Test, PP |  | 5.5 | Systems Integration Testing (SIT) | Complete | COMPLETE |  |  |  |  |  |
| 602 | 1.4.1.7.1.5.3.3 | Test SFTP Connectivity |  | 5d | 2023-08-31 A | 2023-09-06 A | 601 | 100% | 2023-08-31 | 2023-09-06 | 5d | Cesar Lopes | 40h | 40h |  | SI Test Data | SI Test, PP |  | 5.5 | Systems Integration Testing (SIT) | Complete | COMPLETE |  |  |  |  |  |
| 603 | 1.4.1.7.1.5.3.4 | Test Data - SFTP Onboarding Complete | milestone | 0d | 2023-11-24 A | 2023-11-24 A | 602FS+57d | 100% | 2023-11-24 | 2023-11-24 | 0d | Cesar Lopes |  |  |  | SI Test Data | SI Test, PP |  | 5.13 | Systems Integration Testing (SIT) | Complete | COMPLETE |  | T3-TE-0084 | SITAG | T3 |  |
| 604 | 1.4.1.7.1.5.4 | **Test Data - Provide Sample Files** |  | 10d | 2023-08-21 A | 2023-09-01 A |  | 100% | 2023-08-21 | 2023-09-01 | 10d | N/A | 160h | 160h |  | N/A | N/A | -275.67 | 5.5 | Systems Integration Testing (SIT) |  |  |  |  |  |  |  |
| 605 | 1.4.1.7.1.5.4.1 | Generate Sample Files off IF Messages |  | 8d | 2023-08-21 A | 2023-08-30 A | 541 | 100% | 2023-08-21 | 2023-08-30 | 8d | Cesar Lopes | 64h | 64h |  | SI Test Data | SI Test |  | 5.5 | Systems Integration Testing (SIT) | Complete | COMPLETE |  |  |  |  |  |
| 606 | 1.4.1.7.1.5.4.2 | Transmit Sample Files off IF Messages to Participants (More detail needs to be planned for a POC) |  | 2d | 2023-08-31 A | 2023-09-01 A | 605 | 100% | 2023-08-31 | 2023-09-01 | 2d | Cesar Lopes | 16h | 16h |  | SI Test Data | SI Test |  | 5.5 | Systems Integration Testing (SIT) | Complete | COMPLETE |  |  |  |  |  |
| 607 | 1.4.1.7.1.5.4.3 | Test Data - Provide Sample Files Complete | milestone | 0d | 2023-09-01 A | 2023-09-01 A | 606 | 100% | 2023-09-01 | 2023-09-01 | 0d | Cesar Lopes |  |  |  | SI Test Data | SI Test |  | 5.5 | Systems Integration Testing (SIT) | Complete | COMPLETE | 3/8 - add as t3 milestones. Awaiting approval at TMAG | T3-TE-0085 | SITAG | T3 |  |
| 608 | 1.4.1.7.1.5.5 | **Test Data - Detailed SIT Data Load Guidance** |  | 65d | 2023-09-07 A | 2023-12-06 A |  | 100% | 2023-09-07 | 2023-12-01 | 62d | N/A | 696h | 696h | -0 | N/A | N/A | -275.67 | 5.5 | Systems Integration Testing (SIT) |  |  |  |  |  |  |  |
| 609 | 1.4.1.7.1.5.5.1 | Document Guidance |  | 21d | 2023-09-07 A | 2023-10-05 A | 607FS+3d | 100% | 2023-09-07 | 2023-09-28 | 16d | Cesar Lopes | 168h | 168h |  | SI Test Data | SI Test |  | 5.9 | Systems Integration Testing (SIT) | Complete | COMPLETE |  |  |  |  |  |
| 610 | 1.4.1.7.1.5.5.2 | Provide Guidance to PPs |  | 1d | 2023-10-06 A | 2023-10-06 A | 609 | 100% | 2023-09-29 | 2023-09-29 | 1d | Cesar Lopes | 8h | 8h |  | SI Test Data | SI Test |  | 5.9 | Systems Integration Testing (SIT) | Complete | COMPLETE |  |  |  |  |  |
| 611 | 1.4.1.7.1.5.5.3 | Test Data - Detailed SIT Functional Data Load Guidance Complete | milestone | 0d | 2023-12-06 A | 2023-12-06 A | 610FS+43d | 100% | 2023-12-01 | 2023-12-01 | 0d | Richard Puddephatt |  |  |  | SI Test Data | SI Test |  | 5.13 | Systems Integration Testing (SIT) | Complete | COMPLETE |  | T3-TE-0095 | SITAG | T3 | MHHS-DEL 1545 |
| 612 | 1.4.1.7.1.5.6 | **Test Data - Population of Data Items for Testing Guidance - Draft** |  | 80d | 2023-08-17 A | 2023-12-06 A |  | 100% | 2023-08-17 | 2023-12-01 | 77d | N/A | 736h | 736h | -0 | N/A | N/A | -275.67 | 5.5 | Systems Integration Testing (SIT) |  |  |  |  |  |  |  |
| 613 | 1.4.1.7.1.5.6.1 | Document Guidance - Draft |  | 11d | 2023-08-17 A | 2023-08-31 A | 801 | 100% | 2023-08-17 | 2023-08-31 | 11d | Cesar Lopes | 88h | 88h |  | SI Test Data | SI Test |  | 5.6 | Systems Integration Testing (SIT) | Complete | COMPLETE |  |  |  |  |  |
| 614 | 1.4.1.7.1.5.6.2 | Provide Guidance to PPs - Draft |  | 1d | 2023-09-01 A | 2023-09-01 A | 613 | 100% | 2023-09-01 | 2023-09-01 | 1d | Cesar Lopes | 8h | 8h |  | SI Test Data | SI Test |  | 5.6 | Systems Integration Testing (SIT) | Complete | COMPLETE |  |  |  |  |  |
| 615 | 1.4.1.7.1.5.6.3 | Test Data - Population of Data Items for Testing Guidance - Draft Complete | milestone | 0d | 2023-12-06 A | 2023-12-06 A | 614FS+68d | 100% | 2023-12-01 | 2023-12-01 | 0d | Richard Puddephatt |  |  |  | SI Test Data | SI Test |  | 5.13 | Systems Integration Testing (SIT) | Complete | COMPLETE |  | T3-TE-0096 | SITAG | T3 | MHHS-DEL 816 |
| 616 | 1.4.1.7.1.5.7 | **Test Data - Population of Data Items for Testing Guidance - Final** |  | 87d | 2023-08-17 A | 2023-12-15 A |  | 100% | 2023-10-09 | 2023-12-08 | 45d | N/A | 1352h | 1352h |  | N/A | N/A | -275.67 | 5.5 | Systems Integration Testing (SIT) |  |  |  |  |  |  |  |
| 617 | 1.4.1.7.1.5.7.1 | Update Document Guidance With PPS Feedback |  | 81d | 2023-08-17 A | 2023-12-07 A | 613SS | 100% | 2023-10-09 | 2023-12-07 | 44d | Richard Puddephatt | 648h | 648h |  | SI Test Data | SI Test |  | 5.5 | Systems Integration Testing (SIT) | Complete | COMPLETE |  |  |  |  |  |
| 618 | 1.4.1.7.1.5.7.2 | Provide Final Guidance to PPs |  | 1d | 2023-12-08 A | 2023-12-08 A | 617 | 100% | 2023-12-08 | 2023-12-08 | 1d | Richard Puddephatt | 8h | 8h |  | SI Test Data | SI Test |  | 5.5 | Systems Integration Testing (SIT) | Complete | COMPLETE |  |  |  |  |  |
| 619 | 1.4.1.7.1.5.7.3 | Test Data - Population of Data Items for Testing Guidance - Final Complete | milestone | 0d | 2023-12-15 A | 2023-12-15 A | 618FS+5d | 100% | 2023-12-08 | 2023-12-08 | 0d | Richard Puddephatt |  |  |  | SI Test Data | SI Test |  | 5.14 | Systems Integration Testing (SIT) | Complete | COMPLETE |  | T3-TE-0097 | SITAG | T3 | MHHS-DEL 816 |

Notes:
- 595: 3/8 - JW and CL meeting - added in to give e more clarity around work being undertaken
- 596: 3/8 - JW and CL meeting - added in to give e more clarity around work being undertaken
- 597: 3/8 - JW and CL meeting - added in to give e more clarity around work being undertaken
- 598: 3/8 - JW and CL meeting - added in to give more clarity around work being undertaken
- 599: 3/8 - JW and CL meeting - added in to give more clarity around work being undertaken
- 600: 3/8 - JW and CL meeting - added in to give more clarity around work being undertaken
- 601: 3/8 - JW and CL meeting - added in to give more clarity around work being undertaken
- 602: 3/8 - JW and CL meeting - added in to give more clarity around work being undertaken
- 603: Approved at TMAG on 20/9. 26/9 - RP - Red because we have changed the approach to SFTP onboarding to be phased by interval. To go to TMAG for date change approval. Approved for date change at TMAG on 23/10/23
- 604: 3/8 - JW and CL meeting - added in to give more clarity around work being undertaken
- 605: 3/8 - JW and CL meeting - added in to give more clarity around work being undertaken
- 606: 3/8 - JW and CL meeting - added in to give more clarity around work being undertaken
- 607: 3/8 - JW and CL meeting - added in to give more clarity around work being undertaken
- 608: 3/8 - JW and CL meeting - added in to give more clarity around work being undertaken
- 609: 3/8 - JW and CL meeting - added in to give more clarity around work being undertaken
- 610: 3/8 - JW and CL meeting - added in to give more clarity around work being undertaken
- 611: 28/11- Red because of slow start to CIT Interval 3, doc timelines may need to be extended. Currently no impact on final doc. Aim to update the doc incrementally
- 612: 3/8 - JW and CL meeting - added in to give more clarity around work being undertaken
- 613: 3/8 - JW and CL meeting - added in to give more clarity around work being undertaken
- 614: 3/8 - JW and CL meeting - added in to give more clarity around work being undertaken
- 615: 28/11- Red because of slow start to CIT Interval 3, doc timelines may need to be extended. Currently no impact on final doc. Aim to update the doc incrementally
- 616: 3/8 - JW and CL meeting - added in to give more clarity around work being undertaken
- 617: 3/8 - JW and CL meeting - added in to give more clarity around work being undertaken
- 618: 3/8 - JW and CL meeting - added in to give more clarity around work being undertaken
- 619: 15/8 - JW and CL meeting - added in to give more clarity around work being undertaken. 12/12 - Red because we needed to provide the SRO 5 more working days to review. No impact. No action

| ID | WBS | Task | Type | Duration | Start | Finish | Predecessors | Complete | Baseline start | Baseline finish | Baseline duration | Baseline 1 start | Baseline 1 finish | Constraint | Resources | Work | Actual work | Baseline cost | Responsible | Involved | Update Version | MHHS Programme Phase | Sched Status | RAG | Artefact ID | Milestone ID | Text29 | Tier |
| --- | --- | --- | --- | --- | --- | --- | --- | --- | --- | --- | --- | --- | --- | --- | --- | --- | --- | --- | --- | --- | --- | --- | --- | --- | --- | --- | --- | --- |
| 620 | 1.4.1.7.1.5.8 | **Test Data (SIT A) Interval 1** |  | 40d | 2023-09-04 A | 2023-10-27 A |  | 100% | 2023-09-04 | 2023-09-29 | 20d | 2023-09-04 | 2023-09-29 |  | N/A | 472h | 472h |  | N/A | N/A | 5.0 | Systems Integration Testing (SIT) |  |  |  |  |  |  |
| 621 | 1.4.1.7.1.5.8.1 | Run data allocation |  | 4d | 2023-09-04 A | 2023-09-07 A | 548, 561, 550, 598 | 100% | 2023-09-04 | 2023-09-07 | 4d | 2023-09-04 | 2023-09-07 |  | Cesar Lopes | 32h | 32h |  | SI Test |  | 5.0 | Systems Integration Testing (SIT) | Complete | COMPLETE |  |  |  |  |
| 622 | 1.4.1.7.1.5.8.2 | Cleanse, anonymise and populate data post cut |  | 4d | 2023-09-08 A | 2023-09-13 A | 621 | 100% | 2023-09-08 | 2023-09-13 | 4d | 2023-09-08 | 2023-09-13 |  | Cesar Lopes | 32h | 32h |  | SI Test |  | 5.0 | Systems Integration Testing (SIT) | Complete | COMPLETE |  |  |  |  |
| 623 | 1.4.1.7.1.5.8.3 | Transmit data sets to PPs |  | 3d | 2023-09-15 A | 2023-09-19 A | 622, 535 | 100% | 2023-09-15 | 2023-09-15 | 1d | 2023-09-14 | 2023-09-15 |  | Cesar Lopes | 24h | 24h |  | SI Test |  | 5.0 | Systems Integration Testing (SIT) | Complete | COMPLETE |  |  |  |  |
| 624 | 1.4.1.7.1.5.8.4 | PP - Load test data to test environments |  | 7d | 2023-09-20 A | 2023-09-28 A | 623, 607 | 100% | 2023-09-18 | 2023-09-22 | 5d | 2023-09-18 | 2023-09-22 |  | Cesar Lopes | 56h | 56h |  | PP |  | 5.0 | Systems Integration Testing (SIT) | Complete | COMPLETE |  |  |  |  |
| 625 | 1.4.1.7.1.5.8.5 | PP Check data integrity on test environment |  | 1d | 2023-09-29 A | 2023-09-29 A | 624 | 100% | 2023-09-25 | 2023-09-29 | 5d | 2023-09-25 | 2023-09-29 |  | Cesar Lopes | 8h | 8h |  | PP |  | 5.0 | Systems Integration Testing (SIT) | Complete | COMPLETE |  |  |  |  |
| 626 | 1.4.1.7.1.5.8.6 | PP submit self-declaration to Programme to confirm loading & verification of test data | milestone | 0d | 2023-09-29 A | 2023-09-29 A | 625FF | 100% | 2023-09-29 | 2023-09-29 | 0d | 2023-09-29 | 2023-09-29 |  | Cesar Lopes |  |  |  | PP | SI Test | 5.0 | Systems Integration Testing (SIT) | Complete | COMPLETE |  |  |  |  |
| 627 | 1.4.1.7.1.5.8.7 | Test Data (SIT A) Interval 1 Complete | milestone | 0d | 2023-10-27 A | 2023-10-27 A | 626FS+20d | 100% | 2023-09-29 | 2023-09-29 | 0d |  |  |  | Cesar Lopes |  |  |  | SI Test | PP | 5.10 | Systems Integration Testing (SIT) | Complete | COMPLETE | MHHS-ART148/169 | T3-TE-0073 | SITAG | T3 |
| 628 | 1.4.1.7.1.5.9 | **Other Preparation** |  | 45d | 2023-07-03 A | 2023-09-01 A |  | 100% | 2023-07-03 | 2023-09-01 | 45d | 2023-07-03 | 2023-09-01 |  | N/A | 1080h | 1080h |  | N/A | N/A | 5.0 | Systems Integration Testing (SIT) |  |  |  |  |  |  |
| 629 | 1.4.1.7.1.5.9.1 | Onboarding of Test Participants to Test Management Tool (Azure DevOps) |  | 45d | 2023-07-03 A | 2023-09-01 A | 588SF | 100% | 2023-07-03 | 2023-09-01 | 45d | 2023-07-03 | 2023-09-01 |  | Lee Cox | 360h | 360h |  | SI Test | PP | 5.0 | Systems Integration Testing (SIT) | Complete | COMPLETE |  |  |  |  |
| 630 | 1.4.1.7.1.5.9.2 | Test Management Tool onboarding |  | 45d | 2023-07-03 A | 2023-09-01 A | 588SF | 100% | 2023-07-03 | 2023-09-01 | 45d | 2023-07-03 | 2023-09-01 |  | Lee Cox | 360h | 360h |  | PP | SI Test | 5.0 | Systems Integration Testing (SIT) | Complete | COMPLETE |  |  |  |  |
| 631 | 1.4.1.7.1.5.10 | **SIT Component Integration Test Readiness Report** |  | 28d | 2023-09-14 A | 2023-10-23 A |  | 100% | 2023-10-09 | 2023-10-20 | 9d | 2023-09-11 | 2023-10-20 |  | N/A | 448h | 448h |  | N/A | N/A | 5.6 | Systems Integration Testing (SIT) |  |  |  |  |  |  |
| 632 | 1.4.1.7.1.5.10.1 | PP submit Test Readiness Report to Programme for assurance | milestone | 0d | 2023-10-20 A | 2023-10-20 A | 630, 571, 627 | 100% | 2023-10-09 | 2023-10-09 | 0d | 2023-09-29 | 2023-09-29 | start no earlier than 2023-10-09 | Lee Cox |  |  |  | PP | SI Test | 5.6 | Systems Integration Testing (SIT) | Complete | COMPLETE |  |  |  |  |
| 633 | 1.4.1.7.1.5.10.2 | SI assure Test Participants' Test Readiness Reports |  | 1d | 2023-10-23 A | 2023-10-23 A | 632SS | 100% | 2023-10-10 | 2023-10-16 | 5d | 2023-10-02 | 2023-10-06 |  | Lee Cox | 8h | 8h |  | SI Test | PP,IPA | 5.6 | Systems Integration Testing (SIT) | Complete | COMPLETE |  |  |  |  |
| 634 | 1.4.1.7.1.5.10.3 | SI develop Overarching SIT Component Integration Test Readiness Report |  | 23d | 2023-09-14 A | 2023-10-16 A | 557FS+40d | 100% | 2023-10-10 | 2023-10-13 | 4d | 2023-09-11 | 2023-10-06 |  | Lee Cox | 184h | 184h |  | SI Test |  | 5.6 | Systems Integration Testing (SIT) | Complete | COMPLETE |  |  |  |  |
| 635 | 1.4.1.7.1.5.10.4 | Artefact review (via TMAG) and updates |  | 4d | 2023-10-17 A | 2023-10-20 A | 634 | 100% | 2023-10-16 | 2023-10-20 | 5d | 2023-10-09 | 2023-10-20 |  | Lee Cox | 32h | 32h |  | SI Test | PP,IPA | 5.6 | Systems Integration Testing (SIT) | Complete | COMPLETE |  |  |  |  |
| 636 | 1.4.1.7.1.5.11 | SIT Component Integration Testing 1 Preparation Complete (incl. approval of SI SIT Component Integration Test Readiness Report) | milestone | 0d | 2023-10-27 A | 2023-10-27 A | 635FS+1d, 632, 588, 630, 627, 198, 203, 192, 212, 213, 633 | 100% | 2023-10-23 | 2023-10-23 | 0d | 2023-10-23 | 2023-10-23 |  | Lee Cox |  |  |  | SI Test | PP,IPA | 5.11 | Systems Integration Testing (SIT) | Complete | COMPLETE | MHHS-ART071 | T2-TE-0250 | SITAG | T2 |
| 637 | 1.4.1.7.1.6 | **CIT Interval 2 Preparation** |  | 103d | 2023-07-03 A | 2023-11-22 A |  | 100% | 2023-07-03 | 2023-11-10 | 95d | 2022-11-16 | 2023-11-06 |  | N/A | 3752h | 3752h | -0 | N/A | N/A | 5.0 | Systems Integration Testing (SIT) |  |  |  |  |  |  |
| 638 | 1.4.1.7.1.6.1 | **Environments (SIT A)** |  | 43d | 2023-09-22 A | 2023-11-22 A |  | 100% | 2023-09-22 | 2023-11-10 | 35d | 2022-11-16 | 2023-10-27 |  | N/A | 552h | 552h | -0 | N/A | N/A | 5.0 | Systems Integration Testing (SIT) |  |  |  |  |  |  |
| 639 | 1.4.1.7.1.6.1.1 | SIT Participants' SIT A environments ready to start connectivity proving CIT Interval 2 | milestone | 0d | 2023-09-22 A | 2023-09-22 A |  | 100% | 2023-09-22 | 2023-09-22 | 0d | 2023-09-22 | 2023-09-22 |  | Simon Berry |  |  |  | PP | PP,IPA | 5.6 | Systems Integration Testing (SIT) | Complete | COMPLETE | MHHS-ART139 | T3-TE-0020 | SITAG | T3 |
| 640 | 1.4.1.7.1.6.1.2 | Programme Participants Ready to Start Connectivity Proving | milestone | 0d | 2023-09-22 A | 2023-09-22 A |  | 100% | 2023-09-22 | 2023-09-22 | 0d |  |  | finish no earlier than 2023-09-22 | Simon Berry |  |  |  | PP |  | 5.10 | Systems Integration Testing (SIT) | Complete | COMPLETE |  |  |  |  |
| 641 | 1.4.1.7.1.6.1.3 | Internal Connectivity Proving Phase |  | 10d | 2023-09-25 A | 2023-10-06 A | 640 | 100% | 2023-09-25 | 2023-10-06 | 10d |  |  |  | Simon Berry | 80h | 80h |  | PP |  | 5.10 | Systems Integration Testing (SIT) | Complete | COMPLETE |  |  |  |  |
| 642 | 1.4.1.7.1.6.1.4 | Internal Connectivity Proving Phase Complete | milestone | 0d | 2023-10-06 A | 2023-10-06 A | 641 | 100% | 2023-10-06 | 2023-10-06 | 0d |  |  | start no earlier than 2023-10-06 | Simon Berry |  |  |  | PP |  | 5.10 | Systems Integration Testing (SIT) | Complete | COMPLETE |  |  |  |  |
| 643 | 1.4.1.7.1.6.1.5 | DIP Onboarding Activity (1. PKI Officers and Certificates, 2. Set-up Validation, 3. End Point Creation, 4. Controlled Smoke Test ) |  | 28d | 2023-10-16 A | 2023-11-22 A | 642FS+5d | 100% | 2023-10-16 | 2023-11-10 | 20d |  |  |  | Simon Berry | 224h | 224h |  | PP |  | 5.10 | Systems Integration Testing (SIT) | Complete | COMPLETE |  |  |  |  |
| 644 | 1.4.1.7.1.6.1.6 | DIP Onboarding Complete | milestone | 0d | 2023-11-22 A | 2023-11-22 A | 643 | 100% | 2023-11-10 | 2023-11-10 | 0d |  |  |  | Simon Berry |  |  |  | PP |  | 5.10 | Systems Integration Testing (SIT) | Complete | COMPLETE |  |  |  |  |
| 645 | 1.4.1.7.1.6.1.7 | PPs Register PKI Officers and request PKI certificates Complete - Interval 2 | milestone | 0d | 2023-11-22 A | 2023-11-22 A | 644 | 100% | 2023-10-20 | 2023-10-20 | 0d |  |  |  | Simon Berry |  |  |  | PP | DIP Provider | 5.15 | Systems Integration Testing (SIT) | Complete | COMPLETE |  | T3-TE-0098 | SITAG | T3 |
| 646 | 1.4.1.7.1.6.1.8 | PP Code Deployment | milestone | 0d | 2023-10-20 A | 2023-10-20 A |  | 100% | 2023-10-20 | 2023-10-20 | 0d |  |  | start no earlier than 2023-10-20 | Simon Berry |  |  |  | PP |  | 5.10 | Systems Integration Testing (SIT) | Complete | COMPLETE |  |  |  |  |

Notes:
- 627: 28/7: CH: added in to be aT3 milestone. 10/10 - RP - Red because Avanade plan to load Test Data on week commencing 23/10, this is the earliest it can be planned due to latest code being required (M9 dependant) / Action: 28/7: CH: Needs to be set-up as a reporting milestone. 31/7: Check with Cesar if has been approved so can be baselined
- 631: Action: 21/8 - Rework with Lee
- 632: 18/8 - dates changed to reflect PIT Execution date changes advised by RG
- 633: 18/8 - dates changed to reflect PIT Execution date changes advised by RG / Action: 21/8 - Rework with Lee
- 634: 18/8 - dates changed to reflect PIT Execution date changes advised by RG / Action: 21/8 - Rework with Lee
- 635: 18/8 - dates changed to reflect PIT Execution date changes advised by RG / Action: 21/8 - Rework with Lee
- 636: Red because prep now dependant on an ageed work-off plan.
- 645: 5/12- Red because only 1 PP has successfully registered their PKI Officers; received their PKI certificates; set-up validation compete; end point creation complete; and completed controlled smoke test. The other PP is currently in Step 4 of E2E onboarding

| ID | WBS | Task | Type | Duration | Start | Finish | Predecessors | Complete | Baseline start | Baseline finish | Baseline duration | Baseline 1 start | Baseline 1 finish | Constraint | Resources | Work | Actual work | Baseline cost | Responsible | Involved | Update Version | MHHS Programme Phase | Sched Status | RAG | Artefact ID | Milestone ID | Text29 | Tier |
| --- | --- | --- | --- | --- | --- | --- | --- | --- | --- | --- | --- | --- | --- | --- | --- | --- | --- | --- | --- | --- | --- | --- | --- | --- | --- | --- | --- | --- |
| 647 | 1.4.1.7.1.6.2 | **Test Data (SIT A) Interval 2** |  | 43d | 2023-09-20 A | 2023-11-17 A |  | 100% | 2023-09-18 | 2023-10-20 | 25d | 2023-09-18 | 2023-10-20 |  | N/A | 808h | 808h |  | N/A | N/A | 5.0 | Systems Integration Testing (SIT) |  |  |  |  |  |  |
| 648 | 1.4.1.7.1.6.2.1 | Run data allocation |  | 7d | 2023-09-20 A | 2023-09-28 A | 624SS | 100% | 2023-09-18 | 2023-09-22 | 5d | 2023-09-18 | 2023-09-22 |  | Cesar Lopes | 56h | 56h |  | SI Test |  | 5.0 | Systems Integration Testing (SIT) | Complete | COMPLETE |  |  |  |  |
| 649 | 1.4.1.7.1.6.2.2 | Cleanse and populate data post cut |  | 2d | 2023-09-29 A | 2023-10-02 A | 648 | 100% | 2023-09-25 | 2023-09-29 | 5d | 2023-09-25 | 2023-09-29 |  | Cesar Lopes | 16h | 16h |  | SI Test |  | 5.0 | Systems Integration Testing (SIT) | Complete | COMPLETE |  |  |  |  |
| 650 | 1.4.1.7.1.6.2.3 | Transmit data sets to PPs |  | 1d | 2023-10-03 A | 2023-10-03 A | 649 | 100% | 2023-10-02 | 2023-10-03 | 2d | 2023-10-02 | 2023-10-03 |  | Cesar Lopes | 8h | 8h |  | SI Test |  | 5.0 | Systems Integration Testing (SIT) | Complete | COMPLETE |  |  |  |  |
| 651 | 1.4.1.7.1.6.2.4 | PP - Load test data to test environments |  | 33d | 2023-10-04 A | 2023-11-17 A | 650 | 100% | 2023-10-04 | 2023-10-13 | 8d | 2023-10-04 | 2023-10-13 |  | Cesar Lopes | 264h | 264h |  | PP |  | 5.0 | Systems Integration Testing (SIT) | Complete | COMPLETE |  |  |  |  |
| 652 | 1.4.1.7.1.6.2.5 | PP Check data integrity on test environment |  | 15d | 2023-10-23 A | 2023-11-17 A | 651FF | 100% | 2023-10-16 | 2023-10-20 | 5d | 2023-10-16 | 2023-10-20 |  | Cesar Lopes | 120h | 120h |  | PP |  | 5.0 | Systems Integration Testing (SIT) | Complete | COMPLETE |  |  |  |  |
| 653 | 1.4.1.7.1.6.2.6 | PP submit self-declaration to Programme to confirm loading & verification of test data | milestone | 0d | 2023-11-17 A | 2023-11-17 A | 652FF | 100% | 2023-10-20 | 2023-10-20 | 0d | 2023-10-20 | 2023-10-20 |  | Cesar Lopes |  |  |  | PP | SI Test | 5.0 | Systems Integration Testing (SIT) | Complete | COMPLETE |  |  |  |  |
| 654 | 1.4.1.7.1.6.2.7 | Test Data (SIT A) Interval 2 Complete | milestone | 0d | 2023-11-17 A | 2023-11-17 A | 653 | 100% | 2023-10-20 | 2023-10-20 | 0d |  |  |  | Cesar Lopes |  |  |  | SI Test | PP | 5.12 | Systems Integration Testing (SIT) | Complete | COMPLETE | MHHS-ART148/169 | T3-TE-0074 | SITAG | T3 |
| 655 | 1.4.1.7.1.6.3 | **Other Preparation** |  | 87d | 2023-07-03 A | 2023-10-31 A |  | 100% | 2023-07-03 | 2023-10-31 | 87d | 2023-07-03 | 2023-09-22 |  | N/A | 1392h | 1392h | -0 | N/A | N/A | 5.0 | Systems Integration Testing (SIT) |  |  |  |  |  |  |
| 656 | 1.4.1.7.1.6.3.1 | Onboarding of Test Participants to Test Management Tool (Azure DevOps) |  | 60d | 2023-07-03 A | 2023-09-22 A | 639SF | 100% | 2023-07-03 | 2023-09-22 | 60d | 2023-07-03 | 2023-09-22 |  | Lee Cox | 480h | 480h |  | SI Test | PP | 5.0 | Systems Integration Testing (SIT) | Complete | COMPLETE |  |  |  |  |
| 657 | 1.4.1.7.1.6.3.2 | Test Management Tool onboarding |  | 27d | 2023-09-25 A | 2023-10-31 A | 656 | 100% | 2023-09-25 | 2023-10-31 | 27d | 2023-07-03 | 2023-09-22 |  | Simon Berry | 216h | 216h |  | PP | SI Test | 5.0 | Systems Integration Testing (SIT) | Complete | COMPLETE |  |  |  |  |
| 658 | 1.4.1.7.1.6.4 | **SIT Component Integration Test Readiness Report** |  | 25d | 2023-10-02 A | 2023-11-03 A |  | 100% | 2023-10-02 | 2023-11-03 | 25d | 2023-10-02 | 2023-11-03 |  | N/A | 272h | 272h |  | N/A | N/A | 5.0 | Systems Integration Testing (SIT) |  |  |  |  |  |  |
| 659 | 1.4.1.7.1.6.4.1 | PP submit Test Readiness Report to Programme for assurance | milestone | 0d | 2023-10-25 A | 2023-10-25 A | 571FS+18d | 100% | 2023-10-20 | 2023-10-20 | 0d | 2023-10-20 | 2023-10-20 |  | Lee Cox |  |  |  | PP | SI Test | 5.0 | Systems Integration Testing (SIT) | Complete | COMPLETE |  |  |  |  |
| 660 | 1.4.1.7.1.6.4.2 | SI assure Test Participants' Test Readiness Reports |  | 2d | 2023-10-26 A | 2023-10-27 A | 659 | 100% | 2023-10-23 | 2023-10-27 | 5d | 2023-10-23 | 2023-10-27 |  | Lee Cox | 16h | 16h |  | SI Test | PP,IPA | 5.0 | Systems Integration Testing (SIT) | Complete | COMPLETE |  |  |  |  |
| 661 | 1.4.1.7.1.6.4.3 | SI develop Overarching SIT Component Integration Test Readiness Report |  | 20d | 2023-10-02 A | 2023-10-27 A | 660FF | 100% | 2023-10-02 | 2023-10-27 | 20d | 2023-10-02 | 2023-10-27 |  | Lee Cox | 160h | 160h |  | SI Test |  | 5.0 | Systems Integration Testing (SIT) | Complete | COMPLETE |  |  |  |  |
| 662 | 1.4.1.7.1.6.4.4 | Artefact review (via TMAG) and updates |  | 5d | 2023-10-30 A | 2023-11-03 A | 661 | 100% | 2023-10-30 | 2023-11-03 | 5d | 2023-10-30 | 2023-11-03 |  | Lee Cox | 40h | 40h |  | SI Test | PP,IPA | 5.0 | Systems Integration Testing (SIT) | Complete | COMPLETE |  |  |  |  |
| 663 | 1.4.1.7.1.6.5 | SIT Component Integration Testing 2 Preparation Complete (incl. approval of SI SIT Component Integration Test Readiness Report) | milestone | 0d | 2023-11-06 A | 2023-11-06 A | 657, 662FS+1d, 639, 261 | 100% | 2023-11-06 | 2023-11-06 | 0d | 2023-11-06 | 2023-11-06 |  | Lee Cox |  |  |  | SI Test | PP,IPA | 5.11 | Systems Integration Testing (SIT) | Complete | COMPLETE | MHHS-ART071 | T2-TE-0300 | SITAG | T2 |
| 664 | 1.4.1.7.1.7 | **CIT Interval 3 Preparation** |  | 54d | 2023-10-03 A | 2023-12-15 A |  | 100% | 2023-07-17 | 2023-11-20 | 91d | 2022-11-16 | 2023-11-20 |  | N/A | 2984h | 2984h | -0 | N/A | N/A | 5.0 | Systems Integration Testing (SIT) |  |  |  |  |  |  |
| 665 | 1.4.1.7.1.7.1 | **PIT Test Completion Report (incl. evidence)** |  | 26d | 2023-10-13 A | 2023-11-17 A |  | 100% | 2023-10-13 | 2023-11-10 | 21d | 2023-10-13 | 2023-11-10 |  | N/A | 416h | 416h |  | N/A | N/A | 5.0 | Systems Integration Testing (SIT) |  |  |  |  |  |  |
| 666 | 1.4.1.7.1.7.1.1 | Submit draft PIT Test Completion Report (incl. evidence) and submit to Programme for assurance |  | 11d | 2023-10-13 A | 2023-10-27 A |  | 100% | 2023-10-13 | 2023-10-13 | 1d | 2023-10-13 | 2023-10-13 | must start on 2023-10-13 | Lee Cox | 88h | 88h |  | PP | SI Test | 5.0 | Systems Integration Testing (SIT) | Complete | COMPLETE |  |  |  |  |
| 667 | 1.4.1.7.1.7.1.2 | Finalise PIT Test Completion Report (incl. evidence) |  | 5d | 2023-10-30 A | 2023-11-03 A | 666 | 100% | 2023-10-16 | 2023-11-03 | 15d | 2023-10-16 | 2023-11-03 |  | Lee Cox | 40h | 40h |  | PP | SI Test | 5.0 | Systems Integration Testing (SIT) | Complete | COMPLETE |  |  |  |  |
| 668 | 1.4.1.7.1.7.1.3 | PP PIT Completion Report (excl. Migration/Reverse Migration) submitted to Programme for assurance CIT Interval 3 | milestone | 0d | 2023-11-03 A | 2023-11-03 A | 667, 80, 96 | 100% | 2023-11-03 | 2023-11-03 | 0d | 2023-11-03 | 2023-11-03 |  | Lee Cox |  |  |  | PP | SI Test | 5.11 | Systems Integration Testing (SIT) | Complete | COMPLETE |  | T3-DB-0017 | SITAG | T3 |
| 669 | 1.4.1.7.1.7.1.4 | PP Final PIT Completion Reports assured by SI |  | 10d | 2023-11-06 A | 2023-11-17 A | 668 | 100% | 2023-11-06 | 2023-11-10 | 5d | 2023-11-06 | 2023-11-10 |  | Lee Cox | 80h | 80h |  | SI Test | PP | 5.0 | Systems Integration Testing (SIT) | Complete | COMPLETE |  |  |  |  |
| 670 | 1.4.1.7.1.7.2 | **Environments (SIT A)** |  | 51d | 2023-10-06 A | 2023-12-15 A |  | 100% | 2023-10-06 | 2023-11-10 | 26d | 2022-11-16 | 2023-11-10 |  | N/A | 672h | 672h | -0 | N/A | N/A | 5.0 | Systems Integration Testing (SIT) |  |  |  |  |  |  |
| 671 | 1.4.1.7.1.7.2.1 | Programme Participants Ready to Start Connectivity Proving | milestone | 0d | 2023-10-06 A | 2023-10-06 A |  | 100% | 2023-10-06 | 2023-10-06 | 0d |  |  | start no earlier than 2023-10-06 | Simon Berry |  |  |  | PP | PP.SI Test | 5.10 | Systems Integration Testing (SIT) | Complete | COMPLETE |  |  |  |  |
| 672 | 1.4.1.7.1.7.2.2 | SIT Participants' SIT A environments ready to start connectivity proving CIT Interval 3 | milestone | 0d | 2023-10-06 A | 2023-10-06 A | 671 | 100% | 2023-10-06 | 2023-10-06 | 0d | 2023-10-06 | 2023-10-06 |  | Simon Berry |  |  |  | PP | PP,SI Test | 5.10 | Systems Integration Testing (SIT) | Complete | COMPLETE | MHHS-ART139 | T3-TE-0021 | SITAG | T3 |
| 673 | 1.4.1.7.1.7.2.3 | Internal Connectivity Proving Phase |  | 10d | 2023-10-09 A | 2023-10-20 A | 671FS+1d | 100% | 2023-10-09 | 2023-10-20 | 10d |  |  |  | Simon Berry | 80h | 80h |  | PP | PP,SI Test | 5.10 | Systems Integration Testing (SIT) | Complete | COMPLETE |  |  |  |  |
| 674 | 1.4.1.7.1.7.2.4 | Internal Connectivity Proving Phase Complete | milestone | 0d | 2023-10-20 A | 2023-10-20 A | 673 | 100% | 2023-10-20 | 2023-10-20 | 0d |  |  |  | Simon Berry |  |  |  | PP | PP,SI Test | 5.10 | Systems Integration Testing (SIT) | Complete | COMPLETE |  |  |  |  |
| 675 | 1.4.1.7.1.7.2.5 | DIP Onboarding Activity (1. PKI Officers and Certificates, 2. Set-up Validation, 3. End Point Creation, 4. Controlled Smoke Test ) |  | 35d | 2023-10-30 A | 2023-12-15 A | 674FS+5d | 100% | 2023-10-30 | 2023-11-10 | 10d |  |  |  | Simon Berry | 280h | 280h |  | PP | PP,DIP Provider | 5.10 | Systems Integration Testing (SIT) | Complete | COMPLETE |  |  |  |  |
| 676 | 1.4.1.7.1.7.2.6 | DIP Onboarding Complete | milestone | 0d | 2023-12-15 A | 2023-12-15 A | 675 | 100% | 2023-11-10 | 2023-11-10 | 0d |  |  |  | Simon Berry |  |  |  | PP | PP,DIP Provider | 5.10 | Systems Integration Testing (SIT) | Complete | COMPLETE |  |  |  |  |
| 677 | 1.4.1.7.1.7.2.7 | PPs Register PKI Officers and Request PKI certificates Complete - Interval 3 | milestone | 0d | 2023-12-15 A | 2023-12-15 A | 676FF | 100% | 2023-11-10 | 2023-11-10 | 0d | 2023-10-02 | 2023-10-06 |  | Simon Berry |  |  |  | PP | PP,DIP Provider | 5.13 | Systems Integration Testing (SIT) | Complete | COMPLETE |  | T3-TE-0099 | SITAG | T3 |
| 678 | 1.4.1.7.1.7.2.8 | PP Code Deployment | milestone | 0d | 2023-11-10 A | 2023-11-10 A | 674FS+15d | 100% | 2023-11-10 | 2023-11-10 | 0d |  |  | start no earlier than 2023-10-20 | Simon Berry |  |  |  | PP | PP | 5.10 | Systems Integration Testing (SIT) | Complete | COMPLETE |  |  |  |  |

Notes:
- 654: 28/7: CH: added in to be aT3 milestone. 15/11 - Red because of Data Customisation requirement for St. Clements and additional DIP message requirement. Impact is CIT able to start on selected MPANS remaining MPANS to be fixed by 16/11 / Action: 28/7: CH: Needs to be set-up as a reporting milestone. 31/7: Check with Cesar if has been approved so can be baselined
- 663: Amber because of dependency on PPs PIT and known reduced window to review and prepare documentation. No impact currently known. No action. 7/11 - Approved at TMAG on 6/11 with work-off
- 672: Action: 30/8 - lee said date is 30/10
- 677: 09/01 - 1 particpant yet to complete onboarding. Anticipated resolution unknown

| ID | WBS | Task | Type | Duration | Start | Finish | Predecessors | Complete | Remaining | Baseline start | Baseline finish | Baseline duration | Baseline 1 start | Baseline 1 finish | Total slack | Constraint | Resources | Work | Actual work | Baseline cost | Responsible | Involved | Update Version | MHHS Programme Phase | Sched Status | RAG | Artefact ID | Milestone ID | Text29 | Tier |
| --- | --- | --- | --- | --- | --- | --- | --- | --- | --- | --- | --- | --- | --- | --- | --- | --- | --- | --- | --- | --- | --- | --- | --- | --- | --- | --- | --- | --- | --- | --- |
| 679 | 1.4.1.7.1.7.3 | **Test Data (SIT A) Interval 3** |  | 34d | 2023-10-03 A | 2023-11-17 A |  | 100% |  | 2023-10-02 | 2023-11-03 | 25d | 2023-10-02 | 2023-11-03 |  |  | N/A | 544h | 544h |  | N/A | N/A | 5.0 | Systems Integration Testing (SIT) |  |  |  |  |  |  |
| 680 | 1.4.1.7.1.7.3.1 | Run data allocation |  | 4d | 2023-10-03 A | 2023-10-06 A | 650SS | 100% |  | 2023-10-02 | 2023-10-06 | 5d | 2023-10-02 | 2023-10-06 |  |  | Cesar Lopes | 32h | 32h |  | SI Test |  | 5.0 | Systems Integration Testing (SIT) | Complete | COMPLETE |  |  |  |  |
| 681 | 1.4.1.7.1.7.3.2 | Cleanse and populate data post cut |  | 5d | 2023-10-09 A | 2023-10-13 A | 680 | 100% |  | 2023-10-09 | 2023-10-13 | 5d | 2023-10-09 | 2023-10-13 |  |  | Cesar Lopes | 40h | 40h |  | SI Test |  | 5.0 | Systems Integration Testing (SIT) | Complete | COMPLETE |  |  |  |  |
| 682 | 1.4.1.7.1.7.3.3 | Transmit data sets to PPs |  | 2d | 2023-10-16 A | 2023-10-17 A | 681 | 100% |  | 2023-10-16 | 2023-10-17 | 2d | 2023-10-16 | 2023-10-17 |  |  | Cesar Lopes | 16h | 16h |  | SI Test |  | 5.0 | Systems Integration Testing (SIT) | Complete | COMPLETE |  |  |  |  |
| 683 | 1.4.1.7.1.7.3.4 | PP - Load test data to test environments |  | 8d | 2023-10-18 A | 2023-10-27 A | 682 | 100% |  | 2023-10-18 | 2023-10-27 | 8d | 2023-10-18 | 2023-10-27 |  |  | Cesar Lopes | 64h | 64h |  | PP |  | 5.0 | Systems Integration Testing (SIT) | Complete | COMPLETE |  |  |  |  |
| 684 | 1.4.1.7.1.7.3.5 | PP Check data integrity on test environment |  | 15d | 2023-10-30 A | 2023-11-17 A | 683 | 100% |  | 2023-10-30 | 2023-11-03 | 5d | 2023-10-30 | 2023-11-03 |  |  | Cesar Lopes | 120h | 120h |  | PP |  | 5.0 | Systems Integration Testing (SIT) | Complete | COMPLETE |  |  |  |  |
| 685 | 1.4.1.7.1.7.3.6 | PP submit self-declaration to Programme to confirm loading & verification of test data | milestone | 0d | 2023-11-17 A | 2023-11-17 A | 684FF | 100% |  | 2023-11-03 | 2023-11-03 | 0d | 2023-11-03 | 2023-11-03 |  |  | Cesar Lopes |  |  |  | PP | SI Test | 5.0 | Systems Integration Testing (SIT) | Complete | COMPLETE |  |  |  |  |
| 686 | 1.4.1.7.1.7.3.7 | Test Data (SIT A) Interval 3 Complete | milestone | 0d | 2023-11-17 A | 2023-11-17 A | 685 | 100% |  | 2023-11-03 | 2023-11-03 | 0d |  |  |  |  | Cesar Lopes |  |  |  | SI Test | PP | 5.13 | Systems Integration Testing (SIT) | Complete | COMPLETE | MHHS-ART148/169 | T3-TE-0075 | SITAG | T3 |
| 687 | 1.4.1.7.1.7.4 | **Other Preparation** |  | 25d | 2023-10-16 A | 2023-11-17 A |  | 100% |  | 2023-07-17 | 2023-10-06 | 60d | 2023-07-17 | 2023-10-06 |  |  | N/A | 600h | 600h |  | N/A | N/A | 5.0 | Systems Integration Testing (SIT) |  |  |  |  |  |  |
| 688 | 1.4.1.7.1.7.4.1 | Onboarding of Test Participants to Test Management Tool (Azure DevOps) |  | 25d | 2023-10-16 A | 2023-11-17 A |  | 100% |  | 2023-07-17 | 2023-10-06 | 60d | 2023-07-17 | 2023-10-06 |  | start no earlier than 2023-10-16 | Simon Berry | 200h | 200h |  | SI Test | PP | 5.0 | Systems Integration Testing (SIT) | Complete | COMPLETE |  |  |  |  |
| 689 | 1.4.1.7.1.7.4.2 | Test Management Tool onboarding |  | 25d | 2023-10-16 A | 2023-11-17 A |  | 100% |  | 2023-07-17 | 2023-10-06 | 60d | 2023-07-17 | 2023-10-06 |  | start no earlier than 2023-10-16 | Simon Berry | 200h | 200h |  | PP | SI Test | 5.0 | Systems Integration Testing (SIT) | Complete | COMPLETE |  |  |  |  |
| 690 | 1.4.1.7.1.7.5 | **SIT Component Integration Test Readiness Report** |  | 25d | 2023-10-16 A | 2023-11-17 A |  | 100% |  | 2023-10-16 | 2023-11-17 | 25d | 2023-10-16 | 2023-11-17 |  |  | N/A | 440h | 440h |  | N/A | N/A | 5.0 | Systems Integration Testing (SIT) |  |  |  |  |  |  |
| 691 | 1.4.1.7.1.7.5.1 | PP submit Test Readiness Report to Programme for assurance | milestone | 0d | 2023-11-03 A | 2023-11-03 A | 575 | 100% |  | 2023-11-03 | 2023-11-03 | 0d | 2023-11-03 | 2023-11-03 |  |  | Lee Cox |  |  |  | PP | SI Test | 5.0 | Systems Integration Testing (SIT) | Complete | COMPLETE |  |  |  |  |
| 692 | 1.4.1.7.1.7.5.2 | SI assure Test Participants' Test Readiness Reports |  | 5d | 2023-11-06 A | 2023-11-10 A | 691FF+5d | 100% |  | 2023-11-06 | 2023-11-10 | 5d | 2023-11-06 | 2023-11-10 |  |  | Lee Cox | 40h | 40h |  | SI Test | PP,IPA | 5.0 | Systems Integration Testing (SIT) | Complete | COMPLETE |  |  |  |  |
| 693 | 1.4.1.7.1.7.5.3 | SI develop Overarching SIT Component Integration Test Readiness Report |  | 20d | 2023-10-16 A | 2023-11-10 A | 692FF | 100% |  | 2023-10-16 | 2023-11-10 | 20d | 2023-10-16 | 2023-11-10 |  |  | Lee Cox | 160h | 160h |  | SI Test |  | 5.0 | Systems Integration Testing (SIT) | Complete | COMPLETE |  |  |  |  |
| 694 | 1.4.1.7.1.7.5.4 | Artefact review (via TMAG) and updates |  | 5d | 2023-11-13 A | 2023-11-17 A | 693 | 100% |  | 2023-11-13 | 2023-11-17 | 5d | 2023-11-13 | 2023-11-17 |  |  | Lee Cox | 40h | 40h |  | SI Test | PP,IPA | 5.0 | Systems Integration Testing (SIT) | Complete | COMPLETE |  |  |  |  |
| 695 | 1.4.1.7.1.7.6 | SIT Component Integration Testing 3 Preparation Complete (incl. approval of SI SIT Component Integration Test Readiness Report) | milestone | 0d | 2023-11-20 A | 2023-11-20 A | 694FS+1d, 668, 672, 691, 689, 686, 279 | 100% |  | 2023-11-20 | 2023-11-20 | 0d | 2023-11-20 | 2023-11-20 |  |  | Lee Cox |  |  |  | SI Test | PP,IPA | 5.12 | Systems Integration Testing (SIT) | Complete | COMPLETE | MHHS-ART071 | T2-TE-0350 | SITAG | T2 |
| 696 | 1.4.1.7.1.8 | **CIT Interval 4 Preparation** |  | 36d | 2023-10-16 A | 2023-12-04 |  | 95% | 1.65d | 2023-10-16 | 2023-12-04 | 36d | 2022-11-16 | 2023-12-04 | 909d |  | N/A | 2304h | 2149.41h | -0 | N/A | N/A | 5.0 | Systems Integration Testing (SIT) |  |  |  |  |  |  |
| 697 | 1.4.1.7.1.8.1 | **PIT Test Completion Report (incl. evidence)** |  | 21d | 2023-10-27 A | 2023-11-24 A |  | 100% |  | 2023-10-27 | 2023-11-24 | 21d | 2023-10-27 | 2023-11-24 |  |  | N/A | 336h | 336h |  | N/A | N/A | 5.0 | Systems Integration Testing (SIT) |  |  |  |  |  |  |
| 698 | 1.4.1.7.1.8.1.1 | Submit draft PIT Test Completion Report (incl. evidence) and submit to Programme for assurance |  | 1d | 2023-10-27 A | 2023-10-27 A |  | 100% |  | 2023-10-27 | 2023-10-27 | 1d | 2023-10-27 | 2023-10-27 |  | must start on 2023-10-27 | Lee Cox | 8h | 8h |  | PP | SI Test | 5.0 | Systems Integration Testing (SIT) | Complete | COMPLETE |  |  |  |  |
| 699 | 1.4.1.7.1.8.1.2 | Finalise PIT Test Completion Report (incl. evidence) |  | 15d | 2023-10-30 A | 2023-11-17 A | 698 | 100% |  | 2023-10-30 | 2023-11-17 | 15d | 2023-10-30 | 2023-11-17 |  |  | Lee Cox | 120h | 120h |  | PP | SI Test | 5.0 | Systems Integration Testing (SIT) | Complete | COMPLETE |  |  |  |  |
| 700 | 1.4.1.7.1.8.1.3 | PP PIT Completion Report (excl. Migration/Reverse Migration) submitted to Programme for assurance CIT Interval 4 | milestone | 0d | 2023-11-17 A | 2023-11-17 A | 699, 80, 96 | 100% |  | 2023-11-17 | 2023-11-17 | 0d | 2023-11-17 | 2023-11-17 |  |  | Lee Cox |  |  |  | PP | SI Test | 5.13 | Systems Integration Testing (SIT) | Complete | COMPLETE |  | T3-DB-0019 | SITAG | T3 |
| 701 | 1.4.1.7.1.8.1.4 | PP Final PIT Completion Reports assured by SI |  | 5d | 2023-11-20 A | 2023-11-24 A | 700 | 100% |  | 2023-11-20 | 2023-11-24 | 5d | 2023-11-20 | 2023-11-24 |  |  | Lee Cox | 40h | 40h |  | SI Test | PP | 5.0 | Systems Integration Testing (SIT) | Complete | COMPLETE |  |  |  |  |
| 702 | 1.4.1.7.1.8.2 | **Environments (SIT A)** |  | 25d | 2023-10-23 A | 2023-11-24 A |  | 100% |  | 2023-10-20 | 2023-11-24 | 25d | 2022-11-16 | 2023-11-24 |  |  | N/A | 264h | 264h | -0 | N/A | N/A | 5.0 | Systems Integration Testing (SIT) |  |  |  |  |  |  |
| 703 | 1.4.1.7.1.8.2.1 | Programme Participants Ready to Start Connectivity Proving | milestone | 0d | 2023-10-23 A | 2023-10-23 A |  | 100% |  | 2023-10-23 | 2023-10-23 | 0d |  |  |  | start no earlier than 2023-10-23 | Simon Berry |  |  |  | PP |  | 5.10 | Systems Integration Testing (SIT) | Complete | COMPLETE |  |  |  |  |
| 704 | 1.4.1.7.1.8.2.2 | SIT Participants' SIT A environments ready to start connectivity proving CIT Interval 4 | milestone | 0d | 2023-10-23 A | 2023-10-23 A | 703 | 100% |  | 2023-10-20 | 2023-10-20 | 0d | 2023-10-20 | 2023-10-20 |  |  | Simon Berry |  |  |  | PP | PP,IPA | 5.10 | Systems Integration Testing (SIT) | Complete | COMPLETE | MHHS-ART139 | T3-TE-0022 | SITAG | T3 |
| 705 | 1.4.1.7.1.8.2.3 | Internal Connectivity Proving Phase |  | 10d | 2023-10-23 A | 2023-11-03 A | 704 | 100% |  | 2023-10-23 | 2023-11-03 | 10d |  |  |  |  | Simon Berry | 80h | 80h |  | PP |  | 5.10 | Systems Integration Testing (SIT) | Complete | COMPLETE |  |  |  |  |
| 706 | 1.4.1.7.1.8.2.4 | Internal Connectivity Proving Phase Complete | milestone | 0d | 2023-11-03 A | 2023-11-03 A | 705 | 100% |  | 2023-11-03 | 2023-11-03 | 0d |  |  |  |  | Simon Berry |  |  |  | PP |  | 5.10 | Systems Integration Testing (SIT) | Complete | COMPLETE |  |  |  |  |
| 707 | 1.4.1.7.1.8.2.5 | DIP Onboarding Activity (1. PKI Officers and Certificates, 2. Set-up Validation, 3. End Point Creation, 4. Controlled Smoke Test ) |  | 10d | 2023-11-13 A | 2023-11-24 A | 706FS+5d | 100% |  | 2023-11-13 | 2023-11-24 | 10d |  |  |  |  | Simon Berry | 80h | 80h |  | PP |  | 5.10 | Systems Integration Testing (SIT) | Complete | COMPLETE |  |  |  |  |
| 708 | 1.4.1.7.1.8.2.6 | DIP Onboarding Complete | milestone | 0d | 2023-11-24 A | 2023-11-24 A | 707 | 100% |  | 2023-11-24 | 2023-11-24 | 0d |  |  |  |  | Simon Berry |  |  |  | PP |  | 5.10 | Systems Integration Testing (SIT) | Complete | COMPLETE |  |  |  |  |
| 709 | 1.4.1.7.1.8.2.7 | PPs register PKI Officers and Request PKI Certificates Complete - Interval 4 | milestone | 0d | 2023-11-24 A | 2023-11-24 A | 708 | 100% |  | 2023-11-24 | 2023-11-24 | 0d |  |  |  |  | Simon Berry |  |  |  | PP | DIP Provider | 5.16 | Systems Integration Testing (SIT) | Complete | COMPLETE |  | T3-TE-0100 | SITAG | T3 |
| 710 | 1.4.1.7.1.8.2.8 | PP Code Deployment | milestone | 0d | 2023-11-17 A | 2023-11-17 A |  | 100% |  | 2023-11-17 | 2023-11-17 | 0d |  |  |  | start no earlier than 2023-11-17 | Simon Berry |  |  |  | PP |  | 5.10 | Systems Integration Testing (SIT) | Complete | COMPLETE |  |  |  |  |

Notes:
- 686: 28/7: CH: added in to be aT3 milestone. 14/11-Red because 8 out of 9 participants complete. Final data checks from PP to be made this week. No impact to CIT interval 3 start. / Action: 28/7: CH: Needs to be set-up as a reporting milestone. 31/7: Check with Cesar if has been approved so can be baselined
- 700: 21/11-Red because not all received. Reminders sent. No impact. No issue
- 709: 16/02 - Red because 2 participants yet to complete onboarding. Completed 19/1/24

| ID | WBS | Task | Type | Duration | Start | Finish | Predecessors | Complete | Remaining | Baseline start | Baseline finish | Baseline duration | Baseline 1 start | Baseline 1 finish | Total slack | Constraint | Resources | Work | Actual work | Baseline cost | Responsible | Involved | Update Version | MHHS Programme Phase | Sched Status | RAG | Artefact ID | Milestone ID | Text29 | Tier | Task Status |
| --- | --- | --- | --- | --- | --- | --- | --- | --- | --- | --- | --- | --- | --- | --- | --- | --- | --- | --- | --- | --- | --- | --- | --- | --- | --- | --- | --- | --- | --- | --- | --- |
| 711 | 1.4.1.7.1.8.3 | **Test Data (SIT A) Interval 4** |  | 30d | 2023-10-23 A | 2023-12-01 A |  | 100% |  | 2023-10-16 | 2023-11-17 | 25d | 2023-10-16 | 2023-11-17 |  |  | N/A | 480h | 480h |  | N/A | N/A | 5.0 | Systems Integration Testing (SIT) |  |  |  |  |  |  |  |
| 712 | 1.4.1.7.1.8.3.1 | Run data allocation |  | 5d | 2023-10-23 A | 2023-10-27 A | 681FS+5d | 100% |  | 2023-10-16 | 2023-10-20 | 5d | 2023-10-16 | 2023-10-20 |  |  | Cesar Lopes | 40h | 40h |  | SI Test |  | 5.0 | Systems Integration Testing (SIT) | Complete | COMPLETE |  |  |  |  |  |
| 713 | 1.4.1.7.1.8.3.2 | Cleanse and populate data post cut |  | 2d | 2023-10-30 A | 2023-10-31 A | 712 | 100% |  | 2023-10-23 | 2023-10-27 | 5d | 2023-10-23 | 2023-10-27 |  |  | Cesar Lopes | 16h | 16h |  | SI Test |  | 5.0 | Systems Integration Testing (SIT) | Complete | COMPLETE |  |  |  |  |  |
| 714 | 1.4.1.7.1.8.3.3 | Transmit data sets to PPs |  | 5d | 2023-11-01 A | 2023-11-07 A | 713 | 100% |  | 2023-10-30 | 2023-10-31 | 2d | 2023-10-30 | 2023-10-31 |  |  | Cesar Lopes | 40h | 40h |  | SI Test |  | 5.0 | Systems Integration Testing (SIT) | Complete | COMPLETE |  |  |  |  |  |
| 715 | 1.4.1.7.1.8.3.4 | PP - Load test data to test environments |  | 5d | 2023-11-08 A | 2023-11-14 A | 714 | 100% |  | 2023-11-01 | 2023-11-10 | 8d | 2023-11-01 | 2023-11-10 |  |  | Cesar Lopes | 40h | 40h |  | PP |  | 5.0 | Systems Integration Testing (SIT) | Complete | COMPLETE |  |  |  |  |  |
| 716 | 1.4.1.7.1.8.3.5 | PP Check data integrity on test environment |  | 13d | 2023-11-15 A | 2023-12-01 A | 715 | 100% |  | 2023-11-13 | 2023-11-17 | 5d | 2023-11-13 | 2023-11-17 |  |  | Richard Puddephatt | 104h | 104h |  | PP |  | 5.0 | Systems Integration Testing (SIT) | Complete | COMPLETE |  |  |  |  |  |
| 717 | 1.4.1.7.1.8.3.6 | PP submit self-declaration to Programme to confirm loading & verification of test data | milestone | 0d | 2023-12-01 A | 2023-12-01 A | 716FF | 100% |  | 2023-11-17 | 2023-11-17 | 0d | 2023-11-17 | 2023-11-17 |  |  | Richard Puddephatt |  |  |  | PP | SI Test | 5.0 | Systems Integration Testing (SIT) | Complete | COMPLETE |  |  |  |  |  |
| 718 | 1.4.1.7.1.8.3.7 | Test Data (SIT A) Interval 4 Complete | milestone | 0d | 2023-12-01 A | 2023-12-01 A | 717 | 100% |  | 2023-11-17 | 2023-11-17 | 0d |  |  |  |  | Richard Puddephatt |  |  |  | SI Test | PP | 5.13 | Systems Integration Testing (SIT) | Complete | COMPLETE | MHHS-ART148/169 | T3-TE-0076 | SITAG | T3 |  |
| 719 | 1.4.1.7.1.8.4 | **Other Preparation** |  | 25d | 2023-10-30 A | 2023-12-01 A |  | 100% |  | 2023-10-30 | 2023-12-01 | 25d | 2023-07-31 | 2023-10-20 |  |  | N/A | 600h | 600h | -0 | N/A | N/A | 5.0 | Systems Integration Testing (SIT) |  |  |  |  |  |  |  |
| 720 | 1.4.1.7.1.8.4.1 | Onboarding of Test Participants to Test Management Tool (Azure DevOps) |  | 25d | 2023-10-30 A | 2023-12-01 A |  | 100% |  | 2023-10-30 | 2023-12-01 | 25d | 2023-07-31 | 2023-10-20 |  | start no earlier than 2023-10-30 | Simon Berry | 200h | 200h |  | SI Test | PP | 5.0 | Systems Integration Testing (SIT) | Complete | COMPLETE |  |  |  |  |  |
| 721 | 1.4.1.7.1.8.4.2 | Test Management Tool onboarding |  | 25d | 2023-10-30 A | 2023-12-01 A |  | 100% |  | 2023-10-30 | 2023-12-01 | 25d | 2023-07-31 | 2023-10-20 |  | start no earlier than 2023-10-30 | Simon Berry | 200h | 200h |  | PP | SI Test | 5.0 | Systems Integration Testing (SIT) | Complete | COMPLETE |  |  |  |  |  |
| 722 | 1.4.1.7.1.8.5 | **SIT Component Integration Test Readiness Report** |  | 27d | 2023-10-16 A | 2023-11-21 |  | 78% | 5.91d | 2023-10-30 | 2023-12-01 | 25d | 2023-10-30 | 2023-12-01 | 918d |  | N/A | 472h | 368.75h |  | N/A | N/A | 5.0 | Systems Integration Testing (SIT) |  |  |  |  |  |  |  |
| 723 | 1.4.1.7.1.8.5.1 | PP submit Test Readiness Report to Programme for assurance | milestone | 0d | 2023-11-03 A | 2023-11-03 A | 575 | 100% |  | 2023-11-17 | 2023-11-17 | 0d | 2023-11-17 | 2023-11-17 |  |  | Lee Cox |  |  |  | PP | SI Test | 5.0 | Systems Integration Testing (SIT) | Complete | COMPLETE |  |  |  |  |  |
| 724 | 1.4.1.7.1.8.5.2 | SI assure Test Participants' Test Readiness Reports |  | 5d | 2023-11-06 A | 2023-11-10 A | 723FF+5d | 100% |  | 2023-11-20 | 2023-11-24 | 5d | 2023-11-20 | 2023-11-24 |  |  | Lee Cox | 40h | 40h |  | SI Test | PP,IPA | 5.0 | Systems Integration Testing (SIT) | Complete | COMPLETE |  |  |  |  |  |
| 725 | 1.4.1.7.1.8.5.3 | SI develop Overarching SIT Component Integration Test Readiness Report |  | 20d | 2023-10-16 A | 2023-11-10 A | 724FF | 100% |  | 2023-10-30 | 2023-11-24 | 20d | 2023-10-30 | 2023-11-24 |  |  | Lee Cox | 160h | 160h |  | SI Test |  | 5.0 | Systems Integration Testing (SIT) | Complete | COMPLETE |  |  |  |  |  |
| 726 | 1.4.1.7.1.8.5.4 | Artefact review (via SITAG) and updates |  | 7d | 2023-11-13 | 2023-11-21 | 725 |  |  | 2023-11-27 | 2023-12-01 | 5d | 2023-11-27 | 2023-12-01 | 918d |  | Lee Cox | 56h |  |  | SI Test | PP,IPA | 5.0 | Systems Integration Testing (SIT) | Overdue Start | RED |  |  |  |  | -156.67 |
| 727 | 1.4.1.7.1.8.6 | SIT Component Integration Testing 4 Preparation Complete (incl. approval of SI SIT Component Integration Test Readiness Report) | milestone | 0d | 2023-12-04 A | 2023-12-04 A | 726FS+2d, 700, 704, 723, 718, 296FS+1d | 100% |  | 2023-12-04 | 2023-12-04 | 0d | 2023-12-04 | 2023-12-04 |  |  | Lee Cox |  |  |  | SI Test | PP,IPA | 5.13 | Systems Integration Testing (SIT) | Complete | COMPLETE | MHHS-ART071 | T2-TE-0400 | SITAG | T2 |  |
| 728 | 1.4.1.7.1.9 | **CIT Interval 5 Preparation** |  | 53d | 2023-11-01 A | 2024-01-12 |  | 82% | 9.76d | 2023-10-30 | 2024-01-12 | 55d | 2022-11-16 | 2024-01-08 | 880d |  | N/A | 2624h | 2099h | -0 | N/A | N/A | 5.0 | Systems Integration Testing (SIT) |  |  |  |  |  |  |  |
| 729 | 1.4.1.7.1.9.1 | **PIT Test Completion Report (incl. evidence)** |  | 21d | 2023-11-17 A | 2023-12-15 A |  | 100% |  | 2023-11-17 | 2023-12-15 | 21d | 2023-11-17 | 2023-12-15 |  |  | N/A | 336h | 336h |  | N/A | N/A | 5.0 | Systems Integration Testing (SIT) |  |  |  |  |  |  |  |
| 730 | 1.4.1.7.1.9.1.1 | Submit draft PIT Test Completion Report (incl. evidence) and submit to Programme for assurance |  | 1d | 2023-11-17 A | 2023-11-17 A |  | 100% |  | 2023-11-17 | 2023-11-17 | 1d | 2023-11-17 | 2023-11-17 |  | must start on 2023-11-17 | Lee Cox | 8h | 8h |  | PP | SI Test | 5.0 | Systems Integration Testing (SIT) | Complete | COMPLETE |  |  |  |  |  |
| 731 | 1.4.1.7.1.9.1.2 | Finalise PIT Test Completion Report (incl. evidence) |  | 15d | 2023-11-20 A | 2023-12-08 A | 730 | 100% |  | 2023-11-20 | 2023-12-08 | 15d | 2023-11-20 | 2023-12-08 |  |  | Lee Cox | 120h | 120h |  | PP | SI Test | 5.0 | Systems Integration Testing (SIT) | Complete | COMPLETE |  |  |  |  |  |
| 732 | 1.4.1.7.1.9.1.3 | PP PIT Completion Report (excl. Migration/Reverse Migration) submitted to Programme for assurance CIT Interval 5 | milestone | 0d | 2023-12-08 A | 2023-12-08 A | 731, 80, 96 | 100% |  | 2023-12-08 | 2023-12-08 | 0d | 2023-12-08 | 2023-12-08 |  |  | Lee Cox |  |  |  | PP | SI Test | 5.14 | Systems Integration Testing (SIT) | Complete | COMPLETE |  | T3-DB-0021 | SITAG | T3 |  |
| 733 | 1.4.1.7.1.9.1.4 | PP Final PIT Completion Reports assured by SI |  | 5d | 2023-12-11 A | 2023-12-15 A | 732 | 100% |  | 2023-12-11 | 2023-12-15 | 5d | 2023-12-11 | 2023-12-15 |  |  | Lee Cox | 40h | 40h |  | SI Test | PP | 5.0 | Systems Integration Testing (SIT) | Complete | COMPLETE |  |  |  |  |  |
| 734 | 1.4.1.7.1.9.2 | **Environments (SIT A)** |  | 21d | 2023-11-10 A | 2023-12-08 A |  | 100% |  | 2023-11-10 | 2023-12-08 | 21d | 2022-11-16 | 2023-12-15 |  |  | N/A | 232h | 232h | -0 | N/A | N/A | 5.0 | Systems Integration Testing (SIT) |  |  |  |  |  |  |  |
| 735 | 1.4.1.7.1.9.2.1 | Programme Participants Ready to Start Connectivity Proving | milestone | 0d | 2023-11-10 A | 2023-11-10 A |  | 100% |  | 2023-11-10 | 2023-11-10 | 0d |  |  |  | start no earlier than 2023-11-10 | Simon Berry |  |  |  | PP |  | 5.10 | Systems Integration Testing (SIT) | Complete | COMPLETE |  |  |  |  |  |
| 736 | 1.4.1.7.1.9.2.2 | SIT Participants' SIT A environments ready to start connectivity proving CIT Interval 5 | milestone | 0d | 2023-11-10 A | 2023-11-10 A | 735 | 100% |  | 2023-11-10 | 2023-11-10 | 0d | 2023-11-10 | 2023-11-10 |  |  | Simon Berry |  |  |  | PP | PP,IPA | 5.6 | Systems Integration Testing (SIT) | Complete | COMPLETE | MHHS-ART139 | T3-TE-0023 | SITAG | T3 |  |
| 737 | 1.4.1.7.1.9.2.3 | Internal Connectivity Proving Phase |  | 10d | 2023-11-13 A | 2023-11-24 A | 735FS+1d | 100% |  | 2023-11-13 | 2023-11-24 | 10d |  |  |  |  | Simon Berry | 80h | 80h |  | PP |  | 5.10 | Systems Integration Testing (SIT) | Complete | COMPLETE |  |  |  |  |  |
| 738 | 1.4.1.7.1.9.2.4 | Internal Connectivity Proving Phase Complete | milestone | 0d | 2023-11-24 A | 2023-11-24 A | 737 | 100% |  | 2023-11-24 | 2023-11-24 | 0d |  |  |  |  | Simon Berry |  |  |  | PP |  | 5.10 | Systems Integration Testing (SIT) | Complete | COMPLETE |  |  |  |  |  |
| 739 | 1.4.1.7.1.9.2.5 | DIP Onboarding Activity (1. PKI Officers and Certificates, 2. Set-up Validation, 3. End Point Creation, 4. Controlled Smoke Test ) |  | 10d | 2023-11-27 A | 2023-12-08 A | 738 | 100% |  | 2023-11-27 | 2023-12-08 | 10d |  |  |  |  | Simon Berry | 80h | 80h |  | PP |  | 5.10 | Systems Integration Testing (SIT) | Complete | COMPLETE |  |  |  |  |  |
| 740 | 1.4.1.7.1.9.2.6 | DIP Onboarding Complete | milestone | 0d | 2023-12-08 A | 2023-12-08 A | 739 | 100% |  | 2023-12-08 | 2023-12-08 | 0d |  |  |  |  | Simon Berry |  |  |  | PP |  | 5.10 | Systems Integration Testing (SIT) | Complete | COMPLETE |  |  |  |  |  |
| 741 | 1.4.1.7.1.9.2.7 | PPs register PKI Officers and Request PKI Certificates Complete - Interval 5 | milestone | 0d | 2023-12-08 A | 2023-12-08 A | 740 | 100% |  | 2023-12-08 | 2023-12-08 | 0d | 2023-11-06 | 2023-11-10 |  |  | Simon Berry |  |  |  | PP | DIP Provider | 5.17 | Systems Integration Testing (SIT) | Complete | COMPLETE |  | T3-TE-0101 | SITAG | T3 |  |
| 742 | 1.4.1.7.1.9.2.8 | PP Code Deployment | milestone | 0d | 2023-12-08 A | 2023-12-08 A | 741 | 100% |  | 2023-12-08 | 2023-12-08 | 0d |  |  |  | start no earlier than 2023-10-20 | Simon Berry |  |  |  | PP |  | 5.10 | Systems Integration Testing (SIT) | Complete | COMPLETE |  |  |  |  |  |

Notes:
- 718: 28/11 - red because data was delivered 1 week late. This led to an onward impact. We expect data to be loaded and checked by 1/12. No impact on CIT Tests Start date
- 727: 5/12 - Approved at Etmag on 4/12 with workoff plan
- 732: 4/12- Amber because not all receieved yet. No impact. No action. 19/12 - complete on 14/12
- 741: 16/01- Red because 1 has yet to complete onboarding. 30/1 - Completed on 26/1/24

| ID | WBS | Task | Type | Duration | Start | Finish | Predecessors | Complete | Remaining | Baseline start | Baseline finish | Baseline duration | Baseline 1 start | Baseline 1 finish | Total slack | Free slack | Constraint | Resources | Work | Actual work | Baseline cost | Responsible | Involved | Update Version | MHHS Programme Phase | Sched Status | RAG | Artefact ID | Milestone ID | Text29 | Tier | Task Status |
| --- | --- | --- | --- | --- | --- | --- | --- | --- | --- | --- | --- | --- | --- | --- | --- | --- | --- | --- | --- | --- | --- | --- | --- | --- | --- | --- | --- | --- | --- | --- | --- | --- |
| 743 | 1.4.1.7.1.9.3 | **Test Data (SIT A) Interval 5** |  | 33d | 2023-11-01 A | 2023-12-15 A |  | 100% |  | 2023-10-30 | 2023-12-08 | 30d | 2023-10-30 | 2023-12-08 |  |  |  | N/A | 528h | 528h |  | N/A | N/A | 5.0 | Systems Integration Testing (SIT) |  |  |  |  |  |  |  |
| 744 | 1.4.1.7.1.9.3.1 | Run data allocation |  | 5d | 2023-11-01 A | 2023-11-07 A | 714SS | 100% |  | 2023-10-30 | 2023-11-10 | 10d | 2023-10-30 | 2023-11-10 |  |  |  | Cesar Lopes | 40h | 40h |  | SI Test |  | 5.0 | Systems Integration Testing (SIT) | Complete | COMPLETE |  |  |  |  |  |
| 745 | 1.4.1.7.1.9.3.2 | Cleanse and populate data post cut |  | 8d | 2023-11-08 A | 2023-11-17 A | 744 | 100% |  | 2023-11-13 | 2023-11-17 | 5d | 2023-11-13 | 2023-11-17 |  |  |  | Cesar Lopes | 64h | 64h |  | SI Test |  | 5.0 | Systems Integration Testing (SIT) | Complete | COMPLETE |  |  |  |  |  |
| 746 | 1.4.1.7.1.9.3.3 | Transmit data sets to PPs |  | 2d | 2023-11-20 A | 2023-11-21 A | 745 | 100% |  | 2023-11-20 | 2023-11-21 | 2d | 2023-11-20 | 2023-11-21 |  |  |  | Cesar Lopes | 16h | 16h |  | SI Test |  | 5.0 | Systems Integration Testing (SIT) | Complete | COMPLETE |  |  |  |  |  |
| 747 | 1.4.1.7.1.9.3.4 | PP - Load test data to test environments |  | 8d | 2023-11-22 A | 2023-12-01 A | 746 | 100% |  | 2023-11-22 | 2023-12-01 | 8d | 2023-11-22 | 2023-12-01 |  |  |  | Richard Puddephatt | 64h | 64h |  | PP |  | 5.0 | Systems Integration Testing (SIT) | Complete | COMPLETE |  |  |  |  |  |
| 748 | 1.4.1.7.1.9.3.5 | PP Check data integrity on test environment |  | 10d | 2023-12-04 A | 2023-12-15 A | 747 | 100% |  | 2023-12-04 | 2023-12-08 | 5d | 2023-12-04 | 2023-12-08 |  |  |  | Richard Puddephatt | 80h | 80h |  | PP |  | 5.0 | Systems Integration Testing (SIT) | Complete | COMPLETE |  |  |  |  |  |
| 749 | 1.4.1.7.1.9.3.6 | PP submit self-declaration to Programme to confirm loading & verification of test data | milestone | 0d | 2023-12-15 A | 2023-12-15 A | 748FF | 100% |  | 2023-12-08 | 2023-12-08 | 0d | 2023-12-08 | 2023-12-08 |  |  |  | Richard Puddephatt |  |  |  | PP | SI Test | 5.0 | Systems Integration Testing (SIT) | Complete | COMPLETE |  |  |  |  |  |
| 750 | 1.4.1.7.1.9.3.7 | Test Data (SIT A) Interval 5 Complete | milestone | 0d | 2023-12-15 A | 2023-12-15 A | 749 | 100% |  | 2023-12-08 | 2023-12-08 | 0d |  |  |  |  |  | Richard Puddephatt |  |  |  | SI Test | PP | 5.14 | Systems Integration Testing (SIT) | Complete | COMPLETE | MHHS-ART148/169 | T3-TE-0077 | SITAG | T3 |  |
| 751 | 1.4.1.7.1.9.4 | **Other Preparation** |  | 40d | 2023-11-20 A | 2024-01-12 A |  | 100% |  | 2023-11-20 | 2024-01-12 | 40d | 2023-08-21 | 2023-11-10 |  |  |  | N/A | 928h | 928h | -0 | N/A | N/A | 5.0 | Systems Integration Testing (SIT) |  |  |  |  |  |  |  |
| 752 | 1.4.1.7.1.9.4.1 | Onboarding of Test Participants to Test Management Tool (Azure DevOps) |  | 40d | 2023-11-20 A | 2024-01-12 A |  | 100% |  | 2023-11-20 | 2024-01-12 | 40d | 2023-08-21 | 2023-11-10 |  |  | start no earlier than 2023-11-20 | Simon Berry | 320h | 320h |  | SI Test | PP | 5.0 | Systems Integration Testing (SIT) | Complete | COMPLETE |  |  |  |  |  |
| 753 | 1.4.1.7.1.9.4.2 | Test Management Tool onboarding |  | 36d | 2023-11-20 A | 2024-01-08 A |  | 100% |  | 2023-11-20 | 2024-01-08 | 36d | 2023-08-21 | 2023-11-10 |  |  | start no earlier than 2023-11-20 | Simon Berry | 288h | 288h |  | PP | SI Test | 5.0 | Systems Integration Testing (SIT) | Complete | COMPLETE |  |  |  |  |  |
| 754 | 1.4.1.7.1.9.5 | **SIT Component Integration Test Readiness Report** |  | 35d | 2023-11-20 A | 2024-01-05 |  | 13% | 30.62d | 2023-11-20 | 2024-01-05 | 35d | 2023-11-20 | 2024-01-05 | 885d |  |  | N/A | 600h | 75h |  | N/A | N/A | 5.0 | Systems Integration Testing (SIT) |  |  |  |  |  |  |  |
| 755 | 1.4.1.7.1.9.5.1 | PP submit Test Readiness Report to Programme for assurance | milestone | 0d | 2023-12-08 A | 2023-12-08 A | 579 | 100% |  | 2023-12-08 | 2023-12-08 | 0d | 2023-12-08 | 2023-12-08 |  |  |  | Lee Cox |  |  |  | PP | SI Test | 5.0 | Systems Integration Testing (SIT) | Complete | COMPLETE |  |  |  |  |  |
| 756 | 1.4.1.7.1.9.5.2 | SI assure Test Participants' Test Readiness Reports |  | 5d | 2023-12-11 A | 2023-12-15 A | 755FF+5d | 100% |  | 2023-12-11 | 2023-12-15 | 5d | 2023-12-11 | 2023-12-15 |  |  |  | Lee Cox | 40h | 40h |  | SI Test | PP,IPA | 5.0 | Systems Integration Testing (SIT) | Complete | COMPLETE |  |  |  |  |  |
| 757 | 1.4.1.7.1.9.5.3 | SI develop Overarching SIT Component Integration Test Readiness Report |  | 20d | 2023-11-20 | 2023-12-15 | 756FF |  |  | 2023-11-20 | 2023-12-15 | 20d | 2023-11-20 | 2023-12-15 | 885d | 0d |  | Lee Cox | 160h |  |  | SI Test |  | 5.0 | Systems Integration Testing (SIT) | Overdue Start | RED |  |  |  |  | -149.67 |
| 758 | 1.4.1.7.1.9.5.4 | Artefact review (via SITAG) and updates |  | 15d | 2023-12-18 | 2024-01-05 | 757 |  |  | 2023-12-18 | 2024-01-05 | 15d | 2023-12-18 | 2024-01-05 | 885d |  |  | Lee Cox | 120h |  |  | SI Test | PP,IPA | 5.0 | Systems Integration Testing (SIT) | Overdue Start | RED |  |  |  |  | -121.67 |
| 759 | 1.4.1.7.1.9.6 | SIT Component Integration Testing 5 Preparation Complete (incl. approval of SI SIT Component Integration Test Readiness Report) | milestone | 0d | 2024-01-08 A | 2024-01-08 A | 758FS+1d, 732, 736, 753, 755, 750, 398, 381 | 100% |  | 2024-01-08 | 2024-01-08 | 0d | 2024-01-08 | 2024-01-08 |  |  |  | Lee Cox |  |  |  | SI Test | PP,IPA | 5.15 | Systems Integration Testing (SIT) | Complete | COMPLETE | MHHS-ART071 | T2-TE-0450 | SITAG | T2 |  |
| 760 | 1.4.1.7.1.10 | **CIT Interval 6 Preparation** |  | 45d | 2023-11-20 A | 2024-01-19 A |  | 100% |  | 2023-11-20 | 2024-01-22 | 46d | 2022-11-16 | 2024-01-22 |  |  |  | N/A | 2344h | 2344h | -0 | N/A | N/A | 5.0 | Systems Integration Testing (SIT) |  |  |  |  |  |  |  |
| 761 | 1.4.1.7.1.10.1 | **PIT Test Completion Report (incl. evidence)** |  | 31d | 2023-12-01 A | 2024-01-12 A |  | 100% |  | 2023-12-01 | 2024-01-12 | 31d | 2023-12-01 | 2024-01-12 |  |  |  | N/A | 496h | 496h |  | N/A | N/A | 5.0 | Systems Integration Testing (SIT) |  |  |  |  |  |  |  |
| 762 | 1.4.1.7.1.10.1.1 | Submit draft PIT Test Completion Report (incl. evidence) and submit to Programme for assurance |  | 1d | 2023-12-01 A | 2023-12-01 A |  | 100% |  | 2023-12-01 | 2023-12-01 | 1d | 2023-12-01 | 2023-12-01 |  |  | must start on 2023-12-01 | Lee Cox | 8h | 8h |  | PP | SI Test | 5.0 | Systems Integration Testing (SIT) | Complete | COMPLETE |  |  |  |  |  |
| 763 | 1.4.1.7.1.10.1.2 | Finalise PIT Test Completion Report (incl. evidence) |  | 25d | 2023-12-04 A | 2024-01-05 A | 762 | 100% |  | 2023-12-04 | 2024-01-05 | 25d | 2023-12-04 | 2024-01-05 |  |  |  | Lee Cox | 200h | 200h |  | PP | SI Test | 5.0 | Systems Integration Testing (SIT) | Complete | COMPLETE |  |  |  |  |  |
| 764 | 1.4.1.7.1.10.1.3 | PP PIT Completion Report (excl. Migration/Reverse Migration) submitted to Programme for assurance CIT Interval 6 | milestone | 0d | 2024-01-05 A | 2024-01-05 A | 763, 80, 96, 218, 223, 226 | 100% |  | 2024-01-05 | 2024-01-05 | 0d | 2024-01-05 | 2024-01-05 |  |  |  | Lee Cox |  |  |  | PP | SI Test | 5.19 | Systems Integration Testing (SIT) | Complete | COMPLETE |  | T3-DB-0023 | SITAG | T3 |  |
| 765 | 1.4.1.7.1.10.1.4 | PP Final PIT Completion Reports assured by SI |  | 5d | 2024-01-08 A | 2024-01-12 A | 764 | 100% |  | 2024-01-08 | 2024-01-12 | 5d | 2024-01-08 | 2024-01-12 |  |  |  | Lee Cox | 40h | 40h |  | SI Test | PP | 5.19 | Systems Integration Testing (SIT) | Complete | COMPLETE |  |  |  |  |  |
| 766 | 1.4.1.7.1.10.2 | **Environments (SIT A)** |  | 30d | 2023-11-24 A | 2024-01-05 A |  | 100% |  | 2023-11-24 | 2024-01-05 | 30d | 2022-11-16 | 2024-01-05 |  |  |  | N/A | 264h | 264h | -0 | N/A | N/A | 5.0 | Systems Integration Testing (SIT) |  |  |  |  |  |  |  |
| 767 | 1.4.1.7.1.10.2.1 | Programme Participants Ready to Start Connectivity Proving | milestone | 0d | 2023-11-24 A | 2023-11-24 A |  | 100% |  | 2023-11-24 | 2023-11-24 | 0d |  |  |  |  | start no earlier than 2023-11-24 | Simon Berry |  |  |  | PP |  | 5.10 | Systems Integration Testing (SIT) | Complete | COMPLETE |  |  |  |  |  |
| 768 | 1.4.1.7.1.10.2.2 | SIT Participants' SIT A environments ready to start connectivity proving CIT Interval 6 | milestone | 0d | 2023-11-24 A | 2023-11-24 A | 767 | 100% |  | 2023-11-24 | 2023-11-24 | 0d | 2023-11-24 | 2023-11-24 |  |  |  | Simon Berry |  |  |  | PP | PP,IPA | 5.6 | Systems Integration Testing (SIT) | Complete | COMPLETE | MHHS-ART139 | T3-TE-0024 | SITAG | T3 |  |
| 769 | 1.4.1.7.1.10.2.3 | Internal Connectivity Proving Phase |  | 10d | 2023-11-27 A | 2023-12-08 A | 768FS+1d | 100% |  | 2023-11-27 | 2023-12-08 | 10d |  |  |  |  |  | Simon Berry | 80h | 80h |  | PP |  | 5.10 | Systems Integration Testing (SIT) | Complete | COMPLETE |  |  |  |  |  |
| 770 | 1.4.1.7.1.10.2.4 | Internal Connectivity Proving Phase Complete | milestone | 0d | 2023-12-08 A | 2023-12-08 A | 769 | 100% |  | 2023-12-08 | 2023-12-08 | 0d |  |  |  |  |  | Simon Berry |  |  |  | PP |  | 5.10 | Systems Integration Testing (SIT) | Complete | COMPLETE |  |  |  |  |  |
| 771 | 1.4.1.7.1.10.2.5 | DIP Onboarding Activity (1. PKI Officers and Certificates, 2. Set-up Validation, 3. End Point Creation, 4. Controlled Smoke Test ) |  | 5d | 2023-12-04 A | 2023-12-08 A | 768FS+6d | 100% |  | 2023-12-04 | 2023-12-08 | 5d |  |  |  |  |  | Simon Berry | 40h | 40h |  | PP |  | 5.10 | Systems Integration Testing (SIT) | Complete | COMPLETE |  |  |  |  |  |
| 772 | 1.4.1.7.1.10.2.6 | DIP Onboarding Complete | milestone | 0d | 2023-12-08 A | 2023-12-08 A | 771 | 100% |  | 2023-12-08 | 2023-12-08 | 0d |  |  |  |  |  | Simon Berry |  |  |  | PP |  | 5.10 | Systems Integration Testing (SIT) | Complete | COMPLETE |  |  |  |  |  |
| 773 | 1.4.1.7.1.10.2.7 | PPs register PKI Officers and Request PKI Certificates Complete - Interval 6 | milestone | 0d | 2023-12-08 A | 2023-12-08 A | 772 | 100% |  | 2023-12-08 | 2023-12-08 | 0d | 2023-11-20 | 2023-11-24 |  |  | start no earlier than 2023-12-08 | Simon Berry |  |  |  | PP | DIP Provider | 5.17 | Systems Integration Testing (SIT) | Complete | COMPLETE |  | T3-TE-0102 | SITAG | T3 |  |
| 774 | 1.4.1.7.1.10.2.8 | PP Code Deployment | milestone | 0d | 2024-01-05 A | 2024-01-05 A |  | 100% |  | 2024-01-05 | 2024-01-05 | 0d |  |  |  |  | start no earlier than 2024-01-05 | Simon Berry |  |  |  | PP |  | 5.10 | Systems Integration Testing (SIT) | Complete | COMPLETE |  |  |  |  |  |

Notes:
- 750: 28/7: CH: added in to be aT3 milestone. 12/12 - Red because PPs required additional time due to some data changes required. No impact. Action to follow-up with PPs for latest progress / Action: 28/7: CH: Needs to be set-up as a reporting milestone. 31/7: Check with Cesar if has been approved so can be baselined
- 759: 2/1/24 - Approved at Dec TMAG following change in CIT governance
- 764: 9/1 - Not all completion reports yet received. Completed 22/2/24
- 768: 29/11 - Red because forecast date missed. Participants status to be determined by 4th December. No risk to future milestones
- 771: 5/12 -
- 773: 12/12 - Red because 1 Participant still to complete. 30/1 - Completed 29/1/24

| ID | WBS | Task | Type | Duration | Start | Finish | Predecessors | Complete | Remaining | Baseline start | Baseline finish | Baseline duration | Baseline 1 start | Baseline 1 finish | Total slack | Constraint | Resources | Work | Actual work | Baseline cost | Responsible | Involved | Update Version | MHHS Programme Phase | Sched Status | RAG | Artefact ID | Milestone ID | Text29 | Tier |
| --- | --- | --- | --- | --- | --- | --- | --- | --- | --- | --- | --- | --- | --- | --- | --- | --- | --- | --- | --- | --- | --- | --- | --- | --- | --- | --- | --- | --- | --- | --- |
| 775 | 1.4.1.7.1.10.3 | **Test Data (SIT A) Interval 6** |  | 25d | 2023-11-20 A | 2023-12-22 A |  | 100% |  | 2023-11-20 | 2023-12-22 | 25d | 2023-11-20 | 2023-12-22 |  |  | N/A | 400h | 400h |  | N/A | N/A | 5.0 | Systems Integration Testing (SIT) |  |  |  |  |  |  |
| 776 | 1.4.1.7.1.10.3.1 | Run data allocation |  | 10d | 2023-11-20 A | 2023-12-01 A | 746SS | 100% |  | 2023-11-20 | 2023-11-24 | 5d | 2023-11-20 | 2023-11-24 |  |  | Richard Puddephatt | 80h | 80h |  | SI Test |  | 5.0 | Systems Integration Testing (SIT) | Complete | COMPLETE |  |  |  |  |
| 777 | 1.4.1.7.1.10.3.2 | Cleanse and populate data post cut |  | 1d | 2023-12-04 A | 2023-12-04 A | 776 | 100% |  | 2023-11-27 | 2023-12-01 | 5d | 2023-11-27 | 2023-12-01 |  |  | Richard Puddephatt | 8h | 8h |  | SI Test |  | 5.0 | Systems Integration Testing (SIT) | Complete | COMPLETE |  |  |  |  |
| 778 | 1.4.1.7.1.10.3.3 | Transmit data sets to PPs |  | 1d | 2023-12-05 A | 2023-12-05 A | 777 | 100% |  | 2023-12-04 | 2023-12-05 | 2d | 2023-12-04 | 2023-12-05 |  |  | Richard Puddephatt | 8h | 8h |  | SI Test |  | 5.0 | Systems Integration Testing (SIT) | Complete | COMPLETE |  |  |  |  |
| 779 | 1.4.1.7.1.10.3.4 | PP - Load test data to test environments |  | 8d | 2023-12-06 A | 2023-12-15 A | 778 | 100% |  | 2023-12-06 | 2023-12-15 | 8d | 2023-12-06 | 2023-12-15 |  |  | Richard Puddephatt | 64h | 64h |  | PP |  | 5.0 | Systems Integration Testing (SIT) | Complete | COMPLETE |  |  |  |  |
| 780 | 1.4.1.7.1.10.3.5 | PP Check data integrity on test environment |  | 5d | 2023-12-18 A | 2023-12-22 A | 779 | 100% |  | 2023-12-18 | 2023-12-22 | 5d | 2023-12-18 | 2023-12-22 |  |  | Richard Puddephatt | 40h | 40h |  | PP |  | 5.0 | Systems Integration Testing (SIT) | Complete | COMPLETE |  |  |  |  |
| 781 | 1.4.1.7.1.10.3.6 | PP submit self-declaration to Programme to confirm loading & verification of test data | milestone | 0d | 2023-12-22 A | 2023-12-22 A | 780FF | 100% |  | 2023-12-22 | 2023-12-22 | 0d | 2023-12-22 | 2023-12-22 |  |  | Richard Puddephatt |  |  |  | PP | SI Test | 5.0 | Systems Integration Testing (SIT) | Complete | COMPLETE |  |  |  |  |
| 782 | 1.4.1.7.1.10.3.7 | Test Data (SIT A) Interval 6 Complete | milestone | 0d | 2023-12-22 A | 2023-12-22 A | 781 | 100% |  | 2023-12-22 | 2023-12-22 | 0d |  |  |  |  | Richard Puddephatt |  |  |  | SI Test | PP | 5.5 | Systems Integration Testing (SIT) | Complete | COMPLETE | MHHS-ART148/169 | T3-TE-0078 | SITAG | T3 |
| 783 | 1.4.1.7.1.10.4 | **Other Preparation** |  | 31d | 2023-12-04 A | 2024-01-15 A |  | 100% |  | 2023-12-04 | 2024-01-15 | 31d | 2023-09-04 | 2023-11-24 |  |  | N/A | 744h | 744h | -0 | N/A | N/A | 5.0 | Systems Integration Testing (SIT) |  |  |  |  |  |  |
| 784 | 1.4.1.7.1.10.4.1 | Onboarding of Test Participants to Test Management Tool (Azure DevOps) |  | 31d | 2023-12-04 A | 2024-01-15 A |  | 100% |  | 2023-12-04 | 2024-01-15 | 31d | 2023-09-04 | 2023-11-24 |  | start no earlier than 2023-12-04 | Simon Berry | 248h | 248h |  | SI Test | PP | 5.0 | Systems Integration Testing (SIT) | Complete | COMPLETE |  |  |  |  |
| 785 | 1.4.1.7.1.10.4.2 | Test Management Tool onboarding |  | 31d | 2023-12-04 A | 2024-01-15 A |  | 100% |  | 2023-12-04 | 2024-01-15 | 31d | 2023-09-04 | 2023-11-24 |  | start no earlier than 2023-12-04 | Simon Berry | 248h | 248h |  | PP | SI Test | 5.0 | Systems Integration Testing (SIT) | Complete | COMPLETE |  |  |  |  |
| 786 | 1.4.1.7.1.10.5 | **SIT Component Integration Test Readiness Report** |  | 25d | 2023-11-20 A | 2023-12-22 A |  | 100% |  | 2023-12-18 | 2024-01-19 | 25d | 2023-12-18 | 2024-01-19 |  |  | N/A | 440h | 440h |  | N/A | N/A | 5.0 | Systems Integration Testing (SIT) |  |  |  |  |  |  |
| 787 | 1.4.1.7.1.10.5.1 | PP submit Test Readiness Report to Programme for assurance | milestone | 0d | 2023-12-08 A | 2023-12-08 A | 579 | 100% |  | 2024-01-05 | 2024-01-05 | 0d | 2024-01-05 | 2024-01-05 |  |  | Lee Cox |  |  |  | PP | SI Test | 5.0 | Systems Integration Testing (SIT) | Complete | COMPLETE |  |  |  |  |
| 788 | 1.4.1.7.1.10.5.2 | SI assure Test Participants' Test Readiness Reports |  | 5d | 2023-12-11 A | 2023-12-15 A | 787FF+5d | 100% |  | 2024-01-08 | 2024-01-12 | 5d | 2024-01-08 | 2024-01-12 |  |  | Lee Cox | 40h | 40h |  | SI Test | PP,IPA | 5.0 | Systems Integration Testing (SIT) | Complete | COMPLETE |  |  |  |  |
| 789 | 1.4.1.7.1.10.5.3 | SI develop Overarching SIT Component Integration Test Readiness Report |  | 20d | 2023-11-20 A | 2023-12-15 A | 788FF | 100% |  | 2023-12-18 | 2024-01-12 | 20d | 2023-12-18 | 2024-01-12 |  |  | Lee Cox | 160h | 160h |  | SI Test |  | 5.0 | Systems Integration Testing (SIT) | Complete | COMPLETE |  |  |  |  |
| 790 | 1.4.1.7.1.10.5.4 | Artefact review (via TMAG) and updates |  | 5d | 2023-12-18 A | 2023-12-22 A | 789 | 100% |  | 2024-01-15 | 2024-01-19 | 5d | 2024-01-15 | 2024-01-19 |  |  | Lee Cox | 40h | 40h |  | SI Test | PP,IPA | 5.0 | Systems Integration Testing (SIT) | Complete | COMPLETE |  |  |  |  |
| 791 | 1.4.1.7.1.10.6 | SIT Component Integration Testing 6 Preparation Complete (incl. approval of SI SIT Component Integration Test Readiness Report) | milestone | 0d | 2024-01-19 A | 2024-01-19 A | 790FS+1d, 764, 768, 785, 787, 782, 244, 415 | 100% |  | 2024-01-22 | 2024-01-22 | 0d | 2024-01-22 | 2024-01-22 |  |  | Lee Cox |  |  |  | SI Test | PP,IPA | 5.15 | Systems Integration Testing (SIT) | Complete | COMPLETE | MHHS-ART071 | T2-TE-0500 | SITAG | T2 |
| 792 | 1.4.1.7.2 | **SIT Functional Preparation** |  | 520d | 2022-10-31 A | 2024-10-25 |  | 88% | 60.69d | 2022-10-31 | 2024-10-25 | 520d | 2022-10-31 | 2024-03-01 | 4d |  | N/A | 25226.1h | 17539.1h | -0 | N/A | N/A | 5.0 | Systems Integration Testing (SIT) |  |  |  |  |  |  |
| 793 | 1.4.1.7.2.1 | **Test Approach & Plan** |  | 208d | 2022-10-31 A | 2023-08-16 A |  | 100% |  | 2022-10-31 | 2023-08-16 | 208d | 2022-10-31 | 2023-08-16 |  |  | N/A | 3248h | 3248h |  | N/A | N/A | 5.0 | Systems Integration Testing (SIT) |  |  |  |  |  |  |
| 794 | 1.4.1.7.2.1.1 | Develop document with SITWG |  | 179d | 2022-10-31 A | 2023-07-06 A |  | 100% |  | 2022-10-31 | 2023-07-06 | 179d | 2022-10-31 | 2023-07-06 |  | finish no earlier than 2023-07-06 | Lee Cox | 1432h | 1432h |  | SI Test |  | 5.0 | Systems Integration Testing (SIT) | Complete | COMPLETE |  |  |  |  |
| 795 | 1.4.1.7.2.1.2 | Industry Consultation |  | 10d | 2023-07-07 A | 2023-07-20 A | 794 | 100% |  | 2023-07-07 | 2023-07-20 | 10d |  |  |  |  |  |  |  |  | PP |  | 5.1 | Systems Integration Testing (SIT) | Complete | COMPLETE |  |  |  |  |
| 796 | 1.4.1.7.2.1.3 | Artefact review (via TMAG) and updates |  | 19d | 2023-07-21 A | 2023-08-16 A | 795 | 100% |  | 2023-07-21 | 2023-08-16 | 19d | 2023-07-07 | 2023-08-03 |  | finish no earlier than 2023-08-03 | Lee Cox | 152h | 152h |  | SI Test | PP,IPA,Code Bodies | 5.5 | Systems Integration Testing (SIT) | Complete | COMPLETE |  |  |  |  |
| 797 | 1.4.1.7.2.1.4 | SIT Functional Testing Test Approach & Plan approved | milestone | 0d | 2023-08-16 A | 2023-08-16 A |  | 100% |  | 2023-08-16 | 2023-08-16 | 0d | 2023-08-16 | 2023-08-16 |  | finish no earlier than 2023-08-16 | Lee Cox |  |  |  | SI Test | PP | 5.0 | Systems Integration Testing (SIT) | Complete | COMPLETE | MHHS-ART073 | T3-TE-0013 | SITAG | T3 |
| 798 | 1.4.1.7.2.2 | **Test Data Approach & Plan** |  | 29d | 2023-07-07 A | 2023-08-16 A |  | 100% |  | 2023-07-07 | 2023-08-16 | 29d | 2023-07-07 | 2023-08-16 |  |  | N/A | 464h | 464h |  | N/A | N/A | 5.0 | Systems Integration Testing (SIT) |  |  |  |  |  |  |
| 799 | 1.4.1.7.2.2.1 | Industry Consultation |  | 10d | 2023-07-07 A | 2023-07-20 A | 795SS | 100% |  | 2023-07-07 | 2023-07-20 | 10d |  |  |  |  | Cesar Lopes | 80h | 80h |  | PP |  | 5.1 | Systems Integration Testing (SIT) | Complete | COMPLETE |  |  |  |  |
| 800 | 1.4.1.7.2.2.2 | Artefact review (via TMAG) and updates |  | 19d | 2023-07-21 A | 2023-08-16 A | 799 | 100% |  | 2023-07-21 | 2023-08-16 | 19d | 2023-07-07 | 2023-08-03 |  |  | Cesar Lopes | 152h | 152h |  | SI Test |  | 5.5 | Systems Integration Testing (SIT) | Complete | COMPLETE |  |  |  |  |
| 801 | 1.4.1.7.2.2.3 | SIT Functional Testing Test Data Approach & Plan approved | milestone | 0d | 2023-08-16 A | 2023-08-16 A | 800 | 100% |  | 2023-08-16 | 2023-08-16 | 0d | 2023-08-16 | 2023-08-16 |  |  | Cesar Lopes |  |  |  | SI Test | PP,IPA | 5.5 | Systems Integration Testing (SIT) | Complete | COMPLETE |  |  |  |  |

Notes:
- 782: 28/7: CH: added in to be aT3 milestone / Action: 28/7: CH: Needs to be set-up as a reporting milestone. 31/7: Check with Cesar if has been approved so can be baselined
- 791: 2/1/24 - Approved at Dec TMAG following change in CIT governance

| ID | WBS | Task | Type | Duration | Start | Finish | Predecessors | Complete | Remaining | Baseline start | Baseline finish | Baseline duration | Baseline 1 start | Baseline 1 finish | Total slack | Constraint | Resources | Work | Actual work | Baseline cost | Responsible | Involved | Update Version | MHHS Programme Phase | Sched Status | RAG | Artefact ID | Milestone ID | Text29 | Tier | Action | Guidance | Task Status |
| --- | --- | --- | --- | --- | --- | --- | --- | --- | --- | --- | --- | --- | --- | --- | --- | --- | --- | --- | --- | --- | --- | --- | --- | --- | --- | --- | --- | --- | --- | --- | --- | --- | --- |
| 802 | 1.4.1.7.2.3 | **Test scenarios** |  | 298d | 2023-01-02 A | 2024-02-21 A |  | 100% |  | 2023-01-02 | 2024-02-21 | 298d | 2023-01-02 | 2023-06-02 |  |  | N/A | 3584h | 3584h | -0 | N/A | N/A | 5.0 | Systems Integration Testing (SIT) |  |  |  |  |  |  |  |  |  |
| 803 | 1.4.1.7.2.3.1 | Development of test scenarios |  | 85d | 2023-01-02 A | 2023-04-28 A | 794SS+45d | 100% |  | 2023-01-02 | 2023-04-28 | 85d | 2023-01-02 | 2023-04-28 |  |  | Lee Cox | 680h | 680h |  | SI Test | PP, Code Bodies | 5.0 | Systems Integration Testing (SIT) | Complete | COMPLETE |  |  |  |  |  |  |  |
| 804 | 1.4.1.7.2.3.2 | Review test scenarios with SIT Working Group |  | 65d | 2023-08-17 A | 2023-11-15 A | 803FS+78d | 100% |  | 2023-08-17 | 2023-11-15 | 65d | 2023-02-01 | 2023-05-26 |  |  | Lee Cox | 520h | 520h |  | SI Test | PP, Code Bodies, IPA | 5.0 | Systems Integration Testing (SIT) | Complete | COMPLETE |  |  |  |  |  |  |  |
| 805 | 1.4.1.7.2.3.3 | SIT Functional Testing Test scenarios (themes 1-5) approved | milestone | 0d | 2023-12-08 A | 2023-12-08 A | 804FS+17d | 100% |  | 2023-12-08 | 2023-12-08 | 0d | 2023-06-02 | 2023-06-02 |  |  | Lee Cox |  |  |  | SI Test | PP | 5.14 | Systems Integration Testing (SIT) | Complete | COMPLETE | MMHS-ART073 | T3-TE-0015 | SITAG | T3 |  |  |  |
| 806 | 1.4.1.7.2.3.4 | SIT Functional Testing Test scenarios (themes 6,7,9) approved | milestone | 0d | 2024-01-17 A | 2024-01-17 A | 805FS+28d | 100% |  | 2024-01-17 | 2024-01-17 | 0d | 2023-06-02 | 2023-06-02 |  |  | Lee Cox |  |  |  | SI Test | PP | 5.16 | Systems Integration Testing (SIT) | Complete | COMPLETE | MMHS-ART073 | T3-TE-0106 | SITAG | T3 |  |  |  |
| 807 | 1.4.1.7.2.3.5 | SIT Functional Testing Test scenarios (theme 8) approved | milestone | 0d | 2024-02-21 A | 2024-02-21 A | 806FS+25d | 100% |  | 2024-02-21 | 2024-02-21 | 0d | 2023-06-02 | 2023-06-02 |  |  | Lee Cox |  |  |  | SI Test | PP | 5.14 | Systems Integration Testing (SIT) | Complete | COMPLETE | MMHS-ART073 | T3-TE-0107 | SITAG | T3 |  |  |  |
| 808 | 1.4.1.7.2.4 | **Test cases** |  | 213d | 2023-05-01 A | 2024-02-21 A |  | 100% |  | 2023-05-01 | 2024-02-21 | 213d | 2023-05-01 | 2023-09-01 |  |  | N/A | 5178.08h | 5178.08h |  | N/A | N/A | 5.0 | Systems Integration Testing (SIT) |  |  |  |  |  |  | 25/7 - needs to be replanned |  |  |
| 809 | 1.4.1.7.2.4.1 | **SI Test cases** |  | 213d | 2023-05-01 A | 2024-02-21 A |  | 100% |  | 2023-05-01 | 2024-02-21 | 213d | 2023-05-01 | 2023-09-01 |  |  | N/A | 3501.04h | 3501.04h |  | N/A | N/A | 5.0 | Systems Integration Testing (SIT) |  |  |  |  |  |  | 25/7 - needs to be replanned |  |  |
| 810 | 1.4.1.7.2.4.1.1 | Development of Test cases |  | 150d | 2023-05-01 A | 2023-11-24 A | 803 | 100% |  | 2023-05-01 | 2023-11-24 | 150d | 2023-05-01 | 2023-07-28 |  |  | Lee Cox | 1200h | 1200h |  | SI Test |  | 5.0 | Systems Integration Testing (SIT) | Complete | COMPLETE |  |  |  |  | 25/7 - needs to be replanned |  |  |
| 811 | 1.4.1.7.2.4.1.2 | Review Test cases with SIT Working Group |  | 78d | 2023-09-25 A | 2024-01-10 A | 810SS+105d | 100% |  | 2023-09-25 | 2024-01-10 | 78d | 2023-05-26 | 2023-08-25 |  |  | Lee Cox | 624h | 624h |  | SI Test | PP,IPA | 5.0 | Systems Integration Testing (SIT) | Complete | COMPLETE |  |  |  |  | 25/7 - needs to be replanned |  |  |
| 812 | 1.4.1.7.2.4.1.3 | SIT Functional Testing Test Cases (themes 1-5) approved | milestone | 0d | 2024-01-17 A | 2024-01-17 A | 811FS+5d | 100% |  | 2024-01-17 | 2024-01-17 | 0d | 2023-09-01 | 2023-09-01 |  |  | Lee Cox |  |  |  | SI Test | PP | 5.14 | Systems Integration Testing (SIT) | Complete | COMPLETE | MHHS-ART140 | T3-TE-0070 | SITAG | T3 |  | 2/1/24 - Approved at Dec TMAG |  |
| 813 | 1.4.1.7.2.4.1.4 | SIT Functional Testing Test cases (themes 6,7,9) approved | milestone | 0d | 2024-01-17 A | 2024-01-17 A | 812 | 100% |  | 2024-01-17 | 2024-01-17 | 0d | 2023-09-01 | 2023-09-01 |  |  | Lee Cox |  |  |  | SI Test | PP | 5.14 | Systems Integration Testing (SIT) | Complete | COMPLETE | MHHS-ART140 | T3-TE-0108 | SITAG | T3 |  |  |  |
| 814 | 1.4.1.7.2.4.1.5 | SIT Functional Testing Test cases (theme 8) approved | milestone | 0d | 2024-02-21 A | 2024-02-21 A | 813FS+25d | 100% |  | 2024-02-21 | 2024-02-21 | 0d | 2023-09-01 | 2023-09-01 |  |  | Lee Cox |  |  |  | SI Test | PP | 5.14 | Systems Integration Testing (SIT) | Complete | COMPLETE | MHHS-ART140 | T3-TE-0109 | SITAG | T3 |  |  |  |
| 815 | 1.4.1.7.2.5 | **Environments (SIT-Staging)** |  | 10d | 2023-12-04 A | 2023-12-15 A |  | 100% |  | 2022-11-16 | 2024-02-09 | 323d | 2022-11-16 | 2024-02-09 |  |  | N/A | 560h | 560h |  | N/A | N/A | 5.0 | Systems Integration Testing (SIT) |  |  |  |  |  |  |  |  |  |
| 816 | 1.4.1.7.2.5.1 | **SIT Functional pre-requisites** |  | 10d | 2023-12-04 A | 2023-12-15 A |  | 100% |  | 2023-12-04 | 2023-12-15 | 10d |  |  |  |  | N/A | 480h | 480h |  | N/A | N/A | 5.3 | Systems Integration Testing (SIT) |  |  |  |  |  |  |  |  |  |
| 817 | 1.4.1.7.2.5.1.1 | **DCC** |  | 10d | 2023-12-04 A | 2023-12-15 A |  | 100% |  | 2023-12-04 | 2023-12-15 | 10d |  |  |  |  | N/A | 400h | 400h |  | N/A | N/A | 5.3 | Systems Integration Testing (SIT) |  |  |  |  |  |  |  |  | -254.67 |
| 818 | 1.4.1.7.2.5.1.1.1 | **CSS** |  | 10d | 2023-12-04 A | 2023-12-15 A |  | 100% |  | 2023-12-04 | 2023-12-15 | 10d |  |  |  |  | N/A | 160h | 160h |  | N/A | N/A | 5.3 | Systems Integration Testing (SIT) |  |  |  |  |  |  |  |  | -254.67 |
| 819 | 1.4.1.7.2.5.1.1.1.1 | SIT participants have requested DCC CSS PKI certificates for access to UIT-B environment |  | 10d | 2023-12-04 A | 2023-12-15 A |  | 100% |  | 2023-12-04 | 2023-12-15 | 10d |  |  |  | start no earlier than 2023-12-04 | Simon Berry | 80h | 80h |  | SIT Participants (Suppliers & Third Parties) | PP | 5.3 | Systems Integration Testing (SIT) | Complete | COMPLETE |  |  |  |  |  |  |  |
| 820 | 1.4.1.7.2.5.1.1.1.2 | SIT participants have received DCC CSS PKI certificates for UIT-B environment | milestone | 0d | 2023-12-15 A | 2023-12-15 A | 819 | 100% |  | 2023-12-15 | 2023-12-15 | 0d |  |  |  |  | Simon Berry |  |  |  | SIT Participants (Suppliers & Third Parties) | PP | 5.5 | Systems Integration Testing (SIT) | Complete | COMPLETE |  | T3-TE-0088 | SITAG | T3 | 7/8 - added as a T3 milestone. Awaiting approval at TMAG |  |  |
| 821 | 1.4.1.7.2.5.1.1.2 | **DSP** |  | 10d | 2023-12-04 A | 2023-12-15 A |  | 100% |  | 2023-12-04 | 2023-12-15 | 10d |  |  |  |  | N/A | 160h | 160h |  | N/A | N/A | 5.3 | Systems Integration Testing (SIT) |  |  |  |  |  |  |  |  | -254.67 |
| 822 | 1.4.1.7.2.5.1.1.2.1 | SIT participants have requested DCC DSP PKI certificates for access to UIT-B environment |  | 10d | 2023-12-04 A | 2023-12-15 A |  | 100% |  | 2023-12-04 | 2023-12-15 | 10d |  |  |  | start no earlier than 2023-12-04 | Simon Berry | 80h | 80h |  | PPs in SDS Market Role | PP | 5.3 | Systems Integration Testing (SIT) | Complete | COMPLETE |  |  |  |  |  |  |  |
| 823 | 1.4.1.7.2.5.1.1.2.2 | SIT participants have received DCC DSP PKI certificates for UIT-B environment | milestone | 0d | 2023-12-15 A | 2023-12-15 A | 822 | 100% |  | 2023-12-15 | 2023-12-15 | 0d |  |  |  |  | Simon Berry |  |  |  | PPs in SDS Market Role | PP | 5.5 | Systems Integration Testing (SIT) | Complete | COMPLETE |  | T3-TE-0089 | SITAG | T3 | 7/8 - added as a T3 milestone. Awaiting approval at TMAG |  |  |
| 824 | 1.4.1.7.2.6 | **Environments (SIT A)** |  | 25d | 2024-02-05 A | 2024-03-08 |  | 99% | 0d | 2024-01-08 | 2024-02-09 | 25d | 2024-02-05 | 2024-02-09 | 0d |  | N/A | 1232h | 1080h |  | N/A | N/A | 5.0 | Systems Integration Testing (SIT) |  |  |  |  |  |  |  |  |  |
| 825 | 1.4.1.7.2.6.1 | **SIT Functional Connectivity Proving** |  | 15d | 2024-02-12 A | 2024-03-01 A |  | 100% |  | 2024-01-08 | 2024-02-02 | 20d |  |  |  |  | N/A | 232h | 232h |  | N/A | N/A | 5.5 | Systems Integration Testing (SIT) |  |  |  |  |  |  |  |  | -288.67 |
| 826 | 1.4.1.7.2.6.1.1 | SIT Functional Connectivity Proving Period |  | 15d | 2024-02-12 A | 2024-03-01 A |  | 100% |  | 2024-02-12 | 2024-03-01 | 20d |  |  |  | start no earlier than 2024-01-08 | Simon Berry | 120h | 120h |  | SI Test | PP | 5.19 | Systems Integration Testing (SIT) | Complete | COMPLETE |  |  |  |  |  |  |  |
| 827 | 1.4.1.7.2.6.1.2 | SIT Functional Connectivity Proving Complete | milestone | 0d | 2024-03-01 A | 2024-03-01 A | 826 | 100% |  | 2024-03-01 | 2024-03-01 | 0d |  |  |  | start no earlier than 2024-03-01 | Simon Berry |  |  |  | SI Test | PP | 5.19 | Systems Integration Testing (SIT) | Complete | COMPLETE |  | T3-TE-0103 | SITAG | T3 |  |  |  |

Notes:
- 805: Red because 8/12 TMAG moved to 20/12 due to reduction of Dec TMAGS. 5/12 Name change to SIT Functional Testing Test scenarios (themes 1-5) approved 20/12 - Approved at TMAG on 20/12
- 806: 5/12 - New milestone to go to 20/12 TMAG for approval. Added because of new delivery approach for SIT functional artifacts 20/12 - Approved at TMAG on 20/12
- 807: 5/12 - New milestone to go to 20/12 TMAG for approval. Added because of new delivery approach for SIT functional artifacts 20/12 - Approved at TMAG on 20/12
- 810: 15/9 - Potentially add in additional lines to track against progress
- 812: 5/12 Name change to SIT Functional Testing Test Cases (themes 1-5) approved 20/12 - Approved at TMAG on 20/12
- 813: 5/12- New milestone added because revised delivery approach for SIT Functional 20/12 - Approved at TMAG on 20/12
- 814: 5/12- New milestone added because revised delivery approach for SIT Functional
- 820: To be proposed as a T3 Milestone at next TMAG
- 823: 19/12 - MHHS PPs who require DCC, DSP, PKI certificates will request them in order to participate in DCC UEPT
- 826: 16/8 - Needs to start 8 weeks before SIT Functional Testing starts
- 827: 21/2/24 - Date change approved at SITAG on 21/2/24. 4/3 - PPs in the process of completing the activity, two thirds complete, the remai nder in various stages of completeness

| ID | WBS | Task | Type | Duration | Start | Finish | Predecessors | Complete | Remaining | Baseline start | Baseline finish | Baseline duration | Baseline 1 start | Baseline 1 finish | Total slack | Free slack | Constraint | Resources | Work | Actual work | Baseline cost | Responsible | Involved | Update Version | MHHS Programme Phase | Sched Status | RAG | Task Status | Artefact ID | Action | Milestone ID | Text29 | Tier |
| --- | --- | --- | --- | --- | --- | --- | --- | --- | --- | --- | --- | --- | --- | --- | --- | --- | --- | --- | --- | --- | --- | --- | --- | --- | --- | --- | --- | --- | --- | --- | --- | --- | --- |
| 828 | 1.4.1.7.2.6.2 | **PP Environments (SIT A)** |  | 25d | 2024-02-05 A | 2024-03-08 A |  | 100% |  | 2024-02-05 | 2024-02-09 | 5d | 2024-02-05 | 2024-02-09 |  |  |  | N/A | 400h | 400h |  | N/A | N/A | 5.0 | Systems Integration Testing (SIT) |  |  |  |  |  |  |  |  |
| 829 | 1.4.1.7.2.6.2.1 | Deployment of MHHS solution code to SIT A environments |  | 25d | 2024-02-05 A | 2024-03-08 A |  | 100% |  | 2024-02-05 | 2024-02-09 | 5d | 2024-02-05 | 2024-02-09 |  |  | start no earlier than 2024-02-05 | Simon Berry | 200h | 200h |  | PP | SI Test | 5.0 | Systems Integration Testing (SIT) | Complete | COMPLETE |  |  |  |  |  |  |
| 830 | 1.4.1.7.2.6.3 | **SI Environments (SIT A)** |  | 25d | 2024-02-05 A | 2024-03-08 A |  | 100% |  | 2024-02-05 | 2024-02-09 | 5d | 2024-02-05 | 2024-02-09 |  |  |  | N/A | 400h | 400h |  | N/A | N/A | 5.0 | Systems Integration Testing (SIT) |  |  |  |  |  |  |  |  |
| 831 | 1.4.1.7.2.6.3.1 | Coordinate deployment of MHHS solution code to SIT Participants' SIT A environments |  | 25d | 2024-02-05 A | 2024-03-08 A | 829SS | 100% |  | 2024-02-05 | 2024-02-09 | 5d | 2024-02-05 | 2024-02-09 |  |  |  | Simon Berry | 200h | 200h |  | SI Test | PP | 5.0 | Systems Integration Testing (SIT) | Complete | COMPLETE |  |  |  |  |  |  |
| 832 | 1.4.1.7.2.7 | **Test data (SIT A)** |  | 225d | 2023-12-18 A | 2024-10-25 |  | 37% | 141.98d | 2023-12-18 | 2024-10-25 | 225d |  |  | 4d |  |  | N/A | 4784h | 1313.02h | -0 | N/A | N/A | 5.4 | Systems Integration Testing (SIT) |  |  | -269.67 |  |  |  |  |  |
| 833 | 1.4.1.7.2.7.1 | **Cycle 1 Test data (SIT A)** |  | 55d | 2023-12-18 A | 2024-03-01 A |  | 100% |  | 2023-12-18 | 2024-03-01 | 55d |  |  |  |  |  | N/A | 872h | 872h | -0 | N/A | N/A | 5.4 | Systems Integration Testing (SIT) |  |  | -269.67 |  |  |  |  |  |
| 834 | 1.4.1.7.2.7.1.1 | Prepare, Generate and Allocate Test Data |  | 28d | 2023-12-18 A | 2024-01-24 A | 611, 619 | 100% |  | 2023-12-18 | 2024-01-24 | 28d |  |  |  |  | start no earlier than 2023-12-11 | Richard Puddephatt | 224h | 224h |  | SI Test Data |  | 5.14 | Systems Integration Testing (SIT) | Complete | COMPLETE |  |  |  |  |  |  |
| 835 | 1.4.1.7.2.7.1.2 | Transmit Data Sets to PPs |  | 4d | 2024-01-26 A | 2024-01-31 A | 834FS+1d | 100% |  | 2024-01-25 | 2024-01-26 | 2d |  |  |  |  |  | Richard Puddephatt | 32h | 32h |  | SI Test Data |  | 5.14 | Systems Integration Testing (SIT) | Complete | COMPLETE |  |  |  |  |  |  |
| 836 | 1.4.1.7.2.7.1.3 | PP's Iterative load and data integrity check |  | 22d | 2024-02-01 A | 2024-03-01 A | 835 | 100% |  | 2024-01-29 | 2024-02-09 | 10d |  |  |  |  |  | Richard Puddephatt | 176h | 176h |  | PP |  | 5.14 | Systems Integration Testing (SIT) | Complete | COMPLETE |  |  |  |  |  |  |
| 837 | 1.4.1.7.2.7.1.4 | Cycle 1 - PP's confirmation that test data is ready for SIT Functional | milestone | 0d | 2024-03-01 A | 2024-03-01 A | 836 | 100% |  | 2024-03-01 | 2024-03-01 | 0d |  |  |  |  |  | Richard Puddephatt |  |  |  | SI Test Data |  | 5.18 | Systems Integration Testing (SIT) | Complete | COMPLETE |  | MHHS-ART140 MHHS-ART169 | 2/8 - added as a T3 milestone. Awaiting approval at TMAG | T3-TE-0079 | SITAG | T3 |
| 838 | 1.4.1.7.2.7.2 | **Cycle 2 Test data (SIT A)** |  | 47d | 2024-03-28 A | 2024-05-31 |  | 32% | 32d | 2024-03-28 | 2024-05-31 | 47d |  |  | 4d |  |  | N/A | 736h | 144h | -0 | N/A | N/A | 5.4 | Systems Integration Testing (SIT) |  |  |  |  |  |  |  |  |
| 839 | 1.4.1.7.2.7.2.1 | Prepare, Generate and Allocate Test Data |  | 31d | 2024-03-28 A | 2024-05-09 | 837FS+18d | 48% | 16d | 2024-03-28 | 2024-05-09 | 31d |  |  | 4d | 0d |  | Richard Puddephatt | 248h | 120h |  | SI Test Data |  | 5.14 | Systems Integration Testing (SIT) | Green | GREEN |  |  |  |  |  |  |
| 840 | 1.4.1.7.2.7.2.2 | Transmit Data Sets to PPs |  | 3d | 2024-05-10 | 2024-05-14 | 839 |  |  | 2024-05-10 | 2024-05-14 | 3d |  |  | 4d | 0d |  | Richard Puddephatt | 24h |  |  | SI Test Data |  | 5.14 | Systems Integration Testing (SIT) | Green | GREEN | 22.33 |  |  |  |  |  |
| 841 | 1.4.1.7.2.7.2.3 | PP's Iterative load and data integrity check |  | 13d | 2024-05-15 | 2024-05-31 | 840 |  |  | 2024-05-15 | 2024-05-31 | 13d |  |  | 4d | 0d |  | Richard Puddephatt | 104h |  |  | PP |  | 5.14 | Systems Integration Testing (SIT) | Green | GREEN | 27.33 |  |  |  |  |  |
| 842 | 1.4.1.7.2.7.2.4 | Cycle 2 - PP's confirmation that test data is ready for SIT Functional | milestone | 0d | 2024-05-31 | 2024-05-31 | 841 |  |  | 2024-05-31 | 2024-05-31 | 0d |  |  | 4d | 0d |  | Richard Puddephatt |  |  |  | SI Test Data |  | 5.22 | Systems Integration Testing (SIT) | Green | GREEN | 43.71 | MHHS-ART140 MHHS-ART169 | 2/8 - added as a T3 milestone. Awaiting approval at TMAG | T3-TE-0080 | SITAG | T3 |
| 843 | 1.4.1.7.2.7.3 | **Cycle 3 Test data (SIT A)** |  | 41d | 2024-06-24 | 2024-08-19 |  |  |  | 2024-06-24 | 2024-08-19 | 41d |  |  | 4d |  |  | N/A | 656h |  | -0 | N/A | N/A | 5.4 | Systems Integration Testing (SIT) |  |  |  |  |  |  |  |  |
| 844 | 1.4.1.7.2.7.3.1 | Prepare, Generate and Allocate Test Data |  | 18d | 2024-06-24 | 2024-07-17 | 842FS+15d |  |  | 2024-06-24 | 2024-07-17 | 18d |  |  | 4d | 0d |  | Richard Puddephatt | 144h |  |  | SI Test Data |  | 5.14 | Systems Integration Testing (SIT) | Green | GREEN | 67.33 |  |  |  |  |  |
| 845 | 1.4.1.7.2.7.3.2 | Transmit Data Sets to PPs |  | 2d | 2024-07-18 | 2024-07-19 | 844 |  |  | 2024-07-18 | 2024-07-19 | 2d |  |  | 4d | 0d |  | Richard Puddephatt | 16h |  |  | SI Test Data |  | 5.14 | Systems Integration Testing (SIT) | Green | GREEN | 91.33 |  |  |  |  |  |
| 846 | 1.4.1.7.2.7.3.3 | PP's Iterative load and data integrity check |  | 21d | 2024-07-22 | 2024-08-19 | 845 |  |  | 2024-07-22 | 2024-08-19 | 21d |  |  | 4d | 0d |  | Richard Puddephatt | 168h |  |  | PP |  | 5.14 | Systems Integration Testing (SIT) | Green | GREEN | 95.33 |  |  |  |  |  |
| 847 | 1.4.1.7.2.7.3.4 | Cycle 3 - PP's confirmation that test data is ready for SIT Functional | milestone | 0d | 2024-08-19 | 2024-08-19 | 846 |  |  | 2024-08-19 | 2024-08-19 | 0d |  |  | 4d | 0d |  | Richard Puddephatt |  |  |  | SI Test Data |  | 5.14 | Systems Integration Testing (SIT) | Green | GREEN | 123.71 | MHHS-ART140 MHHS-ART169 | 2/8 - added as a T3 milestone. Awaiting approval at TMAG | T3-TE-0081 | SITAG | T3 |
| 848 | 1.4.1.7.2.7.4 | **Regression Test data (SIT A)** |  | 45d | 2024-08-26 | 2024-10-25 |  |  |  | 2024-08-26 | 2024-10-25 | 45d |  |  | 4d |  |  | N/A | 720h |  | -0 | N/A | N/A | 5.4 | Systems Integration Testing (SIT) |  |  |  |  |  |  |  |  |
| 849 | 1.4.1.7.2.7.4.1 | Prepare, Generate and Allocate Test Data |  | 23d | 2024-08-26 | 2024-09-25 | 847FS+4d |  |  | 2024-08-26 | 2024-09-25 | 23d |  |  | 4d | 0d |  | Richard Puddephatt | 184h |  |  | SI Test Data |  | 5.14 | Systems Integration Testing (SIT) | Green | GREEN | 130.33 |  |  |  |  |  |
| 850 | 1.4.1.7.2.7.4.2 | Transmit Data Sets to PPs |  | 2d | 2024-09-26 | 2024-09-27 | 849 |  |  | 2024-09-23 | 2024-10-04 | 10d |  |  | 4d | 0d |  | Richard Puddephatt | 16h |  |  | SI Test Data |  | 5.14 | Systems Integration Testing (SIT) | Green | GREEN | 161.33 |  |  |  |  |  |
| 851 | 1.4.1.7.2.7.4.3 | PP's Iterative load and data integrity check |  | 20d | 2024-09-30 | 2024-10-25 | 850 |  |  | 2024-10-21 | 2024-10-25 | 5d |  |  | 4d | 0d |  | Richard Puddephatt | 160h |  |  | PP |  | 5.14 | Systems Integration Testing (SIT) | Green | GREEN | 165.33 |  |  |  |  |  |
| 852 | 1.4.1.7.2.7.4.4 | Regression - PP's confirmation that test data is ready for SIT Functional | milestone | 0d | 2024-10-25 | 2024-10-25 | 851 |  |  | 2024-10-25 | 2024-10-25 | 0d |  |  | 4d |  |  | Richard Puddephatt |  |  |  | SI Test Data |  | 5.14 | Systems Integration Testing (SIT) | Green | GREEN | 190.71 | MHHS-ART140 MHHS-ART169 | 2/8 - added as a T3 milestone. Awaiting approval at TMAG | T3-TE-0082 | SITAG | T3 |

Notes:
- 837: 21/2/24 - Date change approved at SITAG on 21/2/24. 5/3 - Red because 20% of PPs differed the data load to 6/3. These PPs have an action plan to complete this.
- 842: 3/4 - after detailed planning the date has moved back 3 days - this allows more time for participants data loading and checking. To go to April SITAG for for date change approval. 17/4: Approved date change at SITAG on 17/4/24
- 847: 7/12 - Re name milestone to 'Cycle 3 - PP's confirmation that test data is ready for SIT Functional'
- 852: 7/12 - Re name milestone to 'Regression - PP's confirmation that test data is ready for SIT Functional' 20/12 - Approved at TMAG on 20/12

| ID | WBS | Task | Type | Duration | Start | Finish | Predecessors | Complete | Remaining | Baseline start | Baseline finish | Baseline duration | Baseline 1 start | Baseline 1 finish | Total slack | Constraint | Resources | Work | Actual work | Baseline cost | Responsible | Involved | Update Version | MHHS Programme Phase | Sched Status | RAG | Milestone ID | Text29 | Tier | Artefact ID | Task Status |
| --- | --- | --- | --- | --- | --- | --- | --- | --- | --- | --- | --- | --- | --- | --- | --- | --- | --- | --- | --- | --- | --- | --- | --- | --- | --- | --- | --- | --- | --- | --- | --- |
| 853 | 1.4.1.7.2.8 | **SIT Functional Test Readiness Report** |  | 44d | 2024-01-01 A | 2024-02-29 A |  | 100% |  | 2024-01-01 | 2024-02-29 | 44d | 2024-01-01 | 2024-02-23 |  |  | N/A | 2016h | 2016h | -0 | N/A | N/A | 5.0 | Systems Integration Testing (SIT) |  |  |  |  |  |  |  |
| 854 | 1.4.1.7.2.8.1 | **PP SIT Functional Test Readiness Report** |  | 44d | 2024-01-01 A | 2024-02-29 A |  | 100% |  | 2024-01-01 | 2024-02-29 | 44d | 2024-01-01 | 2024-02-09 |  |  | N/A | 864h | 864h | -0 | N/A | N/A | 5.0 | Systems Integration Testing (SIT) |  |  |  |  |  |  |  |
| 855 | 1.4.1.7.2.8.1.1 | Develop draft Test Readiness Report and submit to Programme for assurance |  | 21d | 2024-01-01 A | 2024-01-29 A |  | 100% |  | 2024-01-01 | 2024-01-29 | 20d | 2024-01-01 | 2024-01-29 |  | start no earlier than 2024-01-01 | Lee Cox | 168h | 168h |  | PP | SI Test | 5.0 | Systems Integration Testing (SIT) | Complete | COMPLETE |  |  |  |  |  |
| 856 | 1.4.1.7.2.8.1.2 | Placing Reliance Stage 2 Review |  | 34d | 2024-01-15 A | 2024-02-29 A | 855SS+10d | 100% |  | 2024-01-15 | 2024-02-29 | 34d |  |  |  |  | Lee Cox | 272h | 272h |  | SI Test | PP | 5.12 | Systems Integration Testing (SIT) | Complete | COMPLETE |  |  |  |  |  |
| 857 | 1.4.1.7.2.8.1.3 | Finalise Test Readiness Report and submit to Programme for assurance |  | 9d | 2024-01-30 A | 2024-02-09 A | 855 | 100% |  | 2024-01-29 | 2024-02-09 | 10d | 2024-01-29 | 2024-02-09 |  |  | Lee Cox | 72h | 72h |  | PP | SI Test | 5.0 | Systems Integration Testing (SIT) | Complete | COMPLETE |  |  |  |  |  |
| 858 | 1.4.1.7.2.8.2 | **SI SIT Functional Test Readiness Report** |  | 40d | 2024-01-01 A | 2024-02-23 A |  | 100% |  | 2024-01-01 | 2024-02-23 | 40d | 2024-01-01 | 2024-02-23 |  |  | N/A | 800h | 800h |  | N/A | N/A | 5.0 | Systems Integration Testing (SIT) |  |  |  |  |  |  |  |
| 859 | 1.4.1.7.2.8.2.1 | Assure Test Participants' Test Readiness Reports |  | 35d | 2024-01-01 A | 2024-02-16 A | 855SS, 857FF+5d | 100% |  | 2024-01-01 | 2024-02-16 | 35d | 2024-01-01 | 2024-02-16 |  |  | Lee Cox | 280h | 280h |  | SI Test | PP,IPA | 5.0 | Systems Integration Testing (SIT) | Complete | COMPLETE |  |  |  |  |  |
| 860 | 1.4.1.7.2.8.2.2 | Develop Overarching SIT Functional Test Readiness Report |  | 20d | 2024-01-22 A | 2024-02-16 A | 859FF | 100% |  | 2024-01-22 | 2024-02-16 | 20d | 2024-01-22 | 2024-02-16 |  |  | Lee Cox | 160h | 160h |  | SI Test |  | 5.0 | Systems Integration Testing (SIT) | Complete | COMPLETE |  |  |  |  |  |
| 861 | 1.4.1.7.2.8.2.3 | Artefact review (via TMAG) and updates |  | 5d | 2024-02-19 A | 2024-02-23 A | 860 | 100% |  | 2024-02-19 | 2024-02-23 | 5d | 2024-02-19 | 2024-02-23 |  |  | Lee Cox | 40h | 40h |  | SI Test | PP,IPA | 5.0 | Systems Integration Testing (SIT) | Complete | COMPLETE |  |  |  |  |  |
| 862 | 1.4.1.7.2.9 | SIT Functional Testing Preparation Complete | milestone | 0d | 2024-03-01 A | 2024-03-01 A | 861FF+5d, 797, 313, 856, 805, 812, 837 | 100% |  | 2024-03-01 | 2024-03-01 | 0d | 2024-03-01 | 2024-03-01 |  |  | Lee Cox |  |  |  | SI Test | PP,IPA | 5.0 | Systems Integration Testing (SIT) | Complete | COMPLETE | T2-TE-0550 | SITAG | T2 |  |  |
| 863 | 1.4.1.7.3 | **SIT Migration Testing Preparation** |  | 420d | 2022-10-31 A | 2024-06-07 |  | 78% | 92.68d | 2022-10-31 | 2024-06-07 | 420d | 2022-11-16 | 2024-06-03 | 775d |  | N/A | 19175.7h | 13453.3h | -0 | N/A | N/A | 5.21 | Systems Integration Testing (SIT) |  |  |  |  |  |  |  |
| 864 | 1.4.1.7.3.1 | **Test Approach & Plan** |  | 75d | 2023-09-07 A | 2023-12-20 A |  | 100% |  | 2023-09-07 | 2023-12-20 | 75d | 2023-09-07 | 2023-12-20 |  |  | N/A | 1199.74h | 1199.74h | -0 | N/A | N/A | 5.0 | Systems Integration Testing (SIT) |  |  |  |  |  |  |  |
| 865 | 1.4.1.7.3.1.1 | Develop document with SITWG |  | 32d | 2023-09-07 A | 2023-10-20 A | 1777 | 100% |  | 2023-09-07 | 2023-10-11 | 25d | 2023-09-07 | 2023-10-11 |  | finish no earlier than 2023-10-11 | Lee Cox | 256h | 256h |  | SI Test |  | 5.0 | Systems Integration Testing (SIT) | Complete | COMPLETE |  |  |  |  |  |
| 866 | 1.4.1.7.3.1.2 | Draft document review with Code Bodies |  | 8d | 2023-10-23 A | 2023-11-01 A | 865 | 100% |  | 2023-10-12 | 2023-10-25 | 10d | 2023-10-12 | 2023-10-25 |  |  | Lee Cox | 64h | 64h |  | SI Test | Code Bodies | 5.0 | Systems Integration Testing (SIT) | Complete | COMPLETE |  |  |  |  |  |
| 867 | 1.4.1.7.3.1.3 | Industry Consultation |  | 10d | 2023-11-02 A | 2023-11-15 A | 866 | 100% |  | 2023-11-02 | 2023-11-15 | 10d |  |  |  |  | Lee Cox | 80h | 80h |  | PP |  | 5.1 | Systems Integration Testing (SIT) | Complete | COMPLETE |  |  |  |  |  |
| 868 | 1.4.1.7.3.1.4 | Artefact review (via TMAG) and updates |  | 25d | 2023-11-16 A | 2023-12-20 A | 867 | 100% |  | 2023-11-09 | 2023-12-20 | 30d | 2023-10-26 | 2023-12-20 |  |  | Lee Cox | 200h | 200h |  | SI Test | PP,IPA,Code Bodies | 5.0 | Systems Integration Testing (SIT) | Complete | COMPLETE |  |  |  |  |  |
| 869 | 1.4.1.7.3.1.5 | SIT Migration Testing Test Approach & Plan approved | milestone | 0d | 2023-12-20 A | 2023-12-20 A | 868 | 100% |  | 2023-12-20 | 2023-12-20 | 1d | 2023-12-20 | 2023-12-20 |  | finish no earlier than 2023-12-20 | Lee Cox |  |  |  | SI Test | PP | 5.14 | Systems Integration Testing (SIT) | Complete | COMPLETE | T3-TE-0018 | SITAG | T3 | MHHS-ART073 |  |
| 870 | 1.4.1.7.3.2 | **Test Data Approach & Plan** |  | 35d | 2023-11-02 A | 2023-12-20 A |  | 100% |  | 2023-11-02 | 2023-12-20 | 35d | 2023-10-26 | 2023-12-20 |  |  | N/A | 560h | 560h | -0 | N/A | N/A | 5.0 | Systems Integration Testing (SIT) |  |  |  |  |  |  |  |
| 871 | 1.4.1.7.3.2.1 | Industry Consultation |  | 10d | 2023-11-02 A | 2023-11-15 A | 867SS | 100% |  | 2023-11-02 | 2023-11-15 | 10d |  |  |  |  | PP | 80h | 80h |  | PP |  | 5.1 | Systems Integration Testing (SIT) | Complete | COMPLETE |  |  |  |  |  |
| 872 | 1.4.1.7.3.2.2 | Artefact review (via TMAG) and updates |  | 25d | 2023-11-16 A | 2023-12-20 A | 871 | 100% |  | 2023-11-09 | 2023-12-20 | 30d | 2023-10-26 | 2023-12-20 |  |  | Richard Puddephatt | 200h | 200h |  | SI Test Data |  | 5.0 | Systems Integration Testing (SIT) | Complete | COMPLETE |  |  |  |  |  |
| 873 | 1.4.1.7.3.2.3 | SIT Migration Test Data Test Approach & Plan approved | milestone | 0d | 2023-12-20 A | 2023-12-20 A | 872 | 100% |  | 2023-12-20 | 2023-12-20 | 0d | 2023-12-20 | 2023-12-20 |  |  | Richard Puddephatt |  |  |  | SI Test Data | PP,IPA | 5.14 | Systems Integration Testing (SIT) | Complete | COMPLETE |  |  |  |  |  |
| 874 | 1.4.1.7.3.3 | **Test scenarios & Test Cases** |  | 85d | 2023-12-21 A | 2024-04-17 |  | 99% | 0d | 2023-12-21 | 2024-03-20 | 65d | 2023-07-24 | 2024-01-17 | 0d |  | N/A | 3128h | 2168h | -0 | N/A | N/A | 5.16 | Systems Integration Testing (SIT) |  |  |  |  |  |  |  |
| 875 | 1.4.1.7.3.3.1 | **Theme 1** |  | 65d | 2023-12-21 A | 2024-03-20 A |  | 100% |  | 2023-12-21 | 2024-03-20 | 65d |  |  |  |  | N/A | 816h | 816h | -0 | N/A | N/A | 5.16 |  |  |  |  |  |  |  | -448.67 |
| 876 | 1.4.1.7.3.3.1.1 | Develop Test Scenarios & Test Cases |  | 25d | 2023-12-21 A | 2024-01-24 A | 869 | 100% |  | 2023-12-21 | 2024-01-24 | 25d |  |  |  |  | Lee Cox | 200h | 200h |  | SI Test | SI Test, PP | 5.16 |  | Complete | COMPLETE |  |  |  |  |  |
| 877 | 1.4.1.7.3.3.1.2 | Industry Review Workshop |  | 1d | 2024-01-25 A | 2024-01-25 A | 876 | 100% |  | 2024-01-25 | 2024-01-25 | 1d |  |  |  |  | Lee Cox | 8h | 8h |  | SI Test, PP | SI Test, PP | 5.16 |  | Complete | COMPLETE |  |  |  |  |  |
| 878 | 1.4.1.7.3.3.1.3 | Industry Consultation Review |  | 6d | 2024-02-05 A | 2024-02-12 A | 877FS+6d | 100% |  | 2024-02-05 | 2024-02-12 | 6d |  |  |  |  | Lee Cox | 48h | 48h |  | SI Test, PP | SI Test, PP | 5.16 |  | Complete | COMPLETE |  |  |  |  |  |
| 879 | 1.4.1.7.3.3.1.4 | Review with SIT Working Group |  | 5d | 2024-02-29 A | 2024-03-06 A | 878FS+12d | 100% |  | 2024-02-29 | 2024-03-06 | 5d |  |  |  |  | Lee Cox | 40h | 40h |  | SI Test, PP | SI Test, PP | 5.19 |  | Complete | COMPLETE |  |  |  |  |  |
| 880 | 1.4.1.7.3.3.1.5 | SIT Migration Test scenarios & Test Cases Approved - Theme 1 | milestone | 0d | 2024-03-20 A | 2024-03-20 A | 879FS+10d | 100% |  | 2024-03-20 | 2024-03-20 | 0d |  |  |  |  | Lee Cox |  |  |  | SI Test | SI Test, PP | 5.21 |  | Complete | COMPLETE | T3-TE-0110 | SITAG |  |  |  |

Notes:
- 862: 28/11 - At risk because of challenges with CCP and PP readiness & dependent on successful Secondary Routing Testing. Approved at 1/3 eSITAG
- 869: 24/10 - Amber because consultation window delayed by 5 days. 20/12 - Approved to complete at TMAG on 20/12
- 873: 20/12 - approved at TMAG on 20/12
- 880: 23/1 - New milestones added because of new themed delivery approach. To go to Feb SITAG for approval

| ID | WBS | Task | Type | Duration | Start | Finish | Predecessors | Complete | Remaining | Baseline start | Baseline finish | Baseline duration | Baseline 1 start | Baseline 1 finish | Total slack | Free slack | Constraint | Resources | Work | Actual work | Baseline cost | Responsible | Involved | Task Status | Update Version | Sched Status | RAG | Milestone ID | Text29 | MHHS Programme Phase | Tier |
| --- | --- | --- | --- | --- | --- | --- | --- | --- | --- | --- | --- | --- | --- | --- | --- | --- | --- | --- | --- | --- | --- | --- | --- | --- | --- | --- | --- | --- | --- | --- | --- |
| 881 | 1.4.1.7.3.3.2 | **Theme 2** |  | 85d | 2023-12-21 A | 2024-04-17 |  | 99% | 0d | 2023-12-21 | 2024-04-17 | 85d |  |  | 0d |  |  | N/A | 1096h | 616h | -0 | N/A | N/A | -448.67 | 5.16 |  |  |  |  |  |  |
| 882 | 1.4.1.7.3.3.2.1 | Develop Test Scenarios & Test Cases |  | 40d | 2023-12-21 A | 2024-02-14 A | 869 | 100% |  | 2023-12-21 | 2024-02-14 | 40d |  |  |  |  |  | Lee Cox | 320h | 320h |  | SI Test | SI Test, PP |  | 5.16 | Complete | COMPLETE |  |  |  |  |
| 883 | 1.4.1.7.3.3.2.2 | Industry Review Workshop |  | 1d | 2024-02-15 A | 2024-02-15 A | 882 | 100% |  | 2024-02-15 | 2024-02-15 | 1d |  |  |  |  |  | Lee Cox | 8h | 8h |  | SI Test, PP | SI Test, PP |  | 5.16 | Complete | COMPLETE |  |  |  |  |
| 884 | 1.4.1.7.3.3.2.3 | Industry Consultation Review |  | 6d | 2024-02-26 A | 2024-03-04 A | 883FS+6d | 100% |  | 2024-02-26 | 2024-03-04 | 6d |  |  |  |  |  | Lee Cox | 48h | 48h |  | SI Test, PP | SI Test, PP |  | 5.19 | Complete | COMPLETE |  |  |  |  |
| 885 | 1.4.1.7.3.3.2.4 | Review with SIT Working Group |  | 5d | 2024-03-28 A | 2024-04-03 A | 884FS+17d | 100% |  | 2024-03-28 | 2024-04-03 | 5d |  |  |  |  |  | Lee Cox | 40h | 40h |  | SI Test, PP | SI Test, PP |  | 5.16 | Complete | COMPLETE |  |  |  |  |
| 886 | 1.4.1.7.3.3.2.5 | SIT Migration Test scenarios & Test Cases Approved - Theme 2 | milestone | 0d | 2024-04-17 A | 2024-04-17 A | 885FS+10d | 100% |  | 2024-04-17 | 2024-04-17 | 0d |  |  |  |  |  | Lee Cox |  |  |  | SI Test | SI Test, PP |  | 5.22 | Complete | COMPLETE | T3-TE-0111 | SITAG |  |  |
| 887 | 1.4.1.7.3.3.3 | **Theme 3** |  | 85d | 2023-12-21 A | 2024-04-17 |  | 99% | 0d | 2023-12-21 | 2024-04-17 | 85d |  |  | 0d |  |  | N/A | 1216h | 736h | -0 | N/A | N/A | -448.67 | 5.16 |  |  |  |  |  |  |
| 888 | 1.4.1.7.3.3.3.1 | Develop Test Scenarios & Test Cases |  | 55d | 2023-12-21 A | 2024-03-06 A | 869 | 100% |  | 2023-12-21 | 2024-03-06 | 55d |  |  |  |  |  | Lee Cox | 440h | 440h |  | SI Test | SI Test, PP |  | 5.19 | Complete | COMPLETE |  |  |  |  |
| 889 | 1.4.1.7.3.3.3.2 | Industry Review Workshop |  | 1d | 2024-03-07 A | 2024-03-07 A | 888 | 100% |  | 2024-03-07 | 2024-03-07 | 1d |  |  |  |  |  | Lee Cox | 8h | 8h |  | SI Test, PP | SI Test, PP |  | 5.16 | Complete | COMPLETE |  |  |  |  |
| 890 | 1.4.1.7.3.3.3.3 | Industry Consultation Review |  | 6d | 2024-03-13 A | 2024-03-20 A | 889FS+3d | 100% |  | 2024-03-13 | 2024-03-20 | 6d |  |  |  |  |  | Lee Cox | 48h | 48h |  | SI Test, PP | SI Test, PP |  | 5.16 | Complete | COMPLETE |  |  |  |  |
| 891 | 1.4.1.7.3.3.3.4 | Review with SIT Working Group |  | 5d | 2024-03-28 A | 2024-04-03 A | 890FS+5d | 100% |  | 2024-03-28 | 2024-04-03 | 5d |  |  |  |  |  | Lee Cox | 40h | 40h |  | SI Test, PP | SI Test, PP |  | 5.16 | Complete | COMPLETE |  |  |  |  |
| 892 | 1.4.1.7.3.3.3.5 | SIT Migration Test scenarios & Test Cases Approved - Theme 3 | milestone | 0d | 2024-04-17 A | 2024-04-17 A | 891FS+10d | 100% |  | 2024-04-17 | 2024-04-17 | 0d |  |  |  |  |  | Lee Cox |  |  |  | SI Test | SI Test, PP |  | 5.22 | Complete | COMPLETE | T3-TE-0112 | SITAG |  |  |
| 893 | 1.4.1.7.3.4 | **Environments (SIT B)** |  | 420d | 2022-10-31 A | 2024-06-07 |  | 80% | 82.21d | 2022-10-31 | 2024-06-07 | 420d | 2022-11-16 | 2024-05-13 | 775d |  |  | N/A | 10688h | 8548.7h | -0 | N/A | N/A |  | 5.0 |  |  |  |  | Systems Integration Testing (SIT) |  |
| 894 | 1.4.1.7.3.4.1 | **PP Environments (SIT B)** |  | 26d | 2024-05-03 | 2024-06-07 |  |  |  | 2024-05-03 | 2024-06-07 | 26d | 2022-11-16 | 2024-05-13 | 775d |  |  | N/A | 368h |  | -0 | N/A | N/A |  | 5.0 |  |  |  |  | Systems Integration Testing (SIT) |  |
| 895 | 1.4.1.7.3.4.1.1 | PP Environments available | milestone | 0d | 2024-05-03 | 2024-05-03 | 466 |  |  | 2024-05-03 | 2024-05-03 | 0d | 2022-11-16 | 2024-04-01 | 775d | 0d | start no earlier than 2024-05-03 | Simon Berry |  |  |  | PP | SI Test | 15.33 | 5.21 | Green | GREEN |  |  | Systems Integration Testing (SIT) |  |
| 896 | 1.4.1.7.3.4.1.2 | PP Onboarding / Smoke test |  | 20d | 2024-05-13 | 2024-06-07 | 895FS+6d |  |  | 2024-05-13 | 2024-06-07 | 20d | 2022-11-16 | 2024-04-01 | 775d |  |  | Simon Berry | 160h |  |  | PP | SI Test | 25.33 | 5.21 | Green | GREEN |  |  | Systems Integration Testing (SIT) |  |
| 897 | 1.4.1.7.3.4.1.3 | DTN Connectivity Proving Complete | milestone | 0d | 2024-05-31 | 2024-05-31 | 895FS+21d |  |  | 2024-05-31 | 2024-05-31 | 0d | 2024-04-15 | 2024-04-26 | 775d | 0d |  | Simon Berry |  |  |  | PP | SI Test | 43.71 | 5.21 | Green | GREEN |  |  | Systems Integration Testing (SIT) |  |
| 898 | 1.4.1.7.3.4.1.4 | PP Code Deployment | milestone | 0d | 2024-06-03 | 2024-06-03 | 897FS+1d |  |  | 2024-06-03 | 2024-06-03 | 0d | 2024-04-29 | 2024-05-13 | 775d | 0d |  | Simon Berry |  |  |  | PP | SI Test | 46.71 | 5.21 | Green | GREEN |  |  | Systems Integration Testing (SIT) |  |
| 899 | 1.4.1.7.3.4.2 | **SI Environments (SIT B)** |  | 420d | 2022-10-31 A | 2024-06-07 |  | 84% | 67.2d | 2022-10-31 | 2024-06-07 | 420d | 2022-11-16 | 2024-05-10 | 775d |  |  | N/A | 6960h | 5846.4h | -0 | N/A | N/A |  | 5.0 |  |  |  |  | Systems Integration Testing (SIT) |  |
| 900 | 1.4.1.7.3.4.2.1 | Coordinate SIT Participants' SIT B environment preparation |  | 420d | 2022-10-31 A | 2024-06-07 |  | 90% | 42d | 2022-10-31 | 2024-06-07 | 420d | 2022-11-16 | 2024-04-01 | 775d | 0d |  | Simon Berry | 3360h | 3024h |  | SI Test | PP |  | 5.21 | Green | GREEN |  |  | Systems Integration Testing (SIT) |  |
| 901 | 1.4.1.7.3.4.2.2 | Assure PPs' self-declaration of environment preparation complete (incl. security certificates and security compliance) | milestone | 0d | 2024-06-07 | 2024-06-07 | 900 |  |  | 2024-06-07 | 2024-06-07 | 0d | 2022-11-16 | 2024-03-29 | 775d |  |  | Simon Berry |  |  |  | SI Test | PP | 50.71 | 5.21 | Green | GREEN |  |  | Systems Integration Testing (SIT) |  |
| 902 | 1.4.1.7.3.4.2.3 | SIT Participants' SIT B environments ready to start connectivity proving (incl. certificates and security compliance) | milestone | 0d | 2024-05-03 | 2024-05-03 | 895 |  |  | 2024-05-03 | 2024-05-03 | 0d | 2024-04-01 | 2024-04-01 | 775d | 0d |  | Simon Berry |  |  |  | SI Test | PP,IPA | 15.33 | 5.22 | Green | GREEN | T3-TE-0033 | SITAG | Systems Integration Testing (SIT) | T3 |
| 903 | 1.4.1.7.3.4.2.4 | Coordinate SIT Participants' SIT B environment connectivity proving |  | 26d | 2024-05-03 | 2024-06-07 | 902 |  |  | 2024-05-14 | 2024-06-07 | 19d | 2024-04-01 | 2024-04-26 | 775d |  |  | Simon Berry | 208h |  |  | SI Test | PP | 15.33 | 5.21 | Green | GREEN |  |  | Systems Integration Testing (SIT) |  |
| 904 | 1.4.1.7.3.4.2.5 | Coordinate deployment of MHHS solution code to SIT Participants' SIT B environments |  | 4d | 2024-06-04 | 2024-06-07 | 898 |  |  | 2024-06-04 | 2024-06-07 | 4d | 2024-04-15 | 2024-04-26 | 775d |  |  | Simon Berry | 32h |  |  | SI Test | PP | 47.33 | 5.21 | Green | GREEN |  |  | Systems Integration Testing (SIT) |  |

Notes:
- 886: 23/1 - New milestones added because of new themed delivery approach
- 892: 23/1 - New milestones added because of new themed delivery approach
- 902: 25/3: To go to April SITAG for date change because plan aligned with FTIG and EWG updates regarding settlement testing plan dates and activities. 17/4: Approved date change at SITAG on 17/4/24

| ID | WBS | Task | Type | Duration | Start | Finish | Predecessors | Complete | Remaining | Baseline start | Baseline finish | Baseline duration | Baseline 1 start | Baseline 1 finish | Total slack | Free slack | Constraint | Resources | Work | Actual work | Baseline cost | Responsible | Involved | Update Version | MHHS Programme Phase | Sched Status | RAG | Task Status | Milestone ID | Text29 | Tier | Artefact ID |
| --- | --- | --- | --- | --- | --- | --- | --- | --- | --- | --- | --- | --- | --- | --- | --- | --- | --- | --- | --- | --- | --- | --- | --- | --- | --- | --- | --- | --- | --- | --- | --- | --- |
| 905 | 1.4.1.7.3.5 | **SIT Migration Test Readiness Report** |  | 44d | 2024-04-02 A | 2024-05-31 |  | 22% | 34.5d | 2024-04-02 | 2024-05-31 | 44d | 2024-04-02 | 2024-05-27 | 0d |  |  | N/A | 2024h | 437.26h | -0 | N/A | N/A | 5.0 | Systems Integration Testing (SIT) |  |  |  |  |  |  |  |
| 906 | 1.4.1.7.3.5.1 | **PP SIT Migration Test Readiness Report** |  | 44d | 2024-04-02 A | 2024-05-31 |  | 23% | 33.85d | 2024-04-02 | 2024-05-31 | 44d | 2024-04-02 | 2024-05-13 | 0d |  |  | N/A | 872h | 201.23h | -0 | N/A | N/A | 5.0 | Systems Integration Testing (SIT) |  |  |  |  |  |  |  |
| 907 | 1.4.1.7.3.5.1.1 | Develop draft Test Readiness Report and submit to Programme for assurance |  | 20d | 2024-04-02 A | 2024-04-29 |  | 60% | 8d | 2024-04-02 | 2024-04-30 | 20d | 2024-04-02 | 2024-04-30 | 0d |  | start no earlier than 2024-04-02 | Lee Cox | 160h | 96h |  | PP | SI Test | 5.0 | Systems Integration Testing (SIT) | Green | GREEN |  |  |  |  |  |
| 908 | 1.4.1.7.3.5.1.2 | Placing Reliance Stage 2 Review |  | 35d | 2024-04-15 A | 2024-05-31 | 907SS+9d | 9% | 32d | 2024-04-15 | 2024-05-31 | 35d |  |  | 0d |  |  | Lee Cox | 280h | 24h |  | SI Test | PP | 5.12 | Systems Integration Testing (SIT) | Green | GREEN |  |  |  |  |  |
| 909 | 1.4.1.7.3.5.1.3 | Finalise Test Readiness Report and submit to Programme for assurance |  | 10d | 2024-04-30 | 2024-05-13 | 907 |  |  | 2024-04-30 | 2024-05-13 | 10d | 2024-04-30 | 2024-05-13 | 0d |  |  | Lee Cox | 80h |  |  | PP | SI Test | 5.0 | Systems Integration Testing (SIT) | Green | GREEN | 12.33 |  |  |  |  |
| 910 | 1.4.1.7.3.5.2 | **SI SIT Migration Test Readiness Report** |  | 40d | 2024-04-02 A | 2024-05-27 |  | 20% | 32d | 2024-04-02 | 2024-05-27 | 40d | 2024-04-02 | 2024-05-27 | -1d | 0d |  | N/A | 800h | 160h |  | N/A | N/A | 5.0 | Systems Integration Testing (SIT) |  |  |  |  |  |  |  |
| 911 | 1.4.1.7.3.5.2.1 | Assure Test Participants' Test Readiness Reports |  | 35d | 2024-04-02 A | 2024-05-20 | 907SS, 909FF+5d | 34% | 23d | 2024-04-02 | 2024-05-20 | 35d | 2024-04-02 | 2024-05-20 | -1d | 0d |  | Lee Cox | 280h | 96h |  | SI Test | PP,IPA | 5.0 | Systems Integration Testing (SIT) | Green | GREEN |  |  |  |  |  |
| 912 | 1.4.1.7.3.5.2.2 | Develop Overarching SIT Migration Test Readiness Report |  | 20d | 2024-04-23 | 2024-05-20 | 911FF |  |  | 2024-04-23 | 2024-05-20 | 20d | 2024-04-23 | 2024-05-20 | -1d | 0d |  | Lee Cox | 160h |  |  | SI Test |  | 5.0 | Systems Integration Testing (SIT) | Green | GREEN | 5.33 |  |  |  |  |
| 913 | 1.4.1.7.3.5.2.3 | Artefact review (via SITAG) and updates |  | 5d | 2024-05-21 | 2024-05-27 | 912 |  |  | 2024-05-21 | 2024-05-27 | 5d | 2024-05-21 | 2024-05-27 | -1d | 0d |  | Lee Cox | 40h |  |  | SI Test | PP,IPA | 5.0 | Systems Integration Testing (SIT) | Green | GREEN | 33.33 |  |  |  |  |
| 914 | 1.4.1.7.3.6 | SIT Migration Testing Preparation Complete | milestone | 0d | 2024-06-03 | 2024-06-03 | 913FF+5d, 869, 330, 908, 880, 886, 892 |  |  | 2024-06-03 | 2024-06-03 | 0d | 2024-06-03 | 2024-06-03 | -1d | 0d |  | Lee Cox |  |  |  | SI Test | PP,IPA | 5.0 | Systems Integration Testing (SIT) | Green | GREEN | 46.71 | T2-TE-0650 | SITAG | T2 |  |
| 915 | 1.4.1.7.4 | **SIT Non-Functional Preparation** |  | 193d | 2023-11-30 A | 2024-08-27 |  | 46% | 104.22d | 2023-11-30 | 2024-08-27 | 193d | 2023-07-03 | 2024-08-26 | 719d |  |  | N/A | 9864h | 3379.46h | -0 | N/A | N/A | 5.0 | Systems Integration Testing (SIT) |  |  |  |  |  |  |  |
| 916 | 1.4.1.7.4.1 | **Test Approach & Plan** |  | 120d | 2023-11-30 A | 2024-05-15 |  | 99% | 0d | 2023-11-30 | 2024-05-15 | 120d | 2023-11-30 | 2024-03-20 | 77d |  |  | N/A | 1696h | 1041.96h | -0 | N/A | N/A | 5.0 | Systems Integration Testing (SIT) |  |  |  |  |  |  |  |
| 917 | 1.4.1.7.4.1.1 | Develop document with SITWG |  | 67d | 2023-11-30 A | 2024-03-01 A |  | 100% |  | 2023-11-30 | 2024-03-01 | 67d | 2023-11-30 | 2024-01-10 |  |  | must start on 2023-11-30 | Lee Cox | 536h | 536h |  | SI Test |  | 5.0 | Systems Integration Testing (SIT) | Complete | COMPLETE |  |  |  |  |  |
| 918 | 1.4.1.7.4.1.2 | Draft document review with Code Bodies |  | 10d | 2024-03-04 A | 2024-03-15 A | 917 | 100% |  | 2024-03-04 | 2024-03-15 | 10d | 2024-01-11 | 2024-01-24 |  |  |  | Lee Cox | 80h | 80h |  | SI Test | Code Bodies | 5.0 | Systems Integration Testing (SIT) | Complete | COMPLETE |  |  |  |  |  |
| 919 | 1.4.1.7.4.1.3 | Industry Consultation |  | 10d | 2024-03-18 A | 2024-03-29 A | 918 | 100% |  | 2024-03-18 | 2024-03-29 | 10d |  |  |  |  |  | Lee Cox | 80h | 80h |  | PP |  | 5.1 | Systems Integration Testing (SIT) | Complete | COMPLETE |  |  |  |  |  |
| 920 | 1.4.1.7.4.1.4 | Industry Assurance Review |  | 5d | 2024-04-11 A | 2024-04-17 A | 919FS+8d | 100% |  | 2024-04-11 | 2024-04-17 | 5d |  |  |  |  |  | Lee Cox | 40h | 40h |  |  |  | 5.16 |  | Complete | COMPLETE |  |  |  |  |  |
| 921 | 1.4.1.7.4.1.5 | SIT Non-Functional Testing Test Approach & Plan approved | milestone | 0d | 2024-05-15 | 2024-05-15 | 920FS+20d |  |  | 2024-05-15 | 2024-05-15 | 0d | 2024-03-20 | 2024-03-20 | 77d | 0d |  | Lee Cox |  |  |  | SI Test | PP | 5.18 | Systems Integration Testing (SIT) | Green | GREEN | 27.71 | T3-TE-0026 | SITAG | T3 | MHHS-ART073 |
| 922 | 1.4.1.7.4.2 | **Test Data Approach & Plan** |  | 41d | 2024-03-20 A | 2024-05-15 |  | 51% | 20d | 2024-03-20 | 2024-05-15 | 41d | 2024-01-25 | 2024-03-20 | 77d |  |  | N/A | 656h | 336h | -0 | N/A | N/A | 5.0 | Systems Integration Testing (SIT) |  |  |  |  |  |  |  |
| 923 | 1.4.1.7.4.2.1 | Industry Consultation |  | 14d | 2024-03-20 A | 2024-04-08 A | 919SS+2d | 100% |  | 2024-03-20 | 2024-04-08 | 14d |  |  |  |  |  | Richard Puddephatt | 112h | 112h |  | PP |  | 5.1 | Systems Integration Testing (SIT) | Complete | COMPLETE |  |  |  |  |  |
| 924 | 1.4.1.7.4.2.2 | Artefact review (via SITAG) and updates |  | 27d | 2024-04-09 A | 2024-05-15 | 923 | 26% | 20d | 2024-04-09 | 2024-05-15 | 27d | 2024-01-25 | 2024-03-13 | 77d | 0d |  | Richard Puddephatt | 216h | 56h |  | SI Test |  | 5.0 | Systems Integration Testing (SIT) | Green | GREEN |  |  |  |  |  |
| 925 | 1.4.1.7.4.2.3 | SIT Non-Functional Testing Test Data Approach & Plan approved | milestone | 0d | 2024-05-15 | 2024-05-15 | 921FF, 924 |  |  | 2024-05-15 | 2024-05-15 | 0d | 2024-03-20 | 2024-03-20 | 77d |  |  | Richard Puddephatt |  |  |  | SI Test | PP,IPA | 5.18 | Systems Integration Testing (SIT) | Green | GREEN | 27.71 | T3-TE-0113 | SITAG |  |  |
| 926 | 1.4.1.7.4.3 | **Test scenarios & Test Cases** |  | 98d | 2024-03-04 A | 2024-07-17 |  | 50% | 48.74d | 2024-03-04 | 2024-07-17 | 98d | 2023-07-24 | 2024-01-17 | 27d |  |  | N/A | 3952h | 2001.49h | -0 | N/A | N/A | 5.21 | Systems Integration Testing (SIT) |  |  |  |  |  |  |  |
| 927 | 1.4.1.7.4.3.1 | **Theme 1** |  | 78d | 2024-03-04 A | 2024-06-19 |  | 61% | 30.52d | 2024-03-04 | 2024-06-19 | 78d |  |  | 47d |  |  | N/A | 992h | 603.83h | -0 | N/A | N/A | 5.21 |  |  |  | -448.67 |  |  |  |  |
| 928 | 1.4.1.7.4.3.1.1 | Develop Test Scenarios & Test Cases |  | 33d | 2024-03-04 A | 2024-04-17 | 917 | 85% | 5d | 2024-03-04 | 2024-04-17 | 33d |  |  | 47d | 0d |  | Lee Cox | 264h | 224h |  | SI Test | SI Test, PP | 5.21 |  | Overdue | RED |  |  |  |  |  |
| 929 | 1.4.1.7.4.3.1.2 | Industry Review Workshop |  | 1d | 2024-04-18 | 2024-04-18 | 928 |  |  | 2024-04-18 | 2024-04-18 | 1d |  |  | 47d | 0d |  | Lee Cox | 8h |  |  | SI Test, PP | SI Test, PP | 5.21 |  | Green | GREEN | 0.33 |  |  |  |  |
| 930 | 1.4.1.7.4.3.1.3 | Industry Consultation Review |  | 7d | 2024-05-02 | 2024-05-10 | 929FS+9d |  |  | 2024-05-02 | 2024-05-10 | 7d |  |  | 47d | 0d |  | Lee Cox | 56h |  |  | SI Test, PP | SI Test, PP | 5.21 |  | Green | GREEN | 14.33 |  |  |  |  |
| 931 | 1.4.1.7.4.3.1.4 | Review with NFT Working Group |  | 5d | 2024-05-31 | 2024-06-06 | 930FS+14d |  |  | 2024-05-31 | 2024-06-06 | 5d |  |  | 47d | 0d |  | Lee Cox | 40h |  |  | SI Test, PP | SI Test, PP | 5.21 |  | Green | GREEN | 43.33 |  |  |  |  |
| 932 | 1.4.1.7.4.3.1.5 | SIT NFT Scenarios & Test Cases Approved - Theme 1 | milestone | 0d | 2024-06-19 | 2024-06-19 | 931FS+9d |  |  | 2024-06-19 | 2024-06-19 | 0d |  |  | 47d |  |  | Lee Cox |  |  |  | SI Test | SI Test, PP | 5.22 |  | Green | GREEN | 62.71 | T3-TE-0114 | SITAG |  |  |

Notes:
- 921: 16/1 - Milestone will be missed, recovery planning taking place. To go to Feb SITAG for date change approval. 21/2/24 - Date change approved at SITAG on 21/2/24. 27/2 At risk because of tight delivery schedule
- 925: 13/2 - To go to Feb SITAG as a new milestone. 21/2/24 - Approved at SITAG on 21/2/24 as a new milestone. 3/4 At risk because of tight delivery schedule (added as amber to align with Lee's status)
- 932: 23/1 - New milestone added because of NFT themed delivery approach. To go to April SITAG for approval 17/4: Approved new milestone at SITAG on 17/4/24

| ID | WBS | Task | Type | Duration | Start | Finish | Predecessors | Complete | Remaining | Baseline start | Baseline finish | Baseline duration | Baseline 1 start | Baseline 1 finish | Total slack | Free slack | Constraint | Resources | Work | Actual work | Baseline cost | Responsible | Involved | Task Status | Update Version | Sched Status | RAG | Milestone ID | Text29 | MHHS Programme Phase | Action | Tier |
| --- | --- | --- | --- | --- | --- | --- | --- | --- | --- | --- | --- | --- | --- | --- | --- | --- | --- | --- | --- | --- | --- | --- | --- | --- | --- | --- | --- | --- | --- | --- | --- | --- |
| 933 | 1.4.1.7.4.3.2 | **Theme 2** |  | 98d | 2024-03-04 A | 2024-07-17 |  | 50% | 49d | 2024-03-04 | 2024-07-17 | 98d |  |  | 27d |  |  | N/A | 1312h | 656h |  | N/A | N/A | -448.67 | 5.21 |  |  |  |  |  |  |  |
| 934 | 1.4.1.7.4.3.2.1 | Develop Test Scenarios & Test Cases |  | 53d | 2024-03-04 A | 2024-05-15 | 917 | 62% | 20d | 2024-03-04 | 2024-05-15 | 53d |  |  | 27d | 0d |  | Lee Cox | 424h | 264h |  | SI Test | SI Test, PP |  | 5.21 | Green | GREEN |  |  |  |  |  |
| 935 | 1.4.1.7.4.3.2.2 | Industry Review Workshop |  | 1d | 2024-05-16 | 2024-05-16 | 934 |  |  | 2024-05-16 | 2024-05-16 | 1d |  |  | 27d | 0d |  | Lee Cox | 8h |  |  | SI Test, PP | SI Test, PP | 28.33 | 5.21 | Green | GREEN |  |  |  |  |  |
| 936 | 1.4.1.7.4.3.2.3 | Industry Consultation Review |  | 7d | 2024-05-20 | 2024-05-28 | 935FS+1d |  |  | 2024-05-20 | 2024-05-28 | 7d |  |  | 27d | 0d |  | Lee Cox | 56h |  |  | SI Test, PP | SI Test, PP | 32.33 | 5.21 | Green | GREEN |  |  |  |  |  |
| 937 | 1.4.1.7.4.3.2.4 | Review with NFT Working Group |  | 5d | 2024-06-28 | 2024-07-04 | 936FS+22d |  |  | 2024-06-28 | 2024-07-04 | 5d |  |  | 27d | 0d |  | Lee Cox | 40h |  |  | SI Test, PP | SI Test, PP | 71.33 | 5.21 | Green | GREEN |  |  |  |  |  |
| 938 | 1.4.1.7.4.3.2.5 | SIT NFT Scenarios & Test Cases Approved - Theme 2 | milestone | 0d | 2024-07-17 | 2024-07-17 | 937FS+9d |  |  | 2024-07-17 | 2024-07-17 | 0d |  |  | 27d |  |  | Lee Cox |  |  |  | SI Test | SI Test, PP | 90.71 | 5.22 | Green | GREEN | T3-TE-0115 | SITAG |  |  |  |
| 939 | 1.4.1.7.4.3.3 | **Theme 3** |  | 98d | 2024-03-04 A | 2024-07-17 |  | 44% | 54.88d | 2024-03-04 | 2024-07-17 | 98d |  |  | 27d |  |  | N/A | 1384h | 608.96h | -0 | N/A | N/A | -448.67 | 5.21 |  |  |  |  |  |  |  |
| 940 | 1.4.1.7.4.3.3.1 | Develop Test Scenarios & Test Cases |  | 63d | 2024-03-04 A | 2024-05-29 | 917 | 52% | 30d | 2024-03-04 | 2024-05-29 | 63d |  |  | 27d | 0d |  | Lee Cox | 504h | 264h |  | SI Test | SI Test, PP |  | 5.21 | Green | GREEN |  |  |  |  |  |
| 941 | 1.4.1.7.4.3.3.2 | Industry Review Workshop |  | 1d | 2024-05-30 | 2024-05-30 | 940 |  |  | 2024-05-30 | 2024-05-30 | 1d |  |  | 27d | 0d |  | Lee Cox | 8h |  |  | SI Test, PP | SI Test, PP | 42.33 | 5.21 | Green | GREEN |  |  |  |  |  |
| 942 | 1.4.1.7.4.3.3.3 | Industry Consultation Review |  | 6d | 2024-06-10 | 2024-06-17 | 941FS+6d |  |  | 2024-06-10 | 2024-06-17 | 6d |  |  | 27d | 0d |  | Lee Cox | 48h |  |  | SI Test, PP | SI Test, PP | 53.33 | 5.21 | Green | GREEN |  |  |  |  |  |
| 943 | 1.4.1.7.4.3.3.4 | Review with NFT Working Group |  | 5d | 2024-06-28 | 2024-07-04 | 942FS+8d |  |  | 2024-06-28 | 2024-07-04 | 5d |  |  | 27d | 0d |  | Lee Cox | 40h |  |  | SI Test, PP | SI Test, PP | 71.33 | 5.21 | Green | GREEN |  |  |  |  |  |
| 944 | 1.4.1.7.4.3.3.5 | SIT NFT Scenarios & Test Cases Approved - Theme 3 | milestone | 0d | 2024-07-17 | 2024-07-17 | 943FS+9d |  |  | 2024-07-17 | 2024-07-17 | 0d |  |  | 27d |  |  | Lee Cox |  |  |  | SI Test | SI Test, PP | 90.71 | 5.22 | Green | GREEN | T3-TE-0114 | SITAG |  |  |  |
| 945 | 1.4.1.7.4.4 | **Environments (SIT B)** |  | 0d | 2024-08-27 | 2024-08-27 |  |  |  | 2024-08-27 | 2024-08-27 | 0d | 2024-07-30 | 2024-08-05 | 719d |  |  | N/A |  |  | -0 | N/A | N/A |  | 5.0 |  |  |  |  | Systems Integration Testing (SIT) |  |  |
| 946 | 1.4.1.7.4.4.1 | **PP Environments (SIT B)** |  | 0d | 2024-08-27 | 2024-08-27 |  |  |  | 2024-08-27 | 2024-08-27 | 0d | 2024-07-30 | 2024-08-05 | 719d |  |  | N/A |  |  | -0 | N/A | N/A |  | 5.0 |  |  |  |  | Systems Integration Testing (SIT) |  |  |
| 947 | 1.4.1.7.4.4.1.1 | Deployment of MHHS solution code to SIT B environments | milestone | 0d | 2024-08-27 | 2024-08-27 |  |  |  | 2024-08-27 | 2024-08-27 | 0d | 2024-07-30 | 2024-08-05 | 719d | 0d | start no earlier than 2024-08-27 | Simon Berry |  |  |  | PP | SI Test | 131.33 | 5.21 | Green | GREEN |  |  | Systems Integration Testing (SIT) | 26/3/24: Lee said change to SB and align to IR7 |  |
| 948 | 1.4.1.7.4.4.2 | **SI Environments (SIT B)** |  | 0d | 2024-08-27 | 2024-08-27 |  |  |  | 2024-08-27 | 2024-08-27 | 0d | 2024-07-30 | 2024-08-05 | 719d |  |  | N/A |  |  | -0 | N/A | N/A |  | 5.0 |  |  |  |  | Systems Integration Testing (SIT) |  |  |
| 949 | 1.4.1.7.4.4.2.1 | Coordinate deployment of MHHS solution code to SIT Participants' SIT B environments | milestone | 0d | 2024-08-27 | 2024-08-27 | 947SS |  |  | 2024-08-27 | 2024-08-27 | 0d | 2024-07-30 | 2024-08-05 | 719d |  |  | Simon Berry |  |  |  | SI Test | PP | 131.33 | 5.21 | Green | GREEN |  |  | Systems Integration Testing (SIT) |  |  |
| 950 | 1.4.1.7.4.5 | **SIT Non-Functional Test Readiness Report** |  | 44d | 2024-06-25 | 2024-08-23 |  |  |  | 2024-06-25 | 2024-08-23 | 44d | 2024-06-25 | 2024-08-19 | -1d | 0d |  | N/A | 2064h |  | -0 | N/A | N/A |  | 5.0 |  |  |  |  | Systems Integration Testing (SIT) |  |  |
| 951 | 1.4.1.7.4.5.1 | **PP SIT Non-Functional Test Readiness Report** |  | 44d | 2024-06-25 | 2024-08-23 |  |  |  | 2024-06-25 | 2024-08-23 | 44d | 2024-06-25 | 2024-08-05 | -1d | 0d |  | N/A | 912h |  | -0 | N/A | N/A |  | 5.0 |  |  |  |  | Systems Integration Testing (SIT) |  |  |
| 952 | 1.4.1.7.4.5.1.1 | Develop draft Test Readiness Report and submit to Programme for assurance |  | 20d | 2024-06-25 | 2024-07-22 |  |  |  | 2024-06-25 | 2024-07-22 | 20d | 2024-06-25 | 2024-07-22 | -1d | 0d | start no earlier than 2024-06-25 | Lee Cox | 160h |  |  | PP | SI Test | 68.33 | 5.0 | Green | GREEN |  |  | Systems Integration Testing (SIT) |  |  |
| 953 | 1.4.1.7.4.5.1.2 | Placing Reliance Stage 2 Review |  | 40d | 2024-07-01 | 2024-08-23 | 952SS+4d |  |  | 2024-07-01 | 2024-08-23 | 40d |  |  | 0d |  |  | Lee Cox | 320h |  |  | SI Test | PP | 74.33 | 5.12 | Green | GREEN |  |  | Systems Integration Testing (SIT) |  |  |
| 954 | 1.4.1.7.4.5.1.3 | Finalise Test Readiness Report and submit to Programme for assurance |  | 10d | 2024-07-23 | 2024-08-05 | 952 |  |  | 2024-07-23 | 2024-08-05 | 10d | 2024-07-23 | 2024-08-05 | -1d | 0d |  | Lee Cox | 80h |  |  | PP | SI Test | 96.33 | 5.0 | Green | GREEN |  |  | Systems Integration Testing (SIT) |  |  |
| 955 | 1.4.1.7.4.5.2 | **SI SIT Non-Functional Test Readiness Report** |  | 40d | 2024-06-25 | 2024-08-19 |  |  |  | 2024-06-25 | 2024-08-19 | 40d | 2024-06-25 | 2024-08-19 | -1d | 0d |  | N/A | 800h |  |  | N/A | N/A |  | 5.0 |  |  |  |  | Systems Integration Testing (SIT) |  |  |
| 956 | 1.4.1.7.4.5.2.1 | Assure Test Participants' Test Readiness Reports |  | 35d | 2024-06-25 | 2024-08-12 | 952SS, 954FF+5d |  |  | 2024-06-25 | 2024-08-12 | 35d | 2024-06-25 | 2024-08-12 | -1d | 0d |  | Lee Cox | 280h |  |  | SI Test | PP,IPA | 68.33 | 5.0 | Green | GREEN |  |  | Systems Integration Testing (SIT) |  |  |
| 957 | 1.4.1.7.4.5.2.2 | Develop Overarching SIT Non-Functional Test Readiness Report |  | 20d | 2024-07-16 | 2024-08-12 | 956FF |  |  | 2024-07-16 | 2024-08-12 | 20d | 2024-07-16 | 2024-08-12 | -1d | 0d |  | Lee Cox | 160h |  |  | SI Test |  | 89.33 | 5.0 | Green | GREEN |  |  | Systems Integration Testing (SIT) |  |  |
| 958 | 1.4.1.7.4.5.2.3 | Artefact review (via SITAG) and updates |  | 5d | 2024-08-13 | 2024-08-19 | 957 |  |  | 2024-08-13 | 2024-08-19 | 5d | 2024-08-13 | 2024-08-19 | -1d | 0d |  | Lee Cox | 40h |  |  | SI Test | PP,IPA | 117.33 | 5.0 | Green | GREEN |  |  | Systems Integration Testing (SIT) |  |  |
| 959 | 1.4.1.7.4.6 | SIT Non-Functional Testing Preparation Complete | milestone | 0d | 2024-08-26 | 2024-08-26 | 958FF+5d, 797, 347, 953, 932, 938, 944 |  |  | 2024-08-26 | 2024-08-26 | 0d | 2024-08-26 | 2024-08-26 | -1d | 0d |  | Lee Cox |  |  |  | SI Test | PP,IPA | 130.71 | 5.0 | Green | GREEN | T2-TE-0700 | SITAG | Systems Integration Testing (SIT) |  | T2 |

Notes:
- 938: 23/1 - New milestone added because of NFT themed delivery approach. To go to April SITAG for approval 17/4: Approved new milestone at SITAG on 17/4/24
- 944: 23/1 - New milestone added because of NFT themed delivery approach. To go to April SITAG for approval 17/4: Approved new milestone at SITAG on 17/4/24
- 947: 25/3: SB - Date aligns to IR8 code delivery for SIT B
- 949: 25/3: SB - Date aligns to IR8 code delivery for SIT B

| ID | WBS | Task | Type | Duration | Start | Finish | Predecessors | Complete | Remaining | Baseline start | Baseline finish | Baseline duration | Baseline 1 start | Baseline 1 finish | Total slack | Free slack | Constraint | Resources | Work | Actual work | Baseline cost | Responsible | Involved | Update Version | MHHS Programme Phase | Sched Status | RAG | Artefact ID | Task Status | Milestone ID | Text29 | Tier |
| --- | --- | --- | --- | --- | --- | --- | --- | --- | --- | --- | --- | --- | --- | --- | --- | --- | --- | --- | --- | --- | --- | --- | --- | --- | --- | --- | --- | --- | --- | --- | --- | --- |
| 960 | 1.4.1.7.5 | **SIT Operational Preparation** |  | 170d | 2024-02-01 A | 2024-09-25 |  | 28% | 121.69d | 2024-02-01 | 2025-03-03 | 283d | 2023-08-03 | 2025-03-10 | 697d |  |  | N/A | 7152h | 1876.88h | -0 | N/A | N/A | 5.0 | Systems Integration Testing (SIT) |  |  |  |  |  |  |  |
| 961 | 1.4.1.7.5.1 | **Test Approach & Plan** |  | 75d | 2024-02-01 A | 2024-05-15 |  | 69% | 23.08d | 2024-02-01 | 2024-05-15 | 75d | 2024-02-01 | 2024-05-15 | 98d |  |  | N/A | 1120h | 775.38h | -0 | N/A | N/A | 5.0 | Systems Integration Testing (SIT) |  |  |  |  |  |  |  |
| 962 | 1.4.1.7.5.1.1 | Develop document with SITWG |  | 25d | 2024-02-01 A | 2024-03-06 A |  | 100% |  | 2024-02-01 | 2024-03-06 | 25d | 2024-02-01 | 2024-03-06 |  |  | must start on 2024-02-01 | Lee Cox | 200h | 200h |  | SI Test |  | 5.0 | Systems Integration Testing (SIT) | Complete | COMPLETE |  |  |  |  |  |
| 963 | 1.4.1.7.5.1.2 | Draft document review with Code Bodies |  | 4d | 2024-03-21 A | 2024-03-26 A | 962FS+10d | 100% |  | 2024-03-07 | 2024-03-20 | 10d | 2024-03-07 | 2024-03-20 |  |  |  | Lee Cox | 32h | 32h |  | SI Test | Code Bodies | 5.0 | Systems Integration Testing (SIT) | Complete | COMPLETE |  |  |  |  |  |
| 964 | 1.4.1.7.5.1.3 | Industry Consultation |  | 10d | 2024-03-27 A | 2024-04-09 A | 963 | 100% |  | 2024-03-27 | 2024-04-09 | 10d |  |  |  |  |  | Lee Cox | 80h | 80h |  | PP |  | 5.1 | Systems Integration Testing (SIT) | Complete | COMPLETE |  |  |  |  |  |
| 965 | 1.4.1.7.5.1.4 | Artefact review (via SITAG) and updates |  | 26d | 2024-04-10 A | 2024-05-15 | 964 | 23% | 20d | 2024-04-04 | 2024-05-15 | 30d | 2024-03-21 | 2024-05-15 | 98d | 0d |  | Lee Cox | 208h | 48h |  | SI Test | PP,IPA,Code Bodies | 5.0 | Systems Integration Testing (SIT) | Green | GREEN |  |  |  |  |  |
| 966 | 1.4.1.7.5.1.5 | SIT Operational Testing Test Approach & Plan approved | milestone | 0d | 2024-05-15 | 2024-05-15 | 965 |  |  | 2024-05-15 | 2024-05-15 | 0d | 2024-05-15 | 2024-05-15 | 98d | 0d |  | Lee Cox |  |  |  | SI Test | PP | 5.0 | Systems Integration Testing (SIT) | Green | GREEN | MHHS-ART073 | 27.71 | T3-TE-0029 | SITAG | T3 |
| 967 | 1.4.1.7.5.2 | **Test Data Approach & Plan** |  | 36d | 2024-03-27 A | 2024-05-15 |  | 44% | 20d | 2024-03-27 | 2024-05-15 | 36d | 2024-03-21 | 2024-05-15 | 98d |  |  | N/A | 576h | 256h | -0 | N/A | N/A | 5.0 | Systems Integration Testing (SIT) |  |  |  |  |  |  |  |
| 968 | 1.4.1.7.5.2.1 | Industry Consultation |  | 10d | 2024-03-27 A | 2024-04-09 A | 964SS | 100% |  | 2024-03-27 | 2024-04-09 | 10d |  |  |  |  |  | Richard Puddephatt | 80h | 80h |  | PP |  | 5.1 | Systems Integration Testing (SIT) | Complete | COMPLETE |  |  |  |  |  |
| 969 | 1.4.1.7.5.2.2 | Artefact review (via SITAG) and updates |  | 26d | 2024-04-10 A | 2024-05-15 | 968 | 23% | 20d | 2024-04-10 | 2024-05-15 | 26d | 2024-03-21 | 2024-05-15 | 98d | 0d |  | Richard Puddephatt | 208h | 48h |  | SI Test |  | 5.0 | Systems Integration Testing (SIT) | Green | GREEN |  |  |  |  |  |
| 970 | 1.4.1.7.5.2.3 | SIT Operational Testing Test Data Approach & Plan approved | milestone | 0d | 2024-05-15 | 2024-05-15 | 969 |  |  | 2024-05-15 | 2024-05-15 | 0d | 2024-05-15 | 2024-05-15 | 98d |  |  | Richard Puddephatt |  |  |  | SI Test | PP,IPA | 5.0 | Systems Integration Testing (SIT) | Green | GREEN |  | 27.71 |  |  |  |
| 971 | 1.4.1.7.5.3 | **Test scenarios & Test Cases** |  | 96d | 2024-04-10 A | 2024-08-21 |  | 14% | 82.6d | 2024-04-10 | 2024-08-21 | 96d | 2023-07-24 | 2024-01-17 | 20d |  |  | N/A | 3184h | 459.02h | -0 | N/A | N/A | 5.21 | Systems Integration Testing (SIT) |  |  |  |  |  |  |  |
| 972 | 1.4.1.7.5.3.1 | **Theme 1** |  | 71d | 2024-04-10 A | 2024-07-17 |  | 21% | 55.79d | 2024-04-10 | 2024-07-17 | 71d |  |  | 45d |  |  | N/A | 792h | 169.72h |  | N/A | N/A | 5.21 |  |  |  |  | -448.67 |  |  |  |
| 973 | 1.4.1.7.5.3.1.1 | Develop Test Scenarios & Test Cases |  | 16d | 2024-04-10 A | 2024-05-01 | 964 | 38% | 10d | 2024-04-10 | 2024-05-01 | 16d |  |  | 45d | 0d |  | Lee Cox | 128h | 48h |  | SI Test | SI Test, PP | 5.21 |  | Green | GREEN |  |  |  |  |  |
| 974 | 1.4.1.7.5.3.1.2 | Industry Review Workshop |  | 1d | 2024-05-02 | 2024-05-02 | 973 |  |  | 2024-05-02 | 2024-05-02 | 1d |  |  | 45d | 0d |  | Lee Cox | 8h |  |  | SI Test, PP | SI Test, PP | 5.21 |  | Green | GREEN |  | 14.33 |  |  |  |
| 975 | 1.4.1.7.5.3.1.3 | Industry Consultation Review |  | 6d | 2024-05-10 | 2024-05-17 | 974FS+5d |  |  | 2024-05-10 | 2024-05-17 | 6d |  |  | 45d | 0d |  | Lee Cox | 48h |  |  | SI Test, PP | SI Test, PP | 5.21 |  | Green | GREEN |  | 22.33 |  |  |  |
| 976 | 1.4.1.7.5.3.1.4 | Review with SIT Working Group |  | 5d | 2024-06-27 | 2024-07-03 | 975FS+28d |  |  | 2024-06-27 | 2024-07-03 | 5d |  |  | 45d | 0d |  | Lee Cox | 40h |  |  | SI Test, PP | SI Test, PP | 5.21 |  | Green | GREEN |  | 70.33 |  |  |  |
| 977 | 1.4.1.7.5.3.1.5 | SIT Operational Scenarios & Test Cases Approved - Theme 1 | milestone | 0d | 2024-07-17 | 2024-07-17 | 976FS+10d |  |  | 2024-07-17 | 2024-07-17 | 0d |  |  | 45d |  |  | Lee Cox |  |  |  | SI Test | SI Test, PP | 5.22 |  | Green | GREEN |  | 90.71 | T3-TE-0117 | SITAG |  |
| 978 | 1.4.1.7.5.3.2 | **Theme 2** |  | 71d | 2024-04-10 A | 2024-07-17 |  | 14% | 61.09d | 2024-04-10 | 2024-07-17 | 71d |  |  | 45d |  |  | N/A | 912h | 127.25h |  | N/A | N/A | 5.21 |  |  |  |  | -448.67 |  |  |  |
| 979 | 1.4.1.7.5.3.2.1 | Develop Test Scenarios & Test Cases |  | 31d | 2024-04-10 A | 2024-05-22 | 964 | 19% | 25d | 2024-04-10 | 2024-05-22 | 31d |  |  | 45d | 0d |  | Lee Cox | 248h | 48h |  | SI Test | SI Test, PP | 5.21 |  | Green | GREEN |  |  |  |  |  |
| 980 | 1.4.1.7.5.3.2.2 | Industry Review Workshop |  | 1d | 2024-05-23 | 2024-05-23 | 979 |  |  | 2024-05-23 | 2024-05-23 | 1d |  |  | 45d | 0d |  | Lee Cox | 8h |  |  | SI Test, PP | SI Test, PP | 5.21 |  | Green | GREEN |  | 35.33 |  |  |  |
| 981 | 1.4.1.7.5.3.2.3 | Industry Consultation Review |  | 6d | 2024-06-04 | 2024-06-11 | 980FS+7d |  |  | 2024-06-04 | 2024-06-11 | 6d |  |  | 45d | 0d |  | Lee Cox | 48h |  |  | SI Test, PP | SI Test, PP | 5.21 |  | Green | GREEN |  | 47.33 |  |  |  |
| 982 | 1.4.1.7.5.3.2.4 | Review with SIT Working Group |  | 5d | 2024-06-27 | 2024-07-03 | 981FS+11d |  |  | 2024-06-27 | 2024-07-03 | 5d |  |  | 45d | 0d |  | Lee Cox | 40h |  |  | SI Test, PP | SI Test, PP | 5.21 |  | Green | GREEN |  | 70.33 |  |  |  |
| 983 | 1.4.1.7.5.3.2.5 | SIT Operational Scenarios & Test Cases Approved - Theme 2 | milestone | 0d | 2024-07-17 | 2024-07-17 | 982FS+10d |  |  | 2024-07-17 | 2024-07-17 | 0d |  |  | 45d |  |  | Lee Cox |  |  |  | SI Test | SI Test, PP | 5.22 |  | Green | GREEN |  | 90.71 | T3-TE-0118 | SITAG |  |

Notes:
- 966: 26/3 - At risk because of tight delivery schedule
- 977: 23/1 - New milestone added because of NFT themed delivery approach. To go to April SITAG for approval. 17/4: Approved as new milestone at SITAG on 17/4/24
- 983: 23/1 - New milestone added because of Operatiional themed delivery approach. To go to April SITAG for approval. 17/4: Approved as new milestone at SITAG on 17/4/24

| ID | WBS | Task | Type | Duration | Start | Finish | Predecessors | Complete | Remaining | Baseline start | Baseline finish | Baseline duration | Baseline 1 start | Baseline 1 finish | Total slack | Free slack | Constraint | Resources | Work | Actual work | Baseline cost | Responsible | Involved | Task Status | Update Version | Sched Status | RAG | Milestone ID | Text29 | MHHS Programme Phase | Tier | Artefact ID | Text3 |
| --- | --- | --- | --- | --- | --- | --- | --- | --- | --- | --- | --- | --- | --- | --- | --- | --- | --- | --- | --- | --- | --- | --- | --- | --- | --- | --- | --- | --- | --- | --- | --- | --- | --- |
| 984 | 1.4.1.7.5.3.3 | **Theme 3** |  | 96d | 2024-04-10 A | 2024-08-21 |  | 10% | 86.07d | 2024-04-10 | 2024-08-21 | 96d |  |  | 20d |  |  | N/A | 1232h | 127.45h |  | N/A | N/A | -448.67 | 5.21 |  |  |  |  |  |  |  |  |
| 985 | 1.4.1.7.5.3.3.1 | Develop Test Scenarios & Test Cases |  | 46d | 2024-04-10 A | 2024-06-12 | 964 | 13% | 40d | 2024-04-10 | 2024-06-12 | 46d |  |  | 20d | 0d |  | Lee Cox | 368h | 48h |  | SI Test | SI Test, PP |  | 5.21 | Green | GREEN |  |  |  |  |  |  |
| 986 | 1.4.1.7.5.3.3.2 | Industry Review Workshop |  | 1d | 2024-06-13 | 2024-06-13 | 985 |  |  | 2024-06-13 | 2024-06-13 | 1d |  |  | 20d | 0d |  | Lee Cox | 8h |  |  | SI Test, PP | SI Test, PP | 56.33 | 5.21 | Green | GREEN |  |  |  |  |  |  |
| 987 | 1.4.1.7.5.3.3.3 | Industry Consultation Review |  | 6d | 2024-06-24 | 2024-07-01 | 986FS+6d |  |  | 2024-06-24 | 2024-07-01 | 6d |  |  | 20d | 0d |  | Lee Cox | 48h |  |  | SI Test, PP | SI Test, PP | 67.33 | 5.21 | Green | GREEN |  |  |  |  |  |  |
| 988 | 1.4.1.7.5.3.3.4 | Review with SIT Working Group |  | 5d | 2024-07-25 | 2024-07-31 | 987FS+17d |  |  | 2024-07-25 | 2024-07-31 | 5d |  |  | 20d | 0d |  | Lee Cox | 40h |  |  | SI Test, PP | SI Test, PP | 98.33 | 5.21 | Green | GREEN |  |  |  |  |  |  |
| 989 | 1.4.1.7.5.3.3.5 | SIT Operational Scenarios & Test Cases Approved - Theme 3 | milestone | 0d | 2024-08-21 | 2024-08-21 | 988FS+15d |  |  | 2024-08-21 | 2024-08-21 | 0d |  |  | 20d |  |  | Lee Cox |  |  |  | SI Test | SI Test, PP | 125.71 | 5.22 | Green | GREEN | T3-TE-0114 | SITAG |  |  |  |  |
| 990 | 1.4.1.7.5.4 | **Environments (SIT B)** |  | 0d | 2024-08-27 | 2024-08-27 |  |  |  | 2024-08-27 | 2024-08-27 | 0d | 2024-09-03 | 2024-09-09 | 719d |  |  | N/A |  |  | -0 | N/A | N/A |  | 5.0 |  |  |  |  | Systems Integration Testing (SIT) |  |  |  |
| 991 | 1.4.1.7.5.4.1 | **PP Environments (SIT B)** |  | 0d | 2024-08-27 | 2024-08-27 |  |  |  | 2024-08-27 | 2024-08-27 | 0d | 2024-09-03 | 2024-09-09 | 719d |  |  | N/A |  |  | -0 | N/A | N/A |  | 5.0 |  |  |  |  | Systems Integration Testing (SIT) |  |  |  |
| 992 | 1.4.1.7.5.4.1.1 | Deployment of MHHS solution code to SIT B environments | milestone | 0d | 2024-08-27 | 2024-08-27 |  |  |  | 2024-08-27 | 2024-08-27 | 0d | 2024-09-03 | 2024-09-09 | 719d | 0d | start no earlier than 2024-08-27 | Simon Berry |  |  |  | PP | SI Test | 131.33 | 5.21 | Green | GREEN |  |  | Systems Integration Testing (SIT) |  |  |  |
| 993 | 1.4.1.7.5.4.2 | **SI Environments (SIT B)** |  | 0d | 2024-08-27 | 2024-08-27 |  |  |  | 2024-08-27 | 2024-08-27 | 0d | 2024-09-03 | 2024-09-09 | 719d |  |  | N/A |  |  | -0 | N/A | N/A |  | 5.0 |  |  |  |  | Systems Integration Testing (SIT) |  |  |  |
| 994 | 1.4.1.7.5.4.2.1 | Coordinate deployment of MHHS solution code to SIT Participants' SIT B environments | milestone | 0d | 2024-08-27 | 2024-08-27 | 992SS |  |  | 2024-08-27 | 2024-08-27 | 0d | 2024-09-03 | 2024-09-09 | 719d |  |  | Simon Berry |  |  |  | SI Test | PP | 131.33 | 5.21 | Green | GREEN |  |  | Systems Integration Testing (SIT) |  |  |  |
| 995 | 1.4.1.7.5.5 | **SIT Operational Test Readiness Report** |  | 33d | 2024-08-05 | 2024-09-18 |  |  |  | 2024-08-05 | 2025-03-03 | 151d | 2025-01-07 | 2025-03-03 | -5d | 0d |  | N/A | 912h |  | -0 | N/A | N/A |  | 5.0 |  |  |  |  | Systems Integration Testing (SIT) |  |  |  |
| 996 | 1.4.1.7.5.5.1 | **PP SIT Operational Test Readiness Report** |  | 0d | 2024-08-05 | 2024-08-05 |  |  |  | 2024-08-05 | 2025-02-03 | 131d | 2025-01-07 | 2025-02-17 | -5d | 0d |  | N/A |  |  | -0 | N/A | N/A |  | 5.0 |  |  |  |  | Systems Integration Testing (SIT) |  |  |  |
| 997 | 1.4.1.7.5.5.1.1 | Test Readiness Report submitted to Programme for assurance | milestone | 0d | 2024-08-05 | 2024-08-05 |  |  |  | 2025-01-07 | 2025-02-03 | 20d | 2025-01-07 | 2025-02-03 | -5d | 0d | start no earlier than 2024-08-05 | Lee Cox |  |  |  | PP | SI Test | 109.33 | 5.0 | Green | GREEN |  |  | Systems Integration Testing (SIT) |  |  |  |
| 998 | 1.4.1.7.5.5.2 | **SI SIT Operational Test Readiness Report** |  | 33d | 2024-08-05 | 2024-09-18 |  |  |  | 2025-01-07 | 2025-03-03 | 40d | 2025-01-07 | 2025-03-03 | -5d | 0d |  | N/A | 648h |  |  | N/A | N/A |  | 5.0 |  |  |  |  | Systems Integration Testing (SIT) |  |  |  |
| 999 | 1.4.1.7.5.5.2.1 | Assure Test Participants' Test Readiness Reports |  | 25d | 2024-08-05 | 2024-09-06 | 997 |  |  | 2025-01-07 | 2025-02-24 | 35d | 2025-01-07 | 2025-02-24 | -5d | 0d |  | Lee Cox | 200h |  |  | SI Test | PP,IPA | 109.33 | 5.0 | Green | GREEN |  |  | Systems Integration Testing (SIT) |  |  |  |
| 1000 | 1.4.1.7.5.5.2.2 | Develop Overarching SIT Operational Test Readiness Report |  | 18d | 2024-08-19 | 2024-09-11 | 999SS+10d |  |  | 2025-01-28 | 2025-02-24 | 20d | 2025-01-28 | 2025-02-24 | -5d | 0d |  | Lee Cox | 144h |  |  | SI Test |  | 123.33 | 5.0 | Green | GREEN |  |  | Systems Integration Testing (SIT) |  |  |  |
| 1001 | 1.4.1.7.5.5.2.3 | Artefact review (via SITAG) and updates |  | 5d | 2024-09-12 | 2024-09-18 | 1000 |  |  | 2025-02-25 | 2025-03-03 | 5d | 2025-02-25 | 2025-03-03 | -5d | 0d |  | Lee Cox | 40h |  |  | SI Test | PP,IPA | 147.33 | 5.0 | Green | GREEN |  |  | Systems Integration Testing (SIT) |  |  |  |
| 1002 | 1.4.1.7.5.6 | SIT Operational Testing Preparation Complete | milestone | 0d | 2024-09-25 | 2024-09-25 | 1001FS+5d, 364, 977, 983, 989 |  |  | 2024-09-25 | 2024-09-25 | 0d | 2025-03-10 | 2025-03-10 | -5d | 0d |  | Lee Cox |  |  |  | SI Test | PP,IPA | 160.71 | 5.10 | Green | GREEN | T2-TE-0750 | SITAG | Systems Integration Testing (SIT) | T2 |  |  |
| 1003 | 1.4.2 | **SIT Execution** |  | 390d | 2023-10-30 A | 2025-04-25 |  | 10% | 350.13d | 2023-10-30 | 2025-04-25 | 390d | 2023-10-30 | 2025-04-25 | 545d |  |  | N/A | 42184h | 3535.66h |  | N/A | N/A |  | 5.0 |  |  |  |  | Systems Integration Testing (SIT) |  |  |  |
| 1004 | 1.4.2.1 | System Integration Testing Start (M9) | milestone | 0d | 2023-10-30 A | 2023-10-30 A | 636FS+5d, 527, 550 | 100% |  | 2023-10-30 | 2023-10-30 | 0d | 2023-10-30 | 2023-10-30 |  |  | must start on 2023-10-30 | Lee Cox |  |  |  | CPT | PMO |  | 5.11 | Complete | COMPLETE | T1-TE-1000 | PSG | Systems Integration Testing (SIT) | T1 | MHHS-ART071 |  |
| 1005 | 1.4.2.2 | **SIT Component Integration Testing** |  | 96d | 2023-10-30 A | 2024-03-11 |  | 99% | 0d | 2023-10-30 | 2024-03-08 | 95d | 2023-10-30 | 2024-03-08 | 0d |  |  | N/A | 1976h | 1733.71h |  | N/A | N/A |  | 5.0 |  |  |  |  | Systems Integration Testing (SIT) |  |  | D24A - Industry Integration Test Completion Report |
| 1006 | 1.4.2.2.1 | SIT Component Integration Testing Start | milestone | 0d | 2023-10-30 A | 2023-10-30 A | 1004 | 100% |  | 2023-10-30 | 2023-10-30 | 0d | 2023-10-30 | 2023-10-30 |  |  |  | Lee Cox |  |  |  | SI Test | PP |  | 5.11 | Complete | COMPLETE |  |  | Systems Integration Testing (SIT) |  |  |  |
| 1007 | 1.4.2.2.2 | Component Integration Testing Interval 1 Start | milestone | 0d | 2023-10-30 A | 2023-10-30 A | 636SS+1d, 557, 561, 565, 115 | 100% |  | 2023-10-30 | 2023-10-30 | 0d | 2023-10-30 | 2023-10-30 |  |  |  | Lee Cox |  |  |  | SI Test | PP |  | 5.11 | Complete | COMPLETE | T3-TE-0060 | SITAG | Systems Integration Testing (SIT) | T3 | MHHS-ART071 |  |
| 1008 | 1.4.2.2.3 | Component Integration Testing Interval 2 Start | milestone | 0d | 2023-11-13 A | 2023-11-13 A | 663SS+5d, 557, 565, 561, 115 | 100% |  | 2023-11-13 | 2023-11-13 | 0d | 2023-11-13 | 2023-11-13 |  |  |  | Lee Cox |  |  |  | SI Test | PP |  | 5.12 | Complete | COMPLETE | T3-TE-0061 | SITAG | Systems Integration Testing (SIT) | T3 |  |  |
| 1009 | 1.4.2.2.4 | Component Integration Testing Interval 3 Start | milestone | 0d | 2023-11-27 A | 2023-11-27 A | 695SS+5d, 557, 561, 565, 115 | 100% |  | 2023-11-27 | 2023-11-27 | 0d | 2023-11-27 | 2023-11-27 |  |  |  | Lee Cox |  |  |  | SI Test | PP |  | 5.0 | Complete | COMPLETE | T3-TE-0062 | SITAG | Systems Integration Testing (SIT) | T3 |  |  |
| 1010 | 1.4.2.2.5 | Component Integration Testing Interval 4 Start | milestone | 0d | 2023-12-11 A | 2023-12-11 A | 727SS+5d, 557, 561, 565, 115 | 100% |  | 2023-12-11 | 2023-12-11 | 0d | 2023-12-11 | 2023-12-11 |  |  |  | Lee Cox |  |  |  | SI Test | PP |  | 5.0 | Complete | COMPLETE | T3-TE-0063 | SITAG | Systems Integration Testing (SIT) | T3 |  |  |
| 1011 | 1.4.2.2.6 | Component Integration Testing Interval 5 Start | milestone | 0d | 2024-01-15 A | 2024-01-15 A | 759SS+5d, 557, 561, 565, 115 | 100% |  | 2024-01-15 | 2024-01-15 | 0d | 2024-01-15 | 2024-01-15 |  |  |  | Lee Cox |  |  |  | SI Test | PP |  | 5.0 | Complete | COMPLETE | T3-TE-0064 |  | Systems Integration Testing (SIT) | T3 |  |  |
| 1012 | 1.4.2.2.7 | Component Integration Testing Interval 6 Start | milestone | 0d | 2024-01-29 A | 2024-01-29 A | 557, 561, 565, 791, 115, 603 | 100% |  | 2024-01-29 | 2024-01-29 | 0d | 2024-01-29 | 2024-01-29 |  |  | must start on 2024-01-29 | Lee Cox |  |  |  | SI Test | PP |  | 5.0 | Complete | COMPLETE | T3-TE-0065 | SITAG | Systems Integration Testing (SIT) | T3 |  |  |
| 1013 | 1.4.2.2.8 | SIT Component Integration Testing Execution |  | 85d | 2023-10-30 A | 2024-02-23 A | 1007SS | 100% |  | 2023-10-30 | 2024-02-23 | 85d | 2023-10-30 | 2024-02-23 |  |  | must start on 2023-10-30 | Lee Cox | 680h | 680h |  | SI Test | PP |  | 5.0 | Complete | COMPLETE |  |  | Systems Integration Testing (SIT) |  |  | D24A - Industry Integration Test Completion Report |
| 1014 | 1.4.2.2.9 | SIT Component Integration Testing End (incl. confirmation that PPs have submitted their Test Completion Reports to Programme for assurance) | milestone | 0d | 2024-02-23 A | 2024-02-23 A | 1013FF | 100% |  | 2024-02-23 | 2024-02-23 | 0d | 2024-02-23 | 2024-02-23 |  |  |  | Lee Cox |  |  |  | SI Test | PP |  | 5.19 | Complete | COMPLETE | T3-TE-0032 | SITAG | Systems Integration Testing (SIT) | T3 | MHHS-ART074 |  |
| 1015 | 1.4.2.2.10 | Assurance of PPs Test Completion Reports |  | 30d | 2024-01-22 A | 2024-03-01 A | 1014FF+5d | 100% |  | 2024-01-22 | 2024-03-01 | 30d | 2024-01-22 | 2024-03-01 |  |  |  | Lee Cox | 240h | 240h |  | SI Test | PP |  | 5.19 | Complete | COMPLETE |  |  | Systems Integration Testing (SIT) |  |  |  |

Notes:
- 989: 23/1 - New milestone added because of Operatiional themed delivery approach. To go to April SITAG for approval. 17/4: Approved as new milestone at SITAG on 17/4/24
- 1002: 6/10 - Needs to go to TMAG for date change. Date needs changing because error on the baseline. Approved for date change at TMAG on 23/10/23
- 1004: On track, however there are a number of associated risks that are being mitigated by the Programme
- 1007: On track, however there are a number of associated risks that are being mitigated by the Programme
- 1010: 13/12 - Complete noting a work-off plan and revised CIT Approach being taken to Dec TMAG
- 1011: 2/1//24 - Approved at 20/12 TMAG based on CIT Gov approach change
- 1012: 2/1//24 - Approved at 20/12 TMAG based on CIT Gov approach change
- 1014: All PPs are expected to complete their CIT by the target date on 09-Feb

| ID | WBS | Task | Type | Duration | Start | Finish | Predecessors | Complete | Remaining | Baseline start | Baseline finish | Baseline duration | Baseline 1 start | Baseline 1 finish | Total slack | Free slack | Resources | Work | Actual work | Responsible | Involved | Update Version | MHHS Programme Phase | Sched Status | RAG | Artefact ID | Milestone ID | Text29 | Tier | Text3 | Task Status |
| --- | --- | --- | --- | --- | --- | --- | --- | --- | --- | --- | --- | --- | --- | --- | --- | --- | --- | --- | --- | --- | --- | --- | --- | --- | --- | --- | --- | --- | --- | --- | --- |
| 1016 | 1.4.2.2.11 | **SIT CI Test Completion Report** |  | 18d | 2024-02-07 A | 2024-03-01 A |  | 100% |  | 2024-02-07 | 2024-03-01 | 18d | 2024-02-07 | 2024-03-01 |  |  | N/A | 288h | 288h | N/A | N/A | 5.0 | Systems Integration Testing (SIT) |  |  |  |  |  |  |  |  |
| 1017 | 1.4.2.2.11.1 | Develop document |  | 13d | 2024-02-07 A | 2024-02-23 A | 1014FF | 100% |  | 2024-02-07 | 2024-02-23 | 13d | 2024-02-07 | 2024-02-23 |  |  | Lee Cox | 104h | 104h | SI Test |  | 5.19 | Systems Integration Testing (SIT) | Complete | COMPLETE |  |  |  |  |  |  |
| 1018 | 1.4.2.2.11.2 | Review & agree document |  | 5d | 2024-02-26 A | 2024-03-01 A | 1017, 1015FF | 100% |  | 2024-02-26 | 2024-03-01 | 5d | 2024-02-26 | 2024-03-01 |  |  | Lee Cox | 40h | 40h | SI Test | PP,IPA | 5.19 | Systems Integration Testing (SIT) | Complete | COMPLETE |  |  |  |  |  |  |
| 1019 | 1.4.2.2.12 | SIT Component Integration Testing Test Completion Report Approved | milestone | 0d | 2024-03-11 A | 2024-03-11 A | 1018FS+6d | 100% |  | 2024-03-08 | 2024-03-08 | 0d | 2024-03-08 | 2024-03-08 |  |  | Lee Cox |  |  | SI Test | PP | 5.18 | Systems Integration Testing (SIT) | Complete | COMPLETE | MHHS-ART074 | T2-TE-0600 | SITAG | T2 |  |  |
| 1020 | 1.4.2.3 | **SIT - Minimum Viable Cohort (MVC)** |  | 240d | 2024-03-11 A | 2025-02-07 |  | 4% | 230.65d | 2024-03-11 | 2025-02-07 | 240d | 2024-03-11 | 2025-02-07 | 600d |  | N/A | 16264h | 864.46h | N/A | N/A | 5.0 | Systems Integration Testing (SIT) |  |  |  |  |  |  |  |  |
| 1021 | 1.4.2.3.1 | **SIT Functional Testing (MVC)** |  | 225d | 2024-03-11 A | 2025-01-17 |  | 9% | 203.64d | 2024-03-11 | 2025-01-17 | 225d | 2024-03-11 | 2025-01-17 | 615d |  | N/A | 8040h | 789.69h | N/A | N/A | 5.0 | Systems Integration Testing (SIT) |  |  |  |  |  |  |  |  |
| 1022 | 1.4.2.3.1.1 | SIT Functional Testing Start | milestone | 0d | 2024-03-11 A | 2024-03-11 A | 1019, 862FS+5d, 797, 805, 806, 807, 814 | 100% |  | 2024-03-11 | 2024-03-11 | 0d | 2024-03-11 | 2024-03-11 |  |  | Lee Cox |  |  | SI Test | PP | 5.0 | Systems Integration Testing (SIT) | Complete | COMPLETE | MHHS-ART073 | T3-TE-0034 | SITAG | T3 |  |  |
| 1023 | 1.4.2.3.1.2 | **SIT Functional Testing Execution (Minimum Viable Cohort)** |  | 225d | 2024-03-11 A | 2025-01-17 |  | 9% | 203.64d | 2024-03-11 | 2025-01-17 | 225d | 2024-03-11 | 2025-01-17 | 615d |  | N/A | 6240h | 618.85h | N/A | N/A | 5.0 | Systems Integration Testing (SIT) |  |  |  |  |  |  | D24C - E2E Test Completion Report | M10 |
| 1024 | 1.4.2.3.1.2.1 | **Cycle 1 (Full Cycle)** |  | 65d | 2024-03-11 A | 2024-06-07 |  | 43% | 37d | 2024-03-11 | 2024-07-12 | 90d | 2024-03-11 | 2024-07-12 | -1d | 0d | N/A | 1040h | 448h | N/A | N/A | 5.0 | Systems Integration Testing (SIT) |  |  |  |  |  |  |  |  |
| 1025 | 1.4.2.3.1.2.1.1 | Test Execution |  | 55d | 2024-03-11 A | 2024-05-24 | 1022SS-1d, 837 | 51% | 27d | 2024-03-11 | 2024-06-28 | 80d | 2024-03-11 | 2024-06-28 | -1d | 0d | Lee Cox | 440h | 224h | PP | SI Test | 5.0 | Systems Integration Testing (SIT) | Green | GREEN |  |  |  |  |  |  |
| 1026 | 1.4.2.3.1.2.1.2 | Defect resolution, assurance, review, data & environments maintenance |  | 10d | 2024-05-27 | 2024-06-07 | 1025 |  |  | 2024-07-01 | 2024-07-12 | 10d | 2024-07-01 | 2024-07-12 | -1d | 0d | Lee Cox | 80h |  | SI Test | PP | 5.0 | Systems Integration Testing (SIT) | Green | GREEN |  |  |  |  |  | 39.33 |
| 1027 | 1.4.2.3.1.2.2 | **SIT Functional Testing progress risk-assessment** |  | 20d | 2024-06-10 | 2024-07-05 |  |  |  | 2024-07-15 | 2024-08-09 | 20d | 2024-07-15 | 2024-08-09 | 755d |  | N/A | 400h |  | N/A | N/A | 5.0 | Systems Integration Testing (SIT) |  |  |  |  |  |  |  |  |
| 1028 | 1.4.2.3.1.2.2.1 | Risk-assessment of SIT Functional progress to assess whether Qualification Testing Execution can start early |  | 15d | 2024-06-10 | 2024-06-28 | 1026 |  |  | 2024-07-15 | 2024-08-02 | 15d | 2024-07-15 | 2024-08-02 | 755d | 0d | Nicola Farley; Lee Cox | 240h |  | SI Test | Code Bodies,PP,IPA | 5.0 | Systems Integration Testing (SIT) | Green | GREEN |  |  |  |  |  | 53.33 |
| 1029 | 1.4.2.3.1.2.2.2 | SITAG decision on early Qualification Testing Execution start | milestone | 0d | 2024-07-05 | 2024-07-05 | 1028FS+5d |  |  | 2024-08-09 | 2024-08-09 | 0d | 2024-08-09 | 2024-08-09 | 755d |  | Nicola Farley; Lee Cox |  |  | SI Test | Code Bodies,PP,IPA | 5.0 | Systems Integration Testing (SIT) | Green | GREEN |  | T3-TE-0039 | QAG | T3 |  | 78.71 |
| 1030 | 1.4.2.3.1.2.3 | **Cycle 2 (Defect retests and targeted regression testing)** |  | 60d | 2024-06-10 | 2024-08-30 |  |  |  | 2024-07-15 | 2024-09-20 | 50d | 2024-07-15 | 2024-09-20 | -1d | 0d | N/A | 960h |  | N/A | N/A | 5.0 | Systems Integration Testing (SIT) |  |  |  |  |  |  |  |  |
| 1031 | 1.4.2.3.1.2.3.1 | Test Execution |  | 50d | 2024-06-10 | 2024-08-16 | 1026, 842 |  |  | 2024-07-15 | 2024-09-06 | 40d | 2024-07-15 | 2024-09-06 | -1d | 0d | Lee Cox | 400h |  | PP | SI Test | 5.0 | Systems Integration Testing (SIT) | Green | GREEN |  |  |  |  |  | 53.33 |
| 1032 | 1.4.2.3.1.2.3.2 | Defect resolution, assurance, review, data & environments maintenance |  | 10d | 2024-08-19 | 2024-08-30 | 1031 |  |  | 2024-09-09 | 2024-09-20 | 10d | 2024-09-09 | 2024-09-20 | -1d | 0d | Lee Cox | 80h |  | SI Test | PP | 5.0 | Systems Integration Testing (SIT) | Green | GREEN |  |  |  |  |  | 123.33 |
| 1033 | 1.4.2.3.1.2.4 | **SIT Functional Testing back-up progress risk-assessment** |  | 20d | 2024-09-02 | 2024-09-27 |  |  |  | 2024-09-23 | 2024-10-18 | 20d | 2024-09-23 | 2024-10-18 | 695d |  | N/A | 400h |  | N/A | N/A | 5.0 | Systems Integration Testing (SIT) |  |  |  |  |  |  |  |  |
| 1034 | 1.4.2.3.1.2.4.1 | Back-up risk-assessment of SIT Functional progress to assess whether Qualification Execution can start early |  | 15d | 2024-09-02 | 2024-09-20 | 1032 |  |  | 2024-09-23 | 2024-10-11 | 15d | 2024-09-23 | 2024-10-11 | 695d | 0d | Nicola Farley; Lee Cox | 240h |  | SI Test | Code Bodies,PP,IPA | 5.0 | Systems Integration Testing (SIT) | Green | GREEN |  |  |  |  |  | 137.33 |
| 1035 | 1.4.2.3.1.2.4.2 | Back-up SITAG decision on early Qualification Testing Execution start | milestone | 0d | 2024-09-27 | 2024-09-27 | 1034FS+5d |  |  | 2024-10-18 | 2024-10-18 | 0d | 2024-10-18 | 2024-10-18 | 695d |  | Nicola Farley; Lee Cox |  |  | SI Test | Code Bodies,PP,IPA | 5.0 | Systems Integration Testing (SIT) | Green | GREEN |  | T3-TE-0041 | QAG | T3 |  | 162.71 |
| 1036 | 1.4.2.3.1.2.5 | **Cycle 3 (Defect retests and targeted regression testing)** |  | 45d | 2024-09-02 | 2024-11-01 |  |  |  | 2024-09-23 | 2024-11-01 | 30d | 2024-09-23 | 2024-11-01 | -1d | 0d | N/A | 720h |  | N/A | N/A | 5.0 | Systems Integration Testing (SIT) |  |  |  |  |  |  |  |  |
| 1037 | 1.4.2.3.1.2.5.1 | Test Execution |  | 35d | 2024-09-02 | 2024-10-18 | 1032, 847 |  |  | 2024-09-23 | 2024-10-18 | 20d | 2024-09-23 | 2024-10-18 | -1d | 0d | Lee Cox | 280h |  | PP | SI Test | 5.0 | Systems Integration Testing (SIT) | Green | GREEN |  |  |  |  |  | 137.33 |
| 1038 | 1.4.2.3.1.2.5.2 | Defect resolution, assurance, review, data & environments maintenance |  | 10d | 2024-10-21 | 2024-11-01 | 1037 |  |  | 2024-10-21 | 2024-11-01 | 10d | 2024-10-21 | 2024-11-01 | -1d | 0d | Lee Cox | 80h |  | SI Test | PP | 5.0 | Systems Integration Testing (SIT) | Green | GREEN |  |  |  |  |  | 186.33 |
| 1039 | 1.4.2.3.1.2.6 | Core Systems Code Freeze | milestone | 0d | 2024-11-01 | 2024-11-01 | 1038FF |  |  | 2024-11-01 | 2024-11-01 | 0d | 2024-11-01 | 2024-11-01 | 669d | 0d | Lee Cox |  |  | SI Test | PP | 5.0 | Systems Integration Testing (SIT) | Green | GREEN |  | T3-TE-0045 | SITAG | T3 |  | 197.71 |
| 1040 | 1.4.2.3.1.2.7 | Regression Testing (code freeze) |  | 45d | 2024-11-04 | 2025-01-03 | 1038, 852 |  |  | 2024-11-04 | 2025-01-03 | 45d | 2024-11-04 | 2025-01-03 | -1d | 0d | Lee Cox | 360h |  | PP | SI Test | 5.0 | Systems Integration Testing (SIT) | Green | GREEN |  |  |  |  |  | 200.33 |
| 1041 | 1.4.2.3.1.2.8 | SIT Functional Testing End (Minimum Viable Cohort) (incl. confirmation that PPs have submitted their Test Completion Reports to Programme for assurance) | milestone | 0d | 2025-01-03 | 2025-01-03 | 1040FF |  |  | 2025-01-03 | 2025-01-03 | 0d | 2025-01-03 | 2025-01-03 | -1d | 0d | Lee Cox |  |  | SI Test | PP | 5.0 | Systems Integration Testing (SIT) | Green | GREEN | MHHS-ART072 | T3-TE-0046 | SITAG | T3 |  | 260.71 |
| 1042 | 1.4.2.3.1.2.9 | Assurance of PPs Test Completion Reports |  | 30d | 2024-12-02 | 2025-01-10 | 1041FF+5d |  |  | 2024-12-02 | 2025-01-10 | 30d | 2024-12-02 | 2025-01-10 | -1d | 0d | Lee Cox | 240h |  | SI Test | PP | 5.0 | Systems Integration Testing (SIT) | Green | GREEN |  |  |  |  |  | 228.33 |

Notes:
- 1019: 20/2 - Date changed to align with SITAG meeting. On track for approval 11/3
- 1022: 28/11 - At risk because of challenges with CCP and PP readiness & dependent on successful Secondary Routing Testing
- 1028: Action: 5/12 - LC said change name from his to nicola and check dates based on new start date for non sit ldso testing
- 1029: Action: 5/12 - LC said change name from his to nicola and check dates based on new start date for non sit ldso testing
- 1031: Action: Lee
- 1034: Action: 5/12 - LC said change name from his to nicola and check dates based on new start date for non sit ldso testing
- 1035: Action: 5/12 - LC said change name from his to nicola and check dates based on new start date for non sit ldso testing

| ID | WBS | Task | Type | Duration | Start | Finish | Predecessors | Baseline start | Baseline finish | Baseline duration | Baseline 1 start | Baseline 1 finish | Total slack | Free slack | Constraint | Resources | Work | Responsible | Involved | Update Version | MHHS Programme Phase | Task Status | Sched Status | RAG | Artefact ID | Milestone ID | Text29 | Tier | Text3 |
| --- | --- | --- | --- | --- | --- | --- | --- | --- | --- | --- | --- | --- | --- | --- | --- | --- | --- | --- | --- | --- | --- | --- | --- | --- | --- | --- | --- | --- | --- |
| 1043 | 1.4.2.3.1.2.10 | **SIT Functional Test Completion Report (Minimum Viable Cohort)** |  | 20d | 2024-12-16 | 2025-01-10 |  | 2024-12-16 | 2025-01-10 | 20d | 2024-12-16 | 2025-01-10 | -1d | 0d |  | N/A | 320h | N/A | N/A | 5.0 | Systems Integration Testing (SIT) |  |  |  |  |  |  |  |  |
| 1044 | 1.4.2.3.1.2.10.1 | Develop document |  | 15d | 2024-12-16 | 2025-01-03 | 1041FF | 2024-12-16 | 2025-01-03 | 15d | 2024-12-16 | 2025-01-03 | -1d | 0d |  | Lee Cox | 120h | SI Test |  | 5.0 | Systems Integration Testing (SIT) | 242.33 | Green | GREEN |  |  |  |  |  |
| 1045 | 1.4.2.3.1.2.10.2 | Review & agree document |  | 5d | 2025-01-06 | 2025-01-10 | 1044, 1042FF | 2025-01-06 | 2025-01-10 | 5d | 2025-01-06 | 2025-01-10 | -1d | 0d |  | Lee Cox | 40h | SI Test | PP,IPA | 5.0 | Systems Integration Testing (SIT) | 263.33 | Green | GREEN |  |  |  |  |  |
| 1046 | 1.4.2.3.1.2.11 | SIT Functional Testing Test Completion Report (Minimum Viable Cohort) Approved | milestone | 0d | 2025-01-17 | 2025-01-17 | 1045FF+5d | 2025-01-17 | 2025-01-17 | 0d | 2025-01-17 | 2025-01-17 | -1d | 0d |  | Lee Cox |  | SI Test | PP | 5.0 | Systems Integration Testing (SIT) | 274.71 | Green | GREEN | MHHS-ART072 | T2-TE-0850 | SITAG | T2 |  |
| 1047 | 1.4.2.3.2 | **SIT Migration Testing (MVC)** |  | 95d | 2024-06-10 | 2024-10-18 |  | 2024-06-10 | 2024-10-18 | 95d | 2024-06-10 | 2024-10-18 | 0d |  |  | N/A | 2000h | N/A | N/A | 5.0 | Systems Integration Testing (SIT) |  |  |  |  |  |  |  |  |
| 1048 | 1.4.2.3.2.1 | SIT Migration Testing Start | milestone | 0d | 2024-06-10 | 2024-06-10 | 914FS+5d, 869, 873, 880, 886, 892 | 2024-06-10 | 2024-06-10 | 0d | 2024-06-10 | 2024-06-10 | -1d | 0d | must start on 2024-06-10 | Lee Cox |  | SI Test | PP | 5.0 | Systems Integration Testing (SIT) | 53.33 | Green | GREEN | MHHS-ART076 | T3-TE-0038 | SITAG | T3 |  |
| 1049 | 1.4.2.3.2.2 | SIT Migration Testing Execution (Minimum Viable Cohort) |  | 85d | 2024-06-10 | 2024-10-04 | 1048SS | 2024-06-10 | 2024-10-04 | 85d | 2024-06-10 | 2024-10-04 | 79d | 0d |  | Lee Cox | 680h | SI Test | PP | 5.0 | Systems Integration Testing (SIT) | 53.33 | Green | GREEN |  |  |  |  | D24E - Migration Test Completion Report |
| 1050 | 1.4.2.3.2.3 | SIT Migration Testing End (Minimum Viable Cohort) (incl. confirmation that PPs have submitted their Test Completion Reports to Programme for assurance) | milestone | 0d | 2024-10-04 | 2024-10-04 | 1049FF | 2024-10-04 | 2024-10-04 | 0d | 2024-10-04 | 2024-10-04 | 79d | 0d |  | Lee Cox |  | SI Test | PP | 5.0 | Systems Integration Testing (SIT) | 169.71 | Green | GREEN | MHHS-ART076 | T3-TE-0043 | SITAG | T3 |  |
| 1051 | 1.4.2.3.2.4 | Assurance of PPs Test Completion Reports |  | 30d | 2024-09-02 | 2024-10-11 | 1050FF+5d | 2024-09-02 | 2024-10-11 | 30d | 2024-09-02 | 2024-10-11 | 79d | 0d |  | Lee Cox | 240h | SI Test | PP | 5.0 | Systems Integration Testing (SIT) | 137.33 | Green | GREEN |  |  |  |  |  |
| 1052 | 1.4.2.3.2.5 | **SIT Migration Testing Test Completion Report (Minimum Viable Cohort)** |  | 20d | 2024-09-16 | 2024-10-11 |  | 2024-09-16 | 2024-10-11 | 20d | 2024-09-16 | 2024-10-11 | 79d |  |  | N/A | 320h | N/A | N/A | 5.0 | Systems Integration Testing (SIT) |  |  |  |  |  |  |  |  |
| 1053 | 1.4.2.3.2.5.1 | Develop document |  | 15d | 2024-09-16 | 2024-10-04 | 1050FF | 2024-09-16 | 2024-10-04 | 15d | 2024-09-16 | 2024-10-04 | 79d | 0d |  | Lee Cox | 120h | SI Test |  | 5.0 | Systems Integration Testing (SIT) | 151.33 | Green | GREEN |  |  |  |  |  |
| 1054 | 1.4.2.3.2.5.2 | Review & agree document |  | 5d | 2024-10-07 | 2024-10-11 | 1053, 1051FF | 2024-10-07 | 2024-10-11 | 5d | 2024-10-07 | 2024-10-11 | 79d | 0d |  | Lee Cox | 40h | SI Test | PP,IPA | 5.0 | Systems Integration Testing (SIT) | 172.33 | Green | GREEN |  |  |  |  |  |
| 1055 | 1.4.2.3.2.6 | SIT Migration Testing Test Completion Report (Minimum Viable Cohort) Approved | milestone | 0d | 2024-10-18 | 2024-10-18 | 1054FF+5d | 2024-10-18 | 2024-10-18 | 0d | 2024-10-18 | 2024-10-18 | 79d |  |  | Lee Cox |  | SI Test | PP | 5.0 | Systems Integration Testing (SIT) | 183.71 | Green | GREEN | MHHS-ART076 | T2-TE-0800 | SITAG | T2 |  |
| 1056 | 1.4.2.3.3 | **SIT Non-Functional Testing (MVC)** |  | 100d | 2024-09-02 | 2025-01-17 |  | 2024-09-02 | 2025-01-17 | 100d | 2024-09-02 | 2025-01-17 | 0d |  |  | N/A | 2080h | N/A | N/A | 5.0 | Systems Integration Testing (SIT) |  |  |  |  |  |  |  |  |
| 1057 | 1.4.2.3.3.1 | SIT Non-Functional Testing Start | milestone | 0d | 2024-09-02 | 2024-09-02 | 959FS+5d, 1031FS+5d, 921, 925, 932, 938, 944 | 2024-09-02 | 2024-09-02 | 0d | 2024-09-02 | 2024-09-02 | -1d | 0d | must start on 2024-09-02 | Lee Cox |  | SI Test | PP | 5.0 | Systems Integration Testing (SIT) | 137.33 | Green | GREEN | MHHS-ART079 | T3-TE-0040 | SITAG | T3 |  |
| 1058 | 1.4.2.3.3.2 | SIT Non-Functional Testing Execution (Minimum Viable Cohort) |  | 90d | 2024-09-02 | 2025-01-03 | 1057SS | 2024-09-02 | 2025-01-03 | 90d | 2024-09-02 | 2025-01-03 | 14d | 0d |  | Lee Cox | 720h | SI Test | PP | 5.0 | Systems Integration Testing (SIT) | 137.33 | Green | GREEN |  |  |  |  | D24D - NF Test Completion Report |
| 1059 | 1.4.2.3.3.3 | SIT Non-Functional Testing End (Minimum Viable Cohort) (incl. confirmation that PPs have submitted their Test Completion Reports to Programme for assurance) | milestone | 0d | 2025-01-03 | 2025-01-03 | 1058FF | 2025-01-03 | 2025-01-03 | 0d | 2025-01-03 | 2025-01-03 | 14d | 0d |  | Lee Cox |  | SI Test | PP | 5.0 | Systems Integration Testing (SIT) | 260.71 | Green | GREEN | MHHS-ART079 | T3-TE-0047 | SITAG | T3 |  |
| 1060 | 1.4.2.3.3.4 | Assurance of PPs Test Completion Reports |  | 30d | 2024-12-02 | 2025-01-10 | 1059FF+5d | 2024-12-02 | 2025-01-10 | 30d | 2024-12-02 | 2025-01-10 | 14d | 0d |  | Lee Cox | 240h | SI Test | PP | 5.0 | Systems Integration Testing (SIT) | 228.33 | Green | GREEN |  |  |  |  |  |
| 1061 | 1.4.2.3.3.5 | **SIT Non-Functional Testing Test Completion Report (Minimum Viable Cohort)** |  | 20d | 2024-12-16 | 2025-01-10 |  | 2024-12-16 | 2025-01-10 | 20d | 2024-12-16 | 2025-01-10 | 14d |  |  | N/A | 320h | N/A | N/A | 5.0 | Systems Integration Testing (SIT) |  |  |  |  |  |  |  |  |
| 1062 | 1.4.2.3.3.5.1 | Develop document |  | 15d | 2024-12-16 | 2025-01-03 | 1059FF | 2024-12-16 | 2025-01-03 | 15d | 2024-12-16 | 2025-01-03 | 14d | 0d |  | Lee Cox | 120h | SI Test |  | 5.0 | Systems Integration Testing (SIT) | 242.33 | Green | GREEN |  |  |  |  |  |
| 1063 | 1.4.2.3.3.5.2 | Review & agree document |  | 5d | 2025-01-06 | 2025-01-10 | 1062, 1060FF | 2025-01-06 | 2025-01-10 | 5d | 2025-01-06 | 2025-01-10 | 14d | 0d |  | Lee Cox | 40h | SI Test | PP,IPA | 5.0 | Systems Integration Testing (SIT) | 263.33 | Green | GREEN |  |  |  |  |  |
| 1064 | 1.4.2.3.3.6 | SIT Non-Functional Testing Test Completion Report (Minimum Viable Cohort) Approved | milestone | 0d | 2025-01-17 | 2025-01-17 | 1063FF+5d | 2025-01-17 | 2025-01-17 | 0d | 2025-01-17 | 2025-01-17 | 14d |  |  | Lee Cox |  | SI Test | PP | 5.0 | Systems Integration Testing (SIT) | 274.71 | Green | GREEN | MHHS-ART079 | T2-TE-0900 | SITAG | T2 |  |
| 1065 | 1.4.2.3.4 | **SIT Operational Testing (MVC)** |  | 89d | 2024-10-07 | 2025-02-07 |  | 2024-10-07 | 2025-02-07 | 90d | 2024-10-07 | 2025-02-07 | -5d | 0d |  | N/A | 1904h | N/A | N/A | 5.0 | Systems Integration Testing (SIT) |  |  |  |  |  |  |  |  |
| 1066 | 1.4.2.3.4.1 | SIT Operational Testing Start | milestone | 0d | 2024-10-07 | 2024-10-07 | 1002FS+8d, 966, 970, 977, 983, 989 | 2024-10-07 | 2024-10-07 | 0d | 2024-10-07 | 2024-10-07 | -5d | 0d |  | Lee Cox |  | SI Test | PP | 5.0 | Systems Integration Testing (SIT) | 172.71 | yellow | GREEN | MHHS-ART073 MHHS-ART143 | T3-TE-0042 | SITAG | T3 |  |
| 1067 | 1.4.2.3.4.2 | SIT Operational Testing Execution (Minimum Viable Cohort) |  | 79d | 2024-10-08 | 2025-01-24 | 1066SS | 2024-10-07 | 2025-01-24 | 80d | 2024-10-07 | 2025-01-24 | -1d | 0d |  | Lee Cox | 632h | SI Test | PP | 5.0 | Systems Integration Testing (SIT) | 173.33 | Green | GREEN |  |  |  |  | D24D - NF Test Completion Report |
| 1068 | 1.4.2.3.4.3 | SIT Operational Testing End (Minimum Viable Cohort) (incl. confirmation that PPs have submitted their Test Completion Reports to Programme for assurance) | milestone | 0d | 2025-01-24 | 2025-01-24 | 1067FF | 2025-01-24 | 2025-01-24 | 0d | 2025-01-24 | 2025-01-24 | -1d | 0d |  | Lee Cox |  | SI Test | PP | 5.0 | Systems Integration Testing (SIT) | 281.71 | Green | GREEN | MHHS-ART081 | T3-TE-0050 | SITAG | T3 |  |
| 1069 | 1.4.2.3.4.4 | Assurance of PPs Test Completion Reports |  | 30d | 2024-12-23 | 2025-01-31 | 1068FF+5d | 2024-12-23 | 2025-01-31 | 30d | 2024-12-23 | 2025-01-31 | -1d | 0d |  | Lee Cox | 240h | SI Test | PP | 5.0 | Systems Integration Testing (SIT) | 249.33 | Green | GREEN |  |  |  |  |  |

| ID | WBS | Task | Type | Duration | Start | Finish | Predecessors | Complete | Remaining | Baseline start | Baseline finish | Baseline duration | Baseline 1 start | Baseline 1 finish | Total slack | Free slack | Constraint | Resources | Work | Actual work | Responsible | Involved | Update Version | MHHS Programme Phase | Task Status | Sched Status | RAG | Artefact ID | Milestone ID | Text29 | Tier | Text3 |
| --- | --- | --- | --- | --- | --- | --- | --- | --- | --- | --- | --- | --- | --- | --- | --- | --- | --- | --- | --- | --- | --- | --- | --- | --- | --- | --- | --- | --- | --- | --- | --- | --- |
| 1070 | 1.4.2.3.4.5 | **SIT Operational Testing Test Completion Report (Minimum Viable Cohort)** |  | 20d | 2025-01-06 | 2025-01-31 |  |  |  | 2025-01-06 | 2025-01-31 | 20d | 2025-01-06 | 2025-01-31 | -1d | 0d |  | N/A | 320h |  | N/A | N/A | 5.0 | Systems Integration Testing (SIT) |  |  |  |  |  |  |  |  |
| 1071 | 1.4.2.3.4.5.1 | Develop document |  | 15d | 2025-01-06 | 2025-01-24 | 1068FF |  |  | 2025-01-06 | 2025-01-24 | 15d | 2025-01-06 | 2025-01-24 | -1d | 0d |  | Lee Cox | 120h |  | SI Test |  | 5.0 | Systems Integration Testing (SIT) | 263.33 | Green | GREEN |  |  |  |  |  |
| 1072 | 1.4.2.3.4.5.2 | Review & agree document |  | 5d | 2025-01-27 | 2025-01-31 | 1071, 1069FF |  |  | 2025-01-27 | 2025-01-31 | 5d | 2025-01-27 | 2025-01-31 | -1d | 0d |  | Lee Cox | 40h |  | SI Test | PP,IPA | 5.0 | Systems Integration Testing (SIT) | 284.33 | Green | GREEN |  |  |  |  |  |
| 1073 | 1.4.2.3.4.6 | SIT Operational Testing Test Completion Report (Minimum Viable Cohort) Approved | milestone | 0d | 2025-02-07 | 2025-02-07 | 1072FF+5d |  |  | 2025-02-07 | 2025-02-07 | 0d | 2025-02-07 | 2025-02-07 | -1d | 0d |  | Lee Cox |  |  | SI Test | PP | 5.0 | Systems Integration Testing (SIT) | 295.71 | Green | GREEN | MHHS-ART081 | T2-TE-0950 | SITAG | T2 |  |
| 1074 | 1.4.2.3.5 | **SIT MVC Test Exit Report** |  | 20d | 2025-01-06 | 2025-01-31 |  |  |  | 2025-01-06 | 2025-01-31 | 20d | 2025-01-06 | 2025-01-31 | -1d | 0d |  | N/A | 320h |  | N/A | N/A | 5.0 | Systems Integration Testing (SIT) |  |  |  |  |  |  |  |  |
| 1075 | 1.4.2.3.5.1 | Develop document |  | 15d | 2025-01-06 | 2025-01-24 | 1071FF |  |  | 2025-01-06 | 2025-01-24 | 15d | 2025-01-06 | 2025-01-24 | -1d | 0d |  | Lee Cox | 120h |  | SI Test |  | 5.0 | Systems Integration Testing (SIT) | 263.33 | Green | GREEN |  |  |  |  |  |
| 1076 | 1.4.2.3.5.2 | Review & agree document |  | 5d | 2025-01-27 | 2025-01-31 | 1075 |  |  | 2025-01-27 | 2025-01-31 | 5d | 2025-01-27 | 2025-01-31 | -1d | 0d |  | Lee Cox | 40h |  | SI Test | PP,IPA | 5.0 | Systems Integration Testing (SIT) | 284.33 | Green | GREEN |  |  |  |  |  |
| 1077 | 1.4.2.3.6 | SIT Minimum Viable Cohort Complete (SIT Minimum Viable Cohort Test Exit Report Approved) | milestone | 0d | 2025-02-07 | 2025-02-07 | 1076FS+5d, 1019, 1046, 1055, 1064, 1073 |  |  | 2025-02-07 | 2025-02-07 | 0d | 2025-02-07 | 2025-02-07 | -1d | 0d | must start on 2025-02-07 | Lee Cox |  |  | CPT | PP,IPA | 5.0 | Systems Integration Testing (SIT) | 295.33 | Green | GREEN | MHHS-ART081 | T1-TE-2000 | PSG | T1 |  |
| 1078 | 1.4.2.4 | **SIT - Other Participants** |  | 295d | 2024-03-11 A | 2025-04-25 |  | 2% | 289.09d | 2024-03-11 | 2025-04-25 | 295d | 2024-03-11 | 2025-04-25 | -5d | 0d |  | N/A | 20824h | 618.53h | N/A | N/A | 5.0 | Systems Integration Testing (SIT) | M10,M11 |  |  |  |  |  |  | D24D - NF Test Completion Report |
| 1079 | 1.4.2.4.1 | **SIT Functional Testing (Other Participants)** |  | 295d | 2024-03-11 A | 2025-04-25 |  | 6% | 277.59d | 2024-03-11 | 2025-04-25 | 295d | 2024-03-11 | 2025-04-25 | -5d | 0d |  | N/A | 8600h | 571.28h | N/A | N/A | 5.0 | Systems Integration Testing (SIT) |  |  |  |  |  |  |  |  |
| 1080 | 1.4.2.4.1.1 | **SIT Functional Testing Execution (Other Participants)** |  | 280d | 2024-03-11 A | 2025-04-04 |  | 6% | 262d | 2024-03-11 | 2025-04-04 | 280d | 2024-03-11 | 2025-04-04 | -5d | 0d |  | N/A | 5840h | 432h | N/A | N/A | 5.0 | Systems Integration Testing (SIT) | M10 |  |  |  |  |  |  | D24C - E2E Test Completion Report |
| 1081 | 1.4.2.4.1.1.1 | **Cycle 1 (Full Cycle)** |  | 65d | 2024-03-11 A | 2024-06-07 |  | 28% | 47d | 2024-03-11 | 2024-07-12 | 90d | 2024-03-11 | 2024-07-12 | -5d | 0d |  | N/A | 1040h | 288h | N/A | N/A | 5.0 | Systems Integration Testing (SIT) |  |  |  |  |  |  |  |  |
| 1082 | 1.4.2.4.1.1.1.1 | Test Execution |  | 55d | 2024-03-11 A | 2024-05-24 | 1025SS, 128 | 33% | 37d | 2024-03-11 | 2024-06-28 | 80d | 2024-03-11 | 2024-06-28 | -5d | 0d |  | Lee Cox | 440h | 144h | PP | SI Test | 5.0 | Systems Integration Testing (SIT) |  | Green | GREEN |  |  |  |  |  |
| 1083 | 1.4.2.4.1.1.1.2 | Defect resolution, assurance, review, data & environments maintenance |  | 10d | 2024-05-27 | 2024-06-07 | 1082 |  |  | 2024-07-01 | 2024-07-12 | 10d | 2024-07-01 | 2024-07-12 | -5d | 0d |  | Lee Cox | 80h |  | SI Test | PP | 5.0 | Systems Integration Testing (SIT) | 39.33 | Green | GREEN |  |  |  |  |  |
| 1084 | 1.4.2.4.1.1.2 | **Cycle 2 (Defect retests and targeted regression testing)** |  | 60d | 2024-06-10 | 2024-08-30 |  |  |  | 2024-07-15 | 2024-09-20 | 50d | 2024-07-15 | 2024-09-20 | -5d | 0d |  | N/A | 960h |  | N/A | N/A | 5.0 | Systems Integration Testing (SIT) |  |  |  |  |  |  |  |  |
| 1085 | 1.4.2.4.1.1.2.1 | Test Execution |  | 50d | 2024-06-10 | 2024-08-16 | 1083, 132, 136 |  |  | 2024-07-15 | 2024-09-06 | 40d | 2024-07-15 | 2024-09-06 | -5d | 0d |  | Lee Cox | 400h |  | PP | SI Test | 5.0 | Systems Integration Testing (SIT) | 53.33 | Green | GREEN |  |  |  |  |  |
| 1086 | 1.4.2.4.1.1.2.2 | Defect resolution, assurance, review, data & environments maintenance |  | 10d | 2024-08-19 | 2024-08-30 | 1085 |  |  | 2024-09-09 | 2024-09-20 | 10d | 2024-09-09 | 2024-09-20 | -5d | 0d |  | Lee Cox | 80h |  | SI Test | PP | 5.0 | Systems Integration Testing (SIT) | 123.33 | Green | GREEN |  |  |  |  |  |
| 1087 | 1.4.2.4.1.1.3 | **Cycle 3 (Defect retests and targeted regression testing)** |  | 45d | 2024-09-02 | 2024-11-01 |  |  |  | 2024-09-23 | 2024-11-01 | 30d | 2024-09-23 | 2024-11-01 | -5d | 0d |  | N/A | 720h |  | N/A | N/A | 5.0 | Systems Integration Testing (SIT) |  |  |  |  |  |  |  |  |
| 1088 | 1.4.2.4.1.1.3.1 | Test Execution |  | 35d | 2024-09-02 | 2024-10-18 | 1086, 140 |  |  | 2024-09-23 | 2024-10-18 | 20d | 2024-09-23 | 2024-10-18 | -5d | 0d |  | Lee Cox | 280h |  | PP | SI Test | 5.0 | Systems Integration Testing (SIT) | 137.33 | Green | GREEN |  |  |  |  |  |
| 1089 | 1.4.2.4.1.1.3.2 | Defect resolution, assurance, review, data & environments maintenance |  | 10d | 2024-10-21 | 2024-11-01 | 1088 |  |  | 2024-10-21 | 2024-11-01 | 10d | 2024-10-21 | 2024-11-01 | -5d | 0d |  | Lee Cox | 80h |  | SI Test | PP | 5.0 | Systems Integration Testing (SIT) | 186.33 | Green | GREEN |  |  |  |  |  |
| 1090 | 1.4.2.4.1.1.4 | Regression Testing (code freeze) |  | 45d | 2024-11-04 | 2025-01-03 | 1089 |  |  | 2024-11-04 | 2025-01-03 | 45d | 2024-11-04 | 2025-01-03 | -5d | 0d |  | Lee Cox | 360h |  | PP | SI Test | 5.0 | Systems Integration Testing (SIT) | 200.33 | Green | GREEN |  |  |  |  |  |
| 1091 | 1.4.2.4.1.1.5 | SIT Other PPs continued support |  | 65d | 2025-01-06 | 2025-04-04 | 1090 |  |  | 2025-01-06 | 2025-04-04 | 65d | 2025-01-06 | 2025-04-04 | -5d | 0d |  | Lee Cox | 520h |  | PP | SI Test | 5.0 | Systems Integration Testing (SIT) | 263.33 | Green | GREEN |  |  |  |  |  |
| 1092 | 1.4.2.4.1.2 | SIT Functional Testing End (Other Participants) (incl. confirmation that PPs have submitted their Test Completion Reports to Programme for assurance) | milestone | 0d | 2025-04-04 | 2025-04-04 | 1091FF |  |  | 2025-04-04 | 2025-04-04 | 0d | 2025-04-04 | 2025-04-04 | -5d | 0d |  | Lee Cox |  |  | SI Test | PP | 5.0 | Systems Integration Testing (SIT) | 351.71 | Green | GREEN | MHHS-ART072 | T3-TE-0052 | SITAG | T3 |  |
| 1093 | 1.4.2.4.1.3 | Assurance of PPs Test Completion Reports |  | 5d | 2025-04-14 | 2025-04-18 | 1092FS+5d |  |  | 2025-04-14 | 2025-04-18 | 5d | 2025-04-14 | 2025-04-18 | -5d | 0d |  | Lee Cox | 40h |  | SI Test | PP | 5.0 | Systems Integration Testing (SIT) | 361.33 | Green | GREEN |  |  |  |  |  |

| ID | WBS | Task | Type | Duration | Start | Finish | Predecessors | Baseline start | Baseline finish | Baseline duration | Baseline 1 start | Baseline 1 finish | Total slack | Free slack | Resources | Work | Responsible | Involved | Update Version | MHHS Programme Phase | Task Status | Sched Status | RAG | Artefact ID | Milestone ID | Text29 | Tier | Text3 |
| --- | --- | --- | --- | --- | --- | --- | --- | --- | --- | --- | --- | --- | --- | --- | --- | --- | --- | --- | --- | --- | --- | --- | --- | --- | --- | --- | --- | --- |
| 1094 | 1.4.2.4.1.4 | **SIT Functional Testing Test Completion Report (Other Participants)** |  | 25d | 2025-03-17 | 2025-04-18 |  | 2025-03-17 | 2025-04-18 | 25d | 2025-03-17 | 2025-04-18 | -5d | 0d | N/A | 360h | N/A | N/A | 5.0 | Systems Integration Testing (SIT) |  |  |  |  |  |  |  |  |
| 1095 | 1.4.2.4.1.4.1 | Develop document |  | 15d | 2025-03-17 | 2025-04-04 | 1092FF | 2025-03-17 | 2025-04-04 | 15d | 2025-03-17 | 2025-04-04 | 0d |  | Lee Cox | 120h | SI Test |  | 5.0 | Systems Integration Testing (SIT) | 333.33 | Green | GREEN |  |  |  |  |  |
| 1096 | 1.4.2.4.1.4.2 | Review & agree document |  | 5d | 2025-04-14 | 2025-04-18 | 1095, 1093FF | 2025-04-14 | 2025-04-18 | 5d | 2025-04-14 | 2025-04-18 | -5d | 0d | Lee Cox | 40h | SI Test | PP,IPA | 5.0 | Systems Integration Testing (SIT) | 361.33 | Green | GREEN |  |  |  |  |  |
| 1097 | 1.4.2.4.1.5 | SIT Functional Testing Test Completion Report (Other Participants) Approved | milestone | 0d | 2025-04-25 | 2025-04-25 | 1096FF+5d | 2025-04-25 | 2025-04-25 | 0d | 2025-04-25 | 2025-04-25 | -5d | 0d | Lee Cox |  | SI Test | PP | 5.0 | Systems Integration Testing (SIT) | 372.71 | Green | GREEN | MHHS-ART072 | T3-TE-0055 | SITAG | T3 |  |
| 1098 | 1.4.2.4.2 | **SIT Migration Testing (Other Participants)** |  | 230d | 2024-06-10 | 2025-04-25 |  | 2024-06-10 | 2025-04-25 | 230d | 2024-06-10 | 2025-04-25 | -5d | 0d | N/A | 3960h | N/A | N/A | 5.0 | Systems Integration Testing (SIT) |  |  |  |  |  |  |  |  |
| 1099 | 1.4.2.4.2.1 | SIT Migration Testing Execution (Other Participants) |  | 215d | 2024-06-10 | 2025-04-04 | 1048SS | 2024-06-10 | 2025-04-04 | 215d | 2024-06-10 | 2025-04-04 | -5d | 0d | Lee Cox | 1720h | SI Test | PP | 5.0 | Systems Integration Testing (SIT) | 53.33 | Green | GREEN |  |  |  |  | D24E - Migration Test Completion Report |
| 1100 | 1.4.2.4.2.2 | SIT Migration Testing End (Other Participants) (incl. confirmation that PPs have submitted their Test Completion Reports to Programme for assurance) | milestone | 0d | 2025-04-04 | 2025-04-04 | 1099FF | 2025-04-04 | 2025-04-04 | 0d | 2025-04-04 | 2025-04-04 | -5d | 0d | Lee Cox |  | SI Test | PP | 5.0 | Systems Integration Testing (SIT) | 351.71 | Green | GREEN | MHHS-ART076 | T3-TE-0051 | SITAG | T3 |  |
| 1101 | 1.4.2.4.2.3 | Assurance of PPs Test Completion Reports |  | 5d | 2025-04-14 | 2025-04-18 | 1100FS+5d | 2025-04-14 | 2025-04-18 | 5d | 2025-04-14 | 2025-04-18 | -5d | 0d | Lee Cox | 40h | SI Test | PP | 5.0 | Systems Integration Testing (SIT) | 361.33 | Green | GREEN |  |  |  |  |  |
| 1102 | 1.4.2.4.2.4 | **SIT Migration Testing Test Completion Report (Other Participants)** |  | 25d | 2025-03-17 | 2025-04-18 |  | 2025-03-17 | 2025-04-18 | 25d | 2025-03-17 | 2025-04-18 | -5d | 0d | N/A | 360h | N/A | N/A | 5.0 | Systems Integration Testing (SIT) |  |  |  |  |  |  |  |  |
| 1103 | 1.4.2.4.2.4.1 | Develop document |  | 15d | 2025-03-17 | 2025-04-04 | 1100FF | 2025-03-17 | 2025-04-04 | 15d | 2025-03-17 | 2025-04-04 | 0d |  | Lee Cox | 120h | SI Test |  | 5.0 | Systems Integration Testing (SIT) | 333.33 | Green | GREEN |  |  |  |  |  |
| 1104 | 1.4.2.4.2.4.2 | Review & agree document |  | 5d | 2025-04-14 | 2025-04-18 | 1103, 1101FF | 2025-04-14 | 2025-04-18 | 5d | 2025-04-14 | 2025-04-18 | -5d | 0d | Lee Cox | 40h | SI Test | PP,IPA | 5.0 | Systems Integration Testing (SIT) | 361.33 | Green | GREEN |  |  |  |  |  |
| 1105 | 1.4.2.4.2.5 | SIT Migration Testing Test Completion Report (Other Participants) Approved | milestone | 0d | 2025-04-25 | 2025-04-25 | 1104FF+5d | 2025-04-25 | 2025-04-25 | 0d | 2025-04-25 | 2025-04-25 | -5d | 0d | Lee Cox |  | SI Test | PP | 5.0 | Systems Integration Testing (SIT) | 372.71 | Green | GREEN | MHHS-ART076 | T3-TE-0056 | SITAG | T3 |  |
| 1106 | 1.4.2.4.3 | **SIT Non-Functional Testing (Other Participants)** |  | 170d | 2024-09-02 | 2025-04-25 |  | 2024-09-02 | 2025-04-25 | 170d | 2024-09-02 | 2025-04-25 | -5d | 0d | N/A | 3000h | N/A | N/A | 5.0 | Systems Integration Testing (SIT) |  |  |  |  |  |  |  |  |
| 1107 | 1.4.2.4.3.1 | SIT Non-Functional Testing Execution (Other Participants) |  | 155d | 2024-09-02 | 2025-04-04 | 1057SS | 2024-09-02 | 2025-04-04 | 155d | 2024-09-02 | 2025-04-04 | -5d | 0d | Lee Cox | 1240h | SI Test | PP | 5.0 | Systems Integration Testing (SIT) | 137.33 | Green | GREEN |  |  |  |  | D24D - NF Test Completion Report |
| 1108 | 1.4.2.4.3.2 | SIT Non-Functional Testing End (Other Participants) (incl. confirmation that PPs have submitted their Test Completion Reports to Programme for assurance) | milestone | 0d | 2025-04-04 | 2025-04-04 | 1107FF | 2025-04-04 | 2025-04-04 | 0d | 2025-04-04 | 2025-04-04 | -5d | 0d | Lee Cox |  | SI Test | PP | 5.0 | Systems Integration Testing (SIT) | 351.71 | Green | GREEN | MHHS-ART079 | T3-TE-0053 | SITAG | T3 |  |
| 1109 | 1.4.2.4.3.3 | Assurance of PPs Test Completion Reports |  | 5d | 2025-04-14 | 2025-04-18 | 1108FS+5d | 2025-04-14 | 2025-04-18 | 5d | 2025-04-14 | 2025-04-18 | -5d | 0d | Lee Cox | 40h | SI Test | PP | 5.0 | Systems Integration Testing (SIT) | 361.33 | Green | GREEN |  |  |  |  |  |
| 1110 | 1.4.2.4.3.4 | **SIT Non-Functional Testing Test Completion Report (Other Participants)** |  | 25d | 2025-03-17 | 2025-04-18 |  | 2025-03-17 | 2025-04-18 | 25d | 2025-03-17 | 2025-04-18 | -5d | 0d | N/A | 360h | N/A | N/A | 5.0 | Systems Integration Testing (SIT) |  |  |  |  |  |  |  |  |
| 1111 | 1.4.2.4.3.4.1 | Develop document |  | 15d | 2025-03-17 | 2025-04-04 | 1108FF | 2025-03-17 | 2025-04-04 | 15d | 2025-03-17 | 2025-04-04 | 0d |  | Lee Cox | 120h | SI Test |  | 5.0 | Systems Integration Testing (SIT) | 333.33 | Green | GREEN |  |  |  |  |  |
| 1112 | 1.4.2.4.3.4.2 | Review & agree document |  | 5d | 2025-04-14 | 2025-04-18 | 1111, 1109FF | 2025-04-14 | 2025-04-18 | 5d | 2025-04-14 | 2025-04-18 | -5d | 0d | Lee Cox | 40h | SI Test | PP,IPA | 5.0 | Systems Integration Testing (SIT) | 361.33 | Green | GREEN |  |  |  |  |  |
| 1113 | 1.4.2.4.3.5 | SIT Non-Functional Testing Test Completion Report (Other Participants) Approved | milestone | 0d | 2025-04-25 | 2025-04-25 | 1112FF+5d | 2025-04-25 | 2025-04-25 | 0d | 2025-04-25 | 2025-04-25 | -5d | 0d | Lee Cox |  | SI Test | PP | 5.0 | Systems Integration Testing (SIT) | 372.71 | Green | GREEN | MHHS-ART079 | T3-TE-0057 | SITAG | T3 |  |
| 1114 | 1.4.2.4.4 | **SIT Operational Testing (Other Participants)** |  | 144d | 2024-10-08 | 2025-04-25 |  | 2024-10-07 | 2025-04-25 | 145d | 2024-10-07 | 2025-04-25 | -5d | 0d | N/A | 2584h | N/A | N/A | 5.0 | Systems Integration Testing (SIT) |  |  |  |  |  |  |  |  |
| 1115 | 1.4.2.4.4.1 | SIT Operational Testing Execution (Other Participants) |  | 129d | 2024-10-08 | 2025-04-04 | 1066SS | 2024-10-07 | 2025-04-04 | 130d | 2024-10-07 | 2025-04-04 | -5d | 0d | Lee Cox | 1032h | SI Test | PP | 5.0 | Systems Integration Testing (SIT) | 173.33 | Green | GREEN |  |  |  |  | D24D - NF Test Completion Report |
| 1116 | 1.4.2.4.4.2 | SIT Operational Testing End (Other Participants) (incl. confirmation that PPs have submitted their Test Completion Reports to Programme for assurance) | milestone | 0d | 2025-04-04 | 2025-04-04 | 1115FF | 2025-04-04 | 2025-04-04 | 0d | 2025-04-04 | 2025-04-04 | -5d | 0d | Lee Cox |  | SI Test | PP | 5.0 | Systems Integration Testing (SIT) | 351.71 | Green | GREEN | MHHS-ART081 | T3-TE-0054 | SITAG | T3 |  |
| 1117 | 1.4.2.4.4.3 | Assurance of PPs Test Completion Reports |  | 5d | 2025-04-14 | 2025-04-18 | 1116FS+5d | 2025-04-14 | 2025-04-18 | 5d | 2025-04-14 | 2025-04-18 | -5d | 0d | Lee Cox | 40h | SI Test | PP | 5.0 | Systems Integration Testing (SIT) | 361.33 | Green | GREEN |  |  |  |  |  |

| ID | WBS | Task | Type | Duration | Start | Finish | Predecessors | Complete | Remaining | Baseline start | Baseline finish | Baseline duration | Baseline 1 start | Baseline 1 finish | Total slack | Free slack | Constraint | Resources | Work | Actual work | Responsible | Involved | Update Version | MHHS Programme Phase | Task Status | Sched Status | RAG | Artefact ID | Milestone ID | Text29 | Tier |
| --- | --- | --- | --- | --- | --- | --- | --- | --- | --- | --- | --- | --- | --- | --- | --- | --- | --- | --- | --- | --- | --- | --- | --- | --- | --- | --- | --- | --- | --- | --- | --- |
| 1118 | 1.4.2.4.4.4 | **SIT Operational Testing Test Completion Report (Other Participants)** |  | 25d | 2025-03-17 | 2025-04-18 |  |  |  | 2025-03-17 | 2025-04-18 | 25d | 2025-03-17 | 2025-04-18 | -5d | 0d |  | N/A | 360h |  | N/A | N/A | 5.0 | Systems Integration Testing (SIT) |  |  |  |  |  |  |  |
| 1119 | 1.4.2.4.4.4.1 | Develop document |  | 15d | 2025-03-17 | 2025-04-04 | 1116FF |  |  | 2025-03-17 | 2025-04-04 | 15d | 2025-03-17 | 2025-04-04 | 0d |  |  | Lee Cox | 120h |  | SI Test |  | 5.0 | Systems Integration Testing (SIT) | 333.33 | Green | GREEN |  |  |  |  |
| 1120 | 1.4.2.4.4.4.2 | Review & agree document |  | 5d | 2025-04-14 | 2025-04-18 | 1119, 1117FF |  |  | 2025-04-14 | 2025-04-18 | 5d | 2025-04-14 | 2025-04-18 | -5d | 0d |  | Lee Cox | 40h |  | SI Test | PP,IPA | 5.0 | Systems Integration Testing (SIT) | 361.33 | Green | GREEN |  |  |  |  |
| 1121 | 1.4.2.4.4.5 | SIT Operational Testing Test Completion Report (Other Participants) Approved | milestone | 0d | 2025-04-25 | 2025-04-25 | 1120FF+5d |  |  | 2025-04-25 | 2025-04-25 | 0d | 2025-04-25 | 2025-04-25 | -5d | 0d |  | Lee Cox |  |  | SI Test | PP | 5.0 | Systems Integration Testing (SIT) | 372.71 | Green | GREEN | MHHS-ART081 | T3-TE-0058 | SITAG | T3 |
| 1122 | 1.4.2.4.5 | **SIT Other Participants Test Exit Report** |  | 20d | 2025-03-17 | 2025-04-11 |  |  |  | 2025-03-17 | 2025-04-11 | 20d | 2025-03-17 | 2025-04-11 | 0d |  |  | N/A | 320h |  | N/A | N/A | 5.0 | Systems Integration Testing (SIT) |  |  |  |  |  |  |  |
| 1123 | 1.4.2.4.5.1 | Develop document |  | 15d | 2025-03-17 | 2025-04-04 | 1119FF |  |  | 2025-03-17 | 2025-04-04 | 15d | 2025-03-17 | 2025-04-04 | 0d |  |  | Lee Cox | 120h |  | SI Test |  | 5.0 | Systems Integration Testing (SIT) | 333.33 | Green | GREEN |  |  |  |  |
| 1124 | 1.4.2.4.5.2 | Review & agree document |  | 5d | 2025-04-07 | 2025-04-11 | 1123 |  |  | 2025-04-07 | 2025-04-11 | 5d | 2025-04-07 | 2025-04-11 | 0d |  |  | Lee Cox | 40h |  | SI Test | PP,IPA | 5.0 | Systems Integration Testing (SIT) | 354.33 | Green | GREEN |  |  |  |  |
| 1125 | 1.4.2.4.6 | SIT - Other Participants Complete | milestone | 0d | 2025-04-21 | 2025-04-21 | 1124FS+5d, 1097, 1105, 1113, 1121 |  |  | 2025-04-21 | 2025-04-21 | 0d | 2025-04-21 | 2025-04-21 | -5d | 0d | must start on 2025-04-21 | Lee Cox |  |  | SI Test | PP | 5.0 | Systems Integration Testing (SIT) | 368.33 | Green | GREEN | MHHS-ART081 | T3-TE-0059 | SITAG | T3 |
| 1126 | 1.4.3 | **E2E Sandbox Testing Preparation** |  | 680d | 2022-10-31 A | 2025-06-06 |  | 9% | 617.15d | 2022-10-31 | 2025-06-06 | 680d | 2022-10-31 | 2025-06-06 | 515d |  |  | N/A | 85576h | 10660h | N/A | N/A | 5.0 | Systems Integration Testing (SIT) |  |  |  |  |  |  |  |
| 1127 | 1.4.3.1 | **Test Artefact Development** |  | 361d | 2023-03-01 | 2024-07-18 |  |  |  | 2023-03-01 | 2023-08-04 | 113d | 2023-03-01 | 2023-08-04 | 747d |  |  | N/A | 8128h |  | N/A | N/A | 5.0 | Systems Integration Testing (SIT) |  |  |  |  |  |  |  |
| 1128 | 1.4.3.1.1 | **E2E Sandbox Guidance** |  | 361d | 2023-03-01 | 2024-07-18 |  |  |  | 2023-03-01 | 2023-08-04 | 113d | 2023-03-01 | 2023-08-04 | 747d |  |  | N/A | 3752h |  | N/A | N/A | 5.0 | Systems Integration Testing (SIT) |  |  |  |  |  |  |  |
| 1129 | 1.4.3.1.1.1 | Develop document |  | 83d | 2023-03-01 | 2023-06-23 |  |  |  | 2023-03-01 | 2023-06-23 | 83d | 2023-03-01 | 2023-06-23 | 995d | 0d | start no earlier than 2023-03-01 | Stuart Scott | 664h |  | SI Test |  | 5.0 | Systems Integration Testing (SIT) | -413.67 | Overdue Start | RED |  |  |  |  |
| 1130 | 1.4.3.1.1.2 | Artefact review (via SITAG) and updates |  | 25d | 2023-06-26 | 2023-07-28 | 1129 |  |  | 2023-06-26 | 2023-07-28 | 25d | 2023-06-26 | 2023-07-28 | 995d | 0d |  | Stuart Scott | 200h |  | SI Test | PP,IPA | 5.0 | Systems Integration Testing (SIT) | -296.67 | Overdue Start | RED |  |  |  |  |
| 1131 | 1.4.3.1.1.3 | E2E Sandbox Guidance approved | milestone | 0d | 2024-07-18 | 2024-07-18 | 1130FF+5d |  |  | 2023-08-04 | 2023-08-04 | 0d | 2023-08-04 | 2023-08-04 | 747d |  | start no earlier than 2024-07-18 | Stuart Scott |  |  | SI Test | PP | 5.22 | Systems Integration Testing (SIT) | 91.33 | Red | RED | MHHS-ART154 | T3-TE-0067 | QAG | T3 |
| 1132 | 1.4.3.1.2 | **E2E Sandbox Test Data Approach & Plan** |  | 93d | 2023-03-29 | 2023-08-04 |  |  |  | 2023-03-29 | 2023-08-04 | 93d | 2023-03-29 | 2023-08-04 | 995d |  |  | N/A | 1488h |  | N/A | N/A | 5.0 | Systems Integration Testing (SIT) |  |  |  |  |  |  |  |
| 1133 | 1.4.3.1.2.1 | Develop document |  | 68d | 2023-03-29 | 2023-06-30 | 1129SS+20d |  |  | 2023-03-29 | 2023-06-30 | 68d | 2023-03-29 | 2023-06-30 | 995d | 0d |  | Stuart Scott | 544h |  | SI Test |  | 5.0 | Systems Integration Testing (SIT) | -385.67 | Overdue Start | RED |  |  |  |  |
| 1134 | 1.4.3.1.2.2 | Review, update & agree document internally |  | 25d | 2023-07-03 | 2023-08-04 | 1133 |  |  | 2023-07-03 | 2023-08-04 | 25d | 2023-07-03 | 2023-08-04 | 995d |  |  | Stuart Scott | 200h |  | SI Test | PP,IPA | 5.0 | Systems Integration Testing (SIT) | -289.67 | Overdue Start | RED |  |  |  |  |
| 1135 | 1.4.3.2 | **UIT Stub Specification and Delivery** |  | 190d | 2023-12-04 A | 2024-08-23 |  | 52% | 92d | 2023-12-04 | 2024-08-23 | 190d | 2023-10-27 | 2024-08-23 | 670d |  |  | N/A | 4560h | 2352h | N/A | N/A | 5.0 | Systems Integration Testing (SIT) |  |  |  |  |  |  |  |
| 1136 | 1.4.3.2.1 | **Qualification Test Stubs** |  | 190d | 2023-12-04 A | 2024-08-23 |  | 52% | 92d | 2023-12-04 | 2024-08-23 | 190d | 2023-10-27 | 2024-08-23 | 670d |  |  | N/A | 3040h | 1568h | N/A | N/A | 5.16 | Systems Integration Testing (SIT) |  |  |  |  |  |  |  |
| 1137 | 1.4.3.2.1.1 | Specify |  | 44d | 2023-12-04 A | 2024-02-01 A | 470FS+13d | 100% |  | 2023-12-04 | 2024-02-01 | 44d | 2023-10-27 | 2023-12-29 |  |  |  | Matthew Bray | 352h | 352h | SI DevOps | Qualification,SRO | 5.0 | Systems Integration Testing (SIT) |  | Complete | COMPLETE |  |  |  |  |
| 1138 | 1.4.3.2.1.2 | Build & Test |  | 100d | 2024-02-02 A | 2024-06-20 | 1137 | 54% | 46d | 2024-02-02 | 2024-06-20 | 100d | 2023-12-29 | 2024-05-24 | 670d | 0d |  | Matthew Bray | 800h | 432h | SI DevOps | Qualification,SRO | 5.0 | Systems Integration Testing (SIT) |  | Green | GREEN |  |  |  |  |
| 1139 | 1.4.3.2.1.3 | UAT |  | 9d | 2024-06-21 | 2024-07-03 | 1138 |  |  | 2024-06-21 | 2024-07-03 | 9d | 2024-05-24 | 2024-06-10 | 670d | 0d |  | Matthew Bray | 72h |  | SI Test | Qualification,SRO | 5.0 | Systems Integration Testing (SIT) | 64.33 | Green | GREEN |  |  |  |  |
| 1140 | 1.4.3.2.1.4 | Beta test |  | 32d | 2024-07-04 | 2024-08-16 | 1139 |  |  | 2024-07-04 | 2024-08-16 | 32d | 2024-06-10 | 2024-07-29 | 670d | 0d |  | Matthew Bray | 256h |  | PP | Qualification,SRO | 5.0 | Systems Integration Testing (SIT) | 77.33 | Green | GREEN |  |  |  |  |
| 1141 | 1.4.3.2.1.5 | Prepare for release |  | 5d | 2024-08-19 | 2024-08-23 | 1140 |  |  | 2024-08-19 | 2024-08-23 | 5d | 2024-07-29 | 2024-08-23 | 670d | 0d |  | Matthew Bray | 40h |  | SI DevOps | Qualification,SRO | 5.0 | Systems Integration Testing (SIT) | 123.33 | Green | GREEN |  |  |  |  |
| 1142 | 1.4.3.2.1.6 | CSS & SMRS Simulators Released | milestone | 0d | 2024-08-23 | 2024-08-23 | 1141 |  |  | 2024-08-23 | 2024-08-23 | 0d | 2024-08-23 | 2024-08-23 | 670d | 0d |  | Matthew Bray |  |  | SI DevOps | Qualification,SRO | 5.0 | Systems Integration Testing (SIT) | 127.71 | Green | GREEN | MHHS-ART080 | T3-TE-0035 | QAG | T3 |

Notes:
- 1131: 18/4: Plan and early view on Sandbox Guidance discussed in QWG 9th April. Next steps were to complete proposal for bringing dates forward and present at May QAG Proposed E2E Sandbox Guidance sign off 18th July QAG
- 1142: 22/1- Change name from CSS & SMRS Simulators Released to Non-SIT LDSO Test Harness Released because original naming is no longer applicable and refreshed scope determined in Dec from Code Bodies via Qualification team. To go to May QAG / Action: 11/12- MB - Might not be delivering css awaiting confirmation from requirements done by sro and code bodies - tbc in jan 24

| ID | WBS | Task | Type | Duration | Start | Finish | Predecessors | Baseline start | Baseline finish | Baseline duration | Baseline 1 start | Baseline 1 finish | Total slack | Free slack | Constraint | Resources | Work | Responsible | Involved | Update Version | MHHS Programme Phase | Task Status | Sched Status | RAG | Milestone ID | Text29 | Tier |
| --- | --- | --- | --- | --- | --- | --- | --- | --- | --- | --- | --- | --- | --- | --- | --- | --- | --- | --- | --- | --- | --- | --- | --- | --- | --- | --- | --- |
| 1143 | 1.4.3.3 | **Environments (UIT)** |  | 680d | 2022-10-31 | 2025-06-06 |  | 2022-10-31 | 2025-06-06 | 680d | 2022-10-31 | 2025-06-06 | 0d |  |  | N/A | 50208h | N/A | N/A | 5.0 | Systems Integration Testing (SIT) |  |  |  |  |  |  |
| 1144 | 1.4.3.3.1 | **Central Party Environments (UIT)** |  | 493d | 2022-11-16 | 2024-10-04 |  | 2022-11-16 | 2024-10-04 | 493d | 2022-11-16 | 2024-10-04 | 366d |  |  | N/A | 11664h | N/A | N/A | 5.0 | Systems Integration Testing (SIT) |  |  |  |  |  |  |
| 1145 | 1.4.3.3.1.1 | Central Parties' environment preparation (incl. security certificates and security compliance) |  | 463d | 2022-11-16 | 2024-08-23 | 466 | 2022-11-16 | 2024-08-23 | 463d | 2022-11-16 | 2024-08-23 | 366d | 0d |  | Simon Berry | 3704h | PP | SI Test | 5.0 | Systems Integration Testing (SIT) | -518.67 | Overdue Start | GREEN |  |  |  |
| 1146 | 1.4.3.3.1.2 | Submit self-declaration of environment preparation complete (incl. security certificates and security compliance) to Programme for assurance |  | 463d | 2022-11-16 | 2024-08-23 | 1145SS | 2022-11-16 | 2024-08-23 | 463d | 2022-11-16 | 2024-08-23 | 670d | 0d |  | Simon Berry | 3704h | PP | SI Test | 5.0 | Systems Integration Testing (SIT) | -518.67 | Overdue Start | GREEN |  |  |  |
| 1147 | 1.4.3.3.1.3 | Central Parties' UIT environment connectivity proving |  | 19d | 2024-08-27 | 2024-09-20 | 1159FS+1d | 2024-08-27 | 2024-09-20 | 19d | 2024-08-27 | 2024-09-20 | 670d | 0d |  | Simon Berry | 152h | PP | SI Test | 5.0 | Systems Integration Testing (SIT) | 131.33 | Green | GREEN |  |  |  |
| 1148 | 1.4.3.3.1.4 | Deployment of MHHS solution code to UIT environments |  | 10d | 2024-09-09 | 2024-09-20 | 1147FF | 2024-09-09 | 2024-09-20 | 10d | 2024-09-09 | 2024-09-20 | 670d | 0d |  | Simon Berry | 80h | PP | SI Test | 5.0 | Systems Integration Testing (SIT) | 144.33 | Green | GREEN |  |  |  |
| 1149 | 1.4.3.3.1.5 | Central Parties' UIT environment Regression Testing |  | 10d | 2024-09-23 | 2024-10-04 | 1148 | 2024-09-23 | 2024-10-04 | 10d | 2024-09-23 | 2024-10-04 | 670d | 0d |  | Simon Berry | 80h | PP | SI Test | 5.0 | Systems Integration Testing (SIT) | 158.33 | Green | GREEN |  |  |  |
| 1150 | 1.4.3.3.2 | **E2E Sandbox Participants (UIT)** |  | 680d | 2022-10-31 | 2025-06-06 |  | 2022-10-31 | 2025-06-06 | 680d | 2022-10-31 | 2025-06-06 | 0d |  |  | N/A | 16240h | N/A | N/A | 5.0 | Systems Integration Testing (SIT) |  |  |  |  |  |  |
| 1151 | 1.4.3.3.2.1 | E2E Sandbox Participants environment preparation (incl. security certificates and security compliance) |  | 660d | 2022-10-31 | 2025-05-09 | 1599FF-2mo | 2022-10-31 | 2025-05-09 | 660d | 2022-10-31 | 2025-05-09 | -1d | 0d | must finish on 2025-05-09 | Simon Berry | 5280h | PP | SI Test | 5.0 | Systems Integration Testing (SIT) | -534.67 | Overdue Start | GREEN |  |  |  |
| 1152 | 1.4.3.3.2.2 | Submit self-declaration of environment preparation complete (incl. security certificates and security compliance) to Programme for assurance |  | 660d | 2022-10-31 | 2025-05-09 |  | 2022-10-31 | 2025-05-09 | 660d | 2022-10-31 | 2025-05-09 | 515d | 0d |  | Simon Berry | 5280h | PP | SI Test | 5.0 | Systems Integration Testing (SIT) | -534.67 | Overdue Start | GREEN |  |  |  |
| 1153 | 1.4.3.3.2.3 | E2E Sandbox Participants UIT environment connectivity proving |  | 20d | 2025-05-12 | 2025-06-06 | 1152 | 2025-05-12 | 2025-06-06 | 20d | 2025-05-12 | 2025-06-06 | 515d | 0d |  | Simon Berry | 160h | PP | SI Test | 5.0 | Systems Integration Testing (SIT) | 389.33 | Green | GREEN |  |  |  |
| 1154 | 1.4.3.3.2.4 | Deployment of MHHS solution code to UIT environments |  | 10d | 2025-05-26 | 2025-06-06 | 1153FF | 2025-05-26 | 2025-06-06 | 10d | 2025-05-26 | 2025-06-06 | 515d | 0d |  | Simon Berry | 80h | PP | SI Test | 5.0 | Systems Integration Testing (SIT) | 403.33 | Green | GREEN |  |  |  |
| 1155 | 1.4.3.3.3 | **SI Environments (UIT)** |  | 680d | 2022-10-31 | 2025-06-06 |  | 2022-10-31 | 2025-06-06 | 680d | 2022-10-31 | 2025-06-06 | 515d |  |  | N/A | 16864h | N/A | N/A | 5.0 | Systems Integration Testing (SIT) |  |  |  |  |  |  |
| 1156 | 1.4.3.3.3.1 | Coordinate Central Parties' UIT environment preparation |  | 463d | 2022-11-16 | 2024-08-23 | 1145SS | 2022-11-16 | 2024-08-23 | 463d | 2022-11-16 | 2024-08-23 | 720d |  |  | Simon Berry | 3704h | SI Test | PP | 5.0 | Systems Integration Testing (SIT) | -518.67 | Overdue Start | GREEN |  |  |  |
| 1157 | 1.4.3.3.3.2 | Coordinate E2E Sandbox Participants' UIT environment preparation (for E2E Sandbox Testing Start) |  | 463d | 2022-10-31 | 2024-08-07 | 1151SS | 2022-10-31 | 2024-08-07 | 463d | 2022-10-31 | 2024-08-07 | 732d |  |  | Simon Berry | 3704h | SI Test | PP | 5.0 | Systems Integration Testing (SIT) | -534.67 | Overdue Start | GREEN |  |  |  |
| 1158 | 1.4.3.3.3.3 | Assure Central Parties' self-declaration of environment preparation complete (incl. security certificates and security compliance) |  | 463d | 2022-11-16 | 2024-08-23 | 1146SS, 1152SS | 2022-11-16 | 2024-08-23 | 463d | 2022-11-16 | 2024-08-23 | 670d | 0d |  | Simon Berry | 3704h | SI Test | PP | 5.0 | Systems Integration Testing (SIT) | -518.67 | Overdue Start | GREEN |  |  |  |
| 1159 | 1.4.3.3.3.4 | Central Parties' UIT environments ready to start connectivity proving (incl. certificates and security compliance) | milestone | 0d | 2024-08-23 | 2024-08-23 | 1158, 1142 | 2024-08-23 | 2024-08-23 | 0d | 2024-08-23 | 2024-08-23 | 670d | 0d |  | Simon Berry |  | SI Test | PP | 5.0 | Systems Integration Testing (SIT) | 127.71 | Green | GREEN | T3-TE-0044 | QAG | T3 |
| 1160 | 1.4.3.3.3.5 | Coordinate Central Parties' UIT environment connectivity proving |  | 19d | 2025-05-12 | 2025-06-05 | 1147SS, 1153SS | 2025-05-12 | 2025-06-05 | 19d | 2025-05-12 | 2025-06-05 | 516d |  |  | Simon Berry | 152h | SI Test | PP | 5.0 | Systems Integration Testing (SIT) | 389.33 | Green | GREEN |  |  |  |
| 1161 | 1.4.3.3.3.6 | Coordinate deployment of MHHS solution code to Central Parties' UIT environments |  | 10d | 2025-05-26 | 2025-06-06 | 1148SS, 1154SS | 2025-05-26 | 2025-06-06 | 10d | 2025-05-26 | 2025-06-06 | 515d |  |  | Simon Berry | 80h | SI Test | PP | 5.0 | Systems Integration Testing (SIT) | 403.33 | Green | GREEN |  |  |  |
| 1162 | 1.4.3.3.3.7 | Coordinate Central Parties' UIT environment Regression Testing |  | 10d | 2024-09-23 | 2024-10-04 | 1149SS | 2024-09-23 | 2024-10-04 | 10d | 2024-09-23 | 2024-10-04 | 690d |  |  | Simon Berry | 80h | SI Test | PP | 5.0 | Systems Integration Testing (SIT) | 158.33 | Green | GREEN |  |  |  |
| 1163 | 1.4.3.4 | **Test Data** |  | 30d | 2024-08-26 | 2024-10-04 |  | 2024-08-26 | 2024-10-04 | 30d | 2024-08-26 | 2024-10-04 | 670d |  |  | N/A | 2400h | N/A | N/A | 5.0 | Systems Integration Testing (SIT) |  |  |  |  |  |  |
| 1164 | 1.4.3.4.1 | **Central Parties (for E2E Sandbox & Qualification)** |  | 30d | 2024-08-26 | 2024-10-04 |  | 2024-08-26 | 2024-10-04 | 30d | 2024-08-26 | 2024-10-04 | 670d |  |  | N/A | 720h | N/A | N/A | 5.0 | Systems Integration Testing (SIT) |  |  |  |  |  |  |
| 1165 | 1.4.3.4.1.1 | Central Parties' UIT environment test data loading & verification (& data cleansing, if required) |  | 30d | 2024-08-26 | 2024-10-04 | 1149FF | 2024-08-26 | 2024-10-04 | 30d | 2024-08-26 | 2024-10-04 | 670d | 0d |  | Simon Berry | 240h | PP | SI Test | 5.0 | Systems Integration Testing (SIT) | 130.33 | Green | GREEN |  |  |  |
| 1166 | 1.4.3.4.1.2 | Submit self-declaration to Programme to confirm loading & verification of test data |  | 30d | 2024-08-26 | 2024-10-04 | 1165SS | 2024-08-26 | 2024-10-04 | 30d | 2024-08-26 | 2024-10-04 | 670d | 0d |  | Simon Berry | 240h | PP | SI Test | 5.0 | Systems Integration Testing (SIT) | 130.33 | Green | GREEN |  |  |  |

| ID | WBS | Task | Type | Duration | Start | Finish | Predecessors | Complete | Remaining | Baseline start | Baseline finish | Baseline duration | Baseline 1 start | Baseline 1 finish | Total slack | Free slack | Constraint | Resources | Work | Actual work | Responsible | Involved | Update Version | MHHS Programme Phase | Task Status | Sched Status | RAG | Artefact ID | Milestone ID | Text29 | Tier |
| --- | --- | --- | --- | --- | --- | --- | --- | --- | --- | --- | --- | --- | --- | --- | --- | --- | --- | --- | --- | --- | --- | --- | --- | --- | --- | --- | --- | --- | --- | --- | --- |
| 1167 | 1.4.3.4.2 | **E2E Sandbox Participants** |  | 30d | 2024-08-26 | 2024-10-04 |  |  |  | 2024-08-26 | 2024-10-04 | 30d | 2024-08-26 | 2024-10-04 | 690d |  |  | N/A | 480h |  | N/A | N/A | 5.0 | Systems Integration Testing (SIT) |  |  |  |  |  |  |  |
| 1168 | 1.4.3.4.2.1 | UIT environment test data loading and verification (and data cleansing, if required) (for E2E Sandbox Testing Start) |  | 30d | 2024-08-26 | 2024-10-04 | 1165FF |  |  | 2024-08-26 | 2024-10-04 | 30d | 2024-08-26 | 2024-10-04 | 690d | 0d |  | Simon Berry | 240h |  | PP | SI Test | 5.0 | Systems Integration Testing (SIT) | 130.33 | Green | GREEN |  |  |  |  |
| 1169 | 1.4.3.4.3 | **SI Test Data** |  | 30d | 2024-08-26 | 2024-10-04 |  |  |  | 2024-08-26 | 2024-10-04 | 30d | 2024-08-26 | 2024-10-04 | 690d |  |  | N/A | 960h |  | N/A | N/A | 5.0 | Systems Integration Testing (SIT) |  |  |  |  |  |  |  |
| 1170 | 1.4.3.4.3.1 | Coordinate Central Parties' UIT environment test data loading and verification (and data cleansing, if required) |  | 30d | 2024-08-26 | 2024-10-04 | 1165SS |  |  | 2024-08-26 | 2024-10-04 | 30d | 2024-08-26 | 2024-10-04 | 690d |  |  | Richard Puddephatt | 240h |  | SI Test | PP | 5.0 | Systems Integration Testing (SIT) | 130.33 | Green | GREEN |  |  |  |  |
| 1171 | 1.4.3.4.3.2 | Assure evidence of Central Parties' UIT environment test data load and verification |  | 30d | 2024-08-26 | 2024-10-04 | 1166SS |  |  | 2024-08-26 | 2024-10-04 | 30d | 2024-08-26 | 2024-10-04 | 690d |  |  | Richard Puddephatt | 240h |  | SI Test | PP | 5.0 | Systems Integration Testing (SIT) | 130.33 | Green | GREEN |  |  |  |  |
| 1172 | 1.4.3.4.3.3 | Coordinate E2E Sandbox Participants' UIT environment test data loading and verification (and data cleansing, if required) (for E2E Sandbox Testing Start) |  | 30d | 2024-08-26 | 2024-10-04 | 1168SS |  |  | 2024-08-26 | 2024-10-04 | 30d | 2024-08-26 | 2024-10-04 | 690d |  |  | Richard Puddephatt | 240h |  | SI Test | PP | 5.0 | Systems Integration Testing (SIT) | 130.33 | Green | GREEN |  |  |  |  |
| 1173 | 1.4.3.5 | **Other Preparation** |  | 484d | 2022-11-16 A | 2024-09-23 |  | 59% | 196.43d | 2022-11-16 | 2024-09-23 | 484d | 2022-11-16 | 2024-09-23 | 699d |  |  | N/A | 13200h | 7805.21h | N/A | N/A | 5.0 | Systems Integration Testing (SIT) |  |  |  |  |  |  |  |
| 1174 | 1.4.3.5.1 | **SI Other Preparation** |  | 66d | 2024-05-02 | 2024-08-01 |  |  |  | 2024-05-02 | 2024-08-01 | 66d | 2024-05-02 | 2024-08-01 | 736d |  |  | N/A | 1056h |  | N/A | N/A | 5.0 | Systems Integration Testing (SIT) |  |  |  |  |  |  |  |
| 1175 | 1.4.3.5.1.1 | Onboarding of UIT E2E Sandbox Participants to Test Management Tool for E2E Sandbox Testing Start (onboarding of participants will be ongoing hereafter) |  | 66d | 2024-05-02 | 2024-08-01 | 1190SS-132d |  |  | 2024-05-02 | 2024-08-01 | 66d | 2024-05-02 | 2024-08-01 | 736d | 0d |  | Stuart Scott | 528h |  | SI Test | PP | 5.0 | Systems Integration Testing (SIT) | 14.33 | Green | GREEN |  |  |  |  |
| 1176 | 1.4.3.5.2 | **Other Preparation (for Central Parties & E2E Sandbox Participants)** |  | 484d | 2022-11-16 A | 2024-09-23 |  | 67% | 161.92d | 2022-11-16 | 2024-09-23 | 484d | 2022-11-16 | 2024-09-23 | 699d |  |  | N/A | 8272h | 5504.64h | N/A | N/A | 5.0 | Systems Integration Testing (SIT) |  |  |  |  |  |  |  |
| 1177 | 1.4.3.5.2.1 | Test Management Tool onboarding for E2E Sandbox Testing Start (onboarding will be ongoing hereafter) |  | 66d | 2024-05-02 | 2024-08-01 | 1175SS |  |  | 2024-05-02 | 2024-08-01 | 66d | 2024-05-02 | 2024-08-01 | 736d |  |  | Stuart Scott | 528h |  | PP | SI Test | 5.0 | Systems Integration Testing (SIT) | 14.33 | Green | GREEN |  |  |  |  |
| 1178 | 1.4.3.5.2.2 | Other Preparation (incl. test execution planning) |  | 484d | 2022-11-16 A | 2024-09-23 | 1145SS, 1151SS | 76% | 118d | 2022-11-16 | 2024-09-23 | 484d | 2022-11-16 | 2024-09-23 | 699d |  |  | Stuart Scott | 3872h | 2928h | PP | SI Test | 5.0 | Systems Integration Testing (SIT) |  | Green | GREEN |  |  |  |  |
| 1179 | 1.4.3.6 | **UIT E2E Sandbox Test Readiness Report** |  | 45d | 2024-08-26 | 2024-10-25 |  |  |  | 2024-08-26 | 2024-10-25 | 45d | 2024-08-26 | 2024-10-25 | 670d |  |  | N/A | 1640h |  | N/A | N/A | 5.0 | Systems Integration Testing (SIT) |  |  |  |  |  |  |  |
| 1180 | 1.4.3.6.1 | **Central Parties E2E Sandbox Test Readiness Report** |  | 30d | 2024-08-26 | 2024-10-04 |  |  |  | 2024-08-26 | 2024-10-04 | 30d | 2024-08-26 | 2024-10-04 | 670d |  |  | N/A | 480h |  | N/A | N/A | 5.0 | Systems Integration Testing (SIT) |  |  |  |  |  |  |  |
| 1181 | 1.4.3.6.1.1 | Develop draft Test Readiness Report and submit to Programme for assurance |  | 20d | 2024-08-26 | 2024-09-20 | 1166FF-10d |  |  | 2024-08-26 | 2024-09-20 | 20d | 2024-08-26 | 2024-09-20 | 670d | 0d |  | Stuart Scott | 160h |  | PP | SI Test | 5.0 | Systems Integration Testing (SIT) | 130.33 | Green | GREEN |  |  |  |  |
| 1182 | 1.4.3.6.1.2 | Finalise Test Readiness Report and submit to Programme for assurance |  | 10d | 2024-09-23 | 2024-10-04 | 1166FF |  |  | 2024-09-23 | 2024-10-04 | 10d | 2024-09-23 | 2024-10-04 | 670d | 0d |  | Stuart Scott | 80h |  | PP | SI Test | 5.0 | Systems Integration Testing (SIT) | 158.33 | Green | GREEN |  |  |  |  |
| 1183 | 1.4.3.6.2 | **SI E2E Sandbox Test Readiness Report** |  | 40d | 2024-08-26 | 2024-10-18 |  |  |  | 2024-08-26 | 2024-10-18 | 40d | 2024-08-26 | 2024-10-18 | 670d |  |  | N/A | 800h |  | N/A | N/A | 5.0 | Systems Integration Testing (SIT) |  |  |  |  |  |  |  |
| 1184 | 1.4.3.6.2.1 | Assure Central Parties' E2E Sandbox Test Readiness Reports |  | 35d | 2024-08-26 | 2024-10-11 | 1181SS, 1182FF+5d |  |  | 2024-08-26 | 2024-10-11 | 35d | 2024-08-26 | 2024-10-11 | 670d | 0d |  | Stuart Scott | 280h |  | SI Test | PP | 5.0 | Systems Integration Testing (SIT) | 130.33 | Green | GREEN |  |  |  |  |
| 1185 | 1.4.3.6.2.2 | Develop Overarching E2E Sandbox Test Readiness Report |  | 20d | 2024-09-16 | 2024-10-11 | 1184FF |  |  | 2024-09-16 | 2024-10-11 | 20d | 2024-09-16 | 2024-10-11 | 670d | 0d |  | Stuart Scott | 160h |  | SI Test |  | 5.0 | Systems Integration Testing (SIT) | 151.33 | Green | GREEN |  |  |  |  |
| 1186 | 1.4.3.6.2.3 | Artefact review (via SITAG) and updates |  | 5d | 2024-10-14 | 2024-10-18 | 1185 |  |  | 2024-10-14 | 2024-10-18 | 5d | 2024-10-14 | 2024-10-18 | 670d | 0d |  | Stuart Scott | 40h |  | SI Test | PP,IPA | 5.0 | Systems Integration Testing (SIT) | 179.33 | Green | GREEN |  |  |  |  |
| 1187 | 1.4.3.6.3 | UIT E2E Sandbox Preparation Complete | milestone | 0d | 2024-10-25 | 2024-10-25 | 1186FS+5d |  |  | 2024-10-25 | 2024-10-25 | 0d | 2024-10-25 | 2024-10-25 | 670d | 1d |  | Stuart Scott |  |  | SI Test | PP | 5.0 | Systems Integration Testing (SIT) | 190.71 | Green | GREEN | MHHS-ART154 MHHS-ART147 | T3-TE-0048 | QAG | T3 |
| 1188 | 1.4.4 | **SIT PPs E2E Sandbox Testing Execution** |  | 316d | 2024-11-04 | 2026-01-19 |  |  |  | 2024-11-04 | 2026-01-19 | 316d | 2024-11-04 | 2026-01-19 | 354d |  |  | N/A | 5056h |  | N/A | N/A | 5.0 | Systems Integration Testing (SIT) |  |  |  |  |  |  |  |
| 1189 | 1.4.4.1 | SIT PPs E2E Sandbox Testing Start | milestone | 0d | 2024-11-04 | 2024-11-04 | 1039FS+1d, 1187FS+5d |  |  | 2024-11-04 | 2024-11-04 | 0d | 2024-11-04 | 2024-11-04 | 669d | 0d |  | Stuart Scott |  |  | SI Test | PP | 5.0 | Systems Integration Testing (SIT) | 200.71 | Green | GREEN | MHHS-ART018 MHHS-ART154 MHHS-ART147 | T3-TE-0049 | QAG | T3 |
| 1190 | 1.4.4.2 | SIT PPs E2E Sandbox Testing Execution |  | 316d | 2024-11-04 | 2026-01-19 | 1189SS-1d, 1600FF |  |  | 2024-11-04 | 2026-01-19 | 316d | 2024-11-04 | 2026-01-19 | 354d | 0d | start no earlier than 2024-11-04 | Stuart Scott | 2528h |  | PP | SI Test | 5.0 | Systems Integration Testing (SIT) | 200.33 | Green | GREEN |  |  |  |  |

| ID | WBS | Task | Type | Duration | Start | Finish | Predecessors | Complete | Remaining | Baseline start | Baseline finish | Baseline duration | Baseline 1 start | Baseline 1 finish | Total slack | Free slack | Constraint | Resources | Work | Actual work | Baseline cost | Responsible | Involved | Update Version | MHHS Programme Phase | Sched Status | RAG | Task Status | Milestone ID | Text29 | Tier | Guidance |
| --- | --- | --- | --- | --- | --- | --- | --- | --- | --- | --- | --- | --- | --- | --- | --- | --- | --- | --- | --- | --- | --- | --- | --- | --- | --- | --- | --- | --- | --- | --- | --- | --- |
| 1191 | 1.4.5 | **External Programme Dependency Management** |  | 174d | 2022-10-31 A | 2023-06-30 A |  | 100% |  | 2022-10-31 | 2023-06-30 | 174d | 2022-10-31 | 2023-06-30 |  |  |  | N/A | 9712h | 9712h |  | N/A | N/A | 5.0 | Systems Integration Testing (SIT) |  |  |  |  |  |  |  |
| 1192 | 1.4.5.1 | **BSC CP1558** |  | 173d | 2022-10-31 A | 2023-06-29 A |  | 100% |  | 2022-10-31 | 2023-06-29 | 173d | 2022-10-31 | 2023-06-29 |  |  |  | N/A | 2768h | 2768h |  | N/A | N/A | 5.0 | Systems Integration Testing (SIT) |  |  |  |  |  |  |  |
| 1193 | 1.4.5.1.1 | Monitor progress to implementation date |  | 173d | 2022-10-31 A | 2023-06-28 A |  | 100% |  | 2022-10-31 | 2023-06-28 | 173d | 2022-10-31 | 2023-06-28 |  |  |  | Andrew Margan | 1384h | 1384h |  | CPT | Code Bodies | 5.0 | Systems Integration Testing (SIT) | Complete | COMPLETE |  |  |  |  |  |
| 1194 | 1.4.5.1.2 | BSC CP1558 Implementation Date | milestone | 0d | 2023-06-29 A | 2023-06-29 A | 1193 | 100% |  | 2023-06-29 | 2023-06-29 | 0d | 2023-06-29 | 2023-06-29 |  |  | must start on 2023-06-29 | Andrew Margan |  |  |  | Code Bodies |  | 5.0 | Systems Integration Testing (SIT) | Complete | COMPLETE |  |  |  |  |  |
| 1195 | 1.4.5.2 | **REC CP R0032** |  | 174d | 2022-10-31 A | 2023-06-30 A |  | 100% |  | 2022-10-31 | 2023-06-30 | 174d | 2022-10-31 | 2023-06-30 |  |  |  | N/A | 2784h | 2784h |  | N/A | N/A | 5.0 | Systems Integration Testing (SIT) |  |  |  |  |  |  |  |
| 1196 | 1.4.5.2.1 | Monitor progress to implementation date |  | 174d | 2022-10-31 A | 2023-06-29 A |  | 100% |  | 2022-10-31 | 2023-06-29 | 174d | 2022-10-31 | 2023-06-29 |  |  |  | Andrew Margan | 1392h | 1392h |  | CPT | Code Bodies | 5.0 | Systems Integration Testing (SIT) | Complete | COMPLETE |  |  |  |  |  |
| 1197 | 1.4.5.2.2 | REC CP R0032 Implementation Date | milestone | 0d | 2023-06-30 A | 2023-06-30 A | 1196 | 100% |  | 2023-06-30 | 2023-06-30 | 0d | 2023-06-30 | 2023-06-30 |  |  | must start on 2023-06-30 | Andrew Margan |  |  |  | Code Bodies |  | 5.0 | Systems Integration Testing (SIT) | Complete | COMPLETE |  |  |  |  |  |
| 1198 | 1.4.5.3 | **REC CP R0044** |  | 173d | 2022-10-31 A | 2023-06-29 A |  | 100% |  | 2022-10-31 | 2023-06-29 | 173d | 2022-10-31 | 2023-06-29 |  |  |  | N/A | 2768h | 2768h |  | N/A | N/A | 5.0 | Systems Integration Testing (SIT) |  |  |  |  |  |  |  |
| 1199 | 1.4.5.3.1 | Monitor progress to implementation date |  | 173d | 2022-10-31 A | 2023-06-28 A |  | 100% |  | 2022-10-31 | 2023-06-28 | 173d | 2022-10-31 | 2023-06-28 |  |  |  | Andrew Margan | 1384h | 1384h |  | CPT | Code Bodies | 5.0 | Systems Integration Testing (SIT) | Complete | COMPLETE |  |  |  |  |  |
| 1200 | 1.4.5.3.2 | REC CP R0044 Implementation Date | milestone | 0d | 2023-06-29 A | 2023-06-29 A | 1199 | 100% |  | 2023-06-29 | 2023-06-29 | 0d | 2023-06-29 | 2023-06-29 |  |  | must start on 2023-06-29 | Andrew Margan |  |  |  | Code Bodies |  | 5.0 | Systems Integration Testing (SIT) | Complete | COMPLETE |  |  |  |  |  |
| 1201 | 1.5 | **NON SIT LDSO QUALIFICATION** |  | 344d | 2023-11-07 A | 2025-02-28 |  | 28% | 247.1d | 2022-10-31 | 2025-01-24 | 585d | 2024-01-29 | 2024-07-05 | 585d |  |  | N/A | 25632h | 5606.8h | -0 | N/A | N/A | 5.18 | Systems Integration Testing (SIT) |  |  |  |  |  |  |  |
| 1202 | 1.5.1 | **Approach Planning** |  | 138d | 2023-11-07 A | 2024-05-16 |  | 88% | 16.56d | 2024-01-29 | 2024-05-28 | 87d |  |  | 585d |  |  | N/A | 2104h | 1368h | -0 | N/A | N/A | 5.18 |  |  |  | -386.67 |  |  |  |  |
| 1203 | 1.5.1.1 | Develop Draft Testing Approach & Plan |  | 61d | 2023-11-07 A | 2024-01-30 A |  | 100% |  |  |  |  |  |  |  |  | start no earlier than 2023-11-07 | Ben Wickins | 488h | 488h |  | Non-SIT LDSO | Non-SIT LDSO | 5.18 |  | Complete | COMPLETE |  |  |  |  |  |
| 1204 | 1.5.1.2 | Draft Testing Approach & Plan Issued to LDSO for Review |  | 1d | 2024-01-31 A | 2024-01-31 A | 1203 | 100% |  |  |  |  |  |  |  |  |  | Ben Wickins | 8h | 8h |  | Non-SIT LDSO | Non-SIT LDSO | 5.18 |  | Complete | COMPLETE |  |  |  |  |  |
| 1205 | 1.5.1.3 | LDSO Review Complete |  | 10d | 2024-02-01 A | 2024-02-14 A | 1204 | 100% |  |  |  |  |  |  |  |  |  | Ben Wickins | 80h | 80h |  | LDSOs | Non-SIT LDSO | 5.18 |  | Complete | COMPLETE |  |  |  |  |  |
| 1206 | 1.5.1.4 | Update Following LDSO Review |  | 14d | 2024-02-15 A | 2024-03-05 A | 1205 | 100% |  |  |  |  |  |  |  |  |  | Ben Wickins | 112h | 112h |  | Non-SIT LDSO | Non-SIT LDSO, Code Bodies | 5.18 |  | Complete | COMPLETE |  |  |  |  |  |
| 1207 | 1.5.1.5 | QWG Review of Approach & Plan |  | 1d | 2024-03-12 A | 2024-03-12 A | 1206FS+4d | 100% |  |  |  |  |  |  |  |  |  | Ben Wickins | 8h | 8h |  | Non-SIT LDSO, PP | Non-SIT LDSO, Code Bodies | 5.18 |  | Complete | COMPLETE |  |  |  |  |  |
| 1208 | 1.5.1.6 | QAG Approval for Approach & Plan | milestone | 0d | 2024-03-21 A | 2024-03-21 A | 1207FS+7d | 100% |  |  |  |  |  |  |  |  |  | Ben Wickins |  |  |  | Code Bodies | Non-SIT LDSO,Code Bodies | 5.18 |  | Complete | COMPLETE |  |  |  |  |  |
| 1209 | 1.5.1.7 | Confirmation of Participants for Non-SIT LDSO Qualification Testing | milestone | 0d | 2024-03-21 A | 2024-03-21 A | 1208 | 100% |  | 2024-01-29 | 2024-01-29 | 0d | 2024-01-29 | 2024-01-29 |  |  |  | Ben Wickins |  |  |  | Non-SIT LDSO | SI Test, PP, IPA | 5.21 | Systems Integration Testing (SIT) | Complete | COMPLETE |  | T3-QU-0011 | QAG (Non-SIT LDSO) | T3 |  |
| 1210 | 1.5.1.8 | Update to Annex 1 for internal review (NF, Not Operational) |  | 15d | 2024-03-18 A | 2024-04-05 A | 918 | 100% |  |  |  |  |  |  |  |  |  | Ben Wickins | 120h | 120h |  | Non-SIT LDSO | PP, Code Bodies | 5.18 |  | Complete | COMPLETE |  |  |  |  | 26/3: Linked to the developmnent of SIT non functional plan |
| 1211 | 1.5.1.9 | Non-Functional, Operational & Migration Approaches Socialised with Code Bodies & LDSO & Feedback Actioned |  | 21d | 2024-04-08 A | 2024-05-06 | 1210 | 38% | 13d |  |  |  |  |  | 585d | 0d |  | Ben Wickins | 168h | 64h |  | Non-SIT LDSO | PP, Code Bodies | 5.18 |  | No BL | GREEN |  |  |  |  |  |
| 1212 | 1.5.1.10 | QWG Review Operational, Non-Functional & Migration Annexes of Approach & Plan |  | 1d | 2024-05-14 | 2024-05-14 | 1211FS+5d |  |  |  |  |  |  |  | 585d | 0d |  | Ben Wickins | 8h |  |  | Non-SIT LDSO, PP | Non-SIT LDSO, PP, Code Bodies | 5.18 |  | No BL | GREEN | 26.33 |  |  |  |  |
| 1213 | 1.5.1.11 | Update Following QWG Review |  | 1d | 2024-05-15 | 2024-05-15 | 1212 |  |  |  |  |  |  |  | 585d | 0d |  | Ben Wickins | 8h |  |  | Non-SIT LDSO, PP | Non-SIT LDSO, Code Bodies | 5.18 |  | No BL | GREEN | 27.33 |  |  |  |  |
| 1214 | 1.5.1.12 | QAG Approval for Operational, Non-Functional & Migration Annexes of Approach & Plan | milestone | 0d | 2024-05-16 | 2024-05-16 | 1213FS+1d, 1209, 921 |  |  | 2024-05-28 | 2024-05-28 | 1d |  |  | 585d | 0d |  | Ben Wickins |  |  |  | Code Bodies | Non-SIT LDSO, Code Bodies | 5.18 |  | Green | GREEN | 28.71 | TBC | QAG (Non-SIT LDSO) |  |  |

Notes:
- 1209: Have confirmed LDSOs going through SIT. We should receive notifications on non-SIT through January. Milestone holds to baseline.
- 1210: Includes time to update Approach & Plan with updates
- 1214: 27/2 - New milestone to go to 21/3 QAG for approval

| ID | WBS | Task | Type | Duration | Start | Finish | Predecessors | Complete | Remaining | Baseline start | Baseline finish | Baseline duration | Baseline 1 start | Baseline 1 finish | Total slack | Free slack | Constraint | Resources | Work | Actual work | Baseline cost | Responsible | Involved | Task Status | Update Version | Sched Status | RAG | Action | Milestone ID | Text29 | MHHS Programme Phase | Tier |
| --- | --- | --- | --- | --- | --- | --- | --- | --- | --- | --- | --- | --- | --- | --- | --- | --- | --- | --- | --- | --- | --- | --- | --- | --- | --- | --- | --- | --- | --- | --- | --- | --- |
| 1215 | 1.5.2 | **Functional Test Cases & Scenarios** |  | 58d | 2024-01-30 A | 2024-04-18 |  | 99% | 0d | 2024-04-18 | 2024-04-18 | 0d |  |  | 585d |  |  | N/A | 928h | 395.43h | -0 | N/A | N/A | -385.67 | 5.18 |  |  |  |  |  |  |  |
| 1216 | 1.5.2.1 | **Functional Test Cases & Scenarios Batch 1** |  | 8d | 2024-01-30 A | 2024-02-08 A |  | 100% |  |  |  |  |  |  |  |  |  | N/A | 104h | 104h |  | N/A | N/A |  | 5.18 |  |  |  |  |  |  |  |
| 1217 | 1.5.2.1.1 | Walkthrough Test Cases & Scenarios Batch 1 with Code Bodies |  | 1d | 2024-01-30 A | 2024-01-30 A | 1203SS+60d | 100% |  |  |  |  |  |  |  |  |  | Ben Wickins | 8h | 8h |  | Non-SIT LDSO | Non-SIT LDSO, Code Bodies |  | 5.18 | Complete | COMPLETE |  |  |  |  |  |
| 1218 | 1.5.2.1.2 | Walkthrough Test Cases & Scenarios Batch 1 with LDSO |  | 1d | 2024-02-01 A | 2024-02-01 A | 1217 | 100% |  |  |  |  |  |  |  |  |  | Ben Wickins | 8h | 8h |  | LDSO, Non-SIT LDSO | LDSO, Non-SIT LDSO |  | 5.18 | Complete | COMPLETE |  |  |  |  |  |
| 1219 | 1.5.2.1.3 | Action Feedback on Test Cases & Scenarios Batch 1 |  | 5d | 2024-02-02 A | 2024-02-08 A | 1218 | 100% |  |  |  |  |  |  |  |  |  | Ben Wickins | 40h | 40h |  | Non-SIT LDSO | Non-SIT LDSO, LDSO , Code Bodies |  | 5.18 | Complete | COMPLETE |  |  |  |  |  |
| 1220 | 1.5.2.2 | **Functional Test Cases & Scenarios Batch 2** |  | 14d | 2024-02-20 A | 2024-03-08 A |  | 100% |  |  |  |  |  |  |  |  |  | N/A | 168h | 168h |  | N/A | N/A |  | 5.18 |  |  |  |  |  |  |  |
| 1221 | 1.5.2.2.1 | Walkthrough Test Cases & Scenarios Batch 2 with Code Bodies |  | 1d | 2024-02-20 A | 2024-02-20 A | 1203SS+75d | 100% |  |  |  |  |  |  |  |  |  | Ben Wickins | 8h | 8h |  | Non-SIT LDSO | Non-SIT LDSO, Code Bodies |  | 5.18 | Complete | COMPLETE |  |  |  |  |  |
| 1222 | 1.5.2.2.2 | Walkthrough Test Cases & Scenarios Batch 2 with LDSO |  | 1d | 2024-03-01 A | 2024-03-01 A | 1221FS+7d | 100% |  |  |  |  |  |  |  |  |  | Ben Wickins | 8h | 8h |  | LDSO, Non-SIT LDSO | LDSO, Non-SIT LDSO |  | 5.18 | Complete | COMPLETE |  |  |  |  |  |
| 1223 | 1.5.2.2.3 | Action Feedback on Test Cases & Scenarios Batch 2 |  | 5d | 2024-03-04 A | 2024-03-08 A | 1222 | 100% |  |  |  |  |  |  |  |  |  | Ben Wickins | 40h | 40h |  | Non-SIT LDSO | Non-SIT LDSO, LDSO , Code Bodies |  | 5.18 | Complete | COMPLETE |  |  |  |  |  |
| 1224 | 1.5.2.3 | **Functional Test Cases & Scenarios Batch 3** |  | 13d | 2024-03-20 A | 2024-04-05 |  | 99% | 0d |  |  |  |  |  | 0d |  |  | N/A | 168h | 91.43h |  | N/A | N/A |  | 5.18 |  |  |  |  |  |  |  |
| 1225 | 1.5.2.3.1 | Walkthrough Test Cases & Scenarios Batch 3 with Code Bodies |  | 1d | 2024-03-20 A | 2024-03-20 A | 1203SS+96d | 100% |  |  |  |  |  |  |  |  |  | Ben Wickins | 8h | 8h |  | Non-SIT LDSO | Non-SIT LDSO, Code Bodies |  | 5.18 | Complete | COMPLETE |  |  |  |  |  |
| 1226 | 1.5.2.3.2 | Walkthrough Test Cases & Scenarios Batch 3 with LDSO |  | 1d | 2024-03-28 A | 2024-03-28 A | 1225FS+5d | 100% |  |  |  |  |  |  |  |  |  | Ben Wickins | 8h | 8h |  | LDSO, Non-SIT LDSO | LDSO, Non-SIT LDSO |  | 5.18 | Complete | COMPLETE |  |  |  |  |  |
| 1227 | 1.5.2.3.3 | Action Feedback on Test Cases & Scenarios Batch 3 |  | 6d | 2024-03-29 A | 2024-04-05 A | 1226 | 100% |  |  |  |  |  |  |  |  |  | Ben Wickins | 48h | 48h |  | Non-SIT LDSO | Non-SIT LDSO, LDSO , Code Bodies |  | 5.18 | Complete | COMPLETE |  |  |  |  |  |
| 1228 | 1.5.2.4 | Test Cases & Scenarios Batch 1-3 Discussion at QWG |  | 1d | 2024-04-09 A | 2024-04-09 A | 1219, 1223, 1227FS+1d | 100% |  |  |  |  |  |  |  |  |  | Ben Wickins | 8h | 8h |  | Non-SIT LDSO, PP | Non-SIT LDSO, Code Bodies |  | 5.18 | Complete | COMPLETE |  |  |  |  |  |
| 1229 | 1.5.2.5 | Action QWG Feedback on Test Cases & Sceanrios Batch 1-3 |  | 2d | 2024-04-10 A | 2024-04-11 A | 1228 | 100% |  |  |  |  |  |  |  |  |  | Ben Wickins | 16h | 16h |  | Non-SIT LDSO | Non-SIT LDSO, Code Bodies |  | 5.18 | Complete | COMPLETE |  |  |  |  |  |
| 1230 | 1.5.2.6 | Approval of Batch 1-3 Test Cases & Scenarios at QAG | milestone | 0d | 2024-04-18 | 2024-04-18 | 1229FS+5d |  |  | 2024-04-18 | 2024-04-18 | 0d |  |  | 585d | 0d |  | Ben Wickins |  |  |  | Code Bodies | Non-SIT LDSO, Code Bodies | 0.71 | 5.19 | Green | GREEN | 27/2 - Ben to confirm if should go to QAG | TBC | QAG (Non-SIT LDSO) |  |  |
| 1231 | 1.5.3 | **Test Execution Schedule** |  | 84d | 2024-04-19 | 2024-08-15 |  |  |  | 2024-04-26 | 2024-07-24 | 64d | 2024-01-29 | 2024-04-26 | 619d |  |  | N/A | 1144h |  | -0 | N/A | N/A |  | 5.18 |  |  |  |  |  | Systems Integration Testing (SIT) |  |
| 1232 | 1.5.3.1 | Draft Test Delivery Schedule |  | 20d | 2024-04-19 | 2024-05-16 | 1230 |  |  |  |  |  | 2024-01-29 | 2024-03-22 | 638d | 0d |  | Ben Wickins | 160h |  |  | Non-SIT LDSO | SI Test, PP, Non-SIT LDSO | 1.33 | 5.18 | No BL | GREEN |  |  |  | Systems Integration Testing (SIT) |  |
| 1233 | 1.5.3.2 | Socialise Test Delivery Schedule with Code Bodies & LDSO for Review & Action Feedback |  | 37d | 2024-05-17 | 2024-07-08 | 1232 |  |  |  |  |  |  |  | 638d | 0d |  | Ben Wickins | 296h |  |  | Non-SIT LDSO | LDSO, Code Bodies, Non-SIT LDSO | 29.33 | 5.18 | No BL | GREEN |  |  |  |  |  |
| 1234 | 1.5.3.3 | Agree Test Execution Timetable Format at QWG, Including Anonymisation Requirements |  | 1d | 2024-07-09 | 2024-07-09 | 1233 |  |  |  |  |  | 2024-03-25 | 2024-04-19 | 638d | 0d |  | Ben Wickins | 8h |  |  | Non-SIT LDSO, PP | Non-SIT LDSO, Code Bodies | 82.33 | 5.18 | No BL | GREEN |  |  |  | Systems Integration Testing (SIT) |  |
| 1235 | 1.5.3.4 | Action QWG Feedback |  | 3d | 2024-07-10 | 2024-07-12 | 1234 |  |  |  |  |  |  |  | 638d | 0d |  | Ben Wickins | 24h |  |  | Non-SIT LDSO, PP | Non-SIT LDSO, Code Bodies | 83.33 | 5.18 | No BL | GREEN |  |  |  |  |  |
| 1236 | 1.5.3.5 | Agree Test Execution Timetable Format at QAG, Including Anonymisation Requirements | milestone | 0d | 2024-07-18 | 2024-07-18 | 1235FS+4d |  |  | 2024-07-24 | 2024-07-24 | 1d |  |  | 638d | 19d |  | Ben Wickins |  |  |  | Code Bodies | Non-SIT LDSO, Code Bodies | 91.71 | 5.18 | Green | GREEN |  | TBC | QAG (Non-SIT LDSO) |  |  |
| 1237 | 1.5.3.6 | Qualification Testing for Non-SIT LDSOs (Functional, Migration, NFT, Operational) Test Execution Schedule Approved | milestone | 0d | 2024-08-15 | 2024-08-15 | 1236 |  |  | 2024-04-26 | 2024-04-26 | 0d | 2024-04-26 | 2024-04-26 | 619d | 34d | start no earlier than 2024-08-15 | Ben Wickins |  |  |  | Non-SIT LDSO | Non-SIT LDSO, Code Bodies, PP | 119.33 | 5.18 | Red | RED |  | T3-QU-0008 | QAG (Non-SIT LDSO) | Systems Integration Testing (SIT) | T3 |
| 1238 | 1.5.4 | **Functional, Non-Functional, Operational & Migration Test Scenarios & Cases** |  | 70d | 2024-03-22 A | 2024-06-27 |  | 41% | 41.5d | 2024-03-22 | 2024-06-27 | 70d |  |  | 653d |  |  | N/A | 1336h | 508.45h |  | N/A | N/A |  | 5.21 |  |  |  |  |  |  |  |
| 1239 | 1.5.4.1 | Test Scenarios & Cases - Functional - Drafted, Reviewed |  | 14d | 2024-04-01 A | 2024-04-18 | 1208 | 93% | 1d | 2024-04-01 | 2024-04-18 | 14d |  |  | 703d | 0d |  | Ben Wickins | 112h | 104h |  | Non-SIT LDSO | Non-SIT LDSO, LDSO, Code Bodies |  | 5.21 | Green | GREEN | 5/3 - BW to confirm if needs to go to qag for approval |  |  |  |  |
| 1240 | 1.5.4.2 | Test Scenarios & Cases- Functional - Approved at QAG | milestone | 0d | 2024-04-18 | 2024-04-18 | 1239 |  |  | 2024-04-18 | 2024-04-18 | 0d |  |  | 703d | 117d |  | Ben Wickins |  |  |  | Non-SIT LDSO | Non-SIT LDSO, LDSO, Code Bodies | 0.71 | 5.21 | Green | GREEN |  | TBC | QAG (Non-SIT LDSO) |  |  |
| 1241 | 1.5.4.3 | Test Scenarios & Cases - Non-Functional - Drafted, Reviewed |  | 40d | 2024-03-22 A | 2024-05-16 | 1208 | 35% | 26d | 2024-03-22 | 2024-06-20 | 65d |  |  | 658d | 0d |  | Ben Wickins | 320h | 112h |  | Non-SIT LDSO | Non-SIT LDSO, LDSO, Code Bodies |  | 5.21 | Green | GREEN | link to 938/8194 - theme 2 |  |  |  |  |
| 1242 | 1.5.4.4 | Test Scenarios & Cases - Non-Functional - Approved at QAG | milestone | 0d | 2024-06-20 | 2024-06-20 | 1241FS+25d |  |  | 2024-06-20 | 2024-06-20 | 0d |  |  | 658d | 72d |  | Ben Wickins |  |  |  | Non-SIT LDSO | Non-SIT LDSO, LDSO, Code Bodies | 63.71 | 5.21 | Green | GREEN |  | TBC | QAG (Non-SIT LDSO) |  |  |
| 1243 | 1.5.4.5 | Test Scenarios & Cases - Migration - Drafted, Reviewed |  | 40d | 2024-03-22 A | 2024-05-16 | 1208 | 48% | 21d | 2024-03-22 | 2024-05-16 | 40d |  |  | 683d | 0d |  | Ben Wickins | 320h | 152h |  | Non-SIT LDSO | Non-SIT LDSO, LDSO, Code Bodies |  | 5.21 | Green | GREEN |  |  |  |  |  |
| 1244 | 1.5.4.6 | Test Scenarios & Cases - Migration - Approved at QAG | milestone | 0d | 2024-05-16 | 2024-05-16 | 1243 |  |  | 2024-05-16 | 2024-05-16 | 0d |  |  | 683d | 97d |  | Ben Wickins |  |  |  | Non-SIT LDSO | Non-SIT LDSO, LDSO, Code Bodies | 28.71 | 5.21 | Green | GREEN |  | TBC | QAG (Non-SIT LDSO) |  |  |
| 1245 | 1.5.4.7 | Test Scenarios & Cases - Operational - Drafted, Reviewed |  | 19d | 2024-06-03 | 2024-06-27 | 1208FS+51d |  |  | 2024-06-03 | 2024-06-27 | 19d |  |  | 643d | 0d |  | Ben Wickins | 152h |  |  | Non-SIT LDSO | Non-SIT LDSO, LDSO, Code Bodies | 46.33 | 5.21 | Green | GREEN | 5/3 - BW to confirm if needs to go to qag for approval |  |  |  |  |
| 1246 | 1.5.4.8 | Test Scenarios & Cases - Operational - Approved at QAG | milestone | 0d | 2024-06-27 | 2024-06-27 | 1245 |  |  | 2024-06-27 | 2024-06-27 | 0d |  |  | 643d | 0d |  | Ben Wickins |  |  |  | Non-SIT LDSO | Non-SIT LDSO, LDSO, Code Bodies | 70.71 | 5.21 | Green | GREEN | 992/8214 link to theme 2? | TBC | QAG (Non-SIT LDSO) |  |  |

Notes:
- 1236: 27/2 - New milestone to go to 21/3 QAG for approval

| ID | WBS | Task | Type | Duration | Start | Finish | Predecessors | Complete | Remaining | Baseline start | Baseline finish | Baseline duration | Total slack | Free slack | Deadline | Resources | Work | Actual work | Baseline cost | Responsible | Involved | Update Version | Task Status | Sched Status | RAG | Milestone ID | Text29 |
| --- | --- | --- | --- | --- | --- | --- | --- | --- | --- | --- | --- | --- | --- | --- | --- | --- | --- | --- | --- | --- | --- | --- | --- | --- | --- | --- | --- |
| 1247 | 1.5.5 | **Cross Check Against SIT** |  | 10d | 2024-06-28 | 2024-07-11 |  |  |  | 2022-10-31 | 2022-11-16 | 13d | 643d |  |  | N/A | 160h |  |  | N/A | N/A | 5.18 |  |  |  |  |  |
| 1248 | 1.5.5.1 | Cross Check Scenarios Against Those Used In Waves |  | 5d | 2024-06-28 | 2024-07-04 | 1246 |  |  |  |  |  | 643d | 0d |  | Ben Wickins | 40h |  |  | Non-SIT LDSO | Non-SIT LDSO | 5.18 | 71.33 | No BL | GREEN |  |  |
| 1249 | 1.5.5.2 | Updates to Test Deliverables Post SIT Cross Check |  | 5d | 2024-07-05 | 2024-07-11 | 1248 |  |  |  |  |  | 643d | 57d |  | Ben Wickins | 40h |  |  | Non-SIT LDSO | Non-SIT LDSO | 5.18 | 78.33 | No BL | GREEN |  |  |
| 1250 | 1.5.6 | **Test Data** |  | 240d | 2024-01-22 A | 2024-12-20 |  | 25% | 179.52d | 2024-05-16 | 2024-09-02 | 77d | 635d |  |  | N/A | 3920h | 669.29h | -0 | N/A | N/A | 5.18 | -385.67 |  |  |  |  |
| 1251 | 1.5.6.1 | Test Data Plan Drafted & Reviewed |  | 84d | 2024-01-22 A | 2024-05-16 | 1203 | 75% | 21d |  |  |  | 635d | 0d |  | Ben Wickins | 672h | 504h |  | Code Bodies | Non-SIT LDSO, Code Bodies | 5.18 |  | No BL | GREEN |  |  |
| 1252 | 1.5.6.2 | Test Data Plan Approved at QAG | milestone | 0d | 2024-05-16 | 2024-05-16 | 1251 |  |  | 2024-04-26 | 2024-04-26 | 0d | 635d | 0d |  | Ben Wickins |  |  |  | Code Bodies | Non-SIT LDSO, Code Bodies | 5.19 | 28.71 | Red | RED | TBC | QAG (Non-SIT LDSO) |
| 1253 | 1.5.6.3 | Develop Test Data Matrices |  | 10d | 2024-05-17 | 2024-05-30 | 1252 |  |  |  |  |  | 642d | 7d |  | Ben Wickins | 80h |  |  | Non-SIT LDSO | Non-SIT LDSO | 5.22 | 29.33 | No BL | GREEN |  |  |
| 1254 | 1.5.6.4 | Test Data Cut |  | 17d | 2024-05-17 | 2024-06-10 | 1252 |  |  |  |  |  | 635d | 0d |  | Ben Wickins | 136h |  |  | PP, Non-SIT LDSO | PP, Non-SIT LDSO | 5.18 | 29.33 | No BL | GREEN |  |  |
| 1255 | 1.5.6.5 | Test Data Cut Complete | milestone | 0d | 2024-06-10 | 2024-06-10 | 1254, 1253 |  |  | 2024-06-10 | 2024-06-10 | 0d | 635d | 0d |  | Ben Wickins |  |  |  | PP, Non-SIT LDSO | PP, Non-SIT LDSO | 5.21 | 53.71 | Green | GREEN | TBC | QAG (Non-SIT LDSO) |
| 1256 | 1.5.6.6 | Test Data Reviewed by the Programme |  | 43d | 2024-06-11 | 2024-08-08 | 1255 |  |  |  |  |  | 635d | 0d |  | Ben Wickins | 344h |  |  | Non-SIT LDSO | PP, Non-SIT LDSO | 5.18 | 54.33 | No BL | GREEN |  |  |
| 1257 | 1.5.6.7 | Test Data Loaded |  | 17d | 2024-08-09 | 2024-09-02 | 1256 |  |  |  |  |  | 635d | 0d |  | Ben Wickins | 136h |  |  | Non-SIT LDSO | PP, Non-SIT LDSO | 5.21 | 113.33 | No BL | GREEN |  |  |
| 1258 | 1.5.6.8 | Test Data Signed Off | milestone | 0d | 2024-09-02 | 2024-09-02 | 1257 |  |  | 2024-09-02 | 2024-09-02 | 0d | 635d | 0d |  | Ben Wickins |  |  |  | Non-SIT LDSO | PP, Non-SIT LDSO | 5.21 | 137.71 | Green | GREEN | TBC | QAG (Non-SIT LDSO) |
| 1259 | 1.5.6.9 | Test Execution Data Support |  | 79d | 2024-09-03 | 2024-12-20 | 1258 |  |  |  |  |  | 635d | 25d |  | Ben Wickins | 632h |  |  | Non-SIT LDSO | Non-SIT LDSO | 5.22 | 138.33 | No BL | GREEN |  |  |
| 1260 | 1.5.7 | **Tooling** |  | 145d | 2024-01-31 A | 2024-08-20 |  | 39% | 89d |  |  |  | 615d |  |  | N/A | 2320h | 896h |  | N/A | N/A | 5.18 | -385.67 |  |  |  |  |
| 1261 | 1.5.7.1 | Design Approach & Set-Up ADO Tool for Test & Defect Management Tool |  | 53d | 2024-01-31 A | 2024-04-12 A | 1203 | 100% |  |  |  |  |  |  |  | Ben Wickins | 424h | 424h |  | Non-SIT LDSO | Non-SIT LDSO, SI Test | 5.18 |  | Complete | COMPLETE |  |  |
| 1262 | 1.5.7.2 | Develop Training Requirements & Materials Inc. Day in the Life |  | 87d | 2024-04-15 A | 2024-08-13 | 1261 | 3% | 84d |  |  |  | 615d | 0d |  | Ben Wickins | 696h | 24h |  | Non-SIT LDSO | Non-SIT LDSO, SI Test | 5.18 |  | No BL | GREEN |  |  |
| 1263 | 1.5.7.3 | ADO Launch |  | 5d | 2024-08-14 | 2024-08-20 | 1262 |  |  |  |  |  | 615d | 30d |  | Ben Wickins | 40h |  |  | Non-SIT LDSO | Non-SIT LDSO | 5.21 | 118.33 | No BL | GREEN |  |  |
| 1264 | 1.5.8 | **Pre-Integration Testing** |  | 171d | 2024-02-05 A | 2024-09-30 |  | 31% | 118d | 2024-04-26 | 2024-09-30 | 112d | 586d |  |  | N/A | 2688h | 544.99h | -0 | N/A | N/A | 5.18 | -385.67 |  |  |  |  |
| 1265 | 1.5.8.1 | PIT Guidance & Templates & Approach & Plans Developed |  | 95d | 2024-02-05 A | 2024-06-14 | 1203FS+3d | 56% | 42d |  |  |  | 586d | 0d |  | Ben Wickins | 760h | 424h |  | Non-SIT LDSO | Non-SIT LDSO, LDSO | 5.18 |  | No BL | GREEN |  |  |
| 1266 | 1.5.8.2 | PIT Test Plan Deadline for Submission for Non-SIT LDSO​ QT | milestone | 0d | 2024-06-14 | 2024-06-14 | 1265 |  |  | 2024-04-26 | 2024-04-26 |  | 586d | 0d |  | Ben Wickins |  |  |  | Non-SIT LDSO | Non-SIT LDSO, LDSO | 5.18 | 57.71 | Red | RED | TBC | QAG (Non-SIT LDSO) |
| 1267 | 1.5.8.3 | Develop and agree PIT Test Senarios |  | 31d | 2024-06-17 | 2024-07-29 | 1266 |  |  |  |  |  | 586d | 0d |  | Ben Wickins | 248h |  |  | Non-SIT LDSO | Non-SIT LDSO, Code Bodies, LDSO | 5.22 | 60.33 | No BL | GREEN |  |  |
| 1268 | 1.5.8.4 | PIT Execution |  | 45d | 2024-07-30 | 2024-09-30 | 1267 |  |  |  |  |  | 586d | 0d |  | Ben Wickins | 360h |  |  | Non-SIT LDSO | Non-SIT LDSO, LDSO | 5.22 | 103.33 | No BL | GREEN |  |  |
| 1269 | 1.5.8.5 | Non-SIT LDSO Participants have submitted PIT Test Completion Report & evidence for QT Entry​ | milestone | 0d | 2024-09-30 | 2024-09-30 | 1268 |  |  | 2024-09-30 | 2024-09-30 | 0d | 586d | 0d |  | Ben Wickins |  |  |  | Non-SIT LDSO | Non-SIT LDSO, LDSO | 5.18 | 165.71 | Green | GREEN | TBC | QAG (Non-SIT LDSO) |
| 1270 | 1.5.9 | **Placing Reliance - Code Body & LDSO** |  | 102d | 2024-01-31 A | 2024-06-20 |  | 55% | 46d | 2024-06-20 | 2024-06-20 | 0d | 611d |  |  | N/A | 1632h | 656h | -0 | N/A | N/A | 5.18 | -100.67 |  |  |  |  |
| 1271 | 1.5.9.1 | Placing Reliance Submitted & Reviewed |  | 21d | 2024-01-31 A | 2024-02-28 A | 1203 | 100% |  |  |  |  |  |  | 2024-01-05 | Ben Wickins | 168h | 168h |  | LDSO, Non-SIT LDSO | LDSO, Non-SIT LDSO | 5.18 |  | Complete | COMPLETE |  |  |
| 1272 | 1.5.9.2 | Define & Agree QT Testing for Each LDSO |  | 22d | 2024-02-29 A | 2024-03-29 A | 1271 | 100% |  |  |  |  |  |  |  | Ben Wickins | 176h | 176h |  | Non-SIT LDSO | LDSO, Non-SIT LDSO | 5.18 |  | Complete | COMPLETE |  |  |
| 1273 | 1.5.9.3 | Develop Test Scope & Reliance Submissions |  | 15d | 2024-04-01 A | 2024-04-19 | 1272 | 87% | 2d |  |  |  | 611d | 0d |  | Ben Wickins | 120h | 104h |  | Non-SIT LDSO | LDSO, Non-SIT LDSO, Code Bodies | 5.18 |  | No BL | GREEN |  |  |
| 1274 | 1.5.9.4 | Review and Consultation |  | 44d | 2024-04-22 | 2024-06-20 | 1273 |  |  |  |  |  | 611d | 0d |  | Ben Wickins | 352h |  |  | Non-SIT LDSO | LDSO, Non-SIT LDSO | 5.22 | 4.33 | No BL | GREEN |  |  |
| 1275 | 1.5.9.5 | PP Test Scope Approved at QAG | milestone | 0d | 2024-06-20 | 2024-06-20 | 1274 |  |  | 2024-06-20 | 2024-06-20 | 0d | 611d | 26d |  | Ben Wickins |  |  |  | Non-SIT LDSO | LDSO, Non-SIT LDSO | 5.19 | 63.71 | Green | GREEN | TBC | QAG (Non-SIT LDSO) |

Notes:
- 1248: To be driven by SIT maturity milestone & test scenarios - possibly brought forward
- 1252: 27/2 - New milestone to go to 21/3 QAG for approval

| ID | WBS | Task | Type | Duration | Start | Finish | Predecessors | Baseline start | Baseline finish | Baseline duration | Baseline 1 start | Baseline 1 finish | Total slack | Free slack | Constraint | Resources | Work | Baseline cost | Responsible | Involved | Update Version | Task Status | Sched Status | RAG | Milestone ID | Text29 | MHHS Programme Phase | Tier |
| --- | --- | --- | --- | --- | --- | --- | --- | --- | --- | --- | --- | --- | --- | --- | --- | --- | --- | --- | --- | --- | --- | --- | --- | --- | --- | --- | --- | --- |
| 1276 | 1.5.10 | **LDSO Test Reporting** |  | 118d | 2024-04-19 | 2024-10-01 |  | 2024-07-26 | 2024-10-10 | 54d |  |  | 585d |  |  | N/A | 1864h | -0 | N/A | N/A | 5.18 |  |  |  |  |  |  |  |
| 1277 | 1.5.10.1 | Interim Test Report & Plan Developed & Reviewed |  | 71d | 2024-04-19 | 2024-07-26 | 1230 |  |  |  |  |  | 585d | 0d |  | Ben Wickins | 568h |  | Non-SIT LDSO, LDSO | Non-SIT LDSO, LDSO | 5.18 | 1.33 | No BL | GREEN |  |  |  |  |
| 1278 | 1.5.10.2 | Test Plan Submission to MHHS Programme For Review | milestone | 0d | 2024-07-26 | 2024-07-26 | 1277 | 2024-07-26 | 2024-07-26 | 0d |  |  | 585d | 0d |  | Ben Wickins |  |  | LDSO | Non-SIT LDSO, LDSO | 5.18 | 99.71 | Green | GREEN | TBC | QAG (Non-SIT LDSO) |  |  |
| 1279 | 1.5.10.3 | Final Test Report Developed & Submitted |  | 44d | 2024-07-29 | 2024-09-26 | 1278 |  |  |  |  |  | 585d | 0d |  | Ben Wickins | 352h |  | Non-SIT LDSO | Non-SIT LDSO, LDSO | 5.18 | 102.33 | No BL | GREEN |  |  |  |  |
| 1280 | 1.5.10.4 | Non-SIT LDSO QT Test Execution Starts | milestone | 0d | 2024-10-01 | 2024-10-01 | 1279FS+3d, 1263, 1286, 1293, 1294, 1237 | 2024-10-10 | 2024-10-10 | 0d |  |  | 585d | 0d |  | Ben Wickins |  |  | Non-SIT LDSO | Non-SIT LDSO, LDSO, Code Bodies | 5.18 | 166.71 | Green | GREEN | TBC | QAG (Non-SIT LDSO) |  |  |
| 1281 | 1.5.11 | **Test Environment** |  | 112d | 2024-04-17 | 2024-09-19 |  | 2024-04-26 | 2025-01-24 | 196d | 2024-01-29 | 2024-07-05 | 593d |  |  | N/A | 1880h | -0 | N/A | N/A | 5.18 |  |  |  |  |  | Systems Integration Testing (SIT) |  |
| 1282 | 1.5.11.1 | Central System (DIP Env & Helix Test Harness) Test Environment DBT |  | 92d | 2024-04-17 | 2024-08-22 | 471 |  |  |  |  |  | 613d | 0d |  | Ben Wickins | 736h |  | LDSO | Non SIT-LDSO, LDSO | 5.20 | -0.67 | Overdue Start | GREEN |  |  |  |  |
| 1283 | 1.5.11.2 | Coordinate LDSO Env Preparation |  | 30d | 2024-07-12 | 2024-08-22 | 1282FF |  |  |  |  |  | 613d | 20d |  | Ben Wickins | 240h |  | Non-SIT LDSO | Non-SIT LDSO | 5.22 | 85.33 | No BL | GREEN |  |  |  |  |
| 1284 | 1.5.11.3 | DIP available for Onboarding |  | 1d | 2024-08-01 | 2024-08-01 |  |  |  |  |  |  | 593d | 0d | start no earlier than 2024-08-01 | Ben Wickins | 8h |  | Test Env | Test Env, Non-SIT LDSO | 5.22 | 105.33 | No BL | GREEN |  |  |  |  |
| 1285 | 1.5.11.4 | Qualification Testing for Non-SIT LDSOs (Functional, Migration, NFT, Operational) Participants' Environments (TBC) Ready To Start Connectivity Proving (Incl. Certificates & Security Compliance) | milestone | 0d | 2024-08-05 | 2024-08-05 | 1284FS+2d | 2024-04-26 | 2024-04-26 | 0d | 2024-04-26 | 2024-04-26 | 593d | 0d |  | Ben Wickins |  |  | Non-SIT LDSO | Code Bodies, PP, IPA | 5.18 | 109.71 | Red | RED | T3-QU-0009 | QAG (Non-SIT LDSO) | Systems Integration Testing (SIT) | T3 |
| 1286 | 1.5.11.5 | LDSO Test Environments Connection Confirmed to UIT Environment | milestone | 0d | 2024-09-19 | 2024-09-19 | 1285FS+33d, 1283 | 2024-09-19 | 2024-09-19 | 0d |  |  | 593d | 8d |  | Ben Wickins |  |  | Non-SIT LDSO | Code Bodies, PP, IPA | 5.18 | 154.71 | Green | GREEN | TBC | QAG (Non-SIT LDSO) |  |  |
| 1287 | 1.5.12 | **Test Readiness** |  | 97d | 2024-05-17 | 2024-09-30 |  | 2024-06-12 | 2024-10-10 | 86d |  |  | 585d |  |  | N/A | 1560h | -0 | N/A | N/A | 5.18 |  |  |  |  |  |  |  |
| 1288 | 1.5.12.1 | Preparation for Interim Test Readiness Report |  | 51d | 2024-05-17 | 2024-07-26 | 1214 |  |  |  |  |  | 585d | 0d |  | Ben Wickins | 408h |  | LDSO | LDSO, Non-SIT LDSO | 5.22 | 29.33 | No BL | GREEN |  |  |  |  |
| 1289 | 1.5.12.2 | Interim Test Readiness Report Submission to MHHS Programme for Review | milestone | 0d | 2024-07-26 | 2024-07-26 | 1288, 1275 | 2024-06-12 | 2024-06-12 | 0d |  |  | 585d | 0d |  | Ben Wickins |  |  | LDSO | Non-SIT LDSO, LDSO | 5.18 | 99.71 | Red | RED | TBC | QAG (Non-SIT LDSO) |  |  |
| 1290 | 1.5.12.3 | LDSO Update Readiness Report & Final Assurance by Programme |  | 25d | 2024-07-29 | 2024-08-30 | 1289 |  |  |  |  |  | 585d | 0d |  | Ben Wickins | 200h |  | Non-SIT LDSO, LDSO | Non-SIT LDSO, LDSO | 5.18 | 102.33 | No BL | GREEN |  |  |  |  |
| 1291 | 1.5.12.4 | Final Test Readiness Report Submitted to MHHS Programme |  | 1d | 2024-09-02 | 2024-09-02 | 1290 |  |  |  |  |  | 593d | 7d |  | Ben Wickins | 8h |  | LDSO | Non-SIT LDSO, Code Bodies | 5.18 | 137.33 | No BL | GREEN |  |  |  |  |
| 1292 | 1.5.12.5 | Final Programme Assurance of LDSO Test Readiness |  | 21d | 2024-09-02 | 2024-09-30 | 1290 |  |  |  |  |  | 585d | 0d |  | Ben Wickins | 168h |  | Non-SIT LDSO | Non-SIT LDSO, LDSO | 5.22 | 137.33 | No BL | GREEN |  |  |  |  |
| 1293 | 1.5.12.6 | Qualification Testing for Non-SIT LDSOs (Functional, Migration, NFT, Operational) Test Readiness Confirmed From The Programme | milestone | 0d | 2024-09-30 | 2024-09-30 | 1291FS+13d, 1269, 1240, 1242, 1244, 1249 | 2024-07-05 | 2024-07-05 | 0d | 2024-07-05 | 2024-07-05 | 586d | 1d |  | Ben Wickins |  |  | Non-SIT LDSO | SI Test, PP, Non-SIT LDSO | 5.18 | 165.71 | Red | RED | T3-QU-0007 | QAG (Non-SIT LDSO) | Systems Integration Testing (SIT) | T3 |
| 1294 | 1.5.12.7 | Qualification Testing for Non-SIT LDSOs (Functional, Migration, NFT, Operational) Test Readiness Confirmed (Final Test Readiness Review for LDSO) | milestone | 0d | 2024-09-30 | 2024-09-30 | 1290, 1292 | 2024-10-10 | 2024-10-10 | 0d | 2024-07-05 | 2024-07-05 | 585d | 0d |  | Ben Wickins |  |  | LDSO | SI Test, PP, LDSO | 5.18 | 165.71 | Green | GREEN | TBC | QAG (Non-SIT LDSO) | Systems Integration Testing (SIT) |  |
| 1295 | 1.5.13 | **Test Window** |  | 59d | 2024-10-01 | 2024-12-20 |  |  |  |  |  |  | 585d |  |  | N/A | 944h |  | N/A | N/A |  | -527.67 | Overdue Start | RED |  |  |  |  |
| 1296 | 1.5.13.1 | All Cohorts Qualification Testing |  | 59d | 2024-10-01 | 2024-12-20 | 1294 |  |  |  |  |  | 585d | 0d |  | Ben Wickins | 472h |  | LDSO | Non-SIT LDSO,Code Bodies,LDSO |  | 166.33 | No BL | GREEN |  |  |  |  |
| 1297 | 1.5.14 | **Test Result Assurance** |  | 60d | 2024-11-04 | 2025-01-24 |  | 2024-12-31 | 2025-01-24 | 18d |  |  | 585d |  |  | N/A | 760h | -0 | N/A | N/A | 5.18 |  |  |  |  |  |  |  |
| 1298 | 1.5.14.1 | LDSOs Develop & Submit Test Report (QT Test Completion Report) |  | 19d | 2024-11-04 | 2024-11-28 | 1280FS+23d |  |  |  |  |  | 585d | 0d |  | Ben Wickins | 152h |  | LDSO | Non-SIT LDSO, LDSO | 5.18 | 200.33 | No BL | GREEN |  |  |  |  |
| 1299 | 1.5.14.2 | Test Reports Reviewed By MHHS & Code Bodies & Finalised |  | 16d | 2024-11-29 | 2024-12-20 | 1298 |  |  |  |  |  | 585d | 0d |  | Ben Wickins | 128h |  | Non-SIT LDSO | Non-SIT LDSO, Code Bodies | 5.18 | 225.33 | No BL | GREEN |  |  |  |  |
| 1300 | 1.5.14.3 | Non-SIT LDSOs submission deadline for their QT Test Completion Report to MHHS Programme | milestone | 0d | 2024-12-20 | 2024-12-20 | 1299, 1296 | 2024-12-31 | 2024-12-31 | 0d |  |  | 585d | 0d |  | Ben Wickins |  |  | Non-SIT LDSO | Non-SIT LDSO | 5.18 | 246.71 | Green | GREEN | TBC | QAG (Non-SIT LDSO) |  |  |
| 1301 | 1.5.14.4 | Qualification Testing for Non-SIT LDSOs (Functional, Migration, NFT, Operational) 1 End | milestone | 0d | 2025-01-24 | 2025-01-24 | 1300FS+25d, 1259 | 2025-01-24 | 2025-01-24 |  |  |  | 610d | 25d |  | Ben Wickins |  |  | Non-SIT LDSO | Non-SIT LDSO | 5.18 | 281.71 | Green | GREEN | T3-QU-0010 | QAG (Non-SIT LDSO) |  |  |

Notes:
- 1284: Action: 11/3: Ask simon B for the link
- 1296: Action: 11/4: Detailed test schedule in development and due for 5/6 when Code Bodies test delivery schedule and will then enter in to QWG/QAG process. Once this has been agreed futher detail will be added re: cohort timelines

| ID | WBS | Task | Type | Duration | Start | Finish | Predecessors | Complete | Remaining | Baseline start | Baseline finish | Baseline duration | Baseline 1 start | Baseline 1 finish | Total slack | Free slack | Constraint | Resources | Work | Actual work | Baseline cost | Responsible | Involved | Update Version | Task Status | Sched Status | RAG | Milestone ID | Text29 | Text3 | MHHS Programme Phase | Artefact ID | Tier |
| --- | --- | --- | --- | --- | --- | --- | --- | --- | --- | --- | --- | --- | --- | --- | --- | --- | --- | --- | --- | --- | --- | --- | --- | --- | --- | --- | --- | --- | --- | --- | --- | --- | --- |
| 1302 | 1.5.15 | **Non-SIT LDSO Qualification Closure** |  | 50d | 2024-12-23 | 2025-02-28 |  |  |  |  |  |  |  |  | 585d |  |  | N/A | 560h |  |  | N/A | N/A | 5.18 |  |  |  |  |  |  |  |  |  |
| 1303 | 1.5.15.1 | Non-SIT LDSO Qualification Learned Captured |  | 15d | 2024-12-23 | 2025-01-10 | 1300 |  |  |  |  |  |  |  | 585d | 0d |  | Ben Wickins | 120h |  |  | Non-SIT LDSO | Non-SIT LDSO | 5.18 | 249.33 | No BL | GREEN |  |  |  |  |  |  |
| 1304 | 1.5.15.2 | Non-SIT LDSO Qualification Closure Down |  | 5d | 2025-01-13 | 2025-01-17 | 1303 |  |  |  |  |  |  |  | 585d | 0d |  | Ben Wickins | 40h |  |  | Non-SIT LDSO | Non-SIT LDSO | 5.18 | 270.33 | No BL | GREEN |  |  |  |  |  |  |
| 1305 | 1.5.15.3 | BSC PAB & REC Manager approval of Qualification Testing for Non-SIT LDSOs (Functional, Migration, NFT, Operational) Completion (Start of Migration for Qualification Participants) | milestone | 0d | 2025-02-28 | 2025-02-28 | 1304FS+30d, 1301 |  |  | 2025-02-21 | 2025-02-21 |  |  |  | 585d |  |  | Ben Wickins |  |  |  | Non-SIT LDSO | Non-SIT LDSO | 5.18 | 316.71 | yellow | RED | T2-QU-500 | QAG (Non-SIT LDSO) |  |  |  |  |
| 1306 | 1.6 | **QUALIFICATION** |  | 1004d | 2023-02-27 A | 2026-12-31 |  | 1% | 995.49d | 2023-02-27 | 2026-12-31 | 1004d | 2023-02-27 | 2026-12-31 | 106d |  |  | N/A | 103304h | 2131.7h | -0 | N/A | N/A | 5.0 |  |  |  |  |  | 1 Aug 2023 - 30 Sep 2024 | Qualification |  |  |
| 1307 | 1.6.1 | Pre-Qualification Submission and PIT Test Plan Deadline for Submission | milestone | 0d | 2024-04-26 | 2024-04-26 |  |  |  | 2024-04-26 | 2024-04-26 | 0d |  |  | 806d |  | start no earlier than 2024-04-26 | Nicola Farley |  |  |  | PP | PP, Code Bodies | 5.18 | 8.33 | Green | GREEN | TBC | QAG |  |  |  |  |
| 1308 | 1.6.2 | **Qualification Preparation** |  | 611d | 2023-02-27 A | 2025-06-30 |  | 1% | 603.67d | 2023-02-27 | 2025-06-30 | 611d | 2023-02-27 | 2025-06-30 | 499d |  |  | N/A | 67976h | 2063.64h |  | N/A | N/A | 5.0 |  |  |  |  |  |  | Qualification |  |  |
| 1309 | 1.6.2.1 | **Artefact Development** |  | 383d | 2023-02-27 A | 2024-08-14 |  | 27% | 280.78d | 2023-02-27 | 2024-08-14 | 383d | 2023-02-27 | 2024-08-14 | 727d |  |  | N/A | 9808h | 2004.98h |  | N/A | N/A | 5.0 |  |  |  |  |  |  | Qualification |  |  |
| 1310 | 1.6.2.1.1 | **Collaborative ways of working** |  | 75d | 2023-02-27 A | 2023-06-09 A |  | 100% |  | 2023-02-27 | 2023-06-09 | 75d | 2023-02-27 | 2023-06-09 |  |  |  | N/A | 1200h | 1200h |  | N/A | N/A | 5.0 |  |  |  |  |  |  | Qualification |  |  |
| 1311 | 1.6.2.1.1.1 | Develop collaboration ways of working with Code Bodies |  | 65d | 2023-02-27 A | 2023-05-26 A |  | 100% |  | 2023-02-27 | 2023-05-26 | 65d | 2023-02-27 | 2023-05-26 |  |  | start no earlier than 2023-02-27 | Lee Cox | 520h | 520h |  | SI Test | Code Bodies | 5.0 |  | Complete | COMPLETE |  |  |  | Qualification |  |  |
| 1312 | 1.6.2.1.1.2 | Internal review and updates |  | 10d | 2023-05-29 A | 2023-06-09 A | 1311 | 100% |  | 2023-05-29 | 2023-06-09 | 10d | 2023-05-29 | 2023-06-09 |  |  |  | Lee Cox | 80h | 80h |  | SI Test | Code Bodies | 5.0 |  | Complete | COMPLETE |  |  |  | Qualification |  |  |
| 1313 | 1.6.2.1.1.3 | Collaborative ways of working agreed | milestone | 0d | 2023-06-09 A | 2023-06-09 A | 1312 | 100% |  | 2023-06-09 | 2023-06-09 | 0d | 2023-06-09 | 2023-06-09 |  |  |  | Lee Cox |  |  |  | SI Test | Code Bodies | 5.0 |  | Complete | COMPLETE |  |  |  | Qualification |  |  |
| 1314 | 1.6.2.1.2 | **Qualification Approach & Plan (iterative development)** |  | 261d | 2023-08-16 A | 2024-08-14 |  |  | 261d | 2023-08-16 | 2024-08-14 | 261d | 2023-08-16 | 2024-08-14 | 727d |  |  | N/A | 5544h |  |  | N/A | N/A | 5.0 |  |  |  |  |  |  | Qualification |  |  |
| 1315 | 1.6.2.1.2.1 | **Qualification Functional Testing** |  | 55d | 2023-08-16 A | 2023-10-31 |  |  | 55d | 2023-08-16 | 2023-10-31 | 55d | 2023-08-16 | 2023-10-31 | 933d |  |  | N/A | 840h |  |  | N/A | N/A | 5.0 |  |  |  |  |  |  | Qualification |  |  |
| 1316 | 1.6.2.1.2.1.1 | Develop Functional Testing elements (incl. Test Data and Schedule for Test Scenario & Script development) of Qualification Approach & Plan with QWG |  | 20d | 2023-08-16 | 2023-09-12 | 797FS-1d |  |  | 2023-08-16 | 2023-09-12 | 20d | 2023-08-16 | 2023-09-12 | 938d | 0d |  | Nicola Farley | 160h |  |  | Code Bodies | SI Test,PP | 5.0 | -245.67 | Overdue Start | RED |  |  |  | Qualification |  |  |
| 1317 | 1.6.2.1.2.1.2 | Review draft artefact with Programme to ensure alignment with SIT |  | 10d | 2023-09-13 | 2023-09-26 | 1316 |  |  | 2023-09-13 | 2023-09-26 | 10d | 2023-09-13 | 2023-09-26 | 938d | 0d |  | Nicola Farley | 80h |  |  | Code Bodies | SI Test | 5.0 | -217.67 | Overdue Start | RED |  |  |  | Qualification |  |  |
| 1318 | 1.6.2.1.2.1.3 | Artefact review (via QWG) and updates |  | 20d | 2023-09-27 | 2023-10-24 | 1317 |  |  | 2023-09-27 | 2023-10-24 | 20d | 2023-09-27 | 2023-10-24 | 938d |  |  | Nicola Farley | 160h |  |  | Code Bodies | SI Test,PP,IPA | 5.0 | -203.67 | Overdue Start | RED |  |  |  | Qualification |  |  |
| 1319 | 1.6.2.1.2.1.4 | Functional Testing elements of Qualification Approach & Plan approved by REC Manager & BSC PAB | milestone | 0d | 2023-10-31 A | 2023-10-31 A | 1318FS+5d | 100% |  | 2023-10-31 | 2023-10-31 | 0d | 2023-10-31 | 2023-10-31 |  |  |  | Nicola Farley |  |  |  | Code Bodies |  | 5.0 |  | Complete | COMPLETE | T3-QU-0063 | QAG |  | Qualification | MHHS-ART073 | T3 |
| 1320 | 1.6.2.1.2.2 | **Qualification Migration Testing** |  | 55d | 2023-12-21 A | 2024-03-06 |  |  | 55d | 2023-12-21 | 2024-03-06 | 55d | 2023-12-21 | 2024-03-06 | 842d |  |  | N/A | 840h |  |  | N/A | N/A | 5.0 |  |  |  |  |  |  | Qualification |  |  |
| 1321 | 1.6.2.1.2.2.1 | Develop Migration Testing elements (incl. Test Data and Schedule for Test Scenario & Script development) of Qualification Approach & Plan with QWG |  | 30d | 2023-12-21 | 2024-01-31 | 869 |  |  | 2023-12-21 | 2024-01-31 | 30d | 2023-12-21 | 2024-01-31 | 847d | 0d |  | Nicola Farley | 240h |  |  | Code Bodies | SI Test,PP | 5.0 | -118.67 | Overdue Start | RED |  |  |  | Qualification |  |  |
| 1322 | 1.6.2.1.2.2.2 | Review draft artefact with Programme to ensure alignment with SIT |  | 10d | 2024-02-01 | 2024-02-14 | 1321 |  |  | 2024-02-01 | 2024-02-14 | 10d | 2024-02-01 | 2024-02-14 | 847d | 0d |  | Nicola Farley | 80h |  |  | Code Bodies | SI Test | 5.0 | -76.67 | Overdue Start | RED |  |  |  | Qualification |  |  |
| 1323 | 1.6.2.1.2.2.3 | Artefact review (via QWG) and updates |  | 10d | 2024-02-15 | 2024-02-28 | 1322 |  |  | 2024-02-15 | 2024-02-28 | 10d | 2024-02-15 | 2024-02-28 | 847d |  |  | Nicola Farley | 80h |  |  | Code Bodies | SI Test,PP,IPA | 5.0 | -62.67 | Overdue Start | RED |  |  |  | Qualification |  |  |
| 1324 | 1.6.2.1.2.2.4 | Migration Testing elements of Qualification Approach & Plan approved by REC Manager & BSC PAB | milestone | 0d | 2024-03-06 A | 2024-03-06 A | 1323FS+5d | 100% |  | 2024-03-06 | 2024-03-06 | 0d | 2024-03-06 | 2024-03-06 |  |  |  | Nicola Farley |  |  |  | Code Bodies |  | 5.0 |  | Complete | COMPLETE | T3-QU-0064 | QAG |  | Qualification | MHHS-ART073 | T3 |
| 1325 | 1.6.2.1.2.3 | **Qualification Non-Functional Testing** |  | 51d | 2024-05-16 | 2024-07-25 |  |  |  | 2024-03-21 | 2024-05-30 | 51d | 2024-03-21 | 2024-05-15 | 689d |  |  | N/A | 776h |  |  | N/A | N/A | 5.2 |  |  |  |  |  |  | Qualification |  |  |
| 1326 | 1.6.2.1.2.3.1 | Develop Non-Functional Testing elements (incl. Test Data and Schedule for Test Scenario & Script development) of Qualification Approach & Plan with QWG |  | 30d | 2024-05-16 | 2024-06-26 | 921 |  |  | 2024-03-21 | 2024-05-01 | 30d | 2024-03-21 | 2024-04-17 | 689d | 0d |  | Nicola Farley | 240h |  |  | Code Bodies | SI Test,PP | 5.2 | 28.33 | Red | RED |  |  |  | Qualification |  |  |
| 1327 | 1.6.2.1.2.3.2 | Review draft artefact with Programme to ensure alignment with SIT |  | 10d | 2024-06-27 | 2024-07-10 | 1326 |  |  | 2024-05-02 | 2024-05-15 | 10d | 2024-04-18 | 2024-05-01 | 689d | 0d |  | Nicola Farley | 80h |  |  | Code Bodies | SI Test | 5.2 | 70.33 | Red | RED |  |  |  | Qualification |  |  |
| 1328 | 1.6.2.1.2.3.3 | Artefact review (via QWG) and updates |  | 6d | 2024-07-11 | 2024-07-18 | 1327 |  |  | 2024-05-16 | 2024-05-23 | 6d | 2024-05-02 | 2024-05-08 | 689d | 0d |  | Nicola Farley | 48h |  |  | Code Bodies | SI Test,PP,IPA | 5.2 | 84.33 | Red | RED |  |  |  | Qualification |  |  |
| 1329 | 1.6.2.1.2.3.4 | Non-Functional Testing elements of Qualification Approach & Plan approved by REC Manager & BSC PAB | milestone | 0d | 2024-07-25 | 2024-07-25 | 1328FS+5d |  |  | 2024-05-30 | 2024-05-30 | 0d | 2024-05-15 | 2024-05-15 | 689d | 14d |  | Nicola Farley |  |  |  | Code Bodies |  | 5.2 | 98.71 | Red | RED | T3-QU-0065 | QAG |  | Qualification | MHHS-ART073 | T3 |

Notes:
- 1307: 21/2/24 - Temp milestone added to aid reporting until planning complete. REMOVE BASELINE IN REPORTING
- 1319: 1/11 - Review of the approach is being undertaken by the programme with the Code Bodies. 21/2/24 - Forecast date is 28/3/24
- 1324: 1/11 - Review of the approach is being undertaken by the programme with the Code Bodies. 21/2/24 - Forecast date is 28/3/24
- 1329: 21/2/24 - Forecast date is thu 27/6/24

| ID | WBS | Task | Type | Duration | Start | Finish | Predecessors | Baseline start | Baseline finish | Baseline duration | Baseline 1 start | Baseline 1 finish | Total slack | Free slack | Resources | Work | Responsible | Involved | Update Version | MHHS Programme Phase | Task Status | Sched Status | RAG | Artefact ID | Milestone ID | Text29 | Tier |
| --- | --- | --- | --- | --- | --- | --- | --- | --- | --- | --- | --- | --- | --- | --- | --- | --- | --- | --- | --- | --- | --- | --- | --- | --- | --- | --- | --- |
| 1330 | 1.6.2.1.2.4 | **Qualification Operational Testing** |  | 65d | 2024-05-16 | 2024-08-14 |  | 2024-05-16 | 2024-08-14 | 65d | 2024-05-16 | 2024-08-14 | 675d |  | N/A | 1000h | N/A | N/A | 5.0 | Qualification |  |  |  |  |  |  |  |
| 1331 | 1.6.2.1.2.4.1 | Develop Operational Testing elements (incl. Test Data and Schedule for Test Scenario & Script development) of Qualification Approach & Plan with QWG |  | 30d | 2024-05-16 | 2024-06-26 | 966 | 2024-05-16 | 2024-06-26 | 30d | 2024-05-16 | 2024-06-26 | 675d | 0d | Nicola Farley | 240h | Code Bodies | SI Test,PP | 5.0 | Qualification | 28.33 | Green | GREEN |  |  |  |  |
| 1332 | 1.6.2.1.2.4.2 | Review draft artefact with Programme to ensure alignment with SIT |  | 10d | 2024-06-27 | 2024-07-10 | 1331 | 2024-06-27 | 2024-07-10 | 10d | 2024-06-27 | 2024-07-10 | 675d | 0d | Nicola Farley | 80h | Code Bodies | SI Test | 5.0 | Qualification | 70.33 | Green | GREEN |  |  |  |  |
| 1333 | 1.6.2.1.2.4.3 | Artefact review (via QWG) and updates |  | 20d | 2024-07-11 | 2024-08-07 | 1332 | 2024-07-11 | 2024-08-07 | 20d | 2024-07-11 | 2024-08-07 | 675d | 0d | Nicola Farley | 160h | Code Bodies | SI Test,PP,IPA | 5.0 | Qualification | 84.33 | Green | GREEN |  |  |  |  |
| 1334 | 1.6.2.1.2.4.4 | Operational Testing elements of Qualification Approach & Plan approved by REC Manager & BSC PAB | milestone | 0d | 2024-08-14 | 2024-08-14 | 1333FS+5d | 2024-08-14 | 2024-08-14 | 0d | 2024-08-14 | 2024-08-14 | 675d | 0d | Nicola Farley |  |  |  | 5.0 | Qualification | 118.71 | Green | GREEN | MHHS-ART073 | T3-QU-0068 | QAG | T3 |
| 1335 | 1.6.2.1.2.4.5 | Final Qualification Approach & Plan approved by REC Manager & BSC PAB | milestone | 0d | 2024-08-14 | 2024-08-14 | 1334, 1329, 1324, 1319 | 2024-08-14 | 2024-08-14 | 0d | 2024-08-14 | 2024-08-14 | 675d | 0d | Nicola Farley |  | Code Bodies |  | 5.0 | Qualification | 118.71 | Green | GREEN | MHHS-ART073 | T3-QU-0062 | QAG | T3 |
| 1336 | 1.6.2.2 | **Qualification Test Tranche-Specific Preparation** |  | 235d | 2024-08-06 | 2025-06-30 |  | 2024-08-06 | 2025-06-30 | 235d | 2024-08-06 | 2025-06-30 | 20d |  | N/A | 53280h | N/A | N/A | 5.0 | Qualification |  |  |  |  |  |  |  |
| 1337 | 1.6.2.2.1 | **Tranche 1 Preparation** |  | 115d | 2024-08-06 | 2025-01-13 |  | 2024-08-06 | 2025-01-13 | 115d | 2024-08-06 | 2025-01-13 | 619d |  | N/A | 9320h | N/A | N/A | 5.0 | Qualification |  |  |  |  |  |  |  |
| 1338 | 1.6.2.2.1.1 | **SI Tranche 1 Preparation** |  | 115d | 2024-08-06 | 2025-01-13 |  | 2024-08-06 | 2025-01-13 | 115d | 2024-08-06 | 2025-01-13 | 619d |  | N/A | 5640h | N/A | N/A | 5.0 | Qualification |  |  |  |  |  |  |  |
| 1339 | 1.6.2.2.1.1.1 | Confirm Qualification Testing Tranche 1 Participants | milestone | 0d | 2024-08-06 | 2024-08-06 | 1569FS-6mo | 2024-08-06 | 2024-08-06 | 0d | 2024-08-06 | 2024-08-06 | 619d | 0d | Nicola Farley |  | Code Bodies | SI Test, PP, IPA | 5.0 | Qualification | 110.33 | Green | GREEN |  | T3-QU-0012 | QAG | T3 |
| 1340 | 1.6.2.2.1.1.2 | **Test execution schedule** |  | 65d | 2024-08-06 | 2024-11-04 |  | 2024-08-06 | 2024-11-04 | 65d | 2024-08-06 | 2024-11-04 | 669d |  | N/A | 1000h | N/A | N/A | 5.0 | Qualification |  |  |  |  |  |  |  |
| 1341 | 1.6.2.2.1.1.2.1 | Develop document |  | 40d | 2024-08-06 | 2024-09-30 | 1339 | 2024-08-06 | 2024-09-30 | 40d | 2024-08-06 | 2024-09-30 | 669d | 0d | Nicola Farley | 320h | Code Bodies | SI Test, PP | 5.0 | Qualification | 110.33 | Green | GREEN |  |  |  |  |
| 1342 | 1.6.2.2.1.1.2.2 | Review & agree document |  | 20d | 2024-10-01 | 2024-10-28 | 1341 | 2024-10-01 | 2024-10-28 | 20d | 2024-10-01 | 2024-10-28 | 669d | 0d | Nicola Farley | 160h | Code Bodies | SI Test, PP | 5.0 | Qualification | 166.33 | Green | GREEN |  |  |  |  |
| 1343 | 1.6.2.2.1.1.2.3 | Qualification Testing Tranche 1 Test execution schedule approved | milestone | 0d | 2024-11-04 | 2024-11-04 | 1342FS+5d | 2024-11-04 | 2024-11-04 | 0d | 2024-11-04 | 2024-11-04 | 669d | 50d | Nicola Farley |  | Code Bodies | SI Test, PP | 5.0 | Qualification | 200.71 | Green | GREEN | 1. MHHS-ART146 2. Artefact ID not yet defined | T3-QU-0016 | QAG | T3 |
| 1344 | 1.6.2.2.1.1.3 | **Environments** |  | 115d | 2024-08-06 | 2025-01-13 |  | 2024-08-06 | 2025-01-13 | 115d | 2024-08-06 | 2025-01-13 | 619d |  | N/A | 1880h | N/A | N/A | 5.0 | Qualification |  |  |  |  |  |  |  |
| 1345 | 1.6.2.2.1.1.3.1 | Coordinate Qualification Participants' environment preparation |  | 60d | 2024-08-06 | 2024-10-28 | 1339 | 2024-08-06 | 2024-10-28 | 60d | 2024-08-06 | 2024-10-28 | 619d | 0d | Simon Berry | 480h | SI Test | Code Bodies, PP | 5.0 | Qualification | 110.33 | Green | GREEN |  |  |  |  |
| 1346 | 1.6.2.2.1.1.3.2 | Coordinate deployment of MHHS solution code to Qualification Participants' UIT environments |  | 10d | 2024-10-15 | 2024-10-28 | 1345FF | 2024-10-15 | 2024-10-28 | 10d | 2024-10-15 | 2024-10-28 | 619d | 0d | Simon Berry | 80h | SI Test | Code Bodies, PP | 5.0 | Qualification | 180.33 | Green | GREEN |  |  |  |  |
| 1347 | 1.6.2.2.1.1.3.3 | Qualification Testing Tranche 1 Participants' UIT environments ready to start connectivity proving (incl. certificates and security compliance) | milestone | 0d | 2024-11-04 | 2024-11-04 | 1346FS+5d | 2024-11-04 | 2024-11-04 | 0d | 2024-11-04 | 2024-11-04 | 619d | 0d | Simon Berry |  | SI Test | Code Bodies, PP, IPA | 5.0 | Qualification | 200.71 | Green | GREEN | MHHS-ART073 | T3-QU-0017 | QAG | T3 |
| 1348 | 1.6.2.2.1.1.3.4 | **Coordinate Qualification Participants' connectivity proving** |  | 50d | 2024-11-05 | 2025-01-13 |  | 2024-11-05 | 2025-01-13 | 50d | 2024-11-05 | 2025-01-13 | 619d |  | N/A | 400h | N/A | N/A | 5.0 | Qualification |  |  |  |  |  |  |  |
| 1349 | 1.6.2.2.1.1.3.4.1 | Assurance of Qualification Participants' connectivity proving |  | 50d | 2024-11-05 | 2025-01-13 | 1347 | 2024-11-05 | 2025-01-13 | 50d | 2024-11-05 | 2025-01-13 | 619d | 0d |  |  | SI Test | Code Bodies, PP | 5.0 | Qualification | 201.33 | Green | GREEN |  |  |  |  |
| 1350 | 1.6.2.2.1.1.4 | **Test Data** |  | 0d | 2024-11-04 | 2024-11-04 |  | 2024-11-04 | 2024-11-04 | 0d | 2024-11-04 | 2024-11-04 | 669d |  | N/A |  | N/A | N/A | 5.0 | Qualification |  |  |  |  |  |  |  |
| 1351 | 1.6.2.2.1.1.4.1 | Confirm MPAN range to Code Bodies (for Code Bodies to allocate to Qualification Testing Tranche 1 Participants) | milestone | 0d | 2024-11-04 | 2024-11-04 | 1347 | 2024-11-04 | 2024-11-04 | 0d | 2024-11-04 | 2024-11-04 | 669d | 50d | Richard Puddephatt |  | SI Test | Code Bodies, PP | 5.0 | Qualification | 200.71 | Green | GREEN | MHHS-ART073 | T3-QU-0018 | QAG | T3 |
| 1352 | 1.6.2.2.1.1.5 | **Other Preparation** |  | 115d | 2024-08-06 | 2025-01-13 |  | 2024-08-06 | 2025-01-13 | 115d | 2024-08-06 | 2025-01-13 | 619d |  | N/A | 1840h | N/A | N/A | 5.0 | Qualification |  |  |  |  |  |  |  |
| 1353 | 1.6.2.2.1.1.5.1 | Onboarding of Test Participants to Test Management Tool |  | 115d | 2024-08-06 | 2025-01-13 | 1339 | 2024-08-06 | 2025-01-13 | 115d | 2024-08-06 | 2025-01-13 | 619d | 0d |  |  | SI Test | Code Bodies, PP | 5.0 | Qualification | 110.33 | Green | GREEN |  |  |  |  |
| 1354 | 1.6.2.2.1.1.5.2 | Other Preparation (activities TBC) |  | 115d | 2024-08-06 | 2025-01-13 | 1339 | 2024-08-06 | 2025-01-13 | 115d | 2024-08-06 | 2025-01-13 | 619d | 0d | Nicola Farley | 920h | Code Bodies | SI Test, PP | 5.0 | Qualification | 110.33 | Green | GREEN |  |  |  |  |
| 1355 | 1.6.2.2.1.1.6 | Qualification Testing Tranche 1 Test Readiness confirmed | milestone | 0d | 2025-01-13 | 2025-01-13 | 1353, 1354, 1339, 1343, 1347, 1351, 1349 | 2025-01-13 | 2025-01-13 | 0d | 2025-01-13 | 2025-01-13 | 619d |  | Nicola Farley |  | Code Bodies | SI Test, PP | 5.0 | Qualification | 270.71 | Green | GREEN |  | T3-QU-0027 | QAG | T3 |

| ID | WBS | Task | Type | Duration | Start | Finish | Predecessors | Baseline start | Baseline finish | Baseline duration | Baseline 1 start | Baseline 1 finish | Total slack | Free slack | Resources | Work | Responsible | Involved | Update Version | MHHS Programme Phase | Task Status | Sched Status | RAG | Milestone ID | Text29 | Tier | Artefact ID |
| --- | --- | --- | --- | --- | --- | --- | --- | --- | --- | --- | --- | --- | --- | --- | --- | --- | --- | --- | --- | --- | --- | --- | --- | --- | --- | --- | --- |
| 1356 | 1.6.2.2.1.2 | **PP Tranche 1 Preparation** |  | 115d | 2024-08-06 | 2025-01-13 |  | 2024-08-06 | 2025-01-13 | 115d | 2024-08-06 | 2025-01-13 | 619d |  | N/A | 2760h | N/A | N/A | 5.0 | Qualification |  |  |  |  |  |  |  |
| 1357 | 1.6.2.2.1.2.1 | Confirm Qualification Testing Tranche 1 Participants | milestone | 0d | 2024-08-06 | 2024-08-06 | 1569FS-6mo | 2024-08-06 | 2024-08-06 | 0d | 2024-08-06 | 2024-08-06 | 619d | 0d |  |  | Code Bodies | SI Test, PP, IPA | 5.0 | Qualification | 110.33 | Green | GREEN | T3-QU-0012 | QAG | T3 |  |
| 1358 | 1.6.2.2.1.2.2 | **Environments** |  | 115d | 2024-08-06 | 2025-01-13 |  | 2024-08-06 | 2025-01-13 | 115d | 2024-08-06 | 2025-01-13 | 619d |  | N/A | 920h | N/A | N/A | 5.0 | Qualification |  |  |  |  |  |  |  |
| 1359 | 1.6.2.2.1.2.2.1 | UIT environment preparation |  | 60d | 2024-08-06 | 2024-10-28 | 1357 | 2024-08-06 | 2024-10-28 | 60d | 2024-08-06 | 2024-10-28 | 619d | 0d |  |  | PP | Code Bodies,SI Test | 5.0 | Qualification | 110.33 | Green | GREEN |  |  |  |  |
| 1360 | 1.6.2.2.1.2.2.2 | Deployment of MHHS solution code to UIT environments |  | 10d | 2024-10-15 | 2024-10-28 | 1359FF | 2024-10-15 | 2024-10-28 | 10d | 2024-10-15 | 2024-10-28 | 619d | 0d |  |  | PP | Code Bodies,SI Test | 5.0 | Qualification | 180.33 | Green | GREEN |  |  |  |  |
| 1361 | 1.6.2.2.1.2.2.3 | Qualification Testing Tranche 1 Participants' UIT environments ready to start connectivity proving (incl. certificates and security compliance) | milestone | 0d | 2024-11-04 | 2024-11-04 | 1360FS+5d | 2024-11-04 | 2024-11-04 | 0d | 2024-11-04 | 2024-11-04 | 619d | 0d |  |  | SI Test | Code Bodies, PP, IPA | 5.0 | Qualification | 200.71 | Green | GREEN | T3-QU-0017 | QAG | T3 | MHHS-ART073 |
| 1362 | 1.6.2.2.1.2.2.4 | UIT environment connectivity proving |  | 50d | 2024-11-05 | 2025-01-13 | 1361 | 2024-11-05 | 2025-01-13 | 50d | 2024-11-05 | 2025-01-13 | 619d | 0d |  |  | PP | Code Bodies,SI Test | 5.0 | Qualification | 201.33 | Green | GREEN |  |  |  |  |
| 1363 | 1.6.2.2.1.2.2.5 | Submit evidence of UIT environment connectivity proving to Programme for assurance |  | 50d | 2024-11-05 | 2025-01-13 | 1362SS | 2024-11-05 | 2025-01-13 | 50d | 2024-11-05 | 2025-01-13 | 619d |  |  |  | PP | Code Bodies,SI Test | 5.0 | Qualification | 201.33 | Green | GREEN |  |  |  |  |
| 1364 | 1.6.2.2.1.2.3 | **Other Preparation** |  | 115d | 2024-08-06 | 2025-01-13 |  | 2024-08-06 | 2025-01-13 | 115d | 2024-08-06 | 2025-01-13 | 619d |  | N/A | 920h | N/A | N/A | 5.0 | Qualification |  |  |  |  |  |  |  |
| 1365 | 1.6.2.2.1.2.3.1 | Other Preparation (incl. test execution planning) |  | 115d | 2024-08-06 | 2025-01-13 | 1357 | 2024-08-06 | 2025-01-13 | 115d | 2024-08-06 | 2025-01-13 | 619d |  |  |  | PP | Code Bodies,SI Test | 5.0 | Qualification | 110.33 | Green | GREEN |  |  |  |  |
| 1366 | 1.6.2.2.1.2.4 | Monitoring of provisional Qualification Testing Tranche 1 Participants' PIT progress and test readiness |  | 115d | 2024-08-06 | 2025-01-13 | 1339 | 2024-08-06 | 2025-01-13 | 115d | 2024-08-06 | 2025-01-13 | 619d |  |  |  | Code Bodies | PP,SI Test | 5.0 | Qualification | 110.33 | Green | GREEN |  |  |  |  |
| 1367 | 1.6.2.2.1.2.5 | Qualification Testing Tranche 1 Test Readiness confirmed | milestone | 0d | 2025-01-13 | 2025-01-13 | 1362FF | 2025-01-13 | 2025-01-13 | 0d | 2025-01-13 | 2025-01-13 | 619d |  |  |  | Code Bodies | SI Test, PP | 5.0 | Qualification | 270.71 | Green | GREEN | T3-QU-0027 | QAG | T3 |  |
| 1368 | 1.6.2.2.2 | **Tranche 2 Preparation** |  | 115d | 2024-09-03 | 2025-02-10 |  | 2024-09-03 | 2025-02-10 | 115d | 2024-09-03 | 2025-02-10 | 599d |  | N/A | 6960h | N/A | N/A | 5.0 | Qualification |  |  |  |  |  |  |  |
| 1369 | 1.6.2.2.2.1 | **SI Tranche 2 Preparation** |  | 115d | 2024-09-03 | 2025-02-10 |  | 2024-09-03 | 2025-02-10 | 115d | 2024-09-03 | 2025-02-10 | 599d |  | N/A | 3280h | N/A | N/A | 5.0 | Qualification |  |  |  |  |  |  |  |
| 1370 | 1.6.2.2.2.1.1 | Confirm Qualification Testing Tranche 2 Participants | milestone | 0d | 2024-09-03 | 2024-09-03 | 1574FS-6mo | 2024-09-03 | 2024-09-03 | 0d | 2024-09-03 | 2024-09-03 | 599d | 0d |  |  | Code Bodies | SI Test, PP, IPA | 5.0 | Qualification | 138.33 | Green | GREEN | T3-QU-0013 | QAG | T3 |  |
| 1371 | 1.6.2.2.2.1.2 | **Test execution schedule** |  | 65d | 2024-09-03 | 2024-12-02 |  | 2024-09-03 | 2024-12-02 | 65d | 2024-09-03 | 2024-12-02 | 649d |  | N/A | 520h | N/A | N/A | 5.0 | Qualification |  |  |  |  |  |  |  |
| 1372 | 1.6.2.2.2.1.2.1 | Develop document |  | 40d | 2024-09-03 | 2024-10-28 | 1370 | 2024-09-03 | 2024-10-28 | 40d | 2024-09-03 | 2024-10-28 | 649d | 0d |  |  | Code Bodies | SI Test, PP | 5.0 | Qualification | 138.33 | Green | GREEN |  |  |  |  |
| 1373 | 1.6.2.2.2.1.2.2 | Review & agree document |  | 20d | 2024-10-29 | 2024-11-25 | 1372 | 2024-10-29 | 2024-11-25 | 20d | 2024-10-29 | 2024-11-25 | 649d | 0d |  |  | Code Bodies | SI Test, PP | 5.0 | Qualification | 194.33 | Green | GREEN |  |  |  |  |
| 1374 | 1.6.2.2.2.1.2.3 | Qualification Testing Tranche 2 Test execution schedule approved | milestone | 0d | 2024-12-02 | 2024-12-02 | 1373FS+5d | 2024-12-02 | 2024-12-02 | 0d | 2024-12-02 | 2024-12-02 | 649d | 50d |  |  | Code Bodies | SI Test, PP | 5.0 | Qualification | 228.71 | Green | GREEN | T3-QU-0020 | QAG | T3 | Artefact ID not yet defined |
| 1375 | 1.6.2.2.2.1.3 | **Environments** |  | 115d | 2024-09-03 | 2025-02-10 |  | 2024-09-03 | 2025-02-10 | 115d | 2024-09-03 | 2025-02-10 | 599d |  | N/A | 920h | N/A | N/A | 5.0 | Qualification |  |  |  |  |  |  |  |
| 1376 | 1.6.2.2.2.1.3.1 | Coordinate Qualification Participants' environment preparation |  | 60d | 2024-09-03 | 2024-11-25 | 1370 | 2024-09-03 | 2024-11-25 | 60d | 2024-09-03 | 2024-11-25 | 599d | 0d |  |  | SI Test | Code Bodies, PP | 5.0 | Qualification | 138.33 | Green | GREEN |  |  |  |  |
| 1377 | 1.6.2.2.2.1.3.2 | Coordinate deployment of MHHS solution code to Qualification Participants' UIT environments |  | 10d | 2024-11-12 | 2024-11-25 | 1376FF | 2024-11-12 | 2024-11-25 | 10d | 2024-11-12 | 2024-11-25 | 599d | 0d |  |  | SI Test | Code Bodies, PP | 5.0 | Qualification | 208.33 | Green | GREEN |  |  |  |  |
| 1378 | 1.6.2.2.2.1.3.3 | Qualification Testing Tranche 2 Participants' UIT environments ready to start connectivity proving (incl. certificates and security compliance) | milestone | 0d | 2024-12-02 | 2024-12-02 | 1377FS+5d | 2024-12-02 | 2024-12-02 | 0d | 2024-12-02 | 2024-12-02 | 599d | 0d |  |  | SI Test | Code Bodies, PP, IPA | 5.0 | Qualification | 228.71 | Green | GREEN | T3-QU-0021 | QAG | T3 |  |
| 1379 | 1.6.2.2.2.1.3.4 | Coordinate Qualification Participants' connectivity proving |  | 50d | 2024-12-03 | 2025-02-10 | 1378 | 2024-12-03 | 2025-02-10 | 50d | 2024-12-03 | 2025-02-10 | 599d | 0d |  |  | SI Test | Code Bodies, PP | 5.0 | Qualification | 229.33 | Green | GREEN |  |  |  |  |
| 1380 | 1.6.2.2.2.1.3.5 | Assurance of Qualification Participants' connectivity proving |  | 50d | 2024-12-03 | 2025-02-10 | 1379SS | 2024-12-03 | 2025-02-10 | 50d | 2024-12-03 | 2025-02-10 | 599d |  |  |  | SI Test | Code Bodies, PP | 5.0 | Qualification | 229.33 | Green | GREEN |  |  |  |  |

| ID | WBS | Task | Type | Duration | Start | Finish | Predecessors | Baseline start | Baseline finish | Baseline duration | Baseline 1 start | Baseline 1 finish | Total slack | Free slack | Resources | Work | Responsible | Involved | Update Version | MHHS Programme Phase | Artefact ID | Task Status | Sched Status | RAG | Milestone ID | Text29 | Tier |
| --- | --- | --- | --- | --- | --- | --- | --- | --- | --- | --- | --- | --- | --- | --- | --- | --- | --- | --- | --- | --- | --- | --- | --- | --- | --- | --- | --- |
| 1381 | 1.6.2.2.2.1.4 | **Test Data** |  | 0d | 2024-12-02 | 2024-12-02 |  | 2024-12-02 | 2024-12-02 | 0d | 2024-12-02 | 2024-12-02 | 649d |  | N/A |  | N/A | N/A | 5.0 | Qualification |  |  |  |  |  |  |  |
| 1382 | 1.6.2.2.2.1.4.1 | Confirm MPAN range to Code Bodies (for Code Bodies to allocate to Qualification Testing Tranche 2 Participants) | milestone | 0d | 2024-12-02 | 2024-12-02 | 1378 | 2024-12-02 | 2024-12-02 | 0d | 2024-12-02 | 2024-12-02 | 649d | 50d | Richard Puddephatt |  | SI Test | Code Bodies, PP | 5.0 | Qualification | MHHS-ART073 | 228.71 | Green | GREEN | T3-QU-0022 | QAG | T3 |
| 1383 | 1.6.2.2.2.1.5 | **Other Preparation** |  | 115d | 2024-09-03 | 2025-02-10 |  | 2024-09-03 | 2025-02-10 | 115d | 2024-09-03 | 2025-02-10 | 599d |  | N/A | 920h | N/A | N/A | 5.0 | Qualification |  |  |  |  |  |  |  |
| 1384 | 1.6.2.2.2.1.5.1 | Onboarding of Test Participants to Test Management Tool |  | 115d | 2024-09-03 | 2025-02-10 | 1370 | 2024-09-03 | 2025-02-10 | 115d | 2024-09-03 | 2025-02-10 | 599d | 0d |  |  | SI Test | Code Bodies, PP | 5.0 | Qualification |  | 138.33 | Green | GREEN |  |  |  |
| 1385 | 1.6.2.2.2.1.5.2 | Other Preparation (activities TBC) |  | 115d | 2024-09-03 | 2025-02-10 | 1370 | 2024-09-03 | 2025-02-10 | 115d | 2024-09-03 | 2025-02-10 | 599d | 0d |  |  | Code Bodies | SI Test, PP | 5.0 | Qualification |  | 138.33 | Green | GREEN |  |  |  |
| 1386 | 1.6.2.2.2.1.6 | Monitoring of provisional Qualification Testing Tranche 2 Participants' PIT progress and test readiness |  | 115d | 2024-09-03 | 2025-02-10 | 1370 | 2024-09-03 | 2025-02-10 | 115d | 2024-09-03 | 2024-09-03 | 599d |  |  |  |  |  | 5.0 | Qualification |  | 138.33 | Green | GREEN |  |  |  |
| 1387 | 1.6.2.2.2.1.7 | Qualification Testing Tranche 2 Test Readiness confirmed | milestone | 0d | 2025-02-10 | 2025-02-10 | 1379, 1384, 1385, 1370, 1374, 1378, 1382 | 2025-02-10 | 2025-02-10 | 0d | 2025-02-10 | 2025-02-10 | 599d |  |  |  | Code Bodies | SI Test, PP | 5.0 | Qualification |  | 298.71 | Green | GREEN | T3-QU-0033 | QAG | T3 |
| 1388 | 1.6.2.2.2.2 | **PP Tranche 2 Preparation** |  | 115d | 2024-09-03 | 2025-02-10 |  | 2024-09-03 | 2025-02-10 | 115d | 2024-09-03 | 2025-02-10 | 599d |  | N/A | 2760h | N/A | N/A | 5.0 | Qualification |  |  |  |  |  |  |  |
| 1389 | 1.6.2.2.2.2.1 | Confirm Qualification Testing Tranche 2 Participants | milestone | 0d | 2024-09-03 | 2024-09-03 | 1574FS-6mo | 2024-09-03 | 2024-09-03 | 0d | 2024-09-03 | 2024-09-03 | 599d | 0d |  |  | Code Bodies | SI Test, PP, IPA | 5.0 | Qualification |  | 138.33 | Green | GREEN | T3-QU-0013 | QAG | T3 |
| 1390 | 1.6.2.2.2.2.2 | **Environments** |  | 115d | 2024-09-03 | 2025-02-10 |  | 2024-09-03 | 2025-02-10 | 115d | 2024-09-03 | 2025-02-10 | 599d |  | N/A | 920h | N/A | N/A | 5.0 | Qualification |  |  |  |  |  |  |  |
| 1391 | 1.6.2.2.2.2.2.1 | UIT environment preparation |  | 60d | 2024-09-03 | 2024-11-25 | 1389 | 2024-09-03 | 2024-11-25 | 60d | 2024-09-03 | 2024-11-25 | 599d | 0d |  |  | PP | Code Bodies,SI Test | 5.0 | Qualification |  | 138.33 | Green | GREEN |  |  |  |
| 1392 | 1.6.2.2.2.2.2.2 | Deployment of MHHS solution code to UIT environments |  | 10d | 2024-11-12 | 2024-11-25 | 1391FF | 2024-11-12 | 2024-11-25 | 10d | 2024-11-12 | 2024-11-25 | 599d | 0d |  |  | PP | Code Bodies,SI Test | 5.0 | Qualification |  | 208.33 | Green | GREEN |  |  |  |
| 1393 | 1.6.2.2.2.2.2.3 | Qualification Testing Tranche 2 Participants' UIT environments ready to start connectivity proving (incl. certificates and security compliance) | milestone | 0d | 2024-12-02 | 2024-12-02 | 1392FS+5d | 2024-12-02 | 2024-12-02 | 0d | 2024-12-02 | 2024-12-02 | 599d | 0d |  |  | SI Test | Code Bodies, PP, IPA | 5.0 | Qualification |  | 228.71 | Green | GREEN | T3-QU-0021 | QAG | T3 |
| 1394 | 1.6.2.2.2.2.2.4 | UIT environment connectivity proving |  | 50d | 2024-12-03 | 2025-02-10 | 1393 | 2024-12-03 | 2025-02-10 | 50d | 2024-12-03 | 2025-02-10 | 599d | 0d |  |  | PP | Code Bodies,SI Test | 5.0 | Qualification |  | 229.33 | Green | GREEN |  |  |  |
| 1395 | 1.6.2.2.2.2.2.5 | Submit evidence of UIT environment connectivity proving to Programme for assurance |  | 50d | 2024-12-03 | 2025-02-10 | 1394SS | 2024-12-03 | 2025-02-10 | 50d | 2024-12-03 | 2025-02-10 | 599d |  |  |  | PP | Code Bodies,SI Test | 5.0 | Qualification |  | 229.33 | Green | GREEN |  |  |  |
| 1396 | 1.6.2.2.2.2.3 | **Other Preparation** |  | 115d | 2024-09-03 | 2025-02-10 |  | 2024-09-03 | 2025-02-10 | 115d | 2024-09-03 | 2025-02-10 | 599d |  | N/A | 920h | N/A | N/A | 5.0 | Qualification |  |  |  |  |  |  |  |
| 1397 | 1.6.2.2.2.2.3.1 | Other Preparation (incl. test execution planning) |  | 115d | 2024-09-03 | 2025-02-10 | 1389 | 2024-09-03 | 2025-02-10 | 115d | 2024-09-03 | 2025-02-10 | 599d |  |  |  | PP | Code Bodies,SI Test | 5.0 | Qualification |  | 138.33 | Green | GREEN |  |  |  |
| 1398 | 1.6.2.2.2.2.4 | Qualification Testing Tranche 2 Test Readiness confirmed | milestone | 0d | 2025-02-10 | 2025-02-10 | 1394FF | 2025-02-10 | 2025-02-10 | 0d | 2025-02-10 | 2025-02-10 | 599d |  |  |  | Code Bodies | SI Test, PP | 5.0 | Qualification |  | 298.71 | Green | GREEN | T3-QU-0033 | QAG | T3 |
| 1399 | 1.6.2.2.3 | **Tranche 3 Preparation** |  | 135d | 2024-09-03 | 2025-03-10 |  | 2024-09-03 | 2025-03-10 | 135d | 2024-10-01 | 2025-03-10 | 0d |  | N/A | 7280h | N/A | N/A | 5.0 | Qualification |  |  |  |  |  |  |  |
| 1400 | 1.6.2.2.3.1 | **SI Tranche 3 Preparation** |  | 135d | 2024-09-03 | 2025-03-10 |  | 2024-09-03 | 2025-03-10 | 135d | 2024-10-01 | 2025-03-10 | 0d |  | N/A | 3440h | N/A | N/A | 5.0 | Qualification |  |  |  |  |  |  |  |
| 1401 | 1.6.2.2.3.1.1 | Confirm Qualification Testing Tranche 3 Participants | milestone | 0d | 2024-10-01 | 2024-10-01 | 1579FS-6mo | 2024-10-01 | 2024-10-01 | 0d | 2024-10-01 | 2024-10-01 | 579d | 0d |  |  | Code Bodies | SI Test, PP, IPA | 5.0 | Qualification |  | 166.33 | Green | GREEN | T3-QU-0014 | QAG | T3 |
| 1402 | 1.6.2.2.3.1.2 | **Test execution schedule** |  | 65d | 2024-10-01 | 2024-12-30 |  | 2024-10-01 | 2024-12-30 | 65d | 2024-10-01 | 2024-12-30 | 629d |  | N/A | 520h | N/A | N/A | 5.0 | Qualification |  |  |  |  |  |  |  |
| 1403 | 1.6.2.2.3.1.2.1 | Develop document |  | 40d | 2024-10-01 | 2024-11-25 | 1401 | 2024-10-01 | 2024-11-25 | 40d | 2024-10-01 | 2024-11-25 | 629d | 0d |  |  | Code Bodies | SI Test, PP | 5.0 | Qualification |  | 166.33 | Green | GREEN |  |  |  |
| 1404 | 1.6.2.2.3.1.2.2 | Review & agree document |  | 20d | 2024-11-26 | 2024-12-23 | 1403 | 2024-11-26 | 2024-12-23 | 20d | 2024-11-26 | 2024-12-23 | 629d | 0d |  |  | Code Bodies | SI Test, PP | 5.0 | Qualification |  | 222.33 | Green | GREEN |  |  |  |
| 1405 | 1.6.2.2.3.1.2.3 | Qualification Testing Tranche 3 Test execution schedule approved | milestone | 0d | 2024-12-30 | 2024-12-30 | 1404FS+5d | 2024-12-30 | 2024-12-30 | 0d | 2024-12-30 | 2024-12-30 | 629d |  |  |  | Code Bodies | SI Test, PP | 5.0 | Qualification | 1. MHHS-ART146 2. Artefact ID not yet defined | 256.71 | Green | GREEN | T3-QU-0024 | QAG | T3 |

| ID | WBS | Task | Type | Duration | Start | Finish | Predecessors | Baseline start | Baseline finish | Baseline duration | Baseline 1 start | Baseline 1 finish | Total slack | Free slack | Resources | Work | Responsible | Involved | Update Version | MHHS Programme Phase | Task Status | Sched Status | RAG | Artefact ID | Milestone ID | Text29 | Tier |
| --- | --- | --- | --- | --- | --- | --- | --- | --- | --- | --- | --- | --- | --- | --- | --- | --- | --- | --- | --- | --- | --- | --- | --- | --- | --- | --- | --- |
| 1406 | 1.6.2.2.3.1.3 | **Environments** |  | 115d | 2024-10-01 | 2025-03-10 |  | 2024-10-01 | 2025-03-10 | 115d | 2024-10-01 | 2025-03-10 | 579d |  | N/A | 920h | N/A | N/A | 5.0 | Qualification |  |  |  |  |  |  |  |
| 1407 | 1.6.2.2.3.1.3.1 | Coordinate Qualification Participants' environment preparation |  | 60d | 2024-10-01 | 2024-12-23 | 1401 | 2024-10-01 | 2024-12-23 | 60d | 2024-10-01 | 2024-12-23 | 579d | 0d |  |  | SI Test | Code Bodies, PP | 5.0 | Qualification | 166.33 | Green | GREEN |  |  |  |  |
| 1408 | 1.6.2.2.3.1.3.2 | Coordinate deployment of MHHS solution code to Qualification Participants' UIT environments |  | 10d | 2024-12-10 | 2024-12-23 | 1407FF | 2024-12-10 | 2024-12-23 | 10d | 2024-12-10 | 2024-12-23 | 579d | 0d |  |  | SI Test | Code Bodies, PP | 5.0 | Qualification | 236.33 | Green | GREEN |  |  |  |  |
| 1409 | 1.6.2.2.3.1.3.3 | Qualification Testing Tranche 3 Participants' UIT environments ready to start connectivity proving (incl. certificates and security compliance) | milestone | 0d | 2024-12-30 | 2024-12-30 | 1408FS+5d | 2024-12-30 | 2024-12-30 | 0d | 2024-12-30 | 2024-12-30 | 579d | 0d |  |  | SI Test | Code Bodies, PP, IPA | 5.0 | Qualification | 256.71 | Green | GREEN | MHHS-ART073 | T3-QU-0025 | QAG | T3 |
| 1410 | 1.6.2.2.3.1.3.4 | Coordinate Qualification Participants' connectivity proving |  | 50d | 2024-12-31 | 2025-03-10 | 1409 | 2024-12-31 | 2025-03-10 | 50d | 2024-12-31 | 2025-03-10 | 579d | 0d |  |  | SI Test | Code Bodies, PP | 5.0 | Qualification | 257.33 | Green | GREEN |  |  |  |  |
| 1411 | 1.6.2.2.3.1.3.5 | Assurance of Qualification Participants' connectivity proving |  | 50d | 2024-12-31 | 2025-03-10 | 1410SS | 2024-12-31 | 2025-03-10 | 50d | 2024-12-31 | 2025-03-10 | 579d |  |  |  | SI Test | Code Bodies, PP | 5.0 | Qualification | 257.33 | Green | GREEN |  |  |  |  |
| 1412 | 1.6.2.2.3.1.4 | **Test Data** |  | 0d | 2024-12-30 | 2024-12-30 |  | 2024-12-30 | 2024-12-30 | 0d | 2024-12-30 | 2024-12-30 | 629d |  | N/A |  | N/A | N/A | 5.0 | Qualification |  |  |  |  |  |  |  |
| 1413 | 1.6.2.2.3.1.4.1 | Confirm MPAN range to Code Bodies (for Code Bodies to allocate to Qualification Testing Tranche 3 Participants) | milestone | 0d | 2024-12-30 | 2024-12-30 | 1409 | 2024-12-30 | 2024-12-30 | 0d | 2024-12-30 | 2024-12-30 | 629d |  | Richard Puddephatt |  | SI Test | Code Bodies, PP | 5.0 | Qualification | 256.71 | Green | GREEN | MHHS-ART073 | T3-QU-0026 | QAG | T3 |
| 1414 | 1.6.2.2.3.1.5 | **Other Preparation** |  | 115d | 2024-10-01 | 2025-03-10 |  | 2024-10-01 | 2025-03-10 | 115d | 2024-10-01 | 2025-03-10 | 579d |  | N/A | 920h | N/A | N/A | 5.0 | Qualification |  |  |  |  |  |  |  |
| 1415 | 1.6.2.2.3.1.5.1 | Onboarding of Test Participants to Test Management Tool |  | 115d | 2024-10-01 | 2025-03-10 | 1401 | 2024-10-01 | 2025-03-10 | 115d | 2024-10-01 | 2025-03-10 | 579d | 0d |  |  | SI Test | Code Bodies, PP | 5.0 | Qualification | 166.33 | Green | GREEN |  |  |  |  |
| 1416 | 1.6.2.2.3.1.5.2 | Other Preparation (activities TBC) |  | 115d | 2024-10-01 | 2025-03-10 | 1401 | 2024-10-01 | 2025-03-10 | 115d | 2024-10-01 | 2025-03-10 | 579d | 0d |  |  | Code Bodies | SI Test, PP | 5.0 | Qualification | 166.33 | Green | GREEN |  |  |  |  |
| 1417 | 1.6.2.2.3.1.6 | Monitoring of provisional Qualification Testing Tranche 3 Participants' PIT progress and test readiness | manual | 115d | 2024-09-03 | 2025-02-10 | 1389 | 2024-09-03 | 2025-02-10 | 115d | 2024-10-01 | 2024-10-01 |  |  |  |  |  |  | 5.0 | Qualification | 138.33 | Green | GREEN |  |  |  |  |
| 1418 | 1.6.2.2.3.1.7 | Qualification Testing Tranche 3 Test Readiness confirmed | milestone | 0d | 2025-03-10 | 2025-03-10 | 1410, 1415, 1416 | 2025-03-10 | 2025-03-10 | 0d | 2025-03-10 | 2025-03-10 | 579d |  |  |  | Code Bodies | SI Test, PP | 5.0 | Qualification | 326.71 | Green | GREEN |  | T3-QU-0038 | QAG | T3 |
| 1419 | 1.6.2.2.3.2 | **PP Tranche 3 Preparation** |  | 115d | 2024-10-01 | 2025-03-10 |  | 2024-10-01 | 2025-03-10 | 115d | 2024-10-01 | 2025-03-10 | 579d |  | N/A | 2760h | N/A | N/A | 5.0 | Qualification |  |  |  |  |  |  |  |
| 1420 | 1.6.2.2.3.2.1 | Confirm Qualification Testing Tranche 3 Participants | milestone | 0d | 2024-10-01 | 2024-10-01 | 1579FS-6mo | 2024-10-01 | 2024-10-01 | 0d | 2024-10-01 | 2024-10-01 | 579d | 0d |  |  | Code Bodies | SI Test, PP, IPA | 5.0 | Qualification | 166.33 | Green | GREEN |  | T3-QU-0014 | QAG | T3 |
| 1421 | 1.6.2.2.3.2.2 | **Environments** |  | 115d | 2024-10-01 | 2025-03-10 |  | 2024-10-01 | 2025-03-10 | 115d | 2024-10-01 | 2025-03-10 | 579d |  | N/A | 920h | N/A | N/A | 5.0 | Qualification |  |  |  |  |  |  |  |
| 1422 | 1.6.2.2.3.2.2.1 | UIT environment preparation |  | 60d | 2024-10-01 | 2024-12-23 | 1420 | 2024-10-01 | 2024-12-23 | 60d | 2024-10-01 | 2024-12-23 | 579d | 0d |  |  | PP | Code Bodies,SI Test | 5.0 | Qualification | 166.33 | Green | GREEN |  |  |  |  |
| 1423 | 1.6.2.2.3.2.2.2 | Deployment of MHHS solution code to UIT environments |  | 10d | 2024-12-10 | 2024-12-23 | 1422FF | 2024-12-10 | 2024-12-23 | 10d | 2024-12-10 | 2024-12-23 | 579d | 0d |  |  | PP | Code Bodies,SI Test | 5.0 | Qualification | 236.33 | Green | GREEN |  |  |  |  |
| 1424 | 1.6.2.2.3.2.2.3 | Qualification Testing Tranche 3 Participants' UIT environments ready to start connectivity proving (incl. certificates and security compliance) | milestone | 0d | 2024-12-30 | 2024-12-30 | 1423FS+5d | 2024-12-30 | 2024-12-30 | 0d | 2024-12-30 | 2024-12-30 | 579d | 0d |  |  | SI Test | Code Bodies, PP, IPA | 5.0 | Qualification | 256.71 | Green | GREEN | MHHS-ART073 | T3-QU-0025 | QAG | T3 |
| 1425 | 1.6.2.2.3.2.2.4 | UIT environment connectivity proving |  | 50d | 2024-12-31 | 2025-03-10 | 1424 | 2024-12-31 | 2025-03-10 | 50d | 2024-12-31 | 2025-03-10 | 579d | 0d |  |  | PP | Code Bodies,SI Test | 5.0 | Qualification | 257.33 | Green | GREEN |  |  |  |  |
| 1426 | 1.6.2.2.3.2.2.5 | Submit evidence of UIT environment connectivity proving to Programme for assurance |  | 50d | 2024-12-31 | 2025-03-10 | 1425SS | 2024-12-31 | 2025-03-10 | 50d | 2024-12-31 | 2025-03-10 | 579d |  |  |  | PP | Code Bodies,SI Test | 5.0 | Qualification | 257.33 | Green | GREEN |  |  |  |  |
| 1427 | 1.6.2.2.3.2.3 | **Other Preparation** |  | 115d | 2024-10-01 | 2025-03-10 |  | 2024-10-01 | 2025-03-10 | 115d | 2024-10-01 | 2025-03-10 | 579d |  | N/A | 920h | N/A | N/A | 5.0 | Qualification |  |  |  |  |  |  |  |
| 1428 | 1.6.2.2.3.2.3.1 | Other Preparation (incl. test execution planning) |  | 115d | 2024-10-01 | 2025-03-10 | 1420 | 2024-10-01 | 2025-03-10 | 115d | 2024-10-01 | 2025-03-10 | 579d |  |  |  | PP | Code Bodies,SI Test | 5.0 | Qualification | 166.33 | Green | GREEN |  |  |  |  |
| 1429 | 1.6.2.2.3.2.4 | Qualification Testing Tranche 3 Test Readiness confirmed | milestone | 0d | 2025-03-10 | 2025-03-10 | 1425FF | 2025-03-10 | 2025-03-10 | 0d | 2025-03-10 | 2025-03-10 | 579d |  |  |  | Code Bodies | SI Test, PP | 5.0 | Qualification | 326.71 | Green | GREEN |  | T3-QU-0038 | QAG | T3 |

| ID | WBS | Task | Type | Duration | Start | Finish | Predecessors | Baseline start | Baseline finish | Baseline duration | Baseline 1 start | Baseline 1 finish | Total slack | Free slack | Resources | Work | Responsible | Involved | Update Version | MHHS Programme Phase | Task Status | Sched Status | RAG | Milestone ID | Text29 | Tier | Artefact ID |
| --- | --- | --- | --- | --- | --- | --- | --- | --- | --- | --- | --- | --- | --- | --- | --- | --- | --- | --- | --- | --- | --- | --- | --- | --- | --- | --- | --- |
| 1430 | 1.6.2.2.4 | **Tranche 4 Preparation** |  | 115d | 2024-10-29 | 2025-04-07 |  | 2024-10-29 | 2025-04-07 | 115d | 2024-10-29 | 2025-04-07 | 0d |  | N/A | 6960h | N/A | N/A | 5.0 | Qualification |  |  |  |  |  |  |  |
| 1431 | 1.6.2.2.4.1 | **SI Tranche 4 Preparation** |  | 115d | 2024-10-29 | 2025-04-07 |  | 2024-10-29 | 2025-04-07 | 115d | 2024-10-29 | 2025-04-07 | 0d |  | N/A | 3280h | N/A | N/A | 5.0 | Qualification |  |  |  |  |  |  |  |
| 1432 | 1.6.2.2.4.1.1 | Confirm Qualification Testing Tranche 4 Participants | milestone | 0d | 2024-10-29 | 2024-10-29 | 1584FS-6mo | 2024-10-29 | 2024-10-29 | 0d | 2024-10-29 | 2024-10-29 | 559d | 0d |  |  | Code Bodies | SI Test, PP, IPA | 5.0 | Qualification | 194.33 | Green | GREEN | T3-QU-0015 | QAG | T3 |  |
| 1433 | 1.6.2.2.4.1.2 | **Test execution schedule** |  | 65d | 2024-10-29 | 2025-01-27 |  | 2024-10-29 | 2025-01-27 | 65d | 2024-10-29 | 2025-01-27 | 609d |  | N/A | 520h | N/A | N/A | 5.0 | Qualification |  |  |  |  |  |  |  |
| 1434 | 1.6.2.2.4.1.2.1 | Develop document |  | 40d | 2024-10-29 | 2024-12-23 | 1432 | 2024-10-29 | 2024-12-23 | 40d | 2024-10-29 | 2024-12-23 | 609d | 0d |  |  | Code Bodies | SI Test, PP | 5.0 | Qualification | 194.33 | Green | GREEN |  |  |  |  |
| 1435 | 1.6.2.2.4.1.2.2 | Review & agree document |  | 20d | 2024-12-24 | 2025-01-20 | 1434 | 2024-12-24 | 2025-01-20 | 20d | 2024-12-24 | 2025-01-20 | 609d | 0d |  |  | Code Bodies | SI Test, PP | 5.0 | Qualification | 250.33 | Green | GREEN |  |  |  |  |
| 1436 | 1.6.2.2.4.1.2.3 | Qualification Testing Tranche 4 Test execution schedule approved | milestone | 0d | 2025-01-27 | 2025-01-27 | 1435FS+5d | 2025-01-27 | 2025-01-27 | 0d | 2025-01-27 | 2025-01-27 | 609d | 50d |  |  | Code Bodies | SI Test, PP | 5.0 | Qualification | 284.71 | Green | GREEN | T3-QU-0030 | QAG | T3 | MHHS-ART146. Artefact ID not yet defined |
| 1437 | 1.6.2.2.4.1.3 | **Environments** |  | 115d | 2024-10-29 | 2025-04-07 |  | 2024-10-29 | 2025-04-07 | 115d | 2024-10-29 | 2025-04-07 | 559d |  | N/A | 920h | N/A | N/A | 5.0 | Qualification |  |  |  |  |  |  |  |
| 1438 | 1.6.2.2.4.1.3.1 | Coordinate Qualification Participants' environment preparation |  | 60d | 2024-10-29 | 2025-01-20 | 1432 | 2024-10-29 | 2025-01-20 | 60d | 2024-10-29 | 2025-01-20 | 559d | 0d |  |  | SI Test | Code Bodies, PP | 5.0 | Qualification | 194.33 | Green | GREEN |  |  |  |  |
| 1439 | 1.6.2.2.4.1.3.2 | Coordinate deployment of MHHS solution code to Qualification Participants' UIT environments |  | 10d | 2025-01-07 | 2025-01-20 | 1438FF | 2025-01-07 | 2025-01-20 | 10d | 2025-01-07 | 2025-01-20 | 559d | 0d |  |  | SI Test | Code Bodies, PP | 5.0 | Qualification | 264.33 | Green | GREEN |  |  |  |  |
| 1440 | 1.6.2.2.4.1.3.3 | Qualification Testing Tranche 4 Participants' UIT environments ready to start connectivity proving (incl. certificates and security compliance) | milestone | 0d | 2025-01-27 | 2025-01-27 | 1439FS+5d | 2025-01-27 | 2025-01-27 | 0d | 2025-01-27 | 2025-01-27 | 559d | 0d |  |  | SI Test | Code Bodies, PP, IPA | 5.0 | Qualification | 284.71 | Green | GREEN | T3-QU-0031 | QAG | T3 | MHHS-ART073 |
| 1441 | 1.6.2.2.4.1.3.4 | Coordinate Qualification Participants' connectivity proving |  | 50d | 2025-01-28 | 2025-04-07 | 1440 | 2025-01-28 | 2025-04-07 | 50d | 2025-01-28 | 2025-04-07 | 559d | 0d |  |  | SI Test | Code Bodies, PP | 5.0 | Qualification | 285.33 | Green | GREEN |  |  |  |  |
| 1442 | 1.6.2.2.4.1.3.5 | Assurance of Qualification Participants' connectivity proving |  | 50d | 2025-01-28 | 2025-04-07 | 1441SS | 2025-01-28 | 2025-04-07 | 50d | 2025-01-28 | 2025-04-07 | 559d |  |  |  | SI Test | Code Bodies, PP | 5.0 | Qualification | 285.33 | Green | GREEN |  |  |  |  |
| 1443 | 1.6.2.2.4.1.4 | **Test Data** |  | 0d | 2025-01-27 | 2025-01-27 |  | 2025-01-27 | 2025-01-27 | 0d | 2025-01-27 | 2025-01-27 | 609d |  | N/A |  | N/A | N/A | 5.0 | Qualification |  |  |  |  |  |  |  |
| 1444 | 1.6.2.2.4.1.4.1 | Confirm MPAN range to Code Bodies (for Code Bodies to allocate to Qualification Testing Tranche 4 Participants) | milestone | 0d | 2025-01-27 | 2025-01-27 | 1440 | 2025-01-27 | 2025-01-27 | 0d | 2025-01-27 | 2025-01-27 | 609d | 50d | Richard Puddephatt |  | SI Test | Code Bodies, PP | 5.0 | Qualification | 284.71 | Green | GREEN | T3-QU-0032 | QAG | T3 | MHHS-ART073 |
| 1445 | 1.6.2.2.4.1.5 | **Other Preparation** |  | 115d | 2024-10-29 | 2025-04-07 |  | 2024-10-29 | 2025-04-07 | 115d | 2024-10-29 | 2025-04-07 | 559d |  | N/A | 920h | N/A | N/A | 5.0 | Qualification |  |  |  |  |  |  |  |
| 1446 | 1.6.2.2.4.1.5.1 | Onboarding of Test Participants to Test Management Tool |  | 115d | 2024-10-29 | 2025-04-07 | 1432 | 2024-10-29 | 2025-04-07 | 115d | 2024-10-29 | 2025-04-07 | 559d | 0d |  |  | SI Test | Code Bodies, PP | 5.0 | Qualification | 194.33 | Green | GREEN |  |  |  |  |
| 1447 | 1.6.2.2.4.1.5.2 | Other Preparation (activities TBC) |  | 115d | 2024-10-29 | 2025-04-07 | 1432 | 2024-10-29 | 2025-04-07 | 115d | 2024-10-29 | 2025-04-07 | 559d | 0d |  |  | Code Bodies | SI Test, PP | 5.0 | Qualification | 194.33 | Green | GREEN |  |  |  |  |
| 1448 | 1.6.2.2.4.1.6 | Monitoring of provisional Qualification Testing Tranche 4 Participants' PIT progress and test readiness | manual | 115d | 2024-10-29 | 2025-04-07 | 1432 | 2024-10-29 | 2025-04-07 | 115d | 2024-10-29 | 2024-10-29 |  |  |  |  |  |  | 5.0 | Qualification | 194.33 | Green | GREEN |  |  |  |  |
| 1449 | 1.6.2.2.4.1.7 | Qualification Testing Tranche 4 Test Readiness confirmed | milestone | 0d | 2025-04-07 | 2025-04-07 | 1441, 1446, 1447, 1432, 1436, 1440, 1444 | 2025-04-07 | 2025-04-07 | 0d | 2025-04-07 | 2025-04-07 | 559d |  |  |  | Code Bodies | SI Test, PP | 5.0 | Qualification | 354.71 | Green | GREEN | T3-QU-0043 | QAG | T3 |  |
| 1450 | 1.6.2.2.4.2 | **PP Tranche 4 Preparation** |  | 115d | 2024-10-29 | 2025-04-07 |  | 2024-10-29 | 2025-04-07 | 115d | 2024-10-29 | 2025-04-07 | 559d |  | N/A | 2760h | N/A | N/A | 5.0 | Qualification |  |  |  |  |  |  |  |
| 1451 | 1.6.2.2.4.2.1 | Confirm Qualification Testing Tranche 4 Participants | milestone | 0d | 2024-10-29 | 2024-10-29 | 1584FS-6mo | 2024-10-29 | 2024-10-29 | 0d | 2024-10-29 | 2024-10-29 | 559d | 0d |  |  | Code Bodies | SI Test, PP, IPA | 5.0 | Qualification | 194.33 | Green | GREEN | T3-QU-0015 | QAG | T3 |  |
| 1452 | 1.6.2.2.4.2.2 | **Environments** |  | 115d | 2024-10-29 | 2025-04-07 |  | 2024-10-29 | 2025-04-07 | 115d | 2024-10-29 | 2025-04-07 | 559d |  | N/A | 920h | N/A | N/A | 5.0 | Qualification |  |  |  |  |  |  |  |
| 1453 | 1.6.2.2.4.2.2.1 | UIT environment preparation |  | 60d | 2024-10-29 | 2025-01-20 | 1451 | 2024-10-29 | 2025-01-20 | 60d | 2024-10-29 | 2025-01-20 | 559d | 0d |  |  | PP | Code Bodies,SI Test | 5.0 | Qualification | 194.33 | Green | GREEN |  |  |  |  |
| 1454 | 1.6.2.2.4.2.2.2 | Deployment of MHHS solution code to UIT environments |  | 10d | 2025-01-07 | 2025-01-20 | 1453FF | 2025-01-07 | 2025-01-20 | 10d | 2025-01-07 | 2025-01-20 | 559d | 0d |  |  | PP | Code Bodies,SI Test | 5.0 | Qualification | 264.33 | Green | GREEN |  |  |  |  |
| 1455 | 1.6.2.2.4.2.2.3 | Qualification Testing Tranche 4 Participants' UIT environments ready to start connectivity proving (incl. certificates and security compliance) | milestone | 0d | 2025-01-27 | 2025-01-27 | 1454FS+5d | 2025-01-27 | 2025-01-27 | 0d | 2025-01-27 | 2025-01-27 | 559d | 0d |  |  | SI Test | Code Bodies, PP, IPA | 5.0 | Qualification | 284.71 | Green | GREEN | T3-QU-0031 | QAG | T3 | MHHS-ART073 |
| 1456 | 1.6.2.2.4.2.2.4 | UIT environment connectivity proving |  | 50d | 2025-01-28 | 2025-04-07 | 1455 | 2025-01-28 | 2025-04-07 | 50d | 2025-01-28 | 2025-04-07 | 559d | 0d |  |  | PP | Code Bodies,SI Test | 5.0 | Qualification | 285.33 | Green | GREEN |  |  |  |  |
| 1457 | 1.6.2.2.4.2.2.5 | Submit evidence of UIT environment connectivity proving to Programme for assurance |  | 50d | 2025-01-28 | 2025-04-07 | 1456SS | 2025-01-28 | 2025-04-07 | 50d | 2025-01-28 | 2025-04-07 | 559d |  |  |  | PP | Code Bodies,SI Test | 5.0 | Qualification | 285.33 | Green | GREEN |  |  |  |  |

| ID | WBS | Task | Type | Duration | Start | Finish | Predecessors | Baseline start | Baseline finish | Baseline duration | Baseline 1 start | Baseline 1 finish | Total slack | Free slack | Resources | Work | Responsible | Involved | Update Version | MHHS Programme Phase | Task Status | Sched Status | RAG | Milestone ID | Text29 | Tier | Artefact ID |
| --- | --- | --- | --- | --- | --- | --- | --- | --- | --- | --- | --- | --- | --- | --- | --- | --- | --- | --- | --- | --- | --- | --- | --- | --- | --- | --- | --- |
| 1458 | 1.6.2.2.4.2.3 | **Other Preparation** |  | 115d | 2024-10-29 | 2025-04-07 |  | 2024-10-29 | 2025-04-07 | 115d | 2024-10-29 | 2025-04-07 | 559d |  | N/A | 920h | N/A | N/A | 5.0 | Qualification |  |  |  |  |  |  |  |
| 1459 | 1.6.2.2.4.2.3.1 | Other Preparation (incl. test execution planning) |  | 115d | 2024-10-29 | 2025-04-07 | 1451 | 2024-10-29 | 2025-04-07 | 115d | 2024-10-29 | 2025-04-07 | 559d |  |  |  | PP | Code Bodies,SI Test | 5.0 | Qualification | 194.33 | Green | GREEN |  |  |  |  |
| 1460 | 1.6.2.2.4.2.4 | Qualification Testing Tranche 4 Test Readiness confirmed | milestone | 0d | 2025-04-07 | 2025-04-07 | 1456FF | 2025-04-07 | 2025-04-07 | 0d | 2025-04-07 | 2025-04-07 | 559d |  |  |  | Code Bodies | SI Test, PP | 5.0 | Qualification | 354.71 | Green | GREEN | T3-QU-0043 | QAG | T3 |  |
| 1461 | 1.6.2.2.5 | **Tranche 5 Preparation** |  | 115d | 2024-11-26 | 2025-05-05 |  | 2024-11-26 | 2025-05-05 | 115d | 2024-11-26 | 2025-05-05 | 0d |  | N/A | 6960h | N/A | N/A | 5.0 | Qualification |  |  |  |  |  |  |  |
| 1462 | 1.6.2.2.5.1 | **SI Tranche 5 Preparation** |  | 115d | 2024-11-26 | 2025-05-05 |  | 2024-11-26 | 2025-05-05 | 115d | 2024-11-26 | 2025-05-05 | 0d |  | N/A | 3280h | N/A | N/A | 5.0 | Qualification |  |  |  |  |  |  |  |
| 1463 | 1.6.2.2.5.1.1 | Confirm Qualification Testing Tranche 5 Participants | milestone | 0d | 2024-11-26 | 2024-11-26 | 1589FS-6mo | 2024-11-26 | 2024-11-26 | 0d | 2024-11-26 | 2024-11-26 | 539d | 0d |  |  | Code Bodies | SI Test, PP, IPA | 5.0 | Qualification | 222.33 | Green | GREEN | T3-QU-0019 | QAG | T3 |  |
| 1464 | 1.6.2.2.5.1.2 | **Test execution schedule** |  | 65d | 2024-11-26 | 2025-02-24 |  | 2024-11-26 | 2025-02-24 | 65d | 2024-11-26 | 2025-02-24 | 589d |  | N/A | 520h | N/A | N/A | 5.0 | Qualification |  |  |  |  |  |  |  |
| 1465 | 1.6.2.2.5.1.2.1 | Develop document |  | 40d | 2024-11-26 | 2025-01-20 | 1463 | 2024-11-26 | 2025-01-20 | 40d | 2024-11-26 | 2025-01-20 | 589d | 0d |  |  | Code Bodies | SI Test, PP | 5.0 | Qualification | 222.33 | Green | GREEN |  |  |  |  |
| 1466 | 1.6.2.2.5.1.2.2 | Review & agree document |  | 20d | 2025-01-21 | 2025-02-17 | 1465 | 2025-01-21 | 2025-02-17 | 20d | 2025-01-21 | 2025-02-17 | 589d | 0d |  |  | Code Bodies | SI Test, PP | 5.0 | Qualification | 278.33 | Green | GREEN |  |  |  |  |
| 1467 | 1.6.2.2.5.1.2.3 | Qualification Testing Tranche 5 Test execution schedule approved | milestone | 0d | 2025-02-24 | 2025-02-24 | 1466FS+5d | 2025-02-24 | 2025-02-24 | 0d | 2025-02-24 | 2025-02-24 | 589d |  |  |  | Code Bodies | SI Test, PP | 5.0 | Qualification | 312.71 | Green | GREEN | T3-QU-0035 | QAG | T3 | MHHS-ART146. Artefact ID not yet defined |
| 1468 | 1.6.2.2.5.1.3 | **Environments** |  | 115d | 2024-11-26 | 2025-05-05 |  | 2024-11-26 | 2025-05-05 | 115d | 2024-11-26 | 2025-05-05 | 539d |  | N/A | 920h | N/A | N/A | 5.0 | Qualification |  |  |  |  |  |  |  |
| 1469 | 1.6.2.2.5.1.3.1 | Coordinate Qualification Participants' environment preparation |  | 60d | 2024-11-26 | 2025-02-17 | 1463 | 2024-11-26 | 2025-02-17 | 60d | 2024-11-26 | 2025-02-17 | 539d | 0d |  |  | SI Test | Code Bodies, PP | 5.0 | Qualification | 222.33 | Green | GREEN |  |  |  |  |
| 1470 | 1.6.2.2.5.1.3.2 | Coordinate deployment of MHHS solution code to Qualification Participants' UIT environments |  | 10d | 2025-02-04 | 2025-02-17 | 1469FF | 2025-02-04 | 2025-02-17 | 10d | 2025-02-04 | 2025-02-17 | 539d | 0d |  |  | SI Test | Code Bodies, PP | 5.0 | Qualification | 292.33 | Green | GREEN |  |  |  |  |
| 1471 | 1.6.2.2.5.1.3.3 | Qualification Testing Tranche 5 Participants' UIT environments ready to start connectivity proving (incl. certificates and security compliance) | milestone | 0d | 2025-02-24 | 2025-02-24 | 1470FS+5d | 2025-02-24 | 2025-02-24 | 0d | 2025-02-24 | 2025-02-24 | 539d | 0d |  |  | SI Test | Code Bodies, PP, IPA | 5.0 | Qualification | 312.71 | Green | GREEN | T3-QU-0036 | QAG | T3 | MHHS-ART073 |
| 1472 | 1.6.2.2.5.1.3.4 | Coordinate Qualification Participants' connectivity proving |  | 48d | 2025-02-25 | 2025-05-01 | 1471 | 2025-02-25 | 2025-05-05 | 50d | 2025-02-25 | 2025-05-05 | 539d | 0d |  |  | SI Test | Code Bodies, PP | 5.0 | Qualification | 313.33 | Green | GREEN |  |  |  |  |
| 1473 | 1.6.2.2.5.1.3.5 | Assurance of Qualification Participants' connectivity proving |  | 50d | 2025-02-25 | 2025-05-05 | 1472SS | 2025-02-25 | 2025-05-05 | 50d | 2025-02-25 | 2025-05-05 | 539d | 0d |  |  | SI Test | Code Bodies, PP | 5.0 | Qualification | 313.33 | Green | GREEN |  |  |  |  |
| 1474 | 1.6.2.2.5.1.4 | **Test Data** |  | 0d | 2025-02-24 | 2025-02-24 |  | 2025-02-24 | 2025-02-24 | 0d | 2025-02-24 | 2025-02-24 | 589d |  | N/A |  | N/A | N/A | 5.0 | Qualification |  |  |  |  |  |  |  |
| 1475 | 1.6.2.2.5.1.4.1 | Confirm MPAN range to Code Bodies (for Code Bodies to allocate to Qualification Testing Tranche 5 Participants) | milestone | 0d | 2025-02-24 | 2025-02-24 | 1471 | 2025-02-24 | 2025-02-24 | 0d | 2025-02-24 | 2025-02-24 | 589d | 50d | Richard Puddephatt |  | SI Test | Code Bodies, PP | 5.0 | Qualification | 312.71 | Green | GREEN | T3-QU-0037 | QAG | T3 | MHHS-ART073 |
| 1476 | 1.6.2.2.5.1.5 | **Other Preparation** |  | 115d | 2024-11-26 | 2025-05-05 |  | 2024-11-26 | 2025-05-05 | 115d | 2024-11-26 | 2025-05-05 | 539d |  | N/A | 920h | N/A | N/A | 5.0 | Qualification |  |  |  |  |  |  |  |
| 1477 | 1.6.2.2.5.1.5.1 | Onboarding of Test Participants to Test Management Tool |  | 115d | 2024-11-26 | 2025-05-05 | 1463 | 2024-11-26 | 2025-05-05 | 115d | 2024-11-26 | 2025-05-05 | 539d | 0d |  |  | SI Test | Code Bodies, PP | 5.0 | Qualification | 222.33 | Green | GREEN |  |  |  |  |
| 1478 | 1.6.2.2.5.1.5.2 | Other Preparation (activities TBC) |  | 115d | 2024-11-26 | 2025-05-05 | 1463 | 2024-11-26 | 2025-05-05 | 115d | 2024-11-26 | 2025-05-05 | 539d | 0d |  |  | Code Bodies | SI Test, PP | 5.0 | Qualification | 222.33 | Green | GREEN |  |  |  |  |
| 1479 | 1.6.2.2.5.1.6 | Monitoring of provisional Qualification Testing Tranche 5 Participants' PIT progress and test readiness | manual | 115d | 2024-11-26 | 2025-05-05 | 1463 | 2024-11-26 | 2025-05-05 | 115d | 2024-11-26 | 2024-11-26 |  |  |  |  |  |  | 5.0 | Qualification | 222.33 | Green | GREEN |  |  |  |  |
| 1480 | 1.6.2.2.5.1.7 | Qualification Testing Tranche 5 Test Readiness confirmed | milestone | 0d | 2025-05-05 | 2025-05-05 | 1472, 1477, 1478, 1463, 1471, 1475, 1473 | 2025-05-05 | 2025-05-05 | 0d | 2025-05-05 | 2025-05-05 | 539d |  |  |  | Code Bodies | SI Test, PP | 5.0 | Qualification | 382.71 | Green | GREEN | T3-QU-0048 | QAG | T3 |  |
| 1481 | 1.6.2.2.5.2 | **PP Tranche 5 Preparation** |  | 115d | 2024-11-26 | 2025-05-05 |  | 2024-11-26 | 2025-05-05 | 115d | 2024-11-26 | 2025-05-05 | 539d |  | N/A | 2760h | N/A | N/A | 5.0 | Qualification |  |  |  |  |  |  |  |
| 1482 | 1.6.2.2.5.2.1 | Confirm Qualification Testing Tranche 5 Participants | milestone | 0d | 2024-11-26 | 2024-11-26 | 1589FS-6mo | 2024-11-26 | 2024-11-26 | 0d | 2024-11-26 | 2024-11-26 | 539d | 0d |  |  | Code Bodies | SI Test, PP, IPA | 5.0 | Qualification | 222.33 | Green | GREEN | T3-QU-0019 | QAG | T3 |  |

| ID | WBS | Task | Type | Duration | Start | Finish | Predecessors | Baseline start | Baseline finish | Baseline duration | Baseline 1 start | Baseline 1 finish | Total slack | Free slack | Resources | Work | Responsible | Involved | Update Version | MHHS Programme Phase | Task Status | Sched Status | RAG | Artefact ID | Milestone ID | Text29 | Tier |
| --- | --- | --- | --- | --- | --- | --- | --- | --- | --- | --- | --- | --- | --- | --- | --- | --- | --- | --- | --- | --- | --- | --- | --- | --- | --- | --- | --- |
| 1483 | 1.6.2.2.5.2.2 | **Environments** |  | 115d | 2024-11-26 | 2025-05-05 |  | 2024-11-26 | 2025-05-05 | 115d | 2024-11-26 | 2025-05-05 | 539d |  | N/A | 920h | N/A | N/A | 5.0 | Qualification |  |  |  |  |  |  |  |
| 1484 | 1.6.2.2.5.2.2.1 | UIT environment preparation |  | 60d | 2024-11-26 | 2025-02-17 | 1482 | 2024-11-26 | 2025-02-17 | 60d | 2024-11-26 | 2025-02-17 | 539d | 0d |  |  | PP | Code Bodies,SI Test | 5.0 | Qualification | 222.33 | Green | GREEN |  |  |  |  |
| 1485 | 1.6.2.2.5.2.2.2 | Deployment of MHHS solution code to UIT environments |  | 10d | 2025-02-04 | 2025-02-17 | 1484FF | 2025-02-04 | 2025-02-17 | 10d | 2025-02-04 | 2025-02-17 | 539d | 0d |  |  | PP | Code Bodies,SI Test | 5.0 | Qualification | 292.33 | Green | GREEN |  |  |  |  |
| 1486 | 1.6.2.2.5.2.2.3 | Qualification Testing Tranche 5 Participants' UIT environments ready to start connectivity proving (incl. certificates and security compliance) | milestone | 0d | 2025-02-24 | 2025-02-24 | 1485FS+5d | 2025-02-24 | 2025-02-24 | 0d | 2025-02-24 | 2025-02-24 | 539d | 0d |  |  | SI Test | Code Bodies, PP, IPA | 5.0 | Qualification | 312.71 | Green | GREEN | MHHS-ART073 | T3-QU-0036 | QAG | T3 |
| 1487 | 1.6.2.2.5.2.2.4 | UIT environment connectivity proving |  | 50d | 2025-02-25 | 2025-05-05 | 1486 | 2025-02-25 | 2025-05-05 | 50d | 2025-02-25 | 2025-05-05 | 539d | 0d |  |  | PP | Code Bodies,SI Test | 5.0 | Qualification | 313.33 | Green | GREEN |  |  |  |  |
| 1488 | 1.6.2.2.5.2.2.5 | Submit evidence of UIT environment connectivity proving to Programme for assurance |  | 50d | 2025-02-25 | 2025-05-05 | 1487SS | 2025-02-25 | 2025-05-05 | 50d | 2025-02-25 | 2025-05-05 | 539d |  |  |  | PP | Code Bodies,SI Test | 5.0 | Qualification | 313.33 | Green | GREEN |  |  |  |  |
| 1489 | 1.6.2.2.5.2.3 | **Other Preparation** |  | 115d | 2024-11-26 | 2025-05-05 |  | 2024-11-26 | 2025-05-05 | 115d | 2024-11-26 | 2025-05-05 | 539d |  | N/A | 920h | N/A | N/A | 5.0 | Qualification |  |  |  |  |  |  |  |
| 1490 | 1.6.2.2.5.2.3.1 | Other Preparation (incl. test execution planning) |  | 115d | 2024-11-26 | 2025-05-05 | 1482 | 2024-11-26 | 2025-05-05 | 115d | 2024-11-26 | 2025-05-05 | 539d |  |  |  | PP | Code Bodies,SI Test | 5.0 | Qualification | 222.33 | Green | GREEN |  |  |  |  |
| 1491 | 1.6.2.2.5.2.4 | Qualification Testing Tranche 5 Test Readiness confirmed | milestone | 0d | 2025-05-05 | 2025-05-05 | 1487FF | 2025-05-05 | 2025-05-05 | 0d | 2025-05-05 | 2025-05-05 | 539d |  |  |  | Code Bodies | SI Test, PP | 5.0 | Qualification | 382.71 | Green | GREEN |  | T3-QU-0048 | QAG | T3 |
| 1492 | 1.6.2.2.6 | **Tranche 6 Preparation** |  | 115d | 2024-12-24 | 2025-06-02 |  | 2024-12-24 | 2025-06-02 | 115d | 2024-12-24 | 2025-06-02 | 0d |  | N/A | 6960h | N/A | N/A | 5.0 | Qualification |  |  |  |  |  |  |  |
| 1493 | 1.6.2.2.6.1 | **SI Tranche 6 Preparation** |  | 115d | 2024-12-24 | 2025-06-02 |  | 2024-12-24 | 2025-06-02 | 115d | 2024-12-24 | 2025-06-02 | 0d |  | N/A | 3280h | N/A | N/A | 5.0 | Qualification |  |  |  |  |  |  |  |
| 1494 | 1.6.2.2.6.1.1 | Confirm Qualification Testing Tranche 6 Participants | milestone | 0d | 2024-12-24 | 2024-12-24 | 1594FS-6mo | 2024-12-24 | 2024-12-24 | 0d | 2024-12-24 | 2024-12-24 | 519d | 0d |  |  | Code Bodies | SI Test, PP, IPA | 5.0 | Qualification | 250.33 | Green | GREEN |  | T3-QU-0023 | QAG | T3 |
| 1495 | 1.6.2.2.6.1.2 | **Test execution schedule** |  | 65d | 2024-12-24 | 2025-03-24 |  | 2024-12-24 | 2025-03-24 | 65d | 2024-12-24 | 2025-03-24 | 569d |  | N/A | 520h | N/A | N/A | 5.0 | Qualification |  |  |  |  |  |  |  |
| 1496 | 1.6.2.2.6.1.2.1 | Develop document |  | 40d | 2024-12-24 | 2025-02-17 | 1494 | 2024-12-24 | 2025-02-17 | 40d | 2024-12-24 | 2025-02-17 | 569d | 0d |  |  | Code Bodies | SI Test, PP | 5.0 | Qualification | 250.33 | Green | GREEN |  |  |  |  |
| 1497 | 1.6.2.2.6.1.2.2 | Review & agree document |  | 20d | 2025-02-18 | 2025-03-17 | 1496 | 2025-02-18 | 2025-03-17 | 20d | 2025-02-18 | 2025-03-17 | 569d | 0d |  |  | Code Bodies | SI Test, PP | 5.0 | Qualification | 306.33 | Green | GREEN |  |  |  |  |
| 1498 | 1.6.2.2.6.1.2.3 | Qualification Testing Tranche 6 Test execution schedule approved | milestone | 0d | 2025-03-24 | 2025-03-24 | 1497FS+5d | 2025-03-24 | 2025-03-24 | 0d | 2025-03-24 | 2025-03-24 | 569d | 50d |  |  | Code Bodies | SI Test, PP | 5.0 | Qualification | 340.71 | Green | GREEN | 1. MHHS-ART146 2. Artefact ID not yet defined | T3-QU-0040 | QAG | T3 |
| 1499 | 1.6.2.2.6.1.3 | **Environments** |  | 115d | 2024-12-24 | 2025-06-02 |  | 2024-12-24 | 2025-06-02 | 115d | 2024-12-24 | 2025-06-02 | 519d |  | N/A | 920h | N/A | N/A | 5.0 | Qualification |  |  |  |  |  |  |  |
| 1500 | 1.6.2.2.6.1.3.1 | Coordinate Qualification Participants' environment preparation |  | 60d | 2024-12-24 | 2025-03-17 | 1494 | 2024-12-24 | 2025-03-17 | 60d | 2024-12-24 | 2025-03-17 | 519d | 0d |  |  | SI Test | Code Bodies, PP | 5.0 | Qualification | 250.33 | Green | GREEN |  |  |  |  |
| 1501 | 1.6.2.2.6.1.3.2 | Coordinate deployment of MHHS solution code to Qualification Participants' UIT environments |  | 10d | 2025-03-04 | 2025-03-17 | 1500FF | 2025-03-04 | 2025-03-17 | 10d | 2025-03-04 | 2025-03-17 | 519d | 0d |  |  | SI Test | Code Bodies, PP | 5.0 | Qualification | 320.33 | Green | GREEN |  |  |  |  |
| 1502 | 1.6.2.2.6.1.3.3 | Qualification Testing Tranche 6 Participants' UIT environments ready to start connectivity proving (incl. certificates and security compliance) | milestone | 0d | 2025-03-24 | 2025-03-24 | 1501FS+5d | 2025-03-24 | 2025-03-24 | 0d | 2025-03-24 | 2025-03-24 | 519d | 0d |  |  | SI Test | Code Bodies, PP, IPA | 5.0 | Qualification | 340.71 | Green | GREEN | MHHS-ART073 | T3-QU-0041 | QAG | T3 |
| 1503 | 1.6.2.2.6.1.3.4 | Coordinate Qualification Participants' connectivity proving |  | 50d | 2025-03-25 | 2025-06-02 | 1502 | 2025-03-25 | 2025-06-02 | 50d | 2025-03-25 | 2025-06-02 | 519d | 0d |  |  | SI Test | Code Bodies, PP | 5.0 | Qualification | 341.33 | Green | GREEN |  |  |  |  |
| 1504 | 1.6.2.2.6.1.3.5 | Assurance of Qualification Participants' connectivity proving |  | 50d | 2025-03-25 | 2025-06-02 | 1503SS | 2025-03-25 | 2025-06-02 | 50d | 2025-03-25 | 2025-06-02 | 519d |  |  |  | SI Test | Code Bodies, PP | 5.0 | Qualification | 341.33 | Green | GREEN |  |  |  |  |
| 1505 | 1.6.2.2.6.1.4 | **Test Data** |  | 0d | 2025-03-24 | 2025-03-24 |  | 2025-03-24 | 2025-03-24 | 0d | 2025-03-24 | 2025-03-24 | 569d |  | N/A |  | N/A | N/A | 5.0 | Qualification |  |  |  |  |  |  |  |
| 1506 | 1.6.2.2.6.1.4.1 | Confirm MPAN range to Code Bodies (for Code Bodies to allocate to Qualification Testing Tranche 6 Participants) | milestone | 0d | 2025-03-24 | 2025-03-24 | 1502 | 2025-03-24 | 2025-03-24 | 0d | 2025-03-24 | 2025-03-24 | 569d | 50d | Richard Puddephatt |  | SI Test | Code Bodies, PP | 5.0 | Qualification | 340.71 | Green | GREEN | MHHS-ART073 | T3-QU-0042 | QAG | T3 |

| ID | WBS | Task | Type | Duration | Start | Finish | Predecessors | Baseline start | Baseline finish | Baseline duration | Baseline 1 start | Baseline 1 finish | Total slack | Free slack | Resources | Work | Responsible | Involved | Update Version | MHHS Programme Phase | Task Status | Sched Status | RAG | Artefact ID | Milestone ID | Text29 | Tier |
| --- | --- | --- | --- | --- | --- | --- | --- | --- | --- | --- | --- | --- | --- | --- | --- | --- | --- | --- | --- | --- | --- | --- | --- | --- | --- | --- | --- |
| 1507 | 1.6.2.2.6.1.5 | **Other Preparation** |  | 115d | 2024-12-24 | 2025-06-02 |  | 2024-12-24 | 2025-06-02 | 115d | 2024-12-24 | 2025-06-02 | 519d |  | N/A | 920h | N/A | N/A | 5.0 | Qualification |  |  |  |  |  |  |  |
| 1508 | 1.6.2.2.6.1.5.1 | Onboarding of Test Participants to Test Management Tool |  | 115d | 2024-12-24 | 2025-06-02 | 1494 | 2024-12-24 | 2025-06-02 | 115d | 2024-12-24 | 2025-06-02 | 519d | 0d |  |  | SI Test | Code Bodies, PP | 5.0 | Qualification | 250.33 | Green | GREEN |  |  |  |  |
| 1509 | 1.6.2.2.6.1.5.2 | Other Preparation (activities TBC) |  | 115d | 2024-12-24 | 2025-06-02 | 1494 | 2024-12-24 | 2025-06-02 | 115d | 2024-12-24 | 2025-06-02 | 519d | 0d |  |  | Code Bodies | SI Test, PP | 5.0 | Qualification | 250.33 | Green | GREEN |  |  |  |  |
| 1510 | 1.6.2.2.6.1.6 | Monitoring of provisional Qualification Testing Tranche 6 Participants' PIT progress and test readiness | manual | 115d | 2024-12-24 | 2025-06-02 | 1494 | 2024-12-24 | 2025-06-02 | 115d | 2024-12-24 | 2024-12-24 |  |  |  |  |  |  | 5.0 | Qualification | 250.33 | Green | GREEN |  |  |  |  |
| 1511 | 1.6.2.2.6.1.7 | Qualification Testing Tranche 6 Test Readiness confirmed | milestone | 0d | 2025-06-02 | 2025-06-02 | 1503, 1508, 1509, 1494, 1498, 1502, 1506 | 2025-06-02 | 2025-06-02 | 0d | 2025-06-02 | 2025-06-02 | 519d |  |  |  | Code Bodies | SI Test, PP | 5.0 | Qualification | 410.71 | Green | GREEN | MHHS-ART146. Artefact ID not yet defined | T3-QU-0050 | QAG | T3 |
| 1512 | 1.6.2.2.6.2 | **PP Tranche 6 Preparation** |  | 115d | 2024-12-24 | 2025-06-02 |  | 2024-12-24 | 2025-06-02 | 115d | 2024-12-24 | 2025-06-02 | 519d |  | N/A | 2760h | N/A | N/A | 5.0 | Qualification |  |  |  |  |  |  |  |
| 1513 | 1.6.2.2.6.2.1 | Confirm Qualification Testing Tranche 6 Participants | milestone | 0d | 2024-12-24 | 2024-12-24 | 1594FS-6mo | 2024-12-24 | 2024-12-24 | 0d | 2024-12-24 | 2024-12-24 | 519d | 0d |  |  | Code Bodies | SI Test, PP, IPA | 5.0 | Qualification | 250.33 | Green | GREEN |  | T3-QU-0023 | QAG | T3 |
| 1514 | 1.6.2.2.6.2.2 | **Environments** |  | 115d | 2024-12-24 | 2025-06-02 |  | 2024-12-24 | 2025-06-02 | 115d | 2024-12-24 | 2025-06-02 | 519d |  | N/A | 920h | N/A | N/A | 5.0 | Qualification |  |  |  |  |  |  |  |
| 1515 | 1.6.2.2.6.2.2.1 | UIT environment preparation |  | 60d | 2024-12-24 | 2025-03-17 | 1513 | 2024-12-24 | 2025-03-17 | 60d | 2024-12-24 | 2025-03-17 | 519d | 0d |  |  | PP | Code Bodies,SI Test | 5.0 | Qualification | 250.33 | Green | GREEN |  |  |  |  |
| 1516 | 1.6.2.2.6.2.2.2 | Deployment of MHHS solution code to UIT environments |  | 10d | 2025-03-04 | 2025-03-17 | 1515FF | 2025-03-04 | 2025-03-17 | 10d | 2025-03-04 | 2025-03-17 | 519d | 0d |  |  | PP | Code Bodies,SI Test | 5.0 | Qualification | 320.33 | Green | GREEN |  |  |  |  |
| 1517 | 1.6.2.2.6.2.2.3 | Qualification Testing Tranche 6 Participants' UIT environments ready to start connectivity proving (incl. certificates and security compliance) | milestone | 0d | 2025-03-24 | 2025-03-24 | 1516FS+5d | 2025-03-24 | 2025-03-24 | 0d | 2025-03-24 | 2025-03-24 | 519d | 0d |  |  | SI Test | Code Bodies, PP, IPA | 5.0 | Qualification | 340.71 | Green | GREEN |  | T3-QU-0041 | QAG | T3 |
| 1518 | 1.6.2.2.6.2.2.4 | UIT environment connectivity proving |  | 50d | 2025-03-25 | 2025-06-02 | 1517 | 2025-03-25 | 2025-06-02 | 50d | 2025-03-25 | 2025-06-02 | 519d | 0d |  |  | PP | Code Bodies,SI Test | 5.0 | Qualification | 341.33 | Green | GREEN |  |  |  |  |
| 1519 | 1.6.2.2.6.2.2.5 | Submit evidence of UIT environment connectivity proving to Programme for assurance |  | 50d | 2025-03-25 | 2025-06-02 | 1518SS | 2025-03-25 | 2025-06-02 | 50d | 2025-03-25 | 2025-06-02 | 519d |  |  |  | PP | Code Bodies,SI Test | 5.0 | Qualification | 341.33 | Green | GREEN |  |  |  |  |
| 1520 | 1.6.2.2.6.2.3 | **Other Preparation** |  | 115d | 2024-12-24 | 2025-06-02 |  | 2024-12-24 | 2025-06-02 | 115d | 2024-12-24 | 2025-06-02 | 519d |  | N/A | 920h | N/A | N/A | 5.0 | Qualification |  |  |  |  |  |  |  |
| 1521 | 1.6.2.2.6.2.3.1 | Other Preparation (incl. test execution planning) |  | 115d | 2024-12-24 | 2025-06-02 | 1513 | 2024-12-24 | 2025-06-02 | 115d | 2024-12-24 | 2025-06-02 | 519d |  |  |  | PP | Code Bodies,SI Test | 5.0 | Qualification | 250.33 | Green | GREEN |  |  |  |  |
| 1522 | 1.6.2.2.6.2.4 | Qualification Testing Tranche 6 Test Readiness confirmed | milestone | 0d | 2025-06-02 | 2025-06-02 | 1518FF | 2025-06-02 | 2025-06-02 | 0d | 2025-06-02 | 2025-06-02 | 519d |  |  |  | Code Bodies | SI Test, PP | 5.0 | Qualification | 410.71 | Green | GREEN |  | T3-QU-0050 | QAG | T3 |
| 1523 | 1.6.2.2.7 | **Tranche 7 Preparation** |  | 115d | 2025-01-21 | 2025-06-30 |  | 2025-01-21 | 2025-06-30 | 115d | 2025-01-21 | 2025-06-30 | 0d |  | N/A | 6960h | N/A | N/A | 5.0 | Qualification |  |  |  |  |  |  |  |
| 1524 | 1.6.2.2.7.1 | **SI Tranche 7 Preparation** |  | 115d | 2025-01-21 | 2025-06-30 |  | 2025-01-21 | 2025-06-30 | 115d | 2025-01-21 | 2025-06-30 | 0d |  | N/A | 3280h | N/A | N/A | 5.0 | Qualification |  |  |  |  |  |  |  |
| 1525 | 1.6.2.2.7.1.1 | Confirm Qualification Testing Tranche 7 Participants | milestone | 0d | 2025-01-21 | 2025-01-21 | 1599FS-6mo | 2025-01-21 | 2025-01-21 | 0d | 2025-01-21 | 2025-01-21 | 499d | 0d |  |  | Code Bodies | SI Test, PP, IPA | 5.0 | Qualification | 278.33 | Green | GREEN |  | T3-QU-0029 | QAG | T3 |
| 1526 | 1.6.2.2.7.1.2 | **Test execution schedule** |  | 65d | 2025-01-21 | 2025-04-21 |  | 2025-01-21 | 2025-04-21 | 65d | 2025-01-21 | 2025-04-21 | 549d |  | N/A | 520h | N/A | N/A | 5.0 | Qualification |  |  |  |  |  |  |  |
| 1527 | 1.6.2.2.7.1.2.1 | Develop document |  | 40d | 2025-01-21 | 2025-03-17 | 1525 | 2025-01-21 | 2025-03-17 | 40d | 2025-01-21 | 2025-03-17 | 549d | 0d |  |  | Code Bodies | SI Test, PP | 5.0 | Qualification | 278.33 | Green | GREEN |  |  |  |  |
| 1528 | 1.6.2.2.7.1.2.2 | Review & agree document |  | 20d | 2025-03-18 | 2025-04-14 | 1527 | 2025-03-18 | 2025-04-14 | 20d | 2025-03-18 | 2025-04-14 | 549d | 0d |  |  | Code Bodies | SI Test, PP | 5.0 | Qualification | 334.33 | Green | GREEN |  |  |  |  |
| 1529 | 1.6.2.2.7.1.2.3 | Qualification Testing Tranche 7 Test execution schedule approved | milestone | 0d | 2025-04-21 | 2025-04-21 | 1528FS+5d | 2025-04-21 | 2025-04-21 | 0d | 2025-04-21 | 2025-04-21 | 549d | 50d |  |  | Code Bodies | SI Test, PP | 5.0 | Qualification | 368.71 | Green | GREEN | 1. MHHS-ART146 2. Artefact ID not yet defined | T3-QU-0045 | QAG | T3 |
| 1530 | 1.6.2.2.7.1.3 | **Environments** |  | 115d | 2025-01-21 | 2025-06-30 |  | 2025-01-21 | 2025-06-30 | 115d | 2025-01-21 | 2025-06-30 | 499d |  | N/A | 920h | N/A | N/A | 5.0 | Qualification |  |  |  |  |  |  |  |
| 1531 | 1.6.2.2.7.1.3.1 | Coordinate Qualification Participants' environment preparation |  | 60d | 2025-01-21 | 2025-04-14 | 1525 | 2025-01-21 | 2025-04-14 | 60d | 2025-01-21 | 2025-04-14 | 499d | 0d |  |  | SI Test | Code Bodies, PP | 5.0 | Qualification | 278.33 | Green | GREEN |  |  |  |  |
| 1532 | 1.6.2.2.7.1.3.2 | Coordinate deployment of MHHS solution code to Qualification Participants' UIT environments |  | 10d | 2025-04-01 | 2025-04-14 | 1531FF | 2025-04-01 | 2025-04-14 | 10d | 2025-04-01 | 2025-04-14 | 499d | 0d |  |  | SI Test | Code Bodies, PP | 5.0 | Qualification | 348.33 | Green | GREEN |  |  |  |  |
| 1533 | 1.6.2.2.7.1.3.3 | Qualification Testing Tranche 7 Participants' UIT environments ready to start connectivity proving (incl. certificates and security compliance) | milestone | 0d | 2025-04-21 | 2025-04-21 | 1532FS+5d | 2025-04-21 | 2025-04-21 | 0d | 2025-04-21 | 2025-04-21 | 499d | 0d |  |  | SI Test | Code Bodies, PP, IPA | 5.0 | Qualification | 368.71 | Green | GREEN | MHHS-ART073 | T3-QU-0046 | QAG | T3 |
| 1534 | 1.6.2.2.7.1.3.4 | Coordinate Qualification Participants' connectivity proving |  | 50d | 2025-04-22 | 2025-06-30 | 1533 | 2025-04-22 | 2025-06-30 | 50d | 2025-04-22 | 2025-06-30 | 499d | 0d |  |  | SI Test | Code Bodies, PP | 5.0 | Qualification | 369.33 | Green | GREEN |  |  |  |  |
| 1535 | 1.6.2.2.7.1.3.5 | Assurance of Qualification Participants' connectivity proving |  | 50d | 2025-04-22 | 2025-06-30 | 1534SS | 2025-04-22 | 2025-06-30 | 50d | 2025-04-22 | 2025-06-30 | 499d |  |  |  | SI Test | Code Bodies, PP | 5.0 | Qualification | 369.33 | Green | GREEN |  |  |  |  |

| ID | WBS | Task | Type | Duration | Start | Finish | Predecessors | Complete | Remaining | Baseline start | Baseline finish | Baseline duration | Baseline 1 start | Baseline 1 finish | Total slack | Free slack | Constraint | Resources | Work | Baseline cost | Responsible | Involved | Update Version | MHHS Programme Phase | Artefact ID | Task Status | Sched Status | RAG | Milestone ID | Text29 | Tier |
| --- | --- | --- | --- | --- | --- | --- | --- | --- | --- | --- | --- | --- | --- | --- | --- | --- | --- | --- | --- | --- | --- | --- | --- | --- | --- | --- | --- | --- | --- | --- | --- |
| 1536 | 1.6.2.2.7.1.4 | **Test Data** |  | 0d | 2025-04-21 | 2025-04-21 |  |  |  | 2025-04-21 | 2025-04-21 | 0d | 2025-04-21 | 2025-04-21 | 549d |  |  | N/A |  |  | N/A | N/A | 5.0 | Qualification |  |  |  |  |  |  |  |
| 1537 | 1.6.2.2.7.1.4.1 | Confirm MPAN range to Code Bodies (for Code Bodies to allocate to Qualification Testing Tranche 7 Participants) | milestone | 0d | 2025-04-21 | 2025-04-21 | 1533 |  |  | 2025-04-21 | 2025-04-21 | 0d | 2025-04-21 | 2025-04-21 | 549d | 50d |  | Richard Puddephatt |  |  | SI Test | Code Bodies, PP | 5.0 | Qualification | MHHS-ART073 | 368.71 | Green | GREEN | T3-QU-0047 | QAG | T3 |
| 1538 | 1.6.2.2.7.1.5 | **Other Preparation** |  | 115d | 2025-01-21 | 2025-06-30 |  |  |  | 2025-01-21 | 2025-06-30 | 115d | 2025-01-21 | 2025-06-30 | 499d |  |  | N/A | 920h |  | N/A | N/A | 5.0 | Qualification |  |  |  |  |  |  |  |
| 1539 | 1.6.2.2.7.1.5.1 | Onboarding of Test Participants to Test Management Tool |  | 115d | 2025-01-21 | 2025-06-30 | 1525 |  |  | 2025-01-21 | 2025-06-30 | 115d | 2025-01-21 | 2025-06-30 | 499d | 0d |  |  |  |  | SI Test | Code Bodies, PP | 5.0 | Qualification |  | 278.33 | Green | GREEN |  |  |  |
| 1540 | 1.6.2.2.7.1.5.2 | Other Preparation (activities TBC) |  | 115d | 2025-01-21 | 2025-06-30 | 1525 |  |  | 2025-01-21 | 2025-06-30 | 115d | 2025-01-21 | 2025-06-30 | 499d | 0d |  |  |  |  | Code Bodies | SI Test, PP | 5.0 | Qualification |  | 278.33 | Green | GREEN |  |  |  |
| 1541 | 1.6.2.2.7.1.6 | Monitoring of provisional Qualification Testing Tranche 7 Participants' PIT progress and test readiness | manual | 115d | 2025-01-21 | 2025-06-30 | 1525 |  |  | 2025-01-21 | 2025-06-30 | 115d | 2025-01-21 | 2025-01-21 |  |  |  |  |  |  |  |  | 5.0 | Qualification |  | 278.33 | Green | GREEN |  |  |  |
| 1542 | 1.6.2.2.7.1.7 | Qualification Testing Tranche 7 Test Readiness confirmed | milestone | 0d | 2025-06-30 | 2025-06-30 | 1534, 1539, 1540, 1525, 1529, 1533, 1537 |  |  | 2025-06-30 | 2025-06-30 | 0d | 2025-06-30 | 2025-06-30 | 499d |  |  |  |  |  | Code Bodies | SI Test, PP | 5.0 | Qualification | 1. MHHS-ART146 2. Artefact ID not yet defined | 438.71 | Green | GREEN | T3-QU-0052 | QAG | T3 |
| 1543 | 1.6.2.2.7.2 | **PP Tranche 7 Preparation** |  | 115d | 2025-01-21 | 2025-06-30 |  |  |  | 2025-01-21 | 2025-06-30 | 115d | 2025-01-21 | 2025-06-30 | 499d |  |  | N/A | 2760h |  | N/A | N/A | 5.0 | Qualification |  |  |  |  |  |  |  |
| 1544 | 1.6.2.2.7.2.1 | Confirm Qualification Testing Tranche 7 Participants | milestone | 0d | 2025-01-21 | 2025-01-21 | 1599FS-6mo |  |  | 2025-01-21 | 2025-01-21 | 0d | 2025-01-21 | 2025-01-21 | 499d | 0d |  |  |  |  | Code Bodies | SI Test, PP, IPA | 5.0 | Qualification |  | 278.33 | Green | GREEN | T3-QU-0029 | QAG | T3 |
| 1545 | 1.6.2.2.7.2.2 | **Environments** |  | 115d | 2025-01-21 | 2025-06-30 |  |  |  | 2025-01-21 | 2025-06-30 | 115d | 2025-01-21 | 2025-06-30 | 499d |  |  | N/A | 920h |  | N/A | N/A | 5.0 | Qualification |  |  |  |  |  |  |  |
| 1546 | 1.6.2.2.7.2.2.1 | UIT environment preparation |  | 60d | 2025-01-21 | 2025-04-14 | 1544 |  |  | 2025-01-21 | 2025-04-14 | 60d | 2025-01-21 | 2025-04-14 | 499d | 0d |  |  |  |  | PP | Code Bodies,SI Test | 5.0 | Qualification |  | 278.33 | Green | GREEN |  |  |  |
| 1547 | 1.6.2.2.7.2.2.2 | Deployment of MHHS solution code to UIT environments |  | 10d | 2025-04-01 | 2025-04-14 | 1546FF |  |  | 2025-04-01 | 2025-04-14 | 10d | 2025-04-01 | 2025-04-14 | 499d | 0d |  |  |  |  | PP | Code Bodies,SI Test | 5.0 | Qualification |  | 348.33 | Green | GREEN |  |  |  |
| 1548 | 1.6.2.2.7.2.2.3 | Qualification Testing Tranche 7 Participants' UIT environments ready to start connectivity proving (incl. certificates and security compliance) | milestone | 0d | 2025-04-21 | 2025-04-21 | 1547FS+5d |  |  | 2025-04-21 | 2025-04-21 | 0d | 2025-04-21 | 2025-04-21 | 499d | 0d |  |  |  |  | SI Test | Code Bodies, PP, IPA | 5.0 | Qualification | MHHS-ART073 | 368.71 | Green | GREEN | T3-QU-0046 | QAG | T3 |
| 1549 | 1.6.2.2.7.2.2.4 | UIT environment connectivity proving |  | 50d | 2025-04-22 | 2025-06-30 | 1548 |  |  | 2025-04-22 | 2025-06-30 | 50d | 2025-04-22 | 2025-06-30 | 499d | 0d |  |  |  |  | PP | Code Bodies,SI Test | 5.0 | Qualification |  | 369.33 | Green | GREEN |  |  |  |
| 1550 | 1.6.2.2.7.2.2.5 | Submit evidence of UIT environment connectivity proving to Programme for assurance |  | 50d | 2025-04-22 | 2025-06-30 | 1549SS |  |  | 2025-04-22 | 2025-06-30 | 50d | 2025-04-22 | 2025-06-30 | 499d |  |  |  |  |  | PP | Code Bodies,SI Test | 5.0 | Qualification |  | 369.33 | Green | GREEN |  |  |  |
| 1551 | 1.6.2.2.7.2.3 | **Other Preparation** |  | 115d | 2025-01-21 | 2025-06-30 |  |  |  | 2025-01-21 | 2025-06-30 | 115d | 2025-01-21 | 2025-06-30 | 499d |  |  | N/A | 920h |  | N/A | N/A | 5.0 | Qualification |  |  |  |  |  |  |  |
| 1552 | 1.6.2.2.7.2.3.1 | Other Preparation (incl. test execution planning) |  | 115d | 2025-01-21 | 2025-06-30 | 1544 |  |  | 2025-01-21 | 2025-06-30 | 115d | 2025-01-21 | 2025-06-30 | 499d |  |  |  |  |  | PP | Code Bodies,SI Test | 5.0 | Qualification |  | 278.33 | Green | GREEN |  |  |  |
| 1553 | 1.6.2.2.7.2.4 | Qualification Testing Tranche 7 Test Readiness confirmed | milestone | 0d | 2025-06-30 | 2025-06-30 | 1549FF |  |  | 2025-06-30 | 2025-06-30 | 0d | 2025-06-30 | 2025-06-30 | 499d |  |  |  |  |  | Code Bodies | SI Test, PP | 5.0 | Qualification | 1. MHHS-ART146 2. Artefact ID not yet defined | 438.71 | Green | GREEN | T3-QU-0052 | QAG | T3 |
| 1554 | 1.6.3 | **Qualification Assessment Document (QAD) Process** |  | 568d | 2024-01-18 A | 2026-03-23 |  |  | 568d | 2024-01-18 | 2026-03-23 | 568d | 2023-11-01 | 2026-01-19 | 309d |  |  | N/A | 4544h | -0 | N/A | N/A | 5.2 | Qualification |  |  |  |  |  |  |  |
| 1555 | 1.6.3.1 | Qualification Assessment Document Preparation Initial Draft (Functional) |  | 30d | 2024-01-18 | 2024-02-28 | 497, 810, 803 |  |  | 2024-01-18 | 2024-02-28 | 30d | 2023-11-01 | 2023-12-12 | 813d | 0d |  |  |  |  | Code Bodies |  | 5.2 | Qualification |  | -90.67 | Overdue Start | RED |  |  |  |
| 1556 | 1.6.3.2 | Artefact review (via QWG) and updates |  | 10d | 2024-02-29 | 2024-03-13 | 1555 |  |  | 2024-02-29 | 2024-03-13 | 10d | 2023-12-13 | 2023-12-26 | 813d | 0d |  |  |  |  | PP |  | 5.2 | Qualification |  | -48.67 | Overdue Start | RED |  |  |  |
| 1557 | 1.6.3.3 | Qualification Assessment Document Initial Draft final review and approval by BSC PAB and REC Manager |  | 24d | 2024-03-14 | 2024-04-16 | 1556 |  |  | 2024-03-14 | 2024-04-16 | 24d | 2023-12-27 | 2024-01-29 | 813d |  |  |  |  |  | Code Bodies |  | 5.2 | Qualification |  | -34.67 | Overdue Start | RED |  |  |  |
| 1558 | 1.6.3.4 | Qualification Assessment Document v1 approved by REC PAB and BSC PAB | milestone | 0d | 2024-04-16 A | 2024-04-16 A | 1557 | 100% |  | 2024-04-16 | 2024-04-16 | 0d | 2024-01-29 | 2024-01-29 |  |  |  | Nicola Farley |  |  | Code Bodies | PP,SI Test | 5.10 | Qualification |  |  | Complete | COMPLETE | T3-QU-0066 | QAG | T3 |
| 1559 | 1.6.3.5 | Qualification Assessment Document Preparation (Non-Functional, Migration, Operational) |  | 30d | 2024-08-15 | 2024-09-25 | 1704SS, 1335, 1701SS |  |  | 2024-08-15 | 2024-09-25 | 30d | 2024-08-15 | 2024-09-25 | 675d | 0d |  |  |  |  | Code bodies |  | 5.0 | Qualification |  | 119.33 | Green | GREEN |  |  |  |
| 1560 | 1.6.3.6 | Qualification Assessment Document final review and approval by BSC PAB and REC Manager |  | 22d | 2024-09-26 | 2024-10-25 | 1559 |  |  | 2024-09-26 | 2024-10-25 | 22d | 2024-09-26 | 2024-10-25 | 675d | 0d | start no earlier than 2024-02-19 |  |  |  | Code Bodies |  | 5.0 | Qualification |  | 161.33 | Green | GREEN |  |  |  |
| 1561 | 1.6.3.7 | Qualification Assessment Document Baselined | milestone | 0d | 2024-10-25 | 2024-10-25 | 1560 |  |  | 2024-10-25 | 2024-10-25 | 0d | 2024-10-25 | 2024-10-25 | 675d |  |  |  |  |  | Code Bodies | PP,SI Test | 5.0 | Qualification |  | 190.71 | Green | GREEN | T3-QU-0067 | QAG | T3 |
| 1562 | 1.6.3.8 | PPs complete Qualification Assessment Document process |  | 501d | 2024-04-22 | 2026-03-23 | 1934FF-2mo, 1558FS+3d, 1704SS, 1701SS |  |  | 2024-04-22 | 2026-03-23 | 501d | 2024-02-19 | 2026-01-19 | 309d | 0d |  |  |  |  | PP | Code Bodies | 5.0 | Qualification |  | 4.33 | Green | GREEN |  |  |  |
| 1563 | 1.6.3.9 | Qualification Assessment Document process monitoring |  | 501d | 2024-04-17 | 2026-03-18 | 1934FF-2mo, 1558, 1704SS, 1701SS |  |  | 2024-04-17 | 2026-03-18 | 501d | 2024-02-19 | 2026-01-19 | 312d |  |  |  |  |  | SI Test | PP,Code Bodies | 5.0 | Qualification |  | -0.67 | Overdue Start | GREEN |  |  |  |

Notes:
- 1555: work in progress - dependencies on SIT F scenarios and cases
- 1556: work in progress - dependencies on SIT F scenarios and cases
- 1557: work in progress - dependencies on SIT F scenarios and cases
- 1558: work in progress - dependencies on SIT F scenarios and cases. 10/11 - To go to TMAG for date change. Approved for date change at TMAG on 23/10/23. 21/2/24 - Forecast date is 28/3/24

| ID | WBS | Task | Type | Duration | Start | Finish | Predecessors | Baseline start | Baseline finish | Baseline duration | Baseline 1 start | Baseline 1 finish | Total slack | Free slack | Resources | Work | Responsible | Involved | Update Version | MHHS Programme Phase | Task Status | Sched Status | RAG | Text3 | Milestone ID | Text29 | Tier | Artefact ID |
| --- | --- | --- | --- | --- | --- | --- | --- | --- | --- | --- | --- | --- | --- | --- | --- | --- | --- | --- | --- | --- | --- | --- | --- | --- | --- | --- | --- | --- |
| 1564 | 1.6.4 | **PAB Support** |  | 340d | 2024-11-26 | 2026-03-16 |  | 2024-11-26 | 2026-03-16 | 340d | 2024-11-26 | 2026-03-16 | 314d |  | N/A | 2720h | N/A | N/A | 5.0 | Qualification |  |  |  |  |  |  |  |  |
| 1565 | 1.6.4.1 | Support PAB in Qualification setup, monitoring & reporting |  | 40d | 2024-11-26 | 2025-01-20 | 1569FS-40d | 2024-11-26 | 2025-01-20 | 40d | 2024-11-26 | 2025-01-20 | 614d |  |  |  | SI Test | Code Bodies | 5.0 | Qualification | 222.33 | Green | GREEN |  |  |  |  |  |
| 1566 | 1.6.4.2 | Support PAB throughout Qualification |  | 300d | 2025-01-21 | 2026-03-16 | 1569SS | 2025-01-21 | 2026-03-16 | 300d | 2025-01-21 | 2026-03-16 | 314d |  |  |  | SI Test | Code Bodies | 5.0 | Qualification | 278.33 | Green | GREEN |  |  |  |  |  |
| 1567 | 1.6.5 | **Qualification Testing Execution & PAB Approval (test execution schedule subject to Qualification Approach & Plan)** |  | 298d | 2025-01-20 | 2026-03-12 |  | 2025-01-20 | 2026-03-16 | 300d | 2025-01-20 | 2026-03-16 | -1d | 0d | N/A | 12448h | N/A | N/A | 5.0 | Qualification | M11 |  |  | D24B - Qualification Test Completion Report first draft |  |  |  |  |
| 1568 | 1.6.5.1 | **Qualification Testing Tranche 1** |  | 180d | 2025-01-20 | 2025-09-29 |  | 2025-01-20 | 2025-09-29 | 180d | 2025-01-20 | 2025-09-29 | -1d | 0d | N/A | 1440h | N/A | N/A | 5.0 | Qualification |  |  |  |  |  |  |  |  |
| 1569 | 1.6.5.1.1 | Qualification Testing Tranche 1 Start | milestone | 0d | 2025-01-20 | 2025-01-20 | 1046FS+1d | 2025-01-20 | 2025-01-20 | 0d | 2025-01-20 | 2025-01-20 | -1d | 0d |  |  | Code Bodies | PP,SI Test | 5.0 | Qualification | 277.71 | Green | GREEN |  | T3-QU-0028 | QAG | T3 |  |
| 1570 | 1.6.5.1.2 | Qualification Testing Tranche 1 End | milestone | 0d | 2025-08-04 | 2025-08-04 | 1569FS+140d | 2025-08-04 | 2025-08-04 | 0d | 2025-08-04 | 2025-08-04 | 2d | 0d |  |  | Code Bodies | PP,SI Test | 5.0 | Qualification | 473.71 | Green | GREEN |  | T3-QU-0054 | QAG | T3 |  |
| 1571 | 1.6.5.1.3 | BSC PAB & REC Manager approval of Qualification Testing Tranche 1 Completion (Start of Migration for Qualification Participants) | milestone | 0d | 2025-09-01 | 2025-09-01 | 1570FS+20d | 2025-09-01 | 2025-09-01 | 0d | 2025-09-01 | 2025-09-01 | 388d | 138d |  |  | Code Bodies | PP | 5.0 | Qualification | 501.71 | Green | GREEN |  | T2-QU-0150 | QAG | T2 | MHHS-ART073 |
| 1572 | 1.6.5.1.4 | Qualification Testing Tranche 1 Participants mobilise production environments |  | 40d | 2025-08-05 | 2025-09-29 | 1570 | 2025-08-05 | 2025-09-29 | 40d | 2025-08-05 | 2025-09-29 | 2d | 0d |  |  | PP | SI Test | 5.0 | Qualification | 474.33 | Green | GREEN |  |  |  |  |  |
| 1573 | 1.6.5.2 | **Qualification Testing Tranche 2** |  | 180d | 2025-02-17 | 2025-10-27 |  | 2025-02-17 | 2025-10-27 | 180d | 2025-02-17 | 2025-10-27 | -1d | 0d | N/A | 1440h | N/A | N/A | 5.0 | Qualification |  |  |  |  |  |  |  |  |
| 1574 | 1.6.5.2.1 | Qualification Testing Tranche 2 Start | milestone | 0d | 2025-02-17 | 2025-02-17 | 1569SS+20d | 2025-02-17 | 2025-02-17 | 0d | 2025-02-17 | 2025-02-17 | -1d | 0d |  |  | Code Bodies | PP,SI Test | 5.0 | Qualification | 305.71 | Green | GREEN |  | T3-QU-0034 | QAG | T3 | MHHS-ART073 |
| 1575 | 1.6.5.2.2 | Qualification Testing Tranche 2 End | milestone | 0d | 2025-09-01 | 2025-09-01 | 1574FS+140d | 2025-09-01 | 2025-09-01 | 0d | 2025-09-01 | 2025-09-01 | 368d | 0d |  |  | Code Bodies | PP,SI Test | 5.0 | Qualification | 501.71 | Green | GREEN |  | T3-QU-0055 | QAG | T3 |  |
| 1576 | 1.6.5.2.3 | BSC PAB & REC Manager approval of Qualification Testing Tranche 2 Completion | milestone | 0d | 2025-09-29 | 2025-09-29 | 1575FS+20d | 2025-09-29 | 2025-09-29 | 0d | 2025-09-29 | 2025-09-29 | 368d | 118d |  |  | Code Bodies | PP | 5.0 | Qualification | 529.71 | Green | GREEN |  | T2-QU-0200 | QAG | T2 | MHHS-ART073 |
| 1577 | 1.6.5.2.4 | Qualification Testing Tranche 2 Participants mobilise production environments |  | 40d | 2025-09-02 | 2025-10-27 | 1575 | 2025-09-02 | 2025-10-27 | 40d | 2025-09-02 | 2025-10-27 | 414d |  |  |  | PP | SI Test | 5.0 | Qualification | 502.33 | Green | GREEN |  |  |  |  |  |
| 1578 | 1.6.5.3 | **Qualification Testing Tranche 3** |  | 180d | 2025-03-17 | 2025-11-24 |  | 2025-03-17 | 2025-11-24 | 180d | 2025-03-17 | 2025-11-24 | -1d | 0d | N/A | 1440h | N/A | N/A | 5.0 | Qualification |  |  |  |  |  |  |  |  |
| 1579 | 1.6.5.3.1 | Qualification Testing Tranche 3 Start | milestone | 0d | 2025-03-17 | 2025-03-17 | 1574SS+20d | 2025-03-17 | 2025-03-17 | 0d | 2025-03-17 | 2025-03-17 | -1d | 0d |  |  | Code Bodies | PP,SI Test | 5.0 | Qualification | 333.71 | Green | GREEN |  | T3-QU-0039 | QAG | T3 | MHHS-ART073 |
| 1580 | 1.6.5.3.2 | Qualification Testing Tranche 3 End | milestone | 0d | 2025-09-29 | 2025-09-29 | 1579FS+140d | 2025-09-29 | 2025-09-29 | 0d | 2025-09-29 | 2025-09-29 | 348d | 0d |  |  | Code Bodies | PP,SI Test | 5.0 | Qualification | 529.71 | Green | GREEN |  | T3-QU-0056 | QAG | T3 |  |
| 1581 | 1.6.5.3.3 | BSC PAB & REC Manager approval of Qualification Testing Tranche 3 Completion | milestone | 0d | 2025-10-27 | 2025-10-27 | 1580FS+20d | 2025-10-27 | 2025-10-27 | 0d | 2025-10-27 | 2025-10-27 | 348d | 98d |  |  | Code Bodies | PP | 5.0 | Qualification | 557.71 | Green | GREEN |  | T2-QU-0250 | QAG | T2 | MHHS-ART073 |
| 1582 | 1.6.5.3.4 | Qualification Testing Tranche 3 Participants mobilise production environments |  | 40d | 2025-09-30 | 2025-11-24 | 1580 | 2025-09-30 | 2025-11-24 | 40d | 2025-09-30 | 2025-11-24 | 394d |  |  |  | PP | SI Test | 5.0 | Qualification | 530.33 | Green | GREEN |  |  |  |  |  |
| 1583 | 1.6.5.4 | **Qualification Testing Tranche 4** |  | 180d | 2025-04-14 | 2025-12-22 |  | 2025-04-14 | 2025-12-22 | 180d | 2025-04-14 | 2025-12-22 | -1d | 0d | N/A | 1440h | N/A | N/A | 5.0 | Qualification |  |  |  |  |  |  |  |  |
| 1584 | 1.6.5.4.1 | Qualification Testing Tranche 4 Start | milestone | 0d | 2025-04-14 | 2025-04-14 | 1579SS+20d | 2025-04-14 | 2025-04-14 | 0d | 2025-04-14 | 2025-04-14 | -1d | 0d |  |  | Code Bodies | PP,SI Test | 5.0 | Qualification | 361.71 | Green | GREEN |  | T3-QU-0044 | QAG | T3 | MHHS-ART073 |
| 1585 | 1.6.5.4.2 | Qualification Testing Tranche 4 End | milestone | 0d | 2025-10-27 | 2025-10-27 | 1584FS+140d | 2025-10-27 | 2025-10-27 | 0d | 2025-10-27 | 2025-10-27 | 328d | 0d |  |  | Code Bodies | PP,SI Test | 5.0 | Qualification | 557.71 | Green | GREEN |  | T3-QU-0057 | QAG | T3 |  |
| 1586 | 1.6.5.4.3 | BSC PAB & REC Manager approval of Qualification Testing Tranche 4 Completion | milestone | 0d | 2025-11-24 | 2025-11-24 | 1585FS+20d | 2025-11-24 | 2025-11-24 | 0d | 2025-11-24 | 2025-11-24 | 328d | 78d |  |  | Code Bodies | PP | 5.0 | Qualification | 585.71 | Green | GREEN |  | T2-QU-0300 | QAG | T2 | MHHS-ART073 |
| 1587 | 1.6.5.4.4 | Qualification Testing Tranche 4 Participants mobilise production environments |  | 40d | 2025-10-28 | 2025-12-22 | 1585 | 2025-10-28 | 2025-12-22 | 40d | 2025-10-28 | 2025-12-22 | 374d |  |  |  | PP | SI Test | 5.0 | Qualification | 558.33 | Green | GREEN |  |  |  |  |  |

| ID | WBS | Task | Type | Duration | Start | Finish | Predecessors | Baseline start | Baseline finish | Baseline duration | Baseline 1 start | Baseline 1 finish | Total slack | Free slack | Constraint | Resources | Work | Baseline cost | Responsible | Involved | Update Version | MHHS Programme Phase | Artefact ID | Task Status | Sched Status | RAG | Milestone ID | Text29 | Tier |
| --- | --- | --- | --- | --- | --- | --- | --- | --- | --- | --- | --- | --- | --- | --- | --- | --- | --- | --- | --- | --- | --- | --- | --- | --- | --- | --- | --- | --- | --- |
| 1588 | 1.6.5.5 | **Qualification Testing Tranche 5** |  | 180d | 2025-05-12 | 2026-01-19 |  | 2025-05-12 | 2026-01-19 | 180d | 2025-05-12 | 2026-01-19 | -1d | 0d |  | N/A | 1440h |  | N/A | N/A | 5.0 | Qualification |  |  |  |  |  |  |  |
| 1589 | 1.6.5.5.1 | Qualification Testing Tranche 5 Start | milestone | 0d | 2025-05-12 | 2025-05-12 | 1584SS+20d | 2025-05-12 | 2025-05-12 | 0d | 2025-05-12 | 2025-05-12 | -1d | 0d |  |  |  |  | Code Bodies | PP,SI Test | 5.0 | Qualification | MHHS-ART073 | 389.71 | Green | GREEN | T3-QU-0049 | QAG | T3 |
| 1590 | 1.6.5.5.2 | Qualification Testing Tranche 5 End | milestone | 0d | 2025-11-24 | 2025-11-24 | 1589FS+140d | 2025-11-24 | 2025-11-24 | 0d | 2025-11-24 | 2025-11-24 | 308d | 0d |  |  |  |  | Code Bodies | PP,SI Test | 5.0 | Qualification |  | 585.71 | Green | GREEN | T3-QU-0058 | QAG | T3 |
| 1591 | 1.6.5.5.3 | BSC PAB & REC Manager approval of Qualification Testing Tranche 5 Completion | milestone | 0d | 2025-12-22 | 2025-12-22 | 1590FS+20d | 2025-12-22 | 2025-12-22 | 0d | 2025-12-22 | 2025-12-22 | 308d | 58d |  |  |  |  | Code Bodies | PP | 5.0 | Qualification | MHHS-ART073 | 613.71 | Green | GREEN | T2-QU-0350 | QAG | T2 |
| 1592 | 1.6.5.5.4 | Qualification Testing Tranche 5 Participants mobilise production environments |  | 40d | 2025-11-25 | 2026-01-19 | 1590 | 2025-11-25 | 2026-01-19 | 40d | 2025-11-25 | 2026-01-19 | 354d |  |  |  |  |  | PP | SI Test | 5.0 | Qualification |  | 586.33 | Green | GREEN |  |  |  |
| 1593 | 1.6.5.6 | **Qualification Testing Tranche 6** |  | 180d | 2025-06-09 | 2026-02-16 |  | 2025-06-09 | 2026-02-16 | 180d | 2025-06-09 | 2026-02-16 | -1d | 0d |  | N/A | 1440h |  | N/A | N/A | 5.0 | Qualification |  |  |  |  |  |  |  |
| 1594 | 1.6.5.6.1 | Qualification Testing Tranche 6 Start | milestone | 0d | 2025-06-09 | 2025-06-09 | 1589SS+20d | 2025-06-09 | 2025-06-09 | 0d | 2025-06-09 | 2025-06-09 | -1d | 0d |  |  |  |  | Code Bodies | PP,SI Test | 5.0 | Qualification | MHHS-ART073 | 417.71 | Green | GREEN | T3-QU-0051 | QAG | T3 |
| 1595 | 1.6.5.6.2 | Qualification Testing Tranche 6 End | milestone | 0d | 2025-12-22 | 2025-12-22 | 1594FS+140d | 2025-12-22 | 2025-12-22 | 0d | 2025-12-22 | 2025-12-22 | 288d | 0d |  |  |  |  | Code Bodies | PP,SI Test | 5.0 | Qualification |  | 613.71 | Green | GREEN | T3-QU-0059 | QAG | T3 |
| 1596 | 1.6.5.6.3 | BSC PAB & REC Manager approval of Qualification Testing Tranche 6 Completion | milestone | 0d | 2026-01-19 | 2026-01-19 | 1595FS+20d | 2026-01-19 | 2026-01-19 | 0d | 2026-01-19 | 2026-01-19 | 288d | 38d |  |  |  |  | PP | SI Test | 5.0 | Qualification | MHHS-ART073 | 641.71 | Green | GREEN | T2-QU-0400 | QAG | T2 |
| 1597 | 1.6.5.6.4 | Qualification Testing Tranche 6 Participants mobilise production environments |  | 40d | 2025-12-23 | 2026-02-16 | 1595 | 2025-12-23 | 2026-02-16 | 40d | 2025-12-23 | 2026-02-16 | 334d |  |  |  |  |  | Code Bodies | PP,SI Test | 5.0 | Qualification |  | 614.33 | Green | GREEN |  |  |  |
| 1598 | 1.6.5.7 | **Qualification Testing Tranche 7** |  | 178d | 2025-07-07 | 2026-03-12 |  | 2025-07-07 | 2026-03-16 | 180d | 2025-07-07 | 2026-03-16 | -1d | 0d |  | N/A | 1424h |  | N/A | N/A | 5.0 | Qualification |  |  |  |  |  |  |  |
| 1599 | 1.6.5.7.1 | Qualification Testing Tranche 7 Start | milestone | 0d | 2025-07-07 | 2025-07-07 | 1594SS+20d | 2025-07-07 | 2025-07-07 | 0d | 2025-07-07 | 2025-07-07 | -1d | 0d |  |  |  |  | Code Bodies | PP,SI Test | 5.0 | Qualification | MHHS-ART073 | 445.71 | Green | GREEN | T3-QU-0053 | QAG | T3 |
| 1600 | 1.6.5.7.2 | Qualification Testing Tranche 7 End | milestone | 0d | 2026-01-19 | 2026-01-19 | 1599FS+140d | 2026-01-19 | 2026-01-19 | 0d | 2026-01-19 | 2026-01-19 | 250d | 0d |  |  |  |  | Code Bodies | PP,SI Test | 5.0 | Qualification |  | 641.71 | Green | GREEN | T3-QU-0060 | QAG | T3 |
| 1601 | 1.6.5.7.3 | BSC PAB & REC Manager approval of Qualification Testing Tranche 7 Completion | milestone | 0d | 2026-02-16 | 2026-02-16 | 1600FS+20d | 2026-02-16 | 2026-02-16 | 0d | 2026-02-16 | 2026-02-16 | 268d | 18d |  |  |  |  | PP | SI Test | 5.0 | Qualification | MHHS-ART073 | 669.71 | Green | GREEN | T2-QU-0450 | QAG | T2 |
| 1602 | 1.6.5.7.4 | Qualification Testing Tranche 7 Participants mobilise production environments |  | 38d | 2026-01-20 | 2026-03-12 | 1600 | 2026-01-20 | 2026-03-16 | 40d | 2026-01-20 | 2026-03-16 | 250d | 0d |  |  |  |  | Code Bodies | PP,SI Test | 5.0 | Qualification |  | 642.33 | Green | GREEN |  |  |  |
| 1603 | 1.6.5.8 | Qualification Testing Monitoring |  | 260d | 2025-01-21 | 2026-01-19 |  | 2025-01-21 | 2026-01-19 | 260d | 2025-01-21 | 2026-01-19 | 354d |  | start no earlier than 2025-01-21 |  |  |  | SI Test | PP,Code Bodies | 5.0 | Qualification |  | 278.33 | Green | GREEN |  |  |  |
| 1604 | 1.6.6 | **BSC PAB & REC Manager sign-off of qualified SIT participants for Migration** |  | 290d | 2024-04-22 | 2025-05-30 |  | 2024-02-19 | 2025-05-30 | 335d | 2024-02-19 | 2025-05-30 | 520d |  |  | N/A | 4640h | -0 | N/A | N/A | 5.0 | Qualification |  |  |  |  |  |  |  |
| 1605 | 1.6.6.1 | **Qualification Testing Tranche 0** |  | 290d | 2024-04-22 | 2025-05-30 |  | 2024-02-19 | 2025-05-30 | 335d | 2024-02-19 | 2025-05-30 | 520d |  |  | N/A | 2320h | -0 | N/A | N/A | 5.0 | Qualification |  |  |  |  |  |  |  |
| 1606 | 1.6.6.1.1 | Tranche 0 QAD completion and assurance |  | 182d | 2024-04-22 | 2024-12-31 | 1562SS | 2024-02-19 | 2024-10-29 | 182d | 2024-02-19 | 2024-10-29 | 628d |  |  |  |  |  | Code Bodies |  | 5.0 | Qualification |  | 4.33 | Red | RED |  |  |  |
| 1607 | 1.6.6.1.2 | Qualification Testing Tranche 0 SIT MVC completion report review |  | 26d | 2025-02-07 | 2025-03-14 | 1077 | 2025-02-10 | 2025-03-17 | 26d | 2025-02-07 | 2025-03-14 | 566d | 0d |  |  |  |  | Code Bodies |  | 5.0 | Qualification |  | 295.33 | Green | GREEN |  |  |  |
| 1608 | 1.6.6.1.3 | Qualification Testing Tranche 0 End for SIT MVC | milestone | 0d | 2025-03-14 | 2025-03-14 | 1757FS+5d, 1607 | 2025-03-17 | 2025-03-17 | 0d | 2025-03-14 | 2025-03-14 | 566d | 0d |  |  |  |  | Code Bodies |  | 5.0 | Qualification |  | 330.71 | Green | GREEN |  |  |  |
| 1609 | 1.6.6.1.4 | Qualification Testing Tranche 0 SIT non-MVC completion report review |  | 30d | 2025-04-21 | 2025-05-30 | 1125 | 2025-04-21 | 2025-05-30 | 30d | 2025-04-21 | 2025-05-30 | 520d | 0d |  |  |  |  | Code Bodies |  | 5.0 | Qualification |  | 368.33 | Green | GREEN |  |  |  |
| 1610 | 1.6.6.1.5 | Qualification Testing Tranche 0 End for SIT non-MVC | milestone | 0d | 2025-05-30 | 2025-05-30 | 1609 | 2025-05-30 | 2025-05-30 | 0d | 2025-05-30 | 2025-05-30 | 520d |  |  |  |  |  | Code Bodies |  | 5.0 | Qualification |  | 407.71 | Green | GREEN |  |  |  |
| 1611 | 1.6.6.1.6 | BSC PAB & REC Code Manager sign-off of qualified SIT participants for Migration (post-M8 & pre-M11) | milestone | 0d | 2025-03-14 | 2025-03-14 | 1608, 1607 | 2025-03-14 | 2025-03-14 | 0d | 2025-03-14 | 2025-03-14 | 566d | 0d |  |  |  |  | Code Bodies | PP | 5.0 | Qualification |  | 330.71 | Green | GREEN | T2-QU-0100 | QAG | T2 |

| ID | WBS | Task | Type | Duration | Start | Finish | Predecessors | Complete | Remaining | Baseline start | Baseline finish | Baseline duration | Baseline 1 start | Baseline 1 finish | Total slack | Constraint | Resources | Work | Actual work | Baseline cost | Responsible | Involved | Update Version | MHHS Programme Phase | Task Status | Sched Status | RAG | Artefact ID | Milestone ID | Text29 | Tier |
| --- | --- | --- | --- | --- | --- | --- | --- | --- | --- | --- | --- | --- | --- | --- | --- | --- | --- | --- | --- | --- | --- | --- | --- | --- | --- | --- | --- | --- | --- | --- | --- |
| 1612 | 1.6.7 | **Qualification PPs E2E Sandbox Execution** |  | 368d | 2025-08-05 | 2026-12-31 |  |  |  | 2025-08-05 | 2026-12-31 | 368d | 2025-08-05 | 2026-12-31 | 106d |  | N/A | 2944h |  |  | N/A | N/A | 5.0 | Qualification |  |  |  |  |  |  |  |
| 1613 | 1.6.7.1 | Qualification PPs E2E Sandbox Testing Execution |  | 368d | 2025-08-05 | 2026-12-31 | 1570 |  |  | 2025-08-05 | 2026-12-31 | 368d | 2025-08-05 | 2026-12-31 | 106d |  |  |  |  |  | PP | SI Test | 5.0 | Qualification | 474.33 | Green | GREEN |  |  |  |  |
| 1614 | 1.7 | **REGULATORY** |  | 680d | 2022-10-31 A | 2025-06-06 |  | 80% | 133.48d | 2022-10-31 | 2025-06-06 | 680d | 2022-10-31 | 2025-03-07 | 515d |  | N/A | 52652.5h | 28143h | -0 | N/A | N/A |  | Regulatory |  |  |  |  |  |  |  |
| 1615 | 1.7.1 | **Baseline MHHS Code Changes** |  | 475d | 2022-10-31 A | 2024-08-23 |  | 94% | 28.93d | 2022-10-31 | 2024-08-23 | 475d | 2022-10-31 | 2024-08-23 | 720d |  | N/A | 35148.5h | 26113.5h | -0 | N/A | N/A | 5.0 | Regulatory |  |  |  |  |  |  |  |
| 1616 | 1.7.1.1 | **Preparation and planning** |  | 35d | 2022-10-31 A | 2022-12-16 A |  | 100% |  | 2022-10-31 | 2022-12-16 | 35d | 2022-10-31 | 2022-12-16 |  |  | N/A | 1000h | 1000h |  | N/A | N/A | 5.0 | Regulatory |  |  |  |  |  |  |  |
| 1617 | 1.7.1.1.1 | Impact assessment of Programme design on codes to determine required changes |  | 20d | 2022-10-31 A | 2022-11-25 A | 48 | 100% |  | 2022-10-31 | 2022-11-25 | 20d | 2022-10-31 | 2022-11-25 |  |  | Andrew Margan | 160h | 160h |  | Code Bodies,SRO Code Drafters | Code Drafting PM | 5.0 | Regulatory |  | Complete | COMPLETE |  |  |  |  |
| 1618 | 1.7.1.1.2 | Become 'code draft ready' |  | 35d | 2022-10-31 A | 2022-12-16 A |  | 100% |  | 2022-10-31 | 2022-12-16 | 35d | 2022-10-31 | 2022-12-16 |  |  | Andrew Margan | 280h | 280h |  | Code Bodies,SRO Code Drafters | Code Drafting PM | 5.0 | Regulatory |  | Complete | COMPLETE |  |  |  |  |
| 1619 | 1.7.1.1.3 | Soft start drafting where possible |  | 35d | 2022-10-31 A | 2022-12-16 A |  | 100% |  | 2022-10-31 | 2022-12-16 | 35d | 2022-10-31 | 2022-12-16 |  |  | Andrew Margan | 280h | 280h |  | Code Bodies,SRO Code Drafters | Code Drafting PM | 5.0 | Regulatory |  | Complete | COMPLETE |  |  |  |  |
| 1620 | 1.7.1.2 | **Code drafting** |  | 445d | 2022-12-12 A | 2024-08-23 |  | 94% | 28.41d | 2022-12-12 | 2024-08-23 | 445d | 2022-12-12 | 2024-08-23 | 720d |  | N/A | 30348.5h | 24953.5h | -0 | N/A | N/A | 5.0 | Regulatory | M6 |  |  |  |  |  |  |
| 1621 | 1.7.1.2.1 | **Data Services (BSC driven)** |  | 118d | 2022-12-12 A | 2023-05-24 A |  | 100% |  | 2022-12-12 | 2023-05-24 | 118d | 2022-12-12 | 2023-05-24 |  |  | N/A | 1816h | 1816h |  | N/A | N/A | 5.0 | Regulatory | M6 |  |  |  |  |  |  |
| 1622 | 1.7.1.2.1.1 | Pre Code Drafting activities |  | 5d | 2022-12-12 A | 2022-12-16 A |  | 100% |  | 2022-12-12 | 2022-12-16 | 5d | 2022-12-12 | 2022-12-16 |  | start no earlier than 2022-12-12 | Andrew Margan | 40h | 40h |  | Code Drafting PM |  | 5.0 | Regulatory |  | Complete | COMPLETE |  |  |  |  |
| 1623 | 1.7.1.2.1.2 | Code and subsidiary document drafting takes place offline |  | 19d | 2023-01-03 A | 2023-01-27 A | 1622FS+11d | 100% |  | 2023-01-03 | 2023-01-27 | 19d | 2023-01-03 | 2023-01-27 |  |  | Andrew Margan | 152h | 152h |  | Code Bodies,SRO Design | Code Drafting PM | 5.0 | Regulatory |  | Complete | COMPLETE |  |  |  |  |
| 1624 | 1.7.1.2.1.3 | Internal review and cross-checking of drafting across code drafters |  | 11d | 2023-01-30 A | 2023-02-13 A | 1623 | 100% |  | 2023-01-30 | 2023-02-13 | 11d | 2023-01-30 | 2023-02-13 |  |  | Andrew Margan | 88h | 88h |  | Code Bodies,SRO Design | Code Drafting PM | 5.0 | Regulatory |  | Complete | COMPLETE |  |  |  |  |
| 1625 | 1.7.1.2.1.4 | External industry review via consultation |  | 20d | 2023-02-14 A | 2023-03-13 A | 1624 | 100% |  | 2023-02-14 | 2023-03-13 | 20d | 2023-02-14 | 2023-03-13 |  |  | Andrew Margan | 160h | 160h |  | PP | Code Drafting PM | 5.0 | Regulatory |  | Complete | COMPLETE |  |  |  |  |
| 1626 | 1.7.1.2.1.5 | Triage and action comments |  | 19d | 2023-03-10 A | 2023-04-05 A | 1625FS-2d | 100% |  | 2023-03-10 | 2023-04-05 | 19d | 2023-03-10 | 2023-04-05 |  |  | Andrew Margan | 152h | 152h |  | Code Bodies,SRO Design | Code Drafting PM | 5.0 | Regulatory |  | Complete | COMPLETE |  |  |  |  |
| 1627 | 1.7.1.2.1.6 | CDWG review |  | 30d | 2023-04-06 A | 2023-05-17 A | 1626 | 100% |  | 2023-04-06 | 2023-05-17 | 30d | 2023-04-06 | 2023-05-17 |  |  | Andrew Margan | 240h | 240h |  | PP | Code Drafting PM | 5.0 | Regulatory |  | Complete | COMPLETE |  |  |  |  |
| 1628 | 1.7.1.2.1.7 | CCAG review |  | 5d | 2023-05-18 A | 2023-05-24 A | 1627 | 100% |  | 2023-05-18 | 2023-05-24 | 5d | 2023-05-18 | 2023-05-24 |  |  | Andrew Margan | 40h | 40h |  | PP |  | 5.0 | Regulatory |  | Complete | COMPLETE |  |  |  |  |
| 1629 | 1.7.1.2.1.8 | Code drafting for Data Services topic area approved | milestone | 0d | 2023-05-24 A | 2023-05-24 A | 1628 | 100% |  | 2023-05-24 | 2023-05-24 | 0d | 2023-05-24 | 2023-05-24 |  |  | Andrew Margan |  |  |  | PP | Code Drafting PM | 5.0 | Regulatory |  | Complete | COMPLETE | MHHS-ART060 | T2-RE-0100 | CCAG | T2 |
| 1630 | 1.7.1.2.2 | **Metering (REC driven)** |  | 118d | 2022-12-12 A | 2023-05-24 A |  | 100% |  | 2022-12-12 | 2023-05-24 | 118d | 2022-12-12 | 2023-05-24 |  |  | N/A | 1816h | 1816h |  | N/A | N/A | 5.0 | Regulatory | M6 |  |  |  |  |  |  |
| 1631 | 1.7.1.2.2.1 | Pre Code Drafting activities |  | 5d | 2022-12-12 A | 2022-12-16 A | 1622SS | 100% |  | 2022-12-12 | 2022-12-16 | 5d | 2022-12-12 | 2022-12-16 |  |  | Andrew Margan | 40h | 40h |  | Code Drafting PM |  | 5.0 | Regulatory |  | Complete | COMPLETE |  |  |  |  |
| 1632 | 1.7.1.2.2.2 | Code and subsidiary document drafting takes place offline |  | 19d | 2023-01-03 A | 2023-01-27 A | 1631FS+11d | 100% |  | 2023-01-03 | 2023-01-27 | 19d | 2023-01-03 | 2023-01-27 |  |  | Andrew Margan | 152h | 152h |  | Code Bodies,SRO Design | Code Drafting PM | 5.0 | Regulatory |  | Complete | COMPLETE |  |  |  |  |
| 1633 | 1.7.1.2.2.3 | Internal review and cross-checking of drafting across code drafters |  | 11d | 2023-01-30 A | 2023-02-13 A | 1632 | 100% |  | 2023-01-30 | 2023-02-13 | 11d | 2023-01-30 | 2023-02-13 |  |  | Andrew Margan | 88h | 88h |  | Code Bodies,SRO Design | Code Drafting PM | 5.0 | Regulatory |  | Complete | COMPLETE |  |  |  |  |
| 1634 | 1.7.1.2.2.4 | External industry review via consultation |  | 20d | 2023-02-14 A | 2023-03-13 A | 1633 | 100% |  | 2023-02-14 | 2023-03-13 | 20d | 2023-02-14 | 2023-03-13 |  |  | Andrew Margan | 160h | 160h |  | PP | Code Drafting PM | 5.0 | Regulatory |  | Complete | COMPLETE |  |  |  |  |
| 1635 | 1.7.1.2.2.5 | Triage and action comments |  | 19d | 2023-03-10 A | 2023-04-05 A | 1634FS-2d | 100% |  | 2023-03-10 | 2023-04-05 | 19d | 2023-03-10 | 2023-04-05 |  |  | Andrew Margan | 152h | 152h |  | Code Bodies,SRO Design | Code Drafting PM | 5.0 | Regulatory |  | Complete | COMPLETE |  |  |  |  |
| 1636 | 1.7.1.2.2.6 | CDWG review |  | 30d | 2023-04-06 A | 2023-05-17 A | 1635 | 100% |  | 2023-04-06 | 2023-05-17 | 30d | 2023-04-06 | 2023-05-17 |  |  | Andrew Margan | 240h | 240h |  | PP | Code Drafting PM | 5.0 | Regulatory |  | Complete | COMPLETE |  |  |  |  |
| 1637 | 1.7.1.2.2.7 | CCAG review |  | 5d | 2023-05-18 A | 2023-05-24 A | 1636 | 100% |  | 2023-05-18 | 2023-05-24 | 5d | 2023-05-18 | 2023-05-24 |  |  | Andrew Margan | 40h | 40h |  | PP |  | 5.0 | Regulatory |  | Complete | COMPLETE |  |  |  |  |
| 1638 | 1.7.1.2.2.8 | Code drafting for Metering topic area approved | milestone | 0d | 2023-05-24 A | 2023-05-24 A | 1637 | 100% |  | 2023-05-24 | 2023-05-24 | 0d | 2023-05-24 | 2023-05-24 |  |  | Andrew Margan |  |  |  | PP | Code Drafting PM | 5.0 | Regulatory |  | Complete | COMPLETE | MHHS-ART060 | T2-RE-0150 | CCAG | T2 |

| ID | WBS | Task | Type | Duration | Start | Finish | Predecessors | Complete | Baseline start | Baseline finish | Baseline duration | Baseline 1 start | Baseline 1 finish | Constraint | Resources | Work | Actual work | Responsible | Involved | Task Status | Update Version | MHHS Programme Phase | Sched Status | RAG | Artefact ID | Milestone ID | Text29 | Tier |
| --- | --- | --- | --- | --- | --- | --- | --- | --- | --- | --- | --- | --- | --- | --- | --- | --- | --- | --- | --- | --- | --- | --- | --- | --- | --- | --- | --- | --- |
| 1639 | 1.7.1.2.3 | **BSC Central Services (BSC driven)** |  | 156d | 2023-02-22 A | 2023-09-27 A |  | 100% | 2023-02-22 | 2023-09-27 | 156d | 2023-02-22 | 2023-09-14 |  | N/A | 3072h | 3072h | N/A | N/A | M6 | 5.0 | Regulatory |  |  |  |  |  |  |
| 1640 | 1.7.1.2.3.1 | Pre Code Drafting activities |  | 5d | 2023-02-22 A | 2023-02-28 A | 1641SS-5d | 100% | 2023-02-22 | 2023-02-28 | 5d | 2023-02-22 | 2023-02-28 |  | Andrew Margan | 40h | 40h | Code Drafting PM |  |  | 5.0 | Regulatory | Complete | COMPLETE |  |  |  |  |
| 1641 | 1.7.1.2.3.2 | Code Drafting (offline) |  | 80d | 2023-03-01 A | 2023-06-20 A | 1625SS | 100% | 2023-03-01 | 2023-06-20 | 80d | 2023-03-01 | 2023-06-20 | must start on 2023-03-01 | Andrew Margan | 640h | 640h | Code Bodies,SRO Design | Code Drafting PM |  | 5.0 | Regulatory | Complete | COMPLETE |  |  |  |  |
| 1642 | 1.7.1.2.3.3 | Internal review and cross-checking of drafting across code drafters |  | 70d | 2023-03-15 A | 2023-06-20 A | 1641SS+10d | 100% | 2023-03-15 | 2023-06-20 | 70d | 2023-03-15 | 2023-06-20 |  | Andrew Margan | 560h | 560h | Code Bodies,SRO Design | Code Drafting PM |  | 5.0 | Regulatory | Complete | COMPLETE |  |  |  |  |
| 1643 | 1.7.1.2.3.4 | External industry review via consultation |  | 15d | 2023-06-21 A | 2023-07-11 A | 1642 | 100% | 2023-06-21 | 2023-07-11 | 15d | 2023-06-21 | 2023-07-11 |  | Andrew Margan | 120h | 120h | PP | Code Drafting PM |  | 5.0 | Regulatory | Complete | COMPLETE |  |  |  |  |
| 1644 | 1.7.1.2.3.5 | Triage and action comments |  | 19d | 2023-07-10 A | 2023-08-03 A | 1643FS-2d | 100% | 2023-07-10 | 2023-08-03 | 19d | 2023-07-10 | 2023-08-03 |  | Andrew Margan | 152h | 152h | Code Bodies,SRO Design | Code Drafting PM |  | 5.0 | Regulatory | Complete | COMPLETE |  |  |  |  |
| 1645 | 1.7.1.2.3.6 | CDWG review |  | 28d | 2023-08-04 A | 2023-09-12 A | 1644 | 100% | 2023-08-04 | 2023-09-12 | 28d | 2023-08-04 | 2023-09-07 |  | Andrew Margan | 224h | 224h | PP | Code Drafting PM |  | 5.0 | Regulatory | Complete | COMPLETE |  |  |  |  |
| 1646 | 1.7.1.2.3.7 | CCAG review |  | 11d | 2023-09-13 A | 2023-09-27 A | 1645 | 100% | 2023-09-13 | 2023-09-27 | 11d | 2023-09-08 | 2023-09-14 |  | Andrew Margan | 88h | 88h | PP |  |  | 5.0 | Regulatory | Complete | COMPLETE |  |  |  |  |
| 1647 | 1.7.1.2.3.8 | Code drafting for BSC Central Services topic area approved | milestone | 0d | 2023-09-27 A | 2023-09-27 A | 1646 | 100% | 2023-09-27 | 2023-09-27 | 0d | 2023-09-14 | 2023-09-14 |  | Andrew Margan |  |  | PP | Code Drafting PM |  | 5.0 | Regulatory | Complete | COMPLETE | MHHS-ART060 | T2-RE-0200 | CCAG | T2 |
| 1648 | 1.7.1.2.4 | **Registration (BSC & REC driven)** |  | 131d | 2023-02-22 A | 2023-08-23 A |  | 100% | 2023-02-22 | 2023-08-23 | 131d | 2023-02-22 | 2023-08-23 |  | N/A | 2552h | 2552h | N/A | N/A | M6 | 5.0 | Regulatory |  |  |  |  |  |  |
| 1649 | 1.7.1.2.4.1 | Pre Code Drafting activities |  | 5d | 2023-02-22 A | 2023-02-28 A | 1650SS-5d | 100% | 2023-02-22 | 2023-02-28 | 5d | 2023-02-22 | 2023-02-28 |  | Andrew Margan | 40h | 40h | Code Drafting PM |  |  | 5.0 | Regulatory | Complete | COMPLETE |  |  |  |  |
| 1650 | 1.7.1.2.4.2 | Code Drafting (offline) |  | 65d | 2023-03-01 A | 2023-05-30 A | 1624, 1633 | 100% | 2023-03-01 | 2023-05-30 | 65d | 2023-03-01 | 2023-05-30 | must start on 2023-03-01 | Andrew Margan | 520h | 520h | Code Bodies,SRO Design | Code Drafting PM |  | 5.0 | Regulatory | Complete | COMPLETE |  |  |  |  |
| 1651 | 1.7.1.2.4.3 | Internal review and cross-checking of drafting across code drafters |  | 55d | 2023-03-15 A | 2023-05-30 A | 1650SS+10d | 100% | 2023-03-15 | 2023-05-30 | 55d | 2023-03-15 | 2023-05-30 |  | Andrew Margan | 440h | 440h | Code Bodies,SRO Design | Code Drafting PM |  | 5.0 | Regulatory | Complete | COMPLETE |  |  |  |  |
| 1652 | 1.7.1.2.4.4 | External industry review via consultation |  | 15d | 2023-05-31 A | 2023-06-20 A | 1651 | 100% | 2023-05-31 | 2023-06-20 | 15d | 2023-05-31 | 2023-06-20 |  | Andrew Margan | 120h | 120h | PP | Code Drafting PM |  | 5.0 | Regulatory | Complete | COMPLETE |  |  |  |  |
| 1653 | 1.7.1.2.4.5 | Triage and action comments |  | 19d | 2023-06-19 A | 2023-07-13 A | 1652FS-2d | 100% | 2023-06-19 | 2023-07-13 | 19d | 2023-06-19 | 2023-07-13 |  | Andrew Margan | 152h | 152h | Code Bodies,SRO Design | Code Drafting PM |  | 5.0 | Regulatory | Complete | COMPLETE |  |  |  |  |
| 1654 | 1.7.1.2.4.6 | CDWG review |  | 18d | 2023-07-14 A | 2023-08-08 A | 1653 | 100% | 2023-07-14 | 2023-08-08 | 18d | 2023-07-14 | 2023-08-16 |  | Andrew Margan | 144h | 144h | PP | Code Drafting PM |  | 5.0 | Regulatory | Complete | COMPLETE |  |  |  |  |
| 1655 | 1.7.1.2.4.7 | CCAG review |  | 11d | 2023-08-09 A | 2023-08-23 A | 1654 | 100% | 2023-08-09 | 2023-08-23 | 11d | 2023-08-17 | 2023-08-23 |  | Andrew Margan | 88h | 88h | PP |  |  | 5.0 | Regulatory | Complete | COMPLETE |  |  |  |  |
| 1656 | 1.7.1.2.4.8 | Code drafting for Registration topic area approved | milestone | 0d | 2023-08-23 A | 2023-08-23 A | 1655 | 100% | 2023-08-23 | 2023-08-23 | 0d | 2023-08-23 | 2023-08-23 |  | Andrew Margan |  |  | PP | Code Drafting PM |  | 5.0 | Regulatory | Complete | COMPLETE | MHHS-ART060 | T2-RE-0250 | CCAG | T2 |
| 1657 | 1.7.1.2.5 | **Governance and Qualification (BSC & REC driven)** |  | 130d | 2023-05-25 A | 2023-11-22 A |  | 100% | 2023-05-25 | 2023-11-22 | 130d | 2023-05-25 | 2023-11-13 |  | N/A | 2448h | 2448h | N/A | N/A | M6 | 5.0 | Regulatory |  |  |  |  |  |  |
| 1658 | 1.7.1.2.5.1 | Pre Code Drafting activities |  | 5d | 2023-05-25 A | 2023-05-31 A | 1659SS-5d | 100% | 2023-05-25 | 2023-05-31 | 5d | 2023-05-25 | 2023-05-31 |  | Andrew Margan | 40h | 40h | Code Drafting PM |  |  | 5.0 | Regulatory | Complete | COMPLETE |  |  |  |  |
| 1659 | 1.7.1.2.5.2 | Code Drafting (offline) |  | 55d | 2023-06-01 A | 2023-08-16 A | 1652SS+1d | 100% | 2023-06-01 | 2023-08-16 | 55d | 2023-06-01 | 2023-08-16 |  | Andrew Margan | 440h | 440h | Code Bodies,SRO Design | Code Drafting PM |  | 5.0 | Regulatory | Complete | COMPLETE |  |  |  |  |
| 1660 | 1.7.1.2.5.3 | Internal review and cross-checking of drafting across code drafters |  | 45d | 2023-06-15 A | 2023-08-16 A | 1659SS+10d | 100% | 2023-06-15 | 2023-08-16 | 45d | 2023-06-15 | 2023-08-16 |  | Andrew Margan | 360h | 360h | Code Bodies,SRO Design | Code Drafting PM |  | 5.0 | Regulatory | Complete | COMPLETE |  |  |  |  |
| 1661 | 1.7.1.2.5.4 | External industry review via consultation |  | 15d | 2023-08-18 A | 2023-09-07 A | 1660FS+1d | 100% | 2023-08-18 | 2023-09-07 | 15d | 2023-08-18 | 2023-09-07 |  | Andrew Margan | 120h | 120h | PP | Code Drafting PM |  | 5.0 | Regulatory | Complete | COMPLETE |  |  |  |  |
| 1662 | 1.7.1.2.5.5 | Triage and action comments |  | 19d | 2023-09-06 A | 2023-10-02 A | 1661FS-2d | 100% | 2023-09-06 | 2023-10-02 | 19d | 2023-09-06 | 2023-10-02 |  | Andrew Margan | 152h | 152h | Code Bodies,SRO Design | Code Drafting PM |  | 5.0 | Regulatory | Complete | COMPLETE |  |  |  |  |
| 1663 | 1.7.1.2.5.6 | CDWG review |  | 31d | 2023-10-03 A | 2023-11-14 A | 1662 | 100% | 2023-10-03 | 2023-11-14 | 31d | 2023-10-03 | 2023-11-06 |  | Andrew Margan | 248h | 248h | PP | Code Drafting PM |  | 5.0 | Regulatory | Complete | COMPLETE |  |  |  |  |
| 1664 | 1.7.1.2.5.7 | CCAG review |  | 6d | 2023-11-15 A | 2023-11-22 A | 1663 | 100% | 2023-11-15 | 2023-11-22 | 6d | 2023-11-07 | 2023-11-13 |  | Andrew Margan | 48h | 48h | PP |  |  | 5.0 | Regulatory | Complete | COMPLETE |  |  |  |  |
| 1665 | 1.7.1.2.5.8 | Code drafting for Governance and Qualification topic areas approved | milestone | 0d | 2023-11-22 A | 2023-11-22 A | 1664 | 100% | 2023-11-22 | 2023-11-22 | 0d | 2023-11-13 | 2023-11-13 |  | Andrew Margan |  |  | PP | Code Drafting PM |  | 5.12 | Regulatory | Complete | COMPLETE | MHHS-ART060 | T3-RE-0300 | CCAG | T2 |

Notes:
- 1665: 10/10 - CH - Agreed at PSG on 4/10 to downgrade from T2 to T3

| ID | WBS | Task | Type | Duration | Start | Finish | Predecessors | Complete | Remaining | Baseline start | Baseline finish | Baseline duration | Baseline 1 start | Baseline 1 finish | Total slack | Constraint | Resources | Work | Actual work | Baseline cost | Responsible | Involved | Task Status | Update Version | MHHS Programme Phase | Sched Status | RAG | Artefact ID | Milestone ID | Text29 | Tier |
| --- | --- | --- | --- | --- | --- | --- | --- | --- | --- | --- | --- | --- | --- | --- | --- | --- | --- | --- | --- | --- | --- | --- | --- | --- | --- | --- | --- | --- | --- | --- | --- |
| 1666 | 1.7.1.2.6 | **Interfaces / Data Specification (REC driven)** |  | 174d | 2023-05-25 A | 2024-01-23 A |  | 100% |  | 2023-05-25 | 2024-01-24 | 175d | 2023-05-25 | 2023-11-13 |  |  | N/A | 3472h | 3472h |  | N/A | N/A | M6 | 5.2 | Regulatory |  |  |  |  |  |  |
| 1667 | 1.7.1.2.6.1 | Pre Code Drafting activities |  | 5d | 2023-05-25 A | 2023-05-31 A | 1668SS-5d | 100% |  | 2023-05-25 | 2023-05-31 | 5d | 2023-05-25 | 2023-05-31 |  |  | Andrew Margan | 40h | 40h |  | Code Drafting PM |  |  | 5.0 | Regulatory | Complete | COMPLETE |  |  |  |  |
| 1668 | 1.7.1.2.6.2 | Code Drafting (offline) |  | 94d | 2023-06-01 A | 2023-10-10 A | 1652SS+1d | 100% |  | 2023-06-01 | 2023-10-10 | 94d | 2023-06-01 | 2023-08-16 |  |  | Andrew Margan | 752h | 752h |  | Code Bodies,SRO Design | Code Drafting PM |  | 5.2 | Regulatory | Complete | COMPLETE |  |  |  |  |
| 1669 | 1.7.1.2.6.3 | Internal review and cross-checking of drafting across code drafters |  | 84d | 2023-06-15 A | 2023-10-10 A | 1668SS+10d | 100% |  | 2023-06-15 | 2023-10-10 | 84d | 2023-06-15 | 2023-08-16 |  |  | Andrew Margan | 672h | 672h |  | Code Bodies,SRO Design | Code Drafting PM |  | 5.2 | Regulatory | Complete | COMPLETE |  |  |  |  |
| 1670 | 1.7.1.2.6.4 | External industry review via consultation |  | 15d | 2023-10-11 A | 2023-10-31 A | 1669 | 100% |  | 2023-10-11 | 2023-10-31 | 15d | 2023-08-18 | 2023-09-07 |  |  | Andrew Margan | 120h | 120h |  | PP | Code Drafting PM |  | 5.2 | Regulatory | Complete | COMPLETE |  |  |  |  |
| 1671 | 1.7.1.2.6.5 | Triage and action comments |  | 20d | 2023-10-30 A | 2023-11-24 A | 1670FS-2d | 100% |  | 2023-10-30 | 2023-11-24 | 20d | 2023-09-06 | 2023-10-02 |  |  | Andrew Margan | 160h | 160h |  | Code Bodies,SRO Design | Code Drafting PM |  | 5.2 | Regulatory | Complete | COMPLETE |  |  |  |  |
| 1672 | 1.7.1.2.6.6 | CDWG review |  | 37d | 2023-11-27 A | 2024-01-16 A | 1671 | 100% |  | 2023-11-27 | 2024-01-09 | 32d | 2023-10-03 | 2023-11-06 |  |  | Andrew Margan | 296h | 296h |  | PP | Code Drafting PM |  | 5.2 | Regulatory | Complete | COMPLETE |  |  |  |  |
| 1673 | 1.7.1.2.6.7 | CCAG review |  | 5d | 2024-01-17 A | 2024-01-23 A | 1672 | 100% |  | 2024-01-10 | 2024-01-24 | 11d | 2023-11-07 | 2023-11-13 |  |  | Andrew Margan | 40h | 40h |  | PP | Code Drafting PM |  | 5.2 | Regulatory | Complete | COMPLETE |  |  |  |  |
| 1674 | 1.7.1.2.6.8 | Code drafting for Interfaces / Data Specification topic areas approved | milestone | 0d | 2024-01-23 A | 2024-01-23 A | 1673 | 100% |  | 2024-01-24 | 2024-01-24 | 0d | 2023-11-13 | 2023-11-13 |  |  | Andrew Margan |  |  |  | PP | Code Drafting PM |  | 5.16 | Regulatory | Complete | COMPLETE | MHHS-ART060 | T3-RE-0350 | CCAG | T2 |
| 1675 | 1.7.1.2.7 | **Migration (BSC & REC driven)** |  | 130d | 2023-05-25 A | 2023-11-22 A |  | 100% |  | 2023-05-25 | 2023-11-22 | 130d | 2023-05-25 | 2023-11-13 |  |  | N/A | 2448h | 2448h |  | N/A | N/A | M6 | 5.0 | Regulatory |  |  |  |  |  |  |
| 1676 | 1.7.1.2.7.1 | Pre Code Drafting activities |  | 5d | 2023-05-25 A | 2023-05-31 A | 1677SS-5d | 100% |  | 2023-05-25 | 2023-05-31 | 5d | 2023-05-25 | 2023-05-31 |  |  | Andrew Margan | 40h | 40h |  | Code Drafting PM |  |  | 5.0 | Regulatory | Complete | COMPLETE |  |  |  |  |
| 1677 | 1.7.1.2.7.2 | Code Drafting (offline) |  | 55d | 2023-06-01 A | 2023-08-16 A | 1652SS+1d | 100% |  | 2023-06-01 | 2023-08-16 | 55d | 2023-06-01 | 2023-08-16 |  |  | Andrew Margan | 440h | 440h |  | Code Bodies,SRO Design | Code Drafting PM |  | 5.0 | Regulatory | Complete | COMPLETE |  |  |  |  |
| 1678 | 1.7.1.2.7.3 | Internal review and cross-checking of drafting across code drafters |  | 45d | 2023-06-15 A | 2023-08-16 A | 1677SS+10d | 100% |  | 2023-06-15 | 2023-08-16 | 45d | 2023-06-15 | 2023-08-16 |  |  | Andrew Margan | 360h | 360h |  | Code Bodies,SRO Design | Code Drafting PM |  | 5.0 | Regulatory | Complete | COMPLETE |  |  |  |  |
| 1679 | 1.7.1.2.7.4 | External industry review via consultation |  | 15d | 2023-08-18 A | 2023-09-07 A | 1678FS+1d | 100% |  | 2023-08-18 | 2023-09-07 | 15d | 2023-08-18 | 2023-09-07 |  |  | Andrew Margan | 120h | 120h |  | PP | Code Drafting PM |  | 5.0 | Regulatory | Complete | COMPLETE |  |  |  |  |
| 1680 | 1.7.1.2.7.5 | Triage and action comments |  | 19d | 2023-09-06 A | 2023-10-02 A | 1679FS-2d | 100% |  | 2023-09-06 | 2023-10-02 | 19d | 2023-09-06 | 2023-10-02 |  |  | Andrew Margan | 152h | 152h |  | Code Bodies,SRO Design | Code Drafting PM |  | 5.0 | Regulatory | Complete | COMPLETE |  |  |  |  |
| 1681 | 1.7.1.2.7.6 | CDWG review |  | 31d | 2023-10-03 A | 2023-11-14 A | 1680 | 100% |  | 2023-10-03 | 2023-11-14 | 31d | 2023-10-03 | 2023-11-06 |  |  | Andrew Margan | 248h | 248h |  | PP | Code Drafting PM |  | 5.0 | Regulatory | Complete | COMPLETE |  |  |  |  |
| 1682 | 1.7.1.2.7.7 | CCAG review |  | 6d | 2023-11-15 A | 2023-11-22 A | 1681 | 100% |  | 2023-11-15 | 2023-11-22 | 6d | 2023-11-07 | 2023-11-13 |  |  | Andrew Margan | 48h | 48h |  | PP | Code Drafting PM |  | 5.0 | Regulatory | Complete | COMPLETE |  |  |  |  |
| 1683 | 1.7.1.2.7.8 | Code drafting for Migration topic area approved | milestone | 0d | 2023-11-22 A | 2023-11-22 A | 1682 | 100% |  | 2023-11-22 | 2023-11-22 | 0d | 2023-11-13 | 2023-11-13 |  |  | Andrew Margan |  |  |  | PP | Code Drafting PM |  | 5.12 | Regulatory | Complete | COMPLETE | MHHS-ART060 | T3-RE-0400 | CCAG | T2 |
| 1684 | 1.7.1.2.8 | **Consequential Code Change** |  | 109d | 2023-10-11 A | 2024-03-11 |  | 99% | 0d | 2023-10-11 | 2024-03-08 | 108d | 2023-08-18 | 2024-03-08 | 0d |  | N/A | 1120h | 1054.4h | -0 | N/A | N/A |  | 5.0 | Regulatory |  |  |  |  |  |  |
| 1685 | 1.7.1.2.8.1 | External industry review via consultation - drop 1 (DCUSA) |  | 15d | 2023-10-11 A | 2023-10-31 A | 1691SS | 100% |  | 2023-10-11 | 2023-10-31 | 15d | 2023-08-18 | 2023-09-07 |  |  | Andrew Margan | 120h | 120h |  | Code Bodies | PP |  | 5.2 | Regulatory | Complete | COMPLETE |  |  |  |  |
| 1686 | 1.7.1.2.8.2 | External industry review via consultation - drop 2 (Elexon) |  | 16d | 2024-02-19 A | 2024-03-11 A | 1701SS | 100% |  | 2024-02-19 | 2024-03-08 | 15d | 2023-10-16 | 2023-11-03 |  | start no earlier than 2024-02-19 | Andrew Margan | 128h | 128h |  | Code Bodies | PP |  | 5.2 | Regulatory | Complete | COMPLETE |  |  |  |  |
| 1687 | 1.7.1.2.9 | **Transition Text (all codes)** |  | 118d | 2023-08-11 A | 2024-01-23 A |  | 100% |  | 2023-08-11 | 2024-01-24 | 119d | 2023-08-11 | 2024-01-25 |  |  | N/A | 2148.53h | 2148.53h |  | N/A | N/A | M6 | 5.2 | Regulatory |  |  |  |  |  |  |
| 1688 | 1.7.1.2.9.1 | Pre Code Drafting activities |  | 8d | 2023-08-11 A | 2023-08-22 A | 1689SS-5d | 100% |  | 2023-08-11 | 2023-08-22 | 8d | 2023-08-11 | 2023-08-17 |  |  | Andrew Margan | 64h | 64h |  | Code Drafting PM |  |  | 5.0 | Regulatory | Complete | COMPLETE |  |  |  |  |
| 1689 | 1.7.1.2.9.2 | Code Drafting (offline) |  | 38d | 2023-08-18 A | 2023-10-10 A | 1679SS | 100% |  | 2023-08-18 | 2023-10-10 | 38d | 2023-08-18 | 2023-10-12 |  |  | Andrew Margan | 304h | 304h |  | Code Bodies,SRO Design | Code Drafting PM |  | 5.2 | Regulatory | Complete | COMPLETE |  |  |  |  |
| 1690 | 1.7.1.2.9.3 | Internal review and cross-checking of drafting across code drafters |  | 28d | 2023-09-01 A | 2023-10-10 A | 1689SS+10d | 100% |  | 2023-09-01 | 2023-10-10 | 28d | 2023-09-01 | 2023-10-12 |  |  | Andrew Margan | 224h | 224h |  | Code Bodies,SRO Design | Code Drafting PM |  | 5.2 | Regulatory | Complete | COMPLETE |  |  |  |  |
| 1691 | 1.7.1.2.9.4 | External industry review via consultation |  | 15d | 2023-10-11 A | 2023-10-31 A | 1690 | 100% |  | 2023-10-11 | 2023-10-31 | 15d | 2023-10-16 | 2023-11-03 |  |  | Andrew Margan | 120h | 120h |  | PP | Code Drafting PM |  | 5.2 | Regulatory | Complete | COMPLETE |  |  |  |  |
| 1692 | 1.7.1.2.9.5 | Triage and action comments |  | 20d | 2023-10-30 A | 2023-11-24 A | 1691FS-2d | 100% |  | 2023-10-30 | 2023-11-24 | 20d | 2023-11-02 | 2023-11-21 |  |  | Andrew Margan | 160h | 160h |  | Code Bodies,SRO Design | Code Drafting PM |  | 5.2 | Regulatory | Complete | COMPLETE |  |  |  |  |
| 1693 | 1.7.1.2.9.6 | CDWG review |  | 37d | 2023-11-27 A | 2024-01-16 A | 1692 | 100% |  | 2023-11-27 | 2024-01-16 | 37d | 2023-11-22 | 2024-01-17 |  |  | Andrew Margan | 296h | 296h |  | PP | Code Drafting PM |  | 5.2 | Regulatory | Complete | COMPLETE |  |  |  |  |
| 1694 | 1.7.1.2.9.7 | CCAG review |  | 5d | 2024-01-17 A | 2024-01-23 A | 1693 | 100% |  | 2024-01-17 | 2024-01-24 | 6d | 2024-01-18 | 2024-01-25 |  |  | Andrew Margan | 40h | 40h |  | PP | Code Drafting PM |  | 5.2 | Regulatory | Complete | COMPLETE |  |  |  |  |
| 1695 | 1.7.1.2.9.8 | Code drafting for Transition Text topic area approved | milestone | 0d | 2024-01-23 A | 2024-01-23 A | 1694 | 100% |  | 2024-01-24 | 2024-01-24 | 0d | 2024-01-25 | 2024-01-25 |  |  | Andrew Margan |  |  |  | PP | Code Drafting PM |  | 5.16 | Regulatory | Complete | COMPLETE | MHHS-ART060 | T3-RE-0450 | CCAG | T2 |

Notes:
- 1674: 10/10 - CH - Agreed at PSG on 4/10 to downgrade from T2 to T3
- 1683: 31/07/23 - Changed date to 22/11/23 from 13/11/23 after approval from CCAG on 28/6/23. 10/10 - CH - Agreed at PSG on 4/10 to downgrade from T2 to T3
- 1685: Review of drop schedule and scope is being undertaken with CCAG.
- 1686: Review of drop schedule and scope is being undertaken with CCAG.
- 1689: Guidance: 14/8/23 - RECCo transition drafting activity is expected to take the full 38 days, noting BSE co-drafting will be expected to take approx. 21 days
- 1695: 10/10 - CH - Agreed at PSG on 4/10 to downgrade from T2 to T3

| ID | WBS | Task | Type | Duration | Start | Finish | Predecessors | Complete | Remaining | Baseline start | Baseline finish | Baseline duration | Baseline 1 start | Baseline 1 finish | Total slack | Free slack | Resources | Work | Actual work | Baseline cost | Responsible | Involved | Task Status | Update Version | MHHS Programme Phase | Sched Status | RAG | Artefact ID | Milestone ID | Text29 | Tier |
| --- | --- | --- | --- | --- | --- | --- | --- | --- | --- | --- | --- | --- | --- | --- | --- | --- | --- | --- | --- | --- | --- | --- | --- | --- | --- | --- | --- | --- | --- | --- | --- |
| 1696 | 1.7.1.2.10 | **Final Code Drafting (mop-up) (all codes)** |  | 199d | 2023-08-18 A | 2024-05-22 |  | 92% | 14.98d | 2023-08-18 | 2024-05-22 | 199d | 2023-08-18 | 2024-05-13 | 653d |  | N/A | 4248h | 3928.12h |  | N/A | N/A | M6 | 5.0 | Regulatory |  |  |  |  |  |  |
| 1697 | 1.7.1.2.10.1 | Forward look and confirm remaining plan |  | 15d | 2023-08-18 A | 2023-09-07 A | 1689SS | 100% |  | 2023-08-18 | 2023-09-07 | 15d | 2023-08-18 | 2023-09-07 |  |  | Andrew Margan | 120h | 120h |  | Code Drafting PM |  |  | 5.0 | Regulatory | Complete | COMPLETE |  |  |  |  |
| 1698 | 1.7.1.2.10.2 | Identify remaining or additional areas of code (e.g. consequential change requirements) to be completed |  | 15d | 2023-08-18 A | 2023-09-07 A | 1697SS | 100% |  | 2023-08-18 | 2023-09-07 | 15d | 2023-08-18 | 2023-09-07 |  |  | Andrew Margan | 120h | 120h |  | Code Bodies,SRO Design | Code Drafting PM |  | 5.0 | Regulatory | Complete | COMPLETE |  |  |  |  |
| 1699 | 1.7.1.2.10.3 | Code Drafting (offline) Interim Consultation (1) |  | 60d | 2023-09-08 A | 2023-11-30 A | 1698 | 100% |  | 2023-09-08 | 2023-11-30 | 60d | 2023-09-08 | 2024-02-15 |  |  | Andrew Margan | 480h | 480h |  | Code Bodies,SRO Design | Code Drafting PM |  | 5.0 | Regulatory | Complete | COMPLETE |  |  |  |  |
| 1700 | 1.7.1.2.10.4 | Internal review and cross-checking of drafting across code drafters Interim Consultation (1) |  | 50d | 2023-09-22 A | 2023-11-30 A | 1699SS+10d | 100% |  | 2023-09-22 | 2023-11-30 | 50d | 2023-09-22 | 2024-02-15 |  |  | Andrew Margan | 400h | 400h |  | Code Bodies,SRO Design | Code Drafting PM |  | 5.0 | Regulatory | Complete | COMPLETE |  |  |  |  |
| 1701 | 1.7.1.2.10.5 | External industry review via consultation Interim Consultation (1) |  | 23d | 2023-12-01 A | 2024-01-02 A | 1700 | 100% |  | 2023-12-01 | 2024-01-02 | 23d | 2024-02-19 | 2024-03-08 |  |  | Andrew Margan | 184h | 184h |  | PP | Code Drafting PM |  | 5.0 | Regulatory | Complete | COMPLETE |  |  |  |  |
| 1702 | 1.7.1.2.10.6 | Code Drafting (offline) Final Consultation (2) |  | 55d | 2023-12-01 A | 2024-02-15 A | 1700 | 100% |  | 2023-12-01 | 2024-02-15 | 55d | 2023-09-08 | 2024-02-15 |  |  | Andrew Margan | 440h | 440h |  | Code Bodies,SRO Design | Code Drafting PM |  | 5.0 | Regulatory | Complete | COMPLETE |  |  |  |  |
| 1703 | 1.7.1.2.10.7 | Internal review and cross-checking of drafting across code drafters Final Consultation (2) |  | 45d | 2023-12-15 A | 2024-02-15 A | 1702SS+10d | 100% |  | 2023-12-15 | 2024-02-15 | 45d | 2023-09-22 | 2024-02-15 |  |  | Andrew Margan | 360h | 360h |  | Code Bodies,SRO Design | Code Drafting PM |  | 5.0 | Regulatory | Complete | COMPLETE |  |  |  |  |
| 1704 | 1.7.1.2.10.8 | External industry review via consultation Final Consultation (2) |  | 16d | 2024-02-19 A | 2024-03-11 A | 1703FS+1d | 100% |  | 2024-02-19 | 2024-03-08 | 15d | 2024-02-19 | 2024-03-08 |  |  | Andrew Margan | 128h | 128h |  | PP | Code Drafting PM |  | 5.0 | Regulatory | Complete | COMPLETE |  |  |  |  |
| 1705 | 1.7.1.2.10.9 | Triage and action comments |  | 18d | 2024-03-11 A | 2024-04-03 A | 1704FS-1d | 100% |  | 2024-03-07 | 2024-04-01 | 18d | 2024-03-07 | 2024-04-03 |  |  | Andrew Margan | 144h | 144h |  | Code Bodies,SRO Design | Code Drafting PM |  | 5.0 | Regulatory | Complete | COMPLETE |  |  |  |  |
| 1706 | 1.7.1.2.10.10 | CDWG review |  | 29d | 2024-04-04 A | 2024-05-14 | 1705 | 34% | 19d | 2024-04-02 | 2024-05-14 | 31d | 2024-04-04 | 2024-05-03 | 653d | 0d | Andrew Margan | 232h | 80h |  | PP | Code Drafting PM |  | 5.0 | Regulatory | Green | GREEN |  |  |  |  |
| 1707 | 1.7.1.2.10.11 | CCAG review |  | 6d | 2024-05-15 | 2024-05-22 | 1706 |  |  | 2024-05-15 | 2024-05-22 | 6d | 2024-05-06 | 2024-05-13 | 653d | 0d | Andrew Margan | 48h |  |  | PP | Code Drafting PM | 27.33 | 5.0 | Regulatory | Green | GREEN |  |  |  |  |
| 1708 | 1.7.1.2.10.12 | Final code drafting (mop-up) approved | milestone | 0d | 2024-05-22 | 2024-05-22 | 1707 |  |  | 2024-05-22 | 2024-05-22 | 0d | 2024-05-13 | 2024-05-13 | 653d | 67d | Andrew Margan |  |  |  | PP | Code Drafting PM | 34.71 | 5.9 | Regulatory | Green | GREEN | MHHS-ART060 | T3-RE-0500 | CCAG | T2 |
| 1709 | 1.7.1.2.11 | **Final code review, consistency check and approval** |  | 102d | 2024-04-04 A | 2024-08-23 |  | 10% | 92.19d | 2024-04-04 | 2024-08-23 | 102d | 2024-05-06 | 2024-08-23 | 720d |  | N/A | 1648h | 158.46h | -0 | N/A | N/A | M6 | 5.0 | Regulatory |  |  |  |  |  |  |
| 1710 | 1.7.1.2.11.1 | Gap analysis of final code against design artefacts (reverse process to code drafting) |  | 38d | 2024-04-04 A | 2024-05-27 | 1706SS | 26% | 28d | 2024-04-04 | 2024-05-27 | 38d | 2024-05-06 | 2024-05-17 | 586d | 0d | Andrew Margan | 304h | 80h |  | Code Bodies,SRO Design | Code Drafting PM |  | 5.0 | Regulatory | Green | GREEN |  |  |  |  |
| 1711 | 1.7.1.2.11.2 | Outputs of gap analysis actioned offline |  | 11d | 2024-05-28 | 2024-06-11 | 1710 |  |  | 2024-05-28 | 2024-06-11 | 11d | 2024-05-20 | 2024-06-07 | 586d | 0d | Andrew Margan | 88h |  |  | Code Bodies,SRO Design | Code Drafting PM | 40.33 | 5.0 | Regulatory | Green | GREEN |  |  |  |  |
| 1712 | 1.7.1.2.11.3 | Final documentation collated for final consultation |  | 8d | 2024-06-12 | 2024-06-21 | 1711 |  |  | 2024-06-10 | 2024-06-21 | 10d | 2024-06-10 | 2024-06-13 | 586d | 0d | Andrew Margan | 64h |  |  | Code Drafting PM | Code Bodies,SRO Design | 55.33 | 5.0 | Regulatory | Green | GREEN |  |  |  |  |
| 1713 | 1.7.1.2.11.4 | External industry review via consultation |  | 20d | 2024-06-24 | 2024-07-19 | 1712 |  |  | 2024-06-24 | 2024-07-19 | 20d | 2024-06-14 | 2024-07-04 | 586d | 0d | Andrew Margan | 160h |  |  | PP | Code Drafting PM | 67.33 | 5.0 | Regulatory | Green | GREEN |  |  |  |  |
| 1714 | 1.7.1.2.11.5 | Triage and action comments |  | 13d | 2024-07-18 | 2024-08-05 | 1713FS-2d |  |  | 2024-07-18 | 2024-08-05 | 13d | 2024-07-03 | 2024-07-19 | 586d | 0d | Andrew Margan | 104h |  |  | Code Bodies,SRO Design | Code Drafting PM | 91.33 | 5.0 | Regulatory | Green | GREEN |  |  |  |  |
| 1715 | 1.7.1.2.11.6 | Final CDWG review |  | 6d | 2024-08-06 | 2024-08-13 | 1714 |  |  | 2024-08-06 | 2024-08-13 | 6d | 2024-07-22 | 2024-08-16 | 586d | 0d | Andrew Margan | 48h |  |  | PP | Code Drafting PM | 110.33 | 5.0 | Regulatory | Green | GREEN |  |  |  |  |
| 1716 | 1.7.1.2.11.7 | Final CCAG review |  | 8d | 2024-08-14 | 2024-08-23 | 1715 |  |  | 2024-08-14 | 2024-08-23 | 8d | 2024-08-19 | 2024-08-23 | 586d | 0d | Andrew Margan | 64h |  |  | PP | Code Drafting PM | 118.33 | 5.0 | Regulatory | Green | GREEN |  |  |  |  |
| 1717 | 1.7.1.2.11.8 | CCAG recommend final code to PSG for baselining | milestone | 0d | 2024-08-23 | 2024-08-23 | 1716 |  |  | 2024-08-23 | 2024-08-23 | 0d | 2024-08-23 | 2024-08-23 | 720d |  | Andrew Margan |  |  |  | PP | Code Drafting PM | 127.71 | 5.9 | Regulatory | Green | GREEN | MHHS-ART060 | T3-RE-0550 | CCAG | T2 |
| 1718 | 1.7.1.3 | Code changes baselined (M6) | milestone | 0d | 2024-08-23 | 2024-08-23 | 1716, 1708, 1695, 1683, 1674, 1665, 1656, 1647, 1638, 1629 |  |  | 2024-08-23 | 2024-08-23 | 0d | 2024-08-23 | 2024-08-23 | 586d | 0d | Andrew Margan |  |  |  | CPT | PP | 127.71 | 5.0 | Regulatory | Green | GREEN | MHHS-ART012 | T1-RE-1000 | PSG | T1 |
| 1719 | 1.7.2 | **Ofgem preparation and enactment of SCR powers** |  | 201d | 2024-02-05 A | 2024-11-12 |  | 17% | 167.29d | 2024-02-05 | 2024-11-12 | 201d | 2024-01-26 | 2024-11-12 | 664d |  | N/A | 7672h | 1101.47h |  | N/A | N/A | M7 | 5.0 | Regulatory |  |  |  |  |  |  |
| 1720 | 1.7.2.1 | **Preparation and enactment of SCR Powers** |  | 201d | 2024-02-05 A | 2024-11-11 |  | 25% | 150.03d | 2024-02-05 | 2024-11-11 | 201d | 2024-01-26 | 2024-11-11 | 664d |  | N/A | 3280h | 831.77h |  | N/A | N/A |  | 5.0 | Regulatory |  |  |  |  |  |  |
| 1721 | 1.7.2.1.1 | Ofgem to keep Ofgem legal informed of process followed and nature of Code drafting to ensure that prepared for SCR go/no go decision |  | 100d | 2024-02-05 A | 2024-06-24 | 1722SF | 53% | 47d | 2024-02-05 | 2024-06-24 | 100d | 2024-01-26 | 2024-06-14 | 765d |  | Andrew Margan | 800h | 424h |  | Ofgem | Code Bodies |  | 5.0 | Regulatory | Green | GREEN |  |  |  |  |
| 1722 | 1.7.2.1.2 | OFGEM Legal to review Code Artefacts deliver policy intent and process followed and confirm that SCR powers are appropriate to use rather than SMAP - SCR go/no go |  | 15d | 2024-06-24 | 2024-07-12 | 1713SS |  |  | 2024-06-24 | 2024-07-12 | 15d | 2024-06-14 | 2024-07-04 | 725d | 0d | Andrew Margan | 120h |  |  | Ofgem | Code Bodies | 67.33 | 5.0 | Regulatory | Green | GREEN |  |  |  |  |
| 1723 | 1.7.2.1.3 | Code Bodies to draft MOD proposal forms |  | 20d | 2024-07-15 | 2024-08-09 | 1722 |  |  | 2024-07-15 | 2024-08-09 | 20d | 2024-07-05 | 2024-08-01 | 730d |  | Andrew Margan | 160h |  |  | Code Bodies | Ofgem | 88.33 | 5.0 | Regulatory | Green | GREEN |  |  |  |  |
| 1724 | 1.7.2.1.4 | Ofgem discuss and agree code mod timetable with code bodies (and MHHSP in relation to the dates for expected decisions) |  | 20d | 2024-07-15 | 2024-08-09 | 1722 |  |  | 2024-07-15 | 2024-08-09 | 20d | 2024-07-05 | 2024-08-01 | 725d | 0d | Andrew Margan | 160h |  |  | Ofgem | Code Bodies | 88.33 | 5.0 | Regulatory | Green | GREEN |  |  |  |  |
| 1725 | 1.7.2.1.5 | Ofgem to draft open letter and direction to each code body specifying the timetable for each modification |  | 5d | 2024-08-12 | 2024-08-16 | 1724 |  |  | 2024-08-12 | 2024-08-16 | 5d | 2024-08-02 | 2024-08-08 | 725d |  | Andrew Margan | 40h |  |  | Ofgem | Code Bodies | 116.33 | 5.0 | Regulatory | Green | GREEN |  |  |  |  |
| 1726 | 1.7.2.1.6 | Ofgem to publish open letter |  | 1d | 2024-08-26 | 2024-08-26 | 1718 |  |  | 2024-08-26 | 2024-08-26 | 1d | 2024-08-26 | 2024-08-26 | 586d | 0d | Andrew Margan | 8h |  |  | Ofgem | Code Bodies | 130.33 | 5.0 | Regulatory | Green | GREEN |  |  |  |  |
| 1727 | 1.7.2.1.7 | Ofgem to publish each Direction to each code body specifying the timetable for each modification |  | 1d | 2024-08-28 | 2024-08-28 | 1726FS+1d |  |  | 2024-08-28 | 2024-08-28 | 1d | 2024-08-28 | 2024-08-28 | 717d |  | Andrew Margan | 8h |  |  | Ofgem | Code Bodies | 132.33 | 5.0 | Regulatory | Green | GREEN |  |  |  |  |
| 1728 | 1.7.2.1.8 | Formally submit (by separate email) Modification Proposal Forms and legal texts to each code body |  | 1d | 2024-08-28 | 2024-08-28 | 1726FS+1d |  |  | 2024-08-28 | 2024-08-28 | 1d | 2024-08-28 | 2024-08-28 | 586d | 0d | Andrew Margan | 8h |  |  | Ofgem | Code Bodies | 132.33 | 5.0 | Regulatory | Green | GREEN |  |  |  |  |
| 1729 | 1.7.2.1.9 | Each Code Body publishes and issues Modification Proposal Forms |  | 3d | 2024-08-29 | 2024-09-02 | 1728 |  |  | 2024-08-29 | 2024-09-02 | 3d | 2024-08-29 | 2024-09-02 | 586d | 0d | Andrew Margan | 24h |  |  | Code Bodies | Ofgem | 133.33 | 5.0 | Regulatory | Green | GREEN |  |  |  |  |
| 1730 | 1.7.2.1.10 | Each Code Body sends Modification Proposal Forms to Panel to approve Mod to go to consultation |  | 10d | 2024-09-03 | 2024-09-16 | 1729 |  |  | 2024-09-03 | 2024-09-16 | 10d | 2024-09-03 | 2024-09-16 | 586d | 0d | Andrew Margan | 80h |  |  | Code Bodies | Ofgem | 138.33 | 5.0 | Regulatory | Green | GREEN |  |  |  |  |
| 1731 | 1.7.2.1.11 | Modification Proposal approved by Panel for Consultation |  | 1d | 2024-09-17 | 2024-09-17 | 1730 |  |  | 2024-09-17 | 2024-09-17 | 1d | 2024-09-17 | 2024-09-17 | 586d | 0d | Andrew Margan | 8h |  |  | Code Bodies | Ofgem | 152.33 | 5.0 | Regulatory | Green | GREEN |  |  |  |  |
| 1732 | 1.7.2.1.12 | Draft Modification Report issued for consultation |  | 1d | 2024-09-18 | 2024-09-18 | 1731 |  |  | 2024-09-18 | 2024-09-18 | 1d | 2024-09-18 | 2024-09-18 | 586d | 0d | Andrew Margan | 8h |  |  | Code Bodies | Ofgem | 153.33 | 5.0 | Regulatory | Green | GREEN |  |  |  |  |
| 1733 | 1.7.2.1.13 | Consultation Close-out for representations |  | 15d | 2024-09-19 | 2024-10-09 | 1732 |  |  | 2024-09-19 | 2024-10-09 | 15d | 2024-09-19 | 2024-10-09 | 586d | 0d | Andrew Margan | 120h |  |  | Code Bodies | Ofgem | 154.33 | 5.0 | Regulatory | Green | GREEN |  |  |  |  |
| 1734 | 1.7.2.1.14 | Each Code Body reviews consultation response and drafts Modification Report |  | 10d | 2024-10-10 | 2024-10-23 | 1733 |  |  | 2024-10-10 | 2024-10-23 | 10d | 2024-10-10 | 2024-10-23 | 586d | 0d | Andrew Margan | 80h |  |  | Code Bodies | Ofgem | 175.33 | 5.0 | Regulatory | Green | GREEN |  |  |  |  |
| 1735 | 1.7.2.1.15 | Final Modification Report sent to Panel for decision with recommendation to approve |  | 1d | 2024-10-24 | 2024-10-24 | 1734 |  |  | 2024-10-24 | 2024-10-24 | 1d | 2024-10-24 | 2024-10-24 | 586d | 0d | Andrew Margan | 8h |  |  | Code Bodies | Ofgem | 189.33 | 5.0 | Regulatory | Green | GREEN |  |  |  |  |
| 1736 | 1.7.2.1.16 | Modification Panel decision |  | 1d | 2024-11-07 | 2024-11-07 | 1735FS+9d |  |  | 2024-11-07 | 2024-11-07 | 1d | 2024-11-07 | 2024-11-07 | 586d | 0d | Andrew Margan | 8h |  |  | Code Bodies | Ofgem | 203.33 | 5.0 | Regulatory | Green | GREEN |  |  |  |  |
| 1737 | 1.7.2.1.17 | Panel make recommendation to OFGEM |  | 2d | 2024-11-08 | 2024-11-11 | 1736 |  |  | 2024-11-08 | 2024-11-11 | 2d | 2024-11-08 | 2024-11-11 | 664d |  | Andrew Margan | 16h |  |  | Code Bodies | Ofgem | 204.33 | 5.0 | Regulatory | Green | GREEN |  |  |  |  |
| 1738 | 1.7.2.1.18 | MTDSG |  | 2d | 2024-11-08 | 2024-11-11 | 1736 |  |  | 2024-11-08 | 2024-11-11 | 2d | 2024-11-08 | 2024-11-11 | 586d | 0d | Andrew Margan | 16h |  |  | Ofgem | Code Bodies | 204.33 | 5.0 | Regulatory | Green | GREEN |  |  |  |  |
| 1739 | 1.7.2.2 | SCR powers enabled (M7) | milestone | 0d | 2024-11-11 | 2024-11-11 | 1738FF, 1718 |  |  | 2024-11-11 | 2024-11-11 | 0d | 2024-11-11 | 2024-11-11 | 586d | 0d | Andrew Margan |  |  |  | CPT | PP | 207.71 | 5.0 | Regulatory | Green | GREEN | MHHS-ART012 | T2-RE-0600 | CCAG | T2 |

Notes:
- 1708: 10/10 - CH - Agreed at PSG on 4/10 to downgrade from T2 to T3
- 1717: 10/10 - CH - Agreed at PSG on 4/10 to downgrade from T2 to T3

| ID | WBS | Task | Type | Duration | Start | Finish | Predecessors | Complete | Remaining | Baseline start | Baseline finish | Baseline duration | Baseline 1 start | Baseline 1 finish | Total slack | Free slack | Constraint | Resources | Work | Actual work | Baseline cost | Responsible | Involved | Update Version | MHHS Programme Phase | Task Status | Sched Status | RAG | Artefact ID | Milestone ID | Text29 | Tier | Text3 |
| --- | --- | --- | --- | --- | --- | --- | --- | --- | --- | --- | --- | --- | --- | --- | --- | --- | --- | --- | --- | --- | --- | --- | --- | --- | --- | --- | --- | --- | --- | --- | --- | --- | --- |
| 1740 | 1.7.2.3 | **Ofgem preparation to enact Smart Meter Act powers [CONTINGENCY ONLY]** |  | 101d | 2024-06-24 | 2024-11-12 |  |  |  | 2024-06-24 | 2024-11-12 | 101d | 2024-06-14 | 2024-11-12 | 664d |  |  | N/A | 2784h |  |  | N/A | N/A | 5.0 | Regulatory |  |  |  |  |  |  |  |  |
| 1741 | 1.7.2.3.1 | SRO recommends Ofgem begin preparation to enact Smart Meter Act powers [CONTINGENCY ONLY] |  | 1d | 2024-06-24 | 2024-06-24 | 1722SS |  |  | 2024-06-24 | 2024-06-24 | 1d | 2024-06-14 | 2024-06-14 | 729d | 0d |  | Andrew Margan | 8h |  |  | Ofgem | Code bodies | 5.0 | Regulatory | 67.33 | Green | GREEN |  |  |  |  |  |
| 1742 | 1.7.2.3.2 | Ofgem drafts letter to DESNZ to request trigger of Smart Meter Act powers [CONTINGENCY ONLY] |  | 15d | 2024-06-25 | 2024-07-15 | 1741 |  |  | 2024-06-25 | 2024-07-15 | 15d | 2024-06-17 | 2024-07-05 | 729d | 0d |  | Andrew Margan | 120h |  |  | Ofgem | Code bodies | 5.0 | Regulatory | 68.33 | Green | GREEN |  |  |  |  |  |
| 1743 | 1.7.2.3.3 | DESNZ SoS letter response to trigger SMAP Powers [CONTINGENCY ONLY] |  | 1mo | 2024-07-16 | 2024-08-12 | 1742 |  |  | 2024-07-16 | 2024-08-12 | 1mo | 2024-07-08 | 2024-08-02 | 729d |  |  | Andrew Margan | 160h |  |  | Ofgem | Code bodies | 5.0 | Regulatory | 89.33 | Green | GREEN |  |  |  |  |  |
| 1744 | 1.7.2.3.4 | Ofgem enables Smart Meters Act powers (support from the Programme, where required) [CONTINGENCY ONLY] |  | 1d | 2024-08-05 | 2024-08-06 | 1748SF |  |  | 2024-08-05 | 2024-08-06 | 1d | 2024-08-05 | 2024-08-06 | 734d | 0d |  | Andrew Margan | 8h |  |  | Tier 2 - M7 |  | 5.0 | Regulatory | 109.33 | Green | GREEN |  |  |  |  |  |
| 1745 | 1.7.2.3.5 | Smart Meters Act powers enabled (M7) [CONTINGENCY ONLY] | milestone | 0d | 2024-08-06 | 2024-08-06 | 1744 |  |  | 2024-08-06 | 2024-08-06 | 0d | 2024-08-06 | 2024-08-06 | 734d |  |  | Andrew Margan |  |  |  | Ofgem | Code bodies | 5.0 | Regulatory | 110.33 | Green | GREEN |  |  |  |  |  |
| 1746 | 1.7.2.3.6 | **Deliver MHHS Code Changes [CONTINGENCY UNDER SMAP]** |  | 70d | 2024-08-06 | 2024-11-12 |  |  |  | 2024-08-06 | 2024-11-12 | 70d | 2024-08-06 | 2024-11-12 | 664d |  |  | N/A | 1680h |  |  | N/A | N/A | 5.0 | Regulatory |  |  |  |  |  |  |  |  |
| 1747 | 1.7.2.3.6.1 | **Ofgem consultation and decision [CONTINGENCY ONLY]** |  | 70d | 2024-08-06 | 2024-11-12 |  |  |  | 2024-08-06 | 2024-11-12 | 70d | 2024-08-06 | 2024-11-12 | 664d |  |  | N/A | 1120h |  |  | N/A | N/A | 5.0 | Regulatory |  |  |  |  |  |  |  |  |
| 1748 | 1.7.2.3.6.1.1 | Ofgem issue completed code to industry for consultation under SMAP (consultation confirms robustness of the process undertaken via CCAG and does not re-open the detail of drafted code) [CONTINGENCY ONLY] |  | 10d | 2024-08-06 | 2024-08-20 | 1749SF |  |  | 2024-08-06 | 2024-08-20 | 10d | 2024-08-06 | 2024-08-20 | 724d | 0d |  | Andrew Margan | 80h |  |  | Ofgem | Code bodies | 5.0 | Regulatory | 110.33 | Green | GREEN |  |  |  |  |  |
| 1749 | 1.7.2.3.6.1.2 | Industry respond to consultation on new Code (28-day consultation) [CONTINGENCY ONLY] |  | 20d | 2024-08-20 | 2024-09-17 | 1750SF |  |  | 2024-08-20 | 2024-09-17 | 20d | 2024-08-20 | 2024-09-17 | 704d | 0d |  | Andrew Margan | 160h |  |  | PP | Ofgem | 5.0 | Regulatory | 124.33 | Green | GREEN |  |  |  |  |  |
| 1750 | 1.7.2.3.6.1.3 | Ofgem considers consultation responses and publishes decision confirming Code Releases dates (release dates may be <56 days following publication of Ofgem decision) [CONTINGENCY ONLY] |  | 40d | 2024-09-17 | 2024-11-12 | 1753SF |  |  | 2024-09-17 | 2024-11-12 | 40d | 2024-09-17 | 2024-11-12 | 664d | 0d |  | Andrew Margan | 320h |  |  | Ofgem | Code bodies | 5.0 | Regulatory | 152.33 | Green | GREEN |  |  |  |  |  |
| 1751 | 1.7.3 | **Deliver MHHS Code Changes** |  | 149d | 2024-11-12 | 2025-06-06 |  |  |  | 2024-11-12 | 2025-06-06 | 149d | 2024-11-12 | 2025-03-07 | 515d |  |  | N/A | 3624h |  |  | N/A | N/A | 5.0 | Regulatory | M8 |  |  |  |  |  |  |  |
| 1752 | 1.7.3.1 | **Releases** |  | 149d | 2024-11-12 | 2025-06-06 |  |  |  | 2024-11-12 | 2025-06-06 | 149d | 2024-11-12 | 2025-03-07 | 515d |  |  | N/A | 2432h |  |  | N/A | N/A | 5.0 | Regulatory |  |  |  |  |  |  |  |  |
| 1753 | 1.7.3.1.1 | Impacted codes make resourcing provisions and prepare to implement new Code via internal code body change processes |  | 78d | 2024-11-12 | 2025-02-27 | 1739 |  |  | 2024-11-12 | 2025-02-27 | 78d | 2024-11-12 | 2025-02-27 | 586d | 0d |  | Andrew Margan | 624h |  |  | Code Bodies |  | 5.0 | Regulatory | 208.33 | Green | GREEN |  |  |  |  |  |
| 1754 | 1.7.3.1.2 | **Main Code Release** |  | 71d | 2025-02-28 | 2025-06-06 |  |  |  | 2025-02-28 | 2025-06-06 | 71d | 2025-02-28 | 2025-03-07 | 515d |  |  | N/A | 616h |  |  | N/A | N/A | 5.0 | Regulatory |  |  |  |  |  |  |  |  |
| 1755 | 1.7.3.1.2.1 | Release preparation (e.g. preparing release documentation) |  | 5d | 2025-02-28 | 2025-03-07 | 1756SF |  |  | 2025-02-28 | 2025-03-07 | 5d | 2025-02-28 | 2025-03-07 | 581d |  |  | Andrew Margan | 40h |  |  | Code Bodies |  | 5.0 | Regulatory | 316.33 | Green | GREEN |  |  |  |  |  |
| 1756 | 1.7.3.1.2.2 | Implement new code on day of code release |  | 1d | 2025-03-07 | 2025-03-07 | 1757SF |  |  | 2025-03-07 | 2025-03-07 | 1d | 2025-03-07 | 2025-03-07 | 580d | 0d |  | Andrew Margan | 8h |  |  | Code Bodies |  | 5.0 | Regulatory | 323.33 | Green | GREEN |  |  |  |  |  |
| 1757 | 1.7.3.1.2.3 | Code changes delivered (M8) | milestone | 0d | 2025-03-07 | 2025-03-07 | 1926SS, 1739, 1718 |  |  | 2025-03-07 | 2025-03-07 | 0d | 2025-03-07 | 2025-03-07 | 515d | 0d |  | Andrew Margan |  |  |  | CPT | Code Bodies,PP | 5.0 | Regulatory | 323.71 | Green | GREEN | MHHS-ART060 | T2-RE-0650 | CCAG | T2 |  |
| 1758 | 1.7.3.1.2.4 | Code changes delivered (M8*) late exit | milestone | 0d | 2025-06-06 | 2025-06-06 | 1757FS+65d |  |  | 2025-06-06 | 2025-06-06 | 0d |  |  | 515d |  |  | Andrew Margan |  |  |  | CPT | Code Bodies,PP | 5.1 | Regulatory | 414.71 | Green | GREEN | MHHS-ART060 | T2-RE-0700 | CCAG | T2 |  |
| 1759 | 1.7.4 | **External Programme Dependency Management** |  | 38d | 2023-12-01 A | 2024-01-24 A |  | 100% |  | 2023-12-01 | 2024-01-24 | 38d | 2023-09-08 | 2024-01-24 |  |  |  | N/A | 768h | 768h |  | N/A | N/A | 5.0 | Regulatory |  |  |  |  |  |  |  |  |
| 1760 | 1.7.4.1 | **DCP397** |  | 38d | 2023-12-01 A | 2024-01-24 A |  | 100% |  | 2023-12-01 | 2024-01-24 | 38d | 2023-09-08 | 2024-01-24 |  |  |  | N/A | 464h | 464h |  | N/A | N/A | 5.0 | Regulatory |  |  |  |  |  |  |  |  |
| 1761 | 1.7.4.1.1 | Ensure DCP397 drafting included in mop-up code drafting activity (link to mop-up) |  | 20d | 2023-12-01 A | 2023-12-28 A | 1702SS, 1699SS | 100% |  | 2023-12-01 | 2023-12-28 | 20d | 2023-09-08 | 2023-10-05 |  |  |  | Andrew Margan | 160h | 160h |  | CPT | Code Bodies,SRO Design, Code Drafting PM | 5.0 | Regulatory |  | Complete | COMPLETE |  |  |  |  |  |
| 1762 | 1.7.4.1.2 | Implementation of DCP397 | milestone | 0d | 2024-01-24 A | 2024-01-24 A |  | 100% |  | 2024-01-24 | 2024-01-24 | 0d | 2024-01-24 | 2024-01-24 |  |  | start no earlier than 2024-01-24 | Andrew Margan |  |  |  | Code Bodies |  | 5.0 | Regulatory |  | Complete | COMPLETE |  |  |  |  |  |
| 1763 | 1.8 | **MIGRATION** |  | 1092d | 2022-10-31 A | 2027-01-05 |  | 31% | 753.07d | 2022-10-31 | 2027-01-05 | 1092d | 2022-10-31 | 2027-01-05 | 103d |  |  | N/A | 151066h | 39348.5h | -0 | N/A | N/A |  | Migration |  |  |  |  |  |  |  | 1 Oct 2024 - 31 Oct 2025 |
| 1764 | 1.8.1 | **Migration Artefact Development and Publication** |  | 635d | 2022-10-31 A | 2025-04-04 |  | 74% | 165.68d | 2022-10-31 | 2025-04-04 | 635d | 2022-10-31 | 2025-04-04 | 560d |  |  | N/A | 31376h | 15197.3h | -0 | N/A | N/A | 5.0 | Migration |  |  |  |  |  |  |  |  |
| 1765 | 1.8.1.1 | **Migration Approach** |  | 28d | 2022-10-31 A | 2022-12-07 A |  | 100% |  | 2022-10-31 | 2022-12-07 | 28d | 2022-10-31 | 2022-12-07 |  |  |  | N/A | 592h | 592h |  | N/A | N/A | 5.0 | Migration |  |  |  |  |  |  |  |  |
| 1766 | 1.8.1.1.1 | Option analysis (via MWG and PPIR) and recommendation |  | 23d | 2022-10-31 A | 2022-11-30 A |  | 100% |  | 2022-10-31 | 2022-11-30 | 23d | 2022-10-31 | 2022-11-30 |  |  |  | John Wiggins; Matthew Breen | 368h | 368h |  | PP | SI Migration | 5.0 | Migration |  | Complete | COMPLETE |  |  |  |  |  |
| 1767 | 1.8.1.1.2 | Migration Approach approved | milestone | 0d | 2022-12-07 A | 2022-12-07 A | 1766FS+5d | 100% |  | 2022-12-07 | 2022-12-07 | 0d | 2022-12-07 | 2022-12-07 |  |  |  | John Wiggins; Matthew Breen |  |  |  | SI Migration | PP,IPA | 5.0 | Migration |  | Complete | COMPLETE | MHHS-DEL770 | T3-MI-0010 | PSG | T3 |  |

Notes:
- 1750: KEEP NOTE IN MS PROJECT PLAN: "This includes publishing decision to the Ofgem website and providing written direction to each code body with code release instruction & date."

| ID | WBS | Task | Type | Duration | Start | Finish | Predecessors | Complete | Baseline start | Baseline finish | Baseline duration | Baseline 1 start | Baseline 1 finish | Resources | Work | Actual work | Baseline cost | Responsible | Involved | Update Version | MHHS Programme Phase | Sched Status | RAG | Milestone ID | Text29 | Tier | Guidance |
| --- | --- | --- | --- | --- | --- | --- | --- | --- | --- | --- | --- | --- | --- | --- | --- | --- | --- | --- | --- | --- | --- | --- | --- | --- | --- | --- | --- |
| 1768 | 1.8.1.2 | **Migration Design** |  | 100d | 2022-11-14 A | 2023-03-31 A |  | 100% | 2022-11-14 | 2023-03-31 | 100d | 2022-11-14 | 2023-03-31 | N/A | 2016h | 2016h |  | N/A | N/A | 5.0 | Migration |  |  |  |  |  |  |
| 1769 | 1.8.1.2.1 | Review and update existing design artefacts and socialise with participants ahead of MDSG |  | 10d | 2022-11-14 A | 2022-11-25 A |  | 100% | 2022-11-14 | 2022-11-25 | 10d | 2022-11-14 | 2022-11-25 | John Wiggins; Matthew Breen | 160h | 160h |  | SI Migration | SRO Design,CPT | 5.0 | Migration | Complete | COMPLETE |  |  |  |  |
| 1770 | 1.8.1.2.2 | Develop design artefacts and supporting technical documents in line with MDSG |  | 53d | 2022-11-30 A | 2023-02-10 A | 1769FS+2d | 100% | 2022-11-30 | 2023-02-10 | 53d | 2022-11-30 | 2023-02-10 | John Wiggins; Matthew Breen | 848h | 848h |  | SI Migration | PP,SRO Function,CPT | 5.0 | Migration | Complete | COMPLETE |  |  |  |  |
| 1771 | 1.8.1.2.3 | Migration design artefacts issued for consultation | milestone | 0d | 2023-02-13 A | 2023-02-13 A | 1770FS+1d | 100% | 2023-02-13 | 2023-02-13 | 0d | 2023-02-13 | 2023-02-13 | John Wiggins; Matthew Breen |  |  |  | SI Migration | PP,SRO Function,CPT | 5.0 | Migration | Complete | COMPLETE | T3-MI-0011 | DAG | T3 |  |
| 1772 | 1.8.1.2.4 | Industry consultation |  | 5d | 2023-02-14 A | 2023-02-20 A | 1771SS | 100% | 2023-02-14 | 2023-02-20 | 5d | 2023-02-14 | 2023-02-20 | John Wiggins; Matthew Breen | 80h | 80h |  | PP | SI Migration | 5.0 | Migration | Complete | COMPLETE |  |  |  |  |
| 1773 | 1.8.1.2.5 | Review consultation feedback, address comments and update artefacts |  | 5d | 2023-02-21 A | 2023-02-27 A | 1772 | 100% | 2023-02-21 | 2023-02-27 | 5d | 2023-02-21 | 2023-02-27 | John Wiggins; Matthew Breen | 80h | 80h |  | SI Migration | PP | 5.0 | Migration | Complete | COMPLETE |  |  |  |  |
| 1774 | 1.8.1.2.6 | Internal artefact review and comms preparation |  | 3d | 2023-02-28 A | 2023-03-02 A | 1773 | 100% | 2023-02-28 | 2023-03-02 | 3d | 2023-02-28 | 2023-03-02 | John Wiggins; Matthew Breen | 48h | 48h |  | SI Migration | SRO Function | 5.0 | Migration | Complete | COMPLETE |  |  |  |  |
| 1775 | 1.8.1.2.7 | Updated Migration Design artefacts issued to PPs for assurance review | milestone | 0d | 2023-03-03 A | 2023-03-03 A | 1774FS+1d | 100% | 2023-03-03 | 2023-03-03 | 0d | 2023-03-03 | 2023-03-03 | John Wiggins; Matthew Breen |  |  |  | SI Migration | PP | 5.0 | Migration | Complete | COMPLETE | T3-MI-0013 | DAG | T3 |  |
| 1776 | 1.8.1.2.8 | Final Migration Design artefacts walkthrough with PPs | milestone | 0d | 2023-03-22 A | 2023-03-22 A | 1775FS+13d | 100% | 2023-03-22 | 2023-03-22 | 0d | 2023-03-22 | 2023-03-22 | John Wiggins; Matthew Breen |  |  |  | SI Migration | PP | 5.0 | Migration | Complete | COMPLETE |  |  |  |  |
| 1777 | 1.8.1.2.9 | Migration Design approved | milestone | 0d | 2023-03-31 A | 2023-03-31 A | 1776FS+7d | 100% | 2023-03-31 | 2023-03-31 | 0d | 2023-03-31 | 2023-03-31 | John Wiggins; Matthew Breen |  |  |  | SI Migration | PP,SRO Function,CPT | 5.0 | Migration | Complete | COMPLETE | T2-MI-0050 | DAG | T2 |  |
| 1778 | 1.8.1.3 | **Transition Design** |  | 186d | 2023-03-01 A | 2023-11-15 A |  | 100% | 2023-03-01 | 2023-11-15 | 186d | 2023-03-01 | 2023-08-03 | N/A | 4328h | 4328h | -0 | N/A | N/A | 5.0 | Migration |  |  |  |  |  |  |
| 1779 | 1.8.1.3.1 | **Tranche 1** |  | 56d | 2023-03-01 A | 2023-05-17 A |  | 100% | 2023-03-01 | 2023-05-17 | 56d | 2023-03-01 | 2023-05-17 | N/A | 856h | 856h |  | N/A | N/A | 5.0 | Migration |  |  |  |  |  |  |
| 1780 | 1.8.1.3.1.1 | Develop design artefacts and supporting technical details with participants |  | 50d | 2023-03-01 A | 2023-05-09 A |  | 100% | 2023-03-01 | 2023-05-09 | 50d | 2023-03-01 | 2023-05-09 | Andrew Margan | 400h | 400h |  | SI Design | PP | 5.0 | Migration | Complete | COMPLETE |  |  |  |  |
| 1781 | 1.8.1.3.1.2 | Issue Material for DAG approval |  | 1d | 2023-05-10 A | 2023-05-10 A | 1780 | 100% | 2023-05-10 | 2023-05-10 | 1d | 2023-05-10 | 2023-05-10 | Andrew Margan | 8h | 8h |  | PP | SI Design | 5.0 | Migration | Complete | COMPLETE |  |  |  |  |
| 1782 | 1.8.1.3.1.3 | Tranche 1 Transition Design approved | milestone | 0d | 2023-05-17 A | 2023-05-17 A | 1781FS+5d | 100% | 2023-05-17 | 2023-05-17 | 0d | 2023-05-17 | 2023-05-17 | Andrew Margan |  |  |  | SI Design | PP | 5.0 | Migration | Complete | COMPLETE | T2-DB-0150 | DAG | T2 |  |
| 1783 | 1.8.1.3.2 | **Tranche 2** |  | 130d | 2023-05-18 A | 2023-11-15 A |  | 100% | 2023-05-18 | 2023-11-15 | 130d | 2023-05-18 | 2023-08-03 | N/A | 1984h | 1984h | -0 | N/A | N/A | 5.0 | Migration |  |  |  |  |  |  |
| 1784 | 1.8.1.3.2.1 | Develop Initial design artefacts and supporting technical details |  | 76d | 2023-05-18 A | 2023-08-31 A | 1782 | 100% | 2023-05-18 | 2023-08-31 | 76d | 2023-05-18 | 2023-07-26 | Andrew Margan | 608h | 608h |  | SRO | PP, CPT, SRO Design | 5.5 | Migration | Complete | COMPLETE |  |  |  |  |
| 1785 | 1.8.1.3.2.2 | Communicate Initial Design Artefacts with Industry (MTDSG) |  | 1d | 2023-09-01 A | 2023-09-01 A | 1784 | 100% | 2023-09-01 | 2023-09-01 | 1d |  |  | Andrew Margan | 8h | 8h |  | SRO | PP, CPT, SRO Design | 5.5 | Migration | Complete | COMPLETE |  |  |  |  |
| 1786 | 1.8.1.3.2.3 | Host MTDSG |  | 1d | 2023-09-11 A | 2023-09-11 A | 1785FS+5d | 100% | 2023-09-11 | 2023-09-11 | 1d |  |  | Andrew Margan | 8h | 8h |  | SRO | PP, CPT, SRO Design | 5.5 | Migration | Complete | COMPLETE |  |  |  |  |
| 1787 | 1.8.1.3.2.4 | Process MTDSG Feedback and Amend Design Artefacts |  | 4d | 2023-09-12 A | 2023-09-15 A | 1786 | 100% | 2023-09-12 | 2023-09-15 | 4d |  |  | Andrew Margan | 32h | 32h |  | SRO | PP, CPT, SRO Design | 5.5 | Migration | Complete | COMPLETE |  |  |  |  |
| 1788 | 1.8.1.3.2.5 | Communicate Amended Design Artefacts with Industry |  | 1d | 2023-09-15 A | 2023-09-15 A | 1787FF | 100% | 2023-09-15 | 2023-09-15 | 1d |  |  | Andrew Margan | 8h | 8h |  | SRO | PP, CPT, SRO Design | 5.5 | Migration | Complete | COMPLETE |  |  |  |  |
| 1789 | 1.8.1.3.2.6 | Host MTDSG |  | 1d | 2023-09-26 A | 2023-09-26 A | 1788FS+6d | 100% | 2023-09-26 | 2023-09-26 | 1d |  |  | Andrew Margan | 8h | 8h |  | SRO | PP, CPT, SRO Design | 5.5 | Migration | Complete | COMPLETE |  |  |  |  |
| 1790 | 1.8.1.3.2.7 | Make Final Amendments to Design Artefact |  | 5d | 2023-09-27 A | 2023-10-03 A | 1789 | 100% | 2023-09-27 | 2023-10-03 | 5d |  |  | Andrew Margan | 40h | 40h |  | SRO | PP, CPT, SRO Design | 5.5 | Migration | Complete | COMPLETE |  |  |  |  |
| 1791 | 1.8.1.3.2.8 | Request DAG Consultation |  | 1d | 2023-10-04 A | 2023-10-04 A | 1790 | 100% | 2023-10-04 | 2023-10-04 | 1d |  |  | Andrew Margan | 8h | 8h |  | SRO | PP, CPT, SRO Design | 5.5 | Migration | Complete | COMPLETE |  |  |  |  |
| 1792 | 1.8.1.3.2.9 | Consultation Period |  | 11d | 2023-10-04 A | 2023-10-18 A | 1791SS | 100% | 2023-10-04 | 2023-10-18 | 11d |  |  | Andrew Margan | 88h | 88h |  | SRO | PP, CPT, SRO Design | 5.5 | Migration | Complete | COMPLETE |  |  |  |  |
| 1793 | 1.8.1.3.2.10 | Action Consultation Comments |  | 5d | 2023-10-19 A | 2023-10-25 A | 1792 | 100% | 2023-10-19 | 2023-10-25 | 5d |  |  | Andrew Margan | 40h | 40h |  | SRO | PP, CPT, SRO Design | 5.5 | Migration | Complete | COMPLETE |  |  |  |  |
| 1794 | 1.8.1.3.2.11 | Post Consultation Industry Assurance |  | 5d | 2023-10-26 A | 2023-11-01 A | 1793 | 100% | 2023-10-26 | 2023-11-01 | 5d |  |  | Andrew Margan | 40h | 40h |  | SRO | PP, CPT, SRO Design | 5.5 | Migration | Complete | COMPLETE |  |  |  |  |
| 1795 | 1.8.1.3.2.12 | Request DAG Approval |  | 1d | 2023-11-01 A | 2023-11-01 A | 1794FF | 100% | 2023-11-01 | 2023-11-01 | 1d |  |  | Andrew Margan | 8h | 8h |  | SRO | PP, CPT, SRO Design | 5.5 | Migration | Complete | COMPLETE |  |  |  |  |
| 1796 | 1.8.1.3.2.13 | DAG Transition Design Approved |  | 1d | 2023-11-08 A | 2023-11-08 A | 1795FS+4d | 100% | 2023-11-08 | 2023-11-08 | 1d |  |  | Andrew Margan | 8h | 8h |  | SRO | PP, CPT, SRO Design | 5.5 | Migration | Complete | COMPLETE |  |  |  |  |
| 1797 | 1.8.1.3.2.14 | Update Transition Design Admin |  | 5d | 2023-11-09 A | 2023-11-15 A | 1796 | 100% | 2023-11-09 | 2023-11-15 | 5d |  |  | Andrew Margan | 40h | 40h |  | SRO | PP, CPT, SRO Design | 5.5 | Migration | Complete | COMPLETE |  |  |  |  |
| 1798 | 1.8.1.3.2.15 | Tranche 2 Transition Design Baselined | milestone | 0d | 2023-11-15 A | 2023-11-15 A | 1797 | 100% | 2023-11-15 | 2023-11-15 | 0d | 2023-08-03 | 2023-08-03 | Andrew Margan |  |  |  | SRO | PP, CPT, SRO Design | 5.12 | Migration | Complete | COMPLETE | T2-DB-0250 | DAG | T2 | 14/8 - Date aligns with DAG |

Notes:
- 1798: 14/8 - Milestone aligned to 5 days after DAG approval, to update comms and admin on collaboration base. CR number to be added. 15/9 - Rebaseline approved at DAG on 13/9/23 / Action: 2/8/23 - needs to be replanned to 15//11/23. AM to raise CR as T2 milestone

| ID | WBS | Task | Type | Duration | Start | Finish | Predecessors | Complete | Remaining | Baseline start | Baseline finish | Baseline duration | Baseline 1 start | Baseline 1 finish | Total slack | Free slack | Resources | Work | Actual work | Responsible | Involved | Update Version | MHHS Programme Phase | Sched Status | RAG | Milestone ID | Text29 | Tier | Action | Task Status |
| --- | --- | --- | --- | --- | --- | --- | --- | --- | --- | --- | --- | --- | --- | --- | --- | --- | --- | --- | --- | --- | --- | --- | --- | --- | --- | --- | --- | --- | --- | --- |
| 1799 | 1.8.1.4 | **Data Assessment Report** |  | 61d | 2022-12-06 A | 2023-02-28 A |  | 100% |  | 2022-12-06 | 2023-02-28 | 61d | 2022-12-06 | 2023-02-28 |  |  | N/A | 1672h | 1672h | N/A | N/A | 5.0 | Migration |  |  |  |  |  |  |  |
| 1800 | 1.8.1.4.1 | Develop document with MWG |  | 49d | 2022-12-06 A | 2023-02-10 A |  | 100% |  | 2022-12-06 | 2023-02-10 | 49d | 2022-12-06 | 2023-02-10 |  |  | John Wiggins; Matthew Breen | 784h | 784h | SI Migration |  | 5.0 | Migration | Complete | COMPLETE |  |  |  |  |  |
| 1801 | 1.8.1.4.2 | Artefact review (via TMAG) and updates |  | 25d | 2023-01-18 A | 2023-02-21 A | 1800FS-18d | 100% |  | 2023-01-18 | 2023-02-21 | 25d | 2023-01-18 | 2023-02-21 |  |  | John Wiggins; Matthew Breen | 400h | 400h | PP | IPA,SI Migration | 5.0 | Migration | Complete | COMPLETE |  |  |  |  |  |
| 1802 | 1.8.1.4.3 | Data Assessment Report approved | milestone | 0d | 2023-02-28 A | 2023-02-28 A | 1801FS+5d | 100% |  | 2023-02-28 | 2023-02-28 | 0d | 2023-02-28 | 2023-02-28 |  |  | John Wiggins; Matthew Breen |  |  | SI Migration | PP,IPA | 5.0 | Migration | Complete | COMPLETE | T3-MI-0012 | MCAG | T3 |  |  |
| 1803 | 1.8.1.5 | **Migration, Cutover & Data Strategy (incl. Migration Entry Criteria)** |  | 102d | 2022-12-08 A | 2023-04-28 A |  | 100% |  | 2022-12-08 | 2023-04-28 | 102d | 2022-12-08 | 2023-04-28 |  |  | N/A | 2336h | 2336h | N/A | N/A | 5.0 | Migration |  |  |  |  |  |  |  |
| 1804 | 1.8.1.5.1 | Develop document with MWG |  | 67d | 2022-12-08 A | 2023-03-10 A | 1767 | 100% |  | 2022-12-08 | 2023-03-10 | 67d | 2022-12-08 | 2023-03-10 |  |  | John Wiggins; Matthew Breen | 1072h | 1072h | SI Migration | PP | 5.0 | Migration | Complete | COMPLETE |  |  |  |  |  |
| 1805 | 1.8.1.5.2 | Artefact review (via TMAG) and updates |  | 28d | 2023-03-15 A | 2023-04-21 A | 1804FS+2d | 100% |  | 2023-03-15 | 2023-04-21 | 28d | 2023-03-15 | 2023-04-21 |  |  | John Wiggins; Matthew Breen | 448h | 448h | PP | SI Migration | 5.0 | Migration | Complete | COMPLETE |  |  |  |  |  |
| 1806 | 1.8.1.5.3 | Migration, Cutover & Data Strategy approved | milestone | 0d | 2023-04-28 A | 2023-04-28 A | 1805FF+5d | 100% |  | 2023-04-28 | 2023-04-28 | 0d | 2023-04-28 | 2023-04-28 |  |  | John Wiggins; Matthew Breen |  |  | SI Migration | PP | 5.0 | Migration | Complete | COMPLETE | T3-MI-0014 | MCAG | T3 |  |  |
| 1807 | 1.8.1.6 | **Data Cleanse Plan** |  | 547d | 2023-03-02 A | 2025-04-04 |  | 53% | 256.53d | 2023-03-02 | 2025-04-04 | 547d | 2023-03-02 | 2025-04-04 | 560d |  | N/A | 15352h | 4093.33h | N/A | N/A | 5.0 | Migration |  |  |  |  |  |  |  |
| 1808 | 1.8.1.6.1 | Develop document with MWG |  | 50d | 2023-03-02 A | 2023-05-10 A |  | 100% |  | 2023-03-02 | 2023-05-10 | 50d | 2023-03-02 | 2023-05-10 |  |  | John Wiggins; Matthew Breen | 800h | 800h | SI Migration | PP | 5.0 | Migration | Complete | COMPLETE |  |  |  |  |  |
| 1809 | 1.8.1.6.2 | Artefact review (via TMAG) and updates |  | 20d | 2023-05-11 A | 2023-06-07 A | 1808 | 100% |  | 2023-05-11 | 2023-06-07 | 20d | 2023-05-11 | 2023-06-07 |  |  | John Wiggins; Matthew Breen | 320h | 320h | PP | SI Migration,IPA | 5.0 | Migration | Complete | COMPLETE |  |  |  |  |  |
| 1810 | 1.8.1.6.3 | Data Cleanse Plan approved | milestone | 0d | 2023-07-19 A | 2023-07-19 A | 1809FS+30d | 100% |  | 2023-07-19 | 2023-07-19 | 0d | 2023-06-14 | 2023-06-14 |  |  | John Wiggins; Matthew Breen |  |  | SI Migration | PP | 5.0 | Migration | Complete | COMPLETE | T3-MI-0020 | MCAG | T3 |  |  |
| 1811 | 1.8.1.6.4 | Monitor Programme Participant adherence to Data Cleanse Plan |  | 467d | 2023-06-15 A | 2025-03-28 | 1810 | 47% | 247d | 2023-06-15 | 2025-03-28 | 467d | 2023-06-15 | 2025-03-28 | 560d | 0d | Matthew Breen | 3736h | 1760h | SI Migration | PP | 5.0 | Migration | Green | GREEN |  |  |  |  |  |
| 1812 | 1.8.1.6.5 | **MTDs** |  | 91d | 2024-08-16 | 2024-12-20 |  |  |  | 2024-08-16 | 2024-12-23 | 91d |  |  | 635d |  | N/A | 2200h |  | N/A | N/A | 5.4 | Migration |  |  |  |  |  |  |  |
| 1813 | 1.8.1.6.5.1 | **ESME ID** |  | 90d | 2024-08-16 | 2024-12-20 |  |  |  | 2024-08-16 | 2024-12-23 | 90d |  |  | 635d |  | N/A | 728h |  | N/A | N/A | 5.4 | Migration |  |  |  |  |  |  |  |
| 1814 | 1.8.1.6.5.1.1 | DCC to extract ESME ID and share with LDSO | milestone | 0d | 2024-08-16 | 2024-08-16 | 1810FS+282d |  |  | 2024-08-16 | 2024-08-16 | 0d |  |  | 635d | 0d | Matthew Breen |  |  | DCC/SI |  | 5.5 | Migration | Green | GREEN | T3-MI-0024 | MCAG | T3 | 27/7 - add in as T3 Milestone | 120.71 |
| 1815 | 1.8.1.6.5.1.2 | LDSO ‘full refresh’ between their Registration Service and the EES (ESME ID) | milestone | 0d | 2024-09-27 | 2024-09-27 | 1814FS+30d |  |  | 2024-09-27 | 2024-09-27 | 0d |  |  | 635d | 0d | Matthew Breen |  |  | LDSO/EES |  | 5.5 | Migration | Green | GREEN | T3-MI-0025 | MCAG | T3 | 27/7 - add in as T3 Milestone. Actual start is 29/9/24 | 162.71 |
| 1816 | 1.8.1.6.5.1.3 | Suppliers complete investigation of exceptions and resolution of exceptions |  | 1d | 2024-12-20 | 2024-12-20 | 1815FS+59d |  |  | 2024-12-20 | 2024-12-20 | 1d |  |  | 635d | 0d | Matthew Breen | 8h |  | Supplier |  | 5.4 | Migration | Green | GREEN |  |  |  |  | 246.33 |
| 1817 | 1.8.1.6.5.1.4 | ESME ID Complete | milestone | 0d | 2024-12-20 | 2024-12-20 | 1816 |  |  | 2024-12-23 | 2024-12-23 | 0d |  |  | 635d | 75d | Matthew Breen |  |  |  |  | 5.4 | Migration | Green | GREEN |  |  |  |  | 246.71 |
| 1818 | 1.8.1.6.5.2 | **Meter Location and Number of Displayed Register Digits** |  | 91d | 2024-08-16 | 2024-12-20 |  |  |  | 2024-08-16 | 2024-12-23 | 91d |  |  | 635d |  | N/A | 744h |  | N/A | N/A | 5.4 | Migration |  |  |  |  |  |  |  |
| 1819 | 1.8.1.6.5.2.1 | MEM to extract data and share with LDSO |  | 1d | 2024-08-16 | 2024-08-16 | 1810FS+281d |  |  | 2024-08-16 | 2024-08-16 | 1d |  |  | 635d | 0d | Matthew Breen | 8h |  | MEM/SI |  | 5.4 | Migration | Green | GREEN |  |  |  |  | 120.33 |
| 1820 | 1.8.1.6.5.2.2 | LDSO ‘full refresh’ between their Registration Service and the EES (Meter Location and Number of Displayed Register Digits) | milestone | 0d | 2024-09-27 | 2024-09-27 | 1819FS+30d |  |  | 2024-09-27 | 2024-09-27 | 0d |  |  | 635d | 0d | Matthew Breen |  |  | LDSO /EES |  | 5.5 | Migration | Green | GREEN | T3-MI-0026 | MCAG | T3 | 27/7 - add in as T3 Milestone | 162.71 |
| 1821 | 1.8.1.6.5.2.3 | Suppliers complete investigation of exceptions and resolution of exceptions |  | 1d | 2024-12-20 | 2024-12-20 | 1820FS+59d |  |  | 2024-12-20 | 2024-12-20 | 1d |  |  | 635d | 0d | Matthew Breen | 8h |  | Supplier |  | 5.4 | Migration | Green | GREEN |  |  |  |  | 246.33 |
| 1822 | 1.8.1.6.5.2.4 | Meter Location and Number of Displayed Register Digits Complete | milestone | 0d | 2024-12-20 | 2024-12-20 | 1821 |  |  | 2024-12-23 | 2024-12-23 | 0d |  |  | 635d | 75d | Matthew Breen |  |  |  |  | 5.4 | Migration | Green | GREEN |  |  |  |  | 246.71 |

Notes:
- 1812: 27/7 - CH added in with Matthew Breen
- 1813: 27/7 - CH added in with Matthew Breen
- 1814: 27/7 - CH added in with Matthew Breen
- 1815: 27/7 - CH added in with Matthew Breen
- 1816: 27/7 - CH added in with Matthew Breen
- 1817: 27/7 - CH added in with Matthew Breen
- 1818: 27/7 - CH added in with Matthew Breen
- 1819: 27/7 - CH added in with Matthew Breen
- 1820: 27/7 - CH added in with Matthew Breen
- 1821: 27/7 - CH added in with Matthew Breen
- 1822: 27/7 - CH added in with Matthew Breen

| ID | WBS | Task | Type | Duration | Start | Finish | Predecessors | Complete | Remaining | Baseline start | Baseline finish | Baseline duration | Baseline 1 start | Baseline 1 finish | Total slack | Free slack | Resources | Work | Actual work | Baseline cost | Responsible | Involved | Update Version | MHHS Programme Phase | Action | Task Status | Sched Status | RAG | Milestone ID | Text29 | Tier | Guidance |
| --- | --- | --- | --- | --- | --- | --- | --- | --- | --- | --- | --- | --- | --- | --- | --- | --- | --- | --- | --- | --- | --- | --- | --- | --- | --- | --- | --- | --- | --- | --- | --- | --- |
| 1823 | 1.8.1.6.6 | **Registration Data** |  | 147d | 2024-09-06 | 2025-03-31 |  |  |  | 2024-09-06 | 2025-03-31 | 147d |  |  | 564d |  | N/A | 1480h |  |  | N/A | N/A | 5.4 | Migration |  |  |  |  |  |  |  |  |
| 1824 | 1.8.1.6.6.1 | **Connection Type** |  | 16d | 2024-09-06 | 2024-09-27 |  |  |  | 2024-09-06 | 2024-09-27 | 16d |  |  | 695d |  | N/A | 144h |  |  | N/A | N/A | 5.4 | Migration |  |  |  |  |  |  |  |  |
| 1825 | 1.8.1.6.6.1.1 | Automated Population of Connection Type for Measurement Classes ‘B’, ‘D’, ‘F’ & ‘G’ | milestone | 0d | 2024-09-13 | 2024-09-13 | 1810FS+302d |  |  | 2024-09-13 | 2024-09-13 | 0d |  |  | 705d | 10d | Matthew Breen |  |  |  | LDSO |  | 5.5 | Migration | 27/7 - add in as T3 Milestone | 148.71 | Green | GREEN | T3-MI-0027 | MCAG | T3 |  |
| 1826 | 1.8.1.6.6.1.2 | BAU Population of Connection Type for Site Specific LLFCs within Measurement Classes ‘C’ & ‘E’ | milestone | 0d | 2024-09-13 | 2024-09-13 | 1810FS+302d |  |  | 2024-09-13 | 2024-09-13 | 0d |  |  | 705d | 10d | Matthew Breen |  |  |  | LDSO |  | 5.5 | Migration | 27/7 - add in as T3 Milestone | 148.71 | Green | GREEN | T3-MI-0028 | MCAG | T3 |  |
| 1827 | 1.8.1.6.6.1.3 | Automated Population of Connection Type for Smart Meters within Measurement Class ‘A’ | milestone | 0d | 2024-09-13 | 2024-09-13 | 1810FS+302d |  |  | 2024-09-13 | 2024-09-13 | 0d |  |  | 705d | 10d | Matthew Breen |  |  |  | LDSO |  | 5.5 | Migration | 27/7 - add in as T3 Milestone | 148.71 | Green | GREEN | T3-MI-0029 | MCAG | T3 |  |
| 1828 | 1.8.1.6.6.1.4 | Population of Connection Type for Traditional and Advanced Meters within Measurement Class ‘A’ |  | 1d | 2024-09-06 | 2024-09-06 | 1810FS+296d |  |  | 2024-09-06 | 2024-09-06 | 1d |  |  | 710d | 15d | Matthew Breen | 8h |  |  | Suppliers |  | 5.4 | Migration |  | 141.33 | Green | GREEN |  |  |  |  |
| 1829 | 1.8.1.6.6.1.5 | Automated Population of Null Connection Type | milestone | 0d | 2024-09-13 | 2024-09-13 | 1810FS+302d |  |  | 2024-09-13 | 2024-09-13 | 0d |  |  | 705d | 10d | Matthew Breen |  |  |  | LDSO |  | 5.5 | Migration | 27/7 - add in as T3 Milestone | 148.71 | Green | GREEN | T3-MI-0030 | MCAG | T3 |  |
| 1830 | 1.8.1.6.6.1.6 | Full MPAN refresh to ESS |  | 1d | 2024-09-27 | 2024-09-27 | 1810FS+311d |  |  | 2024-09-27 | 2024-09-27 | 1d |  |  | 695d | 0d | Matthew Breen | 8h |  |  | LDSO/EES |  | 5.4 | Migration |  | 162.33 | Green | GREEN |  |  |  | Actually takes place on 29/9/24 which is a Sunday |
| 1831 | 1.8.1.6.6.1.7 | Connection Type Complete | milestone | 0d | 2024-09-27 | 2024-09-27 | 1825, 1826, 1827, 1828, 1829, 1830 |  |  | 2024-09-27 | 2024-09-27 | 0d |  |  | 695d | 135d | Matthew Breen |  |  |  |  |  | 5.4 | Migration |  | 162.71 | Green | GREEN |  |  |  |  |
| 1832 | 1.8.1.6.6.2 | **Domestic Premises Indicator** |  | 17d | 2025-03-07 | 2025-03-31 |  |  |  | 2025-03-07 | 2025-03-31 | 17d |  |  | 564d |  | N/A | 160h |  |  | N/A | N/A | 5.4 | Migration |  |  |  |  |  |  |  |  |
| 1833 | 1.8.1.6.6.2.1 | The DCC to extract Domestic Premises Indicator from the CSS and provide a file to each LDSO and EES. |  | 1d | 2025-03-07 | 2025-03-07 | 1810FS+426d |  |  | 2025-03-07 | 2025-03-07 | 1d |  |  | 564d | 0d | Matthew Breen | 8h |  |  | DCC |  | 5.4 | Migration |  | 323.33 | Green | GREEN |  |  |  | 27/7 - needs to end on date of M10 7/3/25 |
| 1834 | 1.8.1.6.6.2.2 | Each LDSO notifies the DCC of any exceptions |  | 1d | 2025-03-07 | 2025-03-07 | 1810FS+426d |  |  | 2025-03-07 | 2025-03-07 | 1d |  |  | 564d | 0d | Matthew Breen | 8h |  |  | LDSO |  | 5.4 | Migration |  | 323.33 | Green | GREEN |  |  |  | 27/7 - needs to end on date of M10 7/3/25 |
| 1835 | 1.8.1.6.6.2.3 | Each LDSO and DCC completes investigation and resolution of exceptions |  | 1d | 2025-03-31 | 2025-03-31 | 1833FS+15d, 1834FS+15d |  |  | 2025-03-31 | 2025-03-31 | 1d |  |  | 564d | 0d | Matthew Breen | 8h |  |  | LDSO / DCC |  | 5.4 | Migration |  | 347.33 | Green | GREEN |  |  |  | 27/7 Needs to take place approx. 1 month after M10 |
| 1836 | 1.8.1.6.6.2.4 | Domestic Premises Indicator Complete | milestone | 0d | 2025-03-31 | 2025-03-31 | 1835 |  |  | 2025-03-31 | 2025-03-31 | 0d |  |  | 564d | 4d | Matthew Breen |  |  |  |  |  | 5.4 | Migration |  | 347.71 | Green | GREEN |  |  |  |  |
| 1837 | 1.8.1.6.7 | **Export / Import MPANs** |  | 151d | 2024-03-22 A | 2024-10-18 |  | 33% | 100.67d | 2024-03-22 | 2024-10-18 | 151d |  |  | 680d |  | N/A | 2440h | 813.33h |  | N/A | N/A | 5.4 | Migration |  |  |  |  |  |  |  |  |
| 1838 | 1.8.1.6.7.1 | **Linking of Export / Import MPANS** |  | 151d | 2024-03-22 A | 2024-10-18 |  | 33% | 100.67d | 2024-03-22 | 2024-10-18 | 151d |  |  | 680d |  | N/A | 1232h | 410.67h |  | N/A | N/A | 5.4 | Migration |  |  |  |  |  |  |  |  |
| 1839 | 1.8.1.6.7.1.1 | LDSO utilises BAU processing (DB05s) to populate each import/export association |  | 1d | 2024-03-22 A | 2024-03-22 A | 1810FS+176d | 100% |  | 2024-03-22 | 2024-03-22 | 1d |  |  |  |  | Matthew Breen | 8h | 8h |  | LDSO |  | 5.4 | Migration |  |  | Complete | COMPLETE |  |  |  |  |
| 1840 | 1.8.1.6.7.1.2 | Each LDSO notifies the Registered Supplier of any exceptions |  | 1d | 2024-04-19 | 2024-04-19 | 1839FS+19d |  |  | 2024-04-19 | 2024-04-19 | 1d |  |  | 680d | 0d | Matthew Breen | 8h |  |  | LDSO |  | 5.4 | Migration |  | 1.33 | Green | GREEN |  |  |  |  |
| 1841 | 1.8.1.6.7.1.3 | Each Supplier completes investigation and resolution of exceptions |  | 1d | 2024-08-23 | 2024-08-23 | 1840FS+89d |  |  | 2024-08-23 | 2024-08-23 | 1d |  |  | 680d | 0d | Matthew Breen | 8h |  |  | Supplier |  | 5.4 | Migration |  | 127.33 | Green | GREEN |  |  |  |  |
| 1842 | 1.8.1.6.7.1.4 | Each LDSO has linked al relevant import/export MPANS | milestone | 0d | 2024-10-18 | 2024-10-18 | 1841FS+40d |  |  | 2024-10-18 | 2024-10-18 | 0d |  |  | 680d | 0d | Matthew Breen |  |  |  | LDSO |  | 5.5 | Migration | 27/7 - add in as T3 Milestone | 183.71 | Green | GREEN | T3-MI-0031 | MCAG | T3 |  |
| 1843 | 1.8.1.6.7.1.5 | Linking of Export / Import MPANS Complete | milestone | 0d | 2024-10-18 | 2024-10-18 | 1842 |  |  | 2024-10-18 | 2024-10-18 | 0d |  |  | 680d | 120d | Matthew Breen |  |  |  |  |  | 5.4 | Migration |  | 183.71 | Green | GREEN |  |  |  |  |
| 1844 | 1.8.1.6.8 | Pre-migration data cleanse complete | milestone | 0d | 2025-04-04 | 2025-04-04 | 1930FS-20d, 1932FS-20d, 1811FS+5d, 1817, 1822, 1831, 1836, 1843 |  |  | 2025-04-04 | 2025-04-04 | 0d | 2025-04-04 | 2025-04-04 | 560d |  | Matthew Breen |  |  |  | SI Migration | PP | 5.0 | Migration |  | 351.71 | Green | GREEN | T2-MI-0450 | MCAG | T2 |  |
| 1845 | 1.8.2 | **Migration Period Planning** |  | 851d | 2023-07-03 A | 2026-10-05 |  | 17% | 708.99d | 2023-07-03 | 2026-10-05 | 851d | 2023-07-03 | 2026-10-05 | 169d |  | N/A | 37298.4h | 5799.18h | -0 | N/A | N/A | 5.0 | Migration |  | M10 |  |  |  |  |  |  |
| 1846 | 1.8.2.1 | **Migration Implementation Plan (incl. Migration Exit Criteria)** |  | 851d | 2023-07-03 A | 2026-10-05 |  | 23% | 656.82d | 2023-07-03 | 2026-10-05 | 851d | 2023-07-03 | 2026-10-05 | 169d |  | N/A | 24754.2h | 5799.18h | -0 | N/A | N/A | 5.0 | Migration |  |  |  |  |  |  |  |  |
| 1847 | 1.8.2.1.1 | **Migration Threshold Volumes** |  | 101d | 2023-07-03 A | 2023-11-20 A |  | 100% |  | 2023-07-03 | 2023-11-15 | 98d | 2023-07-03 | 2023-08-31 |  |  | N/A | 2424h | 2424h | -0 | N/A | N/A | 5.0 | Migration |  |  |  |  |  |  |  |  |
| 1848 | 1.8.2.1.1.1 | Threshold volumes reviewed by MWG |  | 54d | 2023-07-03 A | 2023-09-14 A |  | 100% |  | 2023-07-03 | 2023-09-14 | 54d | 2023-07-03 | 2023-07-28 |  |  | John Wiggins; Matthew Breen | 864h | 864h |  | SI Migration | PP | 5.6 | Migration |  |  | Complete | COMPLETE |  |  |  |  |
| 1849 | 1.8.2.1.1.2 | Artefact review (via TMAG) and updates |  | 47d | 2023-09-15 A | 2023-11-20 A | 1848 | 100% |  | 2023-09-15 | 2023-11-15 | 44d | 2023-07-31 | 2023-08-31 |  |  | John Wiggins; Matthew Breen | 752h | 752h |  | PP | SI Migration | 5.9 | Migration |  |  | Complete | COMPLETE |  |  |  |  |
| 1850 | 1.8.2.1.1.3 | Threshold volumes approved at TMAG | milestone | 0d | 2023-11-20 A | 2023-11-20 A | 1849 | 100% |  | 2023-11-15 | 2023-11-15 | 0d | 2023-08-31 | 2023-08-31 |  |  | John Wiggins; Matthew Breen |  |  |  | SI Migration | PP | 5.12 | Migration | 25/8 - Alex said update date to 31/8 |  | Complete | COMPLETE | T3-MI-0021 | SITAG | T3 |  |

Notes:
- 1823: 27/7 - CH added in with Matthew Breen
- 1824: 27/7 - CH added in with Matthew Breen
- 1825: 27/7 - CH added in with Matthew Breen
- 1826: 27/7 - CH added in with Matthew Breen
- 1827: 27/7 - CH added in with Matthew Breen
- 1828: 27/7 - CH added in with Matthew Breen
- 1829: 27/7 - CH added in with Matthew Breen
- 1830: 27/7 - CH added in with Matthew Breen
- 1831: 27/7 - CH added in with Matthew Breen
- 1832: 27/7 - CH added in with Matthew Breen
- 1833: 27/7 - CH added in with Matthew Breen
- 1834: 27/7 - CH added in with Matthew Breen
- 1835: 27/7 - CH added in with Matthew Breen
- 1836: 27/7 - CH added in with Matthew Breen
- 1837: 27/7 - CH added in with Matthew Breen
- 1838: 27/7 - CH added in with Matthew Breen
- 1839: 27/7 - CH added in with Matthew Breen
- 1840: 27/7 - CH added in with Matthew Breen
- 1841: 27/7 - CH added in with Matthew Breen
- 1842: 27/7 - CH added in with Matthew Breen
- 1843: 27/7 - CH added in with Matthew Breen
- 1849: 7/11 - Red because date of TMAG chnaged
- 1850: Red as plan was to approve at extraordinary TMAG on 8/11, however regular TMAG taking place on 15/11 so deferred approval to this date. To go to TMAG for date change. Approved for date change at TMAG on 23/10/23. 7/11 - Red because date of TMAG changed

| ID | WBS | Task | Type | Duration | Start | Finish | Predecessors | Complete | Remaining | Baseline start | Baseline finish | Baseline duration | Baseline 1 start | Baseline 1 finish | Total slack | Free slack | Constraint | Resources | Work | Actual work | Baseline cost | Responsible | Involved | Update Version | MHHS Programme Phase | Task Status | Sched Status | RAG | Milestone ID | Text29 | Tier |
| --- | --- | --- | --- | --- | --- | --- | --- | --- | --- | --- | --- | --- | --- | --- | --- | --- | --- | --- | --- | --- | --- | --- | --- | --- | --- | --- | --- | --- | --- | --- | --- |
| 1851 | 1.8.2.1.2 | **Operational Migration Planning** |  | 526d | 2024-09-30 | 2026-10-05 |  |  |  | 2024-09-30 | 2026-10-05 | 526d | 2024-09-30 | 2026-10-05 | 169d |  |  | N/A | 10576h |  |  | N/A | N/A | 5.0 | Migration |  |  |  |  |  |  |
| 1852 | 1.8.2.1.2.1 | Agree migration plans for each SIT MVC Supplier |  | 55d | 2024-09-30 | 2024-12-16 | 1926SF-3mo |  |  | 2024-09-30 | 2024-12-16 | 55d | 2024-09-30 | 2024-12-16 | 605d | 0d |  | Warren Fulton | 440h |  |  | SRO | PP | 5.0 | Migration | 165.33 | Green | GREEN |  |  |  |
| 1853 | 1.8.2.1.2.2 | Initial migration plan agreed at SITAG |  | 35d | 2024-12-16 | 2025-01-31 | 1852 |  |  | 2024-12-16 | 2025-01-31 | 35d | 2024-12-16 | 2025-01-31 | 605d | 0d |  | Warren Fulton | 280h |  |  | SRO |  | 5.0 | Migration | 242.33 | Green | GREEN |  |  |  |
| 1854 | 1.8.2.1.2.3 | Migration Period Plan Review 1 Completed | milestone | 0d | 2025-01-31 | 2025-01-31 | 1853 |  |  | 2025-01-31 | 2025-01-31 | 0d | 2025-01-31 | 2025-01-31 | 605d |  |  | Warren Fulton |  |  |  | SRO | PP,IPA | 5.0 | Migration | 288.71 | Green | GREEN | T3-MI-0016 | MCAG | T3 |
| 1855 | 1.8.2.1.2.4 | Finalise initial live plan |  | 1d | 2025-04-07 | 2025-04-07 | 1930 |  |  | 2025-04-07 | 2025-04-07 | 1d | 2025-04-07 | 2025-04-07 | 559d |  |  | Warren Fulton | 8h |  |  | SRO |  | 5.0 | Migration | 354.33 | Green | GREEN |  |  |  |
| 1856 | 1.8.2.1.2.5 | Agree migration plans with suppliers aligned with qualification tranches |  | 314d | 2024-12-30 | 2026-03-12 | 1934FF |  |  | 2025-01-01 | 2026-03-16 | 314d | 2025-01-01 | 2026-03-16 | 316d |  |  | Warren Fulton | 2512h |  |  | SRO | PP | 5.0 | Migration | 256.33 | Green | GREEN |  |  |  |
| 1857 | 1.8.2.1.2.6 | Migration control centre undertakes iterative planning and performance monitoring |  | 391d | 2025-04-07 | 2026-10-05 | 1930 |  |  | 2025-04-07 | 2026-10-05 | 391d | 2025-04-07 | 2026-10-05 | 169d |  |  | Warren Fulton | 3128h |  |  | SRO |  | 5.0 | Migration | 354.33 | Green | GREEN |  |  |  |
| 1858 | 1.8.2.1.3 | **Define acceptance criteria for M15** |  | 78d | 2023-09-04 A | 2023-12-20 A |  | 100% |  | 2023-09-04 | 2023-12-20 | 78d | 2023-09-04 | 2023-11-30 |  |  |  | N/A | 1872h | 1872h | -0 | N/A | N/A | 5.0 | Migration |  |  |  |  |  |  |
| 1859 | 1.8.2.1.3.1 | Review acceptance criteria and reporting requirements with MWG |  | 49d | 2023-09-04 A | 2023-11-09 A |  | 100% |  | 2023-09-04 | 2023-10-27 | 40d | 2023-09-04 | 2023-10-27 |  |  | start no earlier than 2023-09-04 | John Wiggins; Matthew Breen | 784h | 784h |  | SI Migration |  | 5.0 | Migration |  | Complete | COMPLETE |  |  |  |
| 1860 | 1.8.2.1.3.2 | Artefact review (via TMAG) and updates |  | 29d | 2023-11-10 A | 2023-12-20 A | 1859 | 100% |  | 2023-11-10 | 2023-12-20 | 29d | 2023-10-30 | 2023-11-30 |  |  | start no earlier than 2023-10-30 | John Wiggins; Matthew Breen | 464h | 464h |  | PP | SI Migration | 5.0 | Migration |  | Complete | COMPLETE |  |  |  |
| 1861 | 1.8.2.1.3.3 | Acceptance criteria for M15 agreed at TMAG | milestone | 0d | 2023-12-20 A | 2023-12-20 A | 1860 | 100% |  | 2023-12-20 | 2023-12-20 | 0d | 2023-11-30 | 2023-11-30 |  |  | finish no earlier than 2023-11-30 | John Wiggins; Matthew Breen |  |  |  | SI Migration |  | 5.14 | Migration |  | Complete | COMPLETE | T3-MI-0022 | SITAG | T3 |
| 1862 | 1.8.2.1.4 | **M10/M11 cut-over plan** |  | 114d | 2023-12-21 A | 2024-05-28 |  | 88% | 14.1d | 2023-12-21 | 2024-05-28 | 114d | 2024-01-01 | 2024-05-31 | 683d |  |  | N/A | 1688h | 1479.17h | -0 | N/A | N/A | 5.16 | Migration |  |  |  |  |  |  |
| 1863 | 1.8.2.1.4.1 | Draft Document |  | 84d | 2023-12-21 A | 2024-04-16 A | 1861 | 100% |  | 2023-12-21 | 2024-04-16 | 84d |  |  |  |  |  | Matthew Breen | 672h | 672h |  | SI Transition | SI Transition,PP,SRO | 5.16 |  |  | Complete | COMPLETE |  |  |  |
| 1864 | 1.8.2.1.4.2 | Share Document with SRO |  | 1d | 2024-04-17 A | 2024-04-17 A | 1863 | 100% |  | 2024-04-17 | 2024-04-17 | 1d |  |  |  |  |  | Matthew Breen | 8h | 8h |  | SI Transition | SI Transition,PP,SRO | 5.16 |  |  | Complete | COMPLETE |  |  |  |
| 1865 | 1.8.2.1.4.3 | Industry Consultation |  | 11d | 2024-04-23 | 2024-05-07 | 1864FS+3d |  |  | 2024-04-23 | 2024-05-07 | 11d |  |  | 683d | 0d |  | Matthew Breen | 88h |  |  | SI Transition | SI Transition,PP,SRO | 5.16 |  | 5.33 | Green | GREEN |  |  |  |
| 1866 | 1.8.2.1.4.4 | Assurance Meeting |  | 1d | 2024-05-14 | 2024-05-14 | 1865FS+4d |  |  | 2024-05-14 | 2024-05-14 | 1d |  |  | 683d | 0d |  | Matthew Breen | 8h |  |  | SI Transition | SI Transition,PP,SRO | 5.16 |  | 26.33 | Green | GREEN |  |  |  |
| 1867 | 1.8.2.1.4.5 | MCAG Approval of M10/M11 Cut-over Plan | milestone | 0d | 2024-05-28 | 2024-05-28 | 1866FS+10d |  |  | 2024-05-28 | 2024-05-28 | 0d | 2024-05-31 | 2024-05-31 | 683d | 0d |  | Matthew Breen |  |  |  | SI Transition | SI Transition,PP,SRO | 5.19 | Migration | 40.71 | Green | GREEN | T3-MI-0023 | MCAG | T3 |
| 1868 | 1.8.2.1.5 | **M15/M16 cut-over plan** |  | 85d | 2024-05-29 | 2024-09-24 |  |  |  | 2024-03-21 | 2024-09-24 | 134d | 2024-01-01 | 2024-05-31 | 683d |  |  | N/A | 1264h |  | -0 | N/A | N/A | 5.16 | Migration |  |  |  |  |  |  |
| 1869 | 1.8.2.1.5.1 | Draft Document |  | 60d | 2024-05-29 | 2024-08-20 | 1867 |  |  | 2024-03-21 | 2024-08-20 | 109d |  |  | 683d | 0d |  | Matthew Breen | 480h |  |  | SI Transition | SI Transition,PP,SRO | 5.16 |  | 41.33 | Green | GREEN |  |  |  |
| 1870 | 1.8.2.1.5.2 | Share Document with SRO |  | 1d | 2024-08-21 | 2024-08-21 | 1869 |  |  | 2024-08-21 | 2024-08-21 | 1d |  |  | 683d | 0d |  | Matthew Breen | 8h |  |  | SI Transition | SI Transition,PP,SRO | 5.16 |  | 125.33 | Green | GREEN |  |  |  |
| 1871 | 1.8.2.1.5.3 | Industry Consultation |  | 11d | 2024-08-27 | 2024-09-10 | 1870FS+3d |  |  | 2024-08-27 | 2024-09-10 | 11d |  |  | 683d | 0d |  | Matthew Breen | 88h |  |  | SI Transition | SI Transition,PP,SRO | 5.16 |  | 131.33 | Green | GREEN |  |  |  |
| 1872 | 1.8.2.1.5.4 | Assurance Meeting |  | 1d | 2024-09-17 | 2024-09-17 | 1871FS+4d |  |  | 2024-09-17 | 2024-09-17 | 1d |  |  | 683d | 0d |  | Matthew Breen | 8h |  |  | SI Transition | SI Transition,PP,SRO | 5.16 |  | 152.33 | Green | GREEN |  |  |  |
| 1873 | 1.8.2.1.5.5 | Approval of M15/M16 cut-over plan | milestone | 0d | 2024-09-24 | 2024-09-24 | 1872FS+5d |  |  | 2024-09-24 | 2024-09-24 | 0d | 2024-05-31 | 2024-05-31 | 698d |  |  | Matthew Breen |  |  |  | SI Transition | SI Transition,PP,SRO | 5.19 | Migration | 159.71 | Green | GREEN | T3-MI-0032 | MCAG | T3 |
| 1874 | 1.8.2.1.6 | **M16 Methodology** |  | 20d | 2024-09-17 | 2024-10-15 |  |  |  | 2024-09-17 | 2024-10-15 | 20d | 2023-10-02 | 2024-04-26 | 0d | 683d |  | N/A | 160h | 24h | -0 | N/A | N/A | 5.0 | Migration |  |  |  |  |  |  |
| 1875 | 1.8.2.1.6.1 | Draft Document | milestone | 0d | 2024-09-17 | 2024-09-17 | 1872 |  |  | 2024-09-17 | 2024-09-17 | 0d | 2023-10-02 | 2023-12-29 | 683d | 0d |  | Matthew Breen |  |  |  | SI Transition | SI Transition,PP,SRO | 5.16 | Migration | 152.71 | Green | GREEN |  |  |  |
| 1876 | 1.8.2.1.6.2 | Share Document with SRO | milestone | 0d | 2024-09-17 | 2024-09-17 | 1875 |  |  | 2024-09-17 | 2024-09-17 | 0d | 2024-01-01 | 2024-01-26 | 683d | 0d |  | Matthew Breen |  |  |  | SI Transition | SI Transition,PP,SRO | 5.16 | Migration | 152.71 | Green | GREEN |  |  |  |
| 1877 | 1.8.2.1.6.3 | Industry Consultation |  | 11d | 2024-09-24 | 2024-10-08 | 1876FS+4d |  |  | 2024-09-24 | 2024-10-08 | 11d | 2024-01-29 | 2024-03-29 | 683d | 0d |  | Matthew Breen | 88h |  |  | SI Transition | SI Transition,PP,SRO | 5.16 | Migration | 159.33 | Green | GREEN |  |  |  |
| 1878 | 1.8.2.1.6.4 | Assurance Meeting |  | 1d | 2024-10-15 | 2024-10-15 | 1877FS+4d |  |  | 2024-10-15 | 2024-10-15 | 1d | 2024-04-01 | 2024-04-26 | 683d | 0d |  | Matthew Breen | 8h |  |  | SI Transition | SI Transition,PP,SRO | 5.16 | Migration | 180.33 | Green | GREEN |  |  |  |
| 1879 | 1.8.2.1.6.5 | M16 methodology approved | milestone | 0d | 2024-10-15 | 2024-10-15 | 1878 |  |  | 2024-10-15 | 2024-10-15 | 0d | 2024-04-26 | 2024-04-26 | 683d |  |  | Matthew Breen |  |  |  | SI Transition | SI Transition,PP,SRO | 5.17 | Migration | 180.71 | Green | GREEN | T3-MI-0500 | MCAG | T2 |

Notes:
- 1861: 17/10 - Red because initial date was not aligned to a TMAG. On track to delivery by 20/12. To go to 20/11/23 TMAG for approval to change date. 20/11 - Date rebaselined. 20/12 - Approved at TMAG on 20/12
- 1867: 16/1 - Date being replanned. Name to change to MCAG Approval of M10/M11 Cut-over Plan and date to change to 28/5/24. To go to Feb MCAG for approval 27/2 - Approved at MCAG on 27/2/24
- 1873: 16/1 - New milestone for approval at MCAG due to identification of additional requirements. 27/2 - Approved at MCAG on 27/2/24
- 1879: 16/1 - Proposed change to delivery date of 22/10/24 and move from T2-T3 as agreed with the SRO. Other activities renamed to reflect nature of work more accurately. Date change approved at PSG on 7/2/24

| ID | WBS | Task | Type | Duration | Start | Finish | Predecessors | Baseline start | Baseline finish | Baseline duration | Baseline 1 start | Baseline 1 finish | Total slack | Free slack | Constraint | Resources | Work | Responsible | Involved | Update Version | MHHS Programme Phase | Task Status | Sched Status | RAG | Milestone ID | Text29 | Tier |
| --- | --- | --- | --- | --- | --- | --- | --- | --- | --- | --- | --- | --- | --- | --- | --- | --- | --- | --- | --- | --- | --- | --- | --- | --- | --- | --- | --- |
| 1880 | 1.8.2.2 | **Migration Processes, Procedures and Tools** |  | 300d | 2024-01-01 | 2025-02-21 |  | 2024-01-01 | 2025-02-21 | 300d | 2024-01-01 | 2025-02-21 | 0d |  |  | N/A | 5800h | N/A | N/A | 5.0 | Migration |  |  |  |  |  |  |
| 1881 | 1.8.2.2.1 | Design Migration control centre processes and procedures |  | 130d | 2024-01-01 | 2024-06-28 | 1850 | 2024-01-01 | 2024-06-28 | 130d | 2024-01-01 | 2024-06-28 | 0d |  | must start on 2024-01-01 | Warren Fulton | 1040h | SRO |  | 5.0 | Migration | -107.67 | Overdue Start | GREEN |  |  |  |
| 1882 | 1.8.2.2.2 | Develop migration planning and management tool requirements |  | 130d | 2024-01-01 | 2024-06-28 | 1850 | 2024-01-01 | 2024-06-28 | 130d | 2024-01-01 | 2024-06-28 | 0d |  | must start on 2024-01-01 | Warren Fulton | 1040h | SRO |  | 5.0 | Migration | -107.67 | Overdue Start | GREEN |  |  |  |
| 1883 | 1.8.2.2.3 | SITAG approval of migration processes, procedures and tools |  | 20d | 2024-07-01 | 2024-07-26 | 1881 | 2024-07-01 | 2024-07-26 | 20d | 2024-07-01 | 2024-07-26 | 590d | 0d |  | Warren Fulton | 160h | SRO |  | 5.0 | Migration | 74.33 | Green | GREEN |  |  |  |
| 1884 | 1.8.2.2.4 | Migration Processes & Procedures approved | milestone | 0d | 2024-08-02 | 2024-08-02 | 1883FF+5d | 2024-08-02 | 2024-08-02 | 0d | 2024-08-02 | 2024-08-02 | 590d | 0d |  | Warren Fulton |  | SRO | PP,IPA | 5.0 | Migration | 106.71 | Green | GREEN | T3-MI-0017 | MCAG | T3 |
| 1885 | 1.8.2.2.5 | Build and test migration tool |  | 105d | 2024-08-05 | 2024-12-27 | 1884 | 2024-08-05 | 2024-12-27 | 105d | 2024-08-05 | 2024-12-27 | 590d | 0d |  | Warren Fulton | 840h | SRO |  | 5.0 | Migration | 109.33 | Green | GREEN |  |  |  |
| 1886 | 1.8.2.2.6 | Deploy migration tool |  | 20d | 2024-12-30 | 2025-01-24 | 1885 | 2024-12-30 | 2025-01-24 | 20d | 2024-12-30 | 2025-01-24 | 590d | 0d |  | Warren Fulton | 160h | SRO |  | 5.0 | Migration | 256.33 | Green | GREEN |  |  |  |
| 1887 | 1.8.2.2.7 | Operationalisation of migration control centre | manual | 20d | 2025-01-27 | 2025-02-21 | 1886 | 2025-01-27 | 2025-02-21 | 20d | 2025-01-27 | 2025-02-21 |  |  |  | Warren Fulton | 160h | SRO |  | 5.0 | Migration | 284.33 | Green | GREEN |  |  |  |
| 1888 | 1.8.3 | **Go-Live Dress Rehearsals** |  | 110d | 2024-10-04 | 2025-03-06 |  | 2024-10-04 | 2025-03-06 | 110d | 2024-10-04 | 2025-03-06 | 581d |  |  | N/A | 1200h | N/A | N/A | 5.0 | Migration |  |  |  |  |  |  |
| 1889 | 1.8.3.1 | Define dress rehearsal scenarios (incl. engagement with MWG) |  | 20d | 2024-10-04 | 2024-10-31 | 1930FS-131d, 1932FS-131d | 2024-10-04 | 2024-10-31 | 20d | 2024-10-04 | 2024-10-31 | 671d |  |  | Matthew Breen | 160h | SI Migration | PP | 5.0 | Migration | 169.33 | Green | GREEN |  |  |  |
| 1890 | 1.8.3.2 | Set up, coordinate and conduct dress rehearsals |  | 10d | 2025-02-07 | 2025-02-20 | 1077 | 2025-02-07 | 2025-02-20 | 10d | 2025-02-07 | 2025-02-20 | 581d | 0d |  | Matthew Breen | 80h | SI Migration | PP | 5.0 | Migration | 295.33 | Green | GREEN |  |  |  |
| 1891 | 1.8.3.3 | Evaluate dress rehearsals and identify lessons learned |  | 10d | 2025-02-21 | 2025-03-06 | 1890 | 2025-02-21 | 2025-03-06 | 10d | 2025-02-21 | 2025-03-06 | 581d |  |  | Matthew Breen | 80h | SI Migration | PP | 5.0 | Migration | 309.33 | Green | GREEN |  |  |  |
| 1892 | 1.8.4 | **Preparation for Cutover to Live** |  | 40d | 2025-02-10 | 2025-04-04 |  | 2025-02-10 | 2025-04-04 | 40d | 2025-02-07 | 2025-04-04 | 560d |  |  | N/A | 1920h | N/A | N/A | 5.0 | Migration |  |  |  |  |  |  |
| 1893 | 1.8.4.1 | **Central Systems Prepare for Cutover to Live** |  | 20d | 2025-02-10 | 2025-03-07 |  | 2025-02-10 | 2025-03-07 | 20d | 2025-02-07 | 2025-03-07 | 580d |  |  | N/A | 320h | N/A | N/A | 5.0 | Migration | M13 |  |  |  |  |  |
| 1894 | 1.8.4.1.1 | Central Systems Prepare for Cutover to Live |  | 20d | 2025-02-10 | 2025-03-07 | 1926FF, 1077 | 2025-02-10 | 2025-03-07 | 20d | 2025-02-07 | 2025-03-07 | 580d |  |  | Matthew Breen | 160h | PP | SI | 5.0 | Migration | 298.33 | Green | GREEN |  |  |  |
| 1895 | 1.8.4.2 | **Advanced & UMS Prepare for Cutover to Live** |  | 40d | 2025-02-10 | 2025-04-04 |  | 2025-02-10 | 2025-04-04 | 40d | 2025-02-07 | 2025-04-04 | 560d |  |  | N/A | 640h | N/A | N/A | 5.0 | Migration | M13 |  |  |  |  |  |
| 1896 | 1.8.4.2.1 | Advanced & UMS Prepare for Cutover to Live |  | 40d | 2025-02-10 | 2025-04-04 | 1930FF, 1077 | 2025-02-10 | 2025-04-04 | 40d | 2025-02-07 | 2025-04-04 | 560d |  |  | Matthew Breen | 320h | PP | SI | 5.0 | Migration | 298.33 | Green | GREEN |  |  |  |
| 1897 | 1.8.4.3 | **Smart/Non-Smart Prepare for Cutover to Live** |  | 40d | 2025-02-10 | 2025-04-04 |  | 2025-02-10 | 2025-04-04 | 40d | 2025-02-07 | 2025-04-04 | 560d |  |  | N/A | 640h | N/A | N/A | 5.0 | Migration | M14 |  |  |  |  |  |
| 1898 | 1.8.4.3.1 | Smart/Non-Smart Prepare for Cutover to Live |  | 40d | 2025-02-10 | 2025-04-04 | 1932FF, 1077 | 2025-02-10 | 2025-04-04 | 40d | 2025-02-07 | 2025-04-04 | 560d |  |  | Matthew Breen | 320h | PP | SI | 5.0 | Migration | 298.33 | Green | GREEN |  |  |  |
| 1899 | 1.8.5 | **Migration of Advanced Segment** |  | 391d | 2025-04-07 | 2026-10-05 |  | 2025-04-07 | 2026-10-05 | 391d | 2025-04-07 | 2026-10-05 | 0d |  |  | N/A | 8360h | N/A | N/A | 5.0 | Migration | M15 |  |  |  |  |  |
| 1900 | 1.8.5.1 | Migration of Advanced Segment (SIT MVC) |  | 391d | 2025-04-07 | 2026-10-05 | 1930 | 2025-04-07 | 2026-10-05 | 391d | 2025-04-07 | 2026-10-05 | 0d |  |  | Warren Fulton | 3128h | SRO | PP | 5.0 | Migration | 354.33 | Green | GREEN |  |  |  |
| 1901 | 1.8.5.2 | Migration of Advanced Segment (non-SIT PPs) |  | 263d | 2025-09-30 | 2026-10-01 | 1572 | 2025-09-30 | 2026-10-05 | 265d | 2025-09-30 | 2026-10-05 | 2d |  |  | Warren Fulton | 2104h | SRO | PP | 5.0 | Migration | 530.33 | Green | GREEN |  |  |  |
| 1902 | 1.8.6 | **Migration of Unmetered Segment** |  | 391d | 2025-04-07 | 2026-10-05 |  | 2025-04-07 | 2026-10-05 | 391d | 2025-04-07 | 2026-10-05 | 0d |  |  | N/A | 8360h | N/A | N/A | 5.0 | Migration | M15 |  |  |  |  |  |
| 1903 | 1.8.6.1 | Migration of Unmetered Segment (SIT MVC) |  | 391d | 2025-04-07 | 2026-10-05 | 1930 | 2025-04-07 | 2026-10-05 | 391d | 2025-04-07 | 2026-10-05 | 0d |  |  | Warren Fulton | 3128h | SRO | PPC | 5.0 | Migration | 354.33 | Green | GREEN |  |  |  |
| 1904 | 1.8.6.2 | Migration of Unmetered Segment (non-SIT PPs) |  | 263d | 2025-09-30 | 2026-10-01 | 1572 | 2025-09-30 | 2026-10-05 | 265d | 2025-09-30 | 2026-10-05 | 2d |  |  | Warren Fulton | 2104h | SRO | PP | 5.0 | Migration | 530.33 | Green | GREEN |  |  |  |

| ID | WBS | Task | Type | Duration | Start | Finish | Predecessors | Complete | Remaining | Baseline start | Baseline finish | Baseline duration | Baseline 1 start | Baseline 1 finish | Total slack | Free slack | Constraint | Resources | Work | Actual work | Baseline cost | Responsible | Involved | Task Status | Update Version | MHHS Programme Phase | Sched Status | RAG | Milestone ID | Text29 | Tier | Action |
| --- | --- | --- | --- | --- | --- | --- | --- | --- | --- | --- | --- | --- | --- | --- | --- | --- | --- | --- | --- | --- | --- | --- | --- | --- | --- | --- | --- | --- | --- | --- | --- | --- |
| 1905 | 1.8.7 | **Migration of Smart / Non-Smart Segments** |  | 391d | 2025-04-07 | 2026-10-05 |  |  |  | 2025-04-07 | 2026-10-05 | 391d | 2025-04-07 | 2026-10-05 | 0d |  |  | N/A | 8360h |  |  | N/A | N/A | M15 | 5.0 | Migration |  |  |  |  |  |  |
| 1906 | 1.8.7.1 | Migration of Smart / Non-Smart Segments (SIT MVC) |  | 391d | 2025-04-07 | 2026-10-05 | 1930 |  |  | 2025-04-07 | 2026-10-05 | 391d | 2025-04-07 | 2026-10-05 | 0d |  |  | Warren Fulton | 3128h |  |  | SRO | PP | 354.33 | 5.0 | Migration | Green | GREEN |  |  |  |  |
| 1907 | 1.8.7.2 | Migration of Smart / Non-Smart Segments (non-SIT PPs) |  | 263d | 2025-09-30 | 2026-10-01 | 1572 |  |  | 2025-09-30 | 2026-10-05 | 265d | 2025-09-30 | 2026-10-05 | 2d |  |  | Warren Fulton | 2104h |  |  | SRO | PP | 530.33 | 5.0 | Migration | Green | GREEN |  |  |  |  |
| 1908 | 1.8.8 | **Migration Management** |  | 391d | 2025-04-07 | 2026-10-05 |  |  |  | 2025-04-07 | 2026-10-05 | 391d | 2025-04-07 | 2026-10-05 | 169d |  |  | N/A | 6256h |  |  | N/A | N/A | M15 | 5.0 | Migration |  |  |  |  |  |  |
| 1909 | 1.8.8.1 | Migration Management |  | 391d | 2025-04-07 | 2026-10-05 | 1900SS, 1903SS, 1906SS |  |  | 2025-04-07 | 2026-10-05 | 391d | 2025-04-07 | 2026-10-05 | 169d |  |  | Warren Fulton | 3128h |  |  | SRO | PPC | 354.33 | 5.0 | Migration | Green | GREEN |  |  |  |  |
| 1910 | 1.8.9 | **External Programme Dependency Management** |  | 713d | 2022-10-31 A | 2025-07-23 |  | 63% | 265.32d | 2022-10-31 | 2025-12-30 | 827d | 2022-10-31 | 2025-07-01 | 482d |  |  | N/A | 35384h | 18352h | -0 | N/A | N/A |  | 5.0 | Migration |  |  |  |  |  |  |
| 1911 | 1.8.9.1 | **BSC Mod P432 & REC CP R0015** |  | 392d | 2022-10-31 A | 2024-04-30 |  | 98% | 9d | 2022-10-31 | 2025-12-30 | 827d | 2022-10-31 | 2025-07-01 | 803d |  |  | N/A | 6272h | 5688h | -0 | N/A | N/A |  | 5.0 | Migration |  |  |  |  |  |  |
| 1912 | 1.8.9.1.1 | MHHSP engagement with BSCCo until Ofgem decision |  | 316d | 2022-10-31 A | 2024-01-15 A |  | 100% |  | 2022-10-31 | 2024-05-10 | 400d | 2022-10-31 | 2022-12-30 |  |  |  | Matthew Breen | 2528h | 2528h |  | CPT,SRO Function | Code Bodies |  | 5.0 | Migration | Complete | COMPLETE |  |  |  |  |
| 1913 | 1.8.9.1.2 | Monitor progress and await implementation date |  | 76d | 2024-01-16 A | 2024-04-30 | 1912 | 88% | 9d | 2023-07-03 | 2025-12-30 | 652d | 2023-01-02 | 2025-07-01 | 803d |  |  | Matthew Breen | 608h | 536h |  | CPT,SRO Function | Code Bodies |  | 5.0 | Migration | Green | GREEN |  |  |  |  |
| 1914 | 1.8.9.2 | **BSC Mod P434** |  | 713d | 2022-10-31 A | 2025-07-23 |  | 54% | 330d | 2022-10-31 | 2025-07-23 | 713d | 2022-10-31 | 2025-07-01 | 482d |  |  | N/A | 11896h | 6616h |  | N/A | N/A |  | 5.0 | Migration |  |  |  |  |  |  |
| 1915 | 1.8.9.2.1 | MHHSP engagement with BSCCo until Ofgem decision |  | 61d | 2022-10-31 A | 2023-01-23 A |  | 100% |  | 2022-10-31 | 2023-01-23 | 61d | 2022-10-31 | 2022-12-30 |  |  |  | John Wiggins; Matthew Breen | 976h | 976h |  | CPT,SRO Function | Code Bodies |  | 5.0 | Migration | Complete | COMPLETE |  |  |  |  |
| 1916 | 1.8.9.2.2 | Monitor progress and await implementation date |  | 652d | 2023-01-24 A | 2025-07-23 | 1915 | 49% | 330d | 2023-01-24 | 2025-07-23 | 652d | 2023-01-02 | 2025-07-01 | 482d |  |  | Matthew Breen | 5216h | 2576h |  | CPT,SRO Function | Code Bodies |  | 5.0 | Migration | Green | GREEN |  |  |  |  |
| 1917 | 1.8.9.3 | **Elexon System Capacity Upgrade** |  | 697d | 2022-10-31 A | 2025-07-01 |  | 54% | 319d | 2022-10-31 | 2025-07-01 | 697d | 2022-10-31 | 2025-07-01 | 498d |  |  | N/A | 11152h | 6048h |  | N/A | N/A |  | 5.0 | Migration |  |  |  |  |  |  |
| 1918 | 1.8.9.3.1 | Monitor progress to implementation |  | 697d | 2022-10-31 A | 2025-07-01 |  | 54% | 319d | 2022-10-31 | 2025-07-01 | 697d | 2022-10-31 | 2025-07-01 | 498d | 0d |  | Matthew Breen | 5576h | 3024h |  | SI Migration | PP |  | 5.0 | Migration | Green | GREEN |  |  |  |  |
| 1919 | 1.8.9.3.2 | Implementation date | milestone | 0d | 2025-07-01 | 2025-07-01 | 1918 |  |  | 2025-07-01 | 2025-07-01 | 0d | 2025-07-01 | 2025-07-01 | 498d |  |  | Matthew Breen |  |  |  | PP | SI Migration | 439.71 | 5.0 | Migration | Green | GREEN |  |  |  |  |
| 1920 | 1.8.9.4 | **DCC System Capacity Upgrade** |  | 25d | 2025-01-13 | 2025-02-14 |  |  |  | 2025-01-13 | 2025-02-14 | 25d | 2025-01-13 | 2025-02-14 | 595d |  |  | N/A | 360h |  |  | N/A | N/A |  | 5.0 | Migration |  |  |  |  |  |  |
| 1921 | 1.8.9.4.1 | Assurance of DCC capacity upgrade to ensure suitability to support migration |  | 20d | 2025-01-13 | 2025-02-07 | 1926FF-20d |  |  | 2025-01-13 | 2025-02-07 | 20d | 2025-01-13 | 2025-02-07 | 595d | 0d |  | Matthew Breen | 160h |  |  | SI Migration | PP | 270.33 | 5.0 | Migration | Green | GREEN |  |  |  |  |
| 1922 | 1.8.9.4.2 | DCC Capacity Upgrade Operational | milestone | 0d | 2025-02-14 | 2025-02-14 | 1921FS+5d |  |  | 2025-02-14 | 2025-02-14 | 0d | 2025-02-14 | 2025-02-14 | 595d |  |  | Matthew Breen |  |  |  | PP | SI Migration,IPA | 302.71 | 5.0 | Migration | Green | GREEN | T2-MI-0350 | MCAG | T2 |  |
| 1923 | 1.8.9.5 | **Performance Assurance Arrangements** |  | 0d | 2025-07-01 | 2025-07-01 |  |  |  | 2025-07-01 | 2025-07-01 | 0d | 2025-07-01 | 2025-07-01 | 499d |  |  | N/A |  |  |  | N/A | N/A |  | 5.0 | Migration |  |  |  |  |  |  |
| 1924 | 1.8.9.5.1 | Performance assurance regime for migration success delivered | milestone | 0d | 2025-07-01 | 2025-07-01 |  |  |  | 2025-07-01 | 2025-07-01 | 0d | 2025-07-01 | 2025-07-01 | 499d |  | start no earlier than 2025-07-01 | Simon chidwick |  |  |  | Code Bodies | SI Migration | 439.33 | 5.0 | Migration | Green | GREEN |  |  |  | 30/1/24 - To sit with Waren? |
| 1925 | 1.8.10 | **Migration - Tier 1 Milestones** |  | 477d | 2025-03-07 | 2027-01-05 |  |  |  | 2025-03-07 | 2027-01-05 | 477d | 2025-03-07 | 2027-01-05 | 0d |  |  | N/A | 3816h |  |  | N/A | N/A |  | 5.0 | Migration |  |  |  |  |  |  |
| 1926 | 1.8.10.1 | Central systems ready for migrating MPANs (M10) | milestone | 0d | 2025-03-07 | 2025-03-07 | 1077FS+21d |  |  | 2025-03-07 | 2025-03-07 | 0d | 2025-03-07 | 2025-03-07 | 0d |  |  | CPT |  |  |  | CPT | CPT | 323.71 | 5.0 | Migration | Green | GREEN | T1-MI-1000 | PSG | T1 |  |
| 1927 | 1.8.10.2 | Central systems ready for migrating MPANs (M10*) - Late Exit | milestone | 0d | 2025-06-06 | 2025-06-06 | 1926FS+65d |  |  | 2025-06-06 | 2025-06-06 | 0d | 2025-06-06 | 2025-06-06 | 515d |  |  | CPT |  |  |  | CPT | CPT | 414.71 | 5.0 | Migration | Green | GREEN | T2-MI-1500 | PSG | T1 |  |
| 1928 | 1.8.10.3 | Load Shaping Service switched on (M13) | milestone | 0d | 2025-03-07 | 2025-03-07 | 1926 |  |  | 2025-03-07 | 2025-03-07 | 0d | 2025-03-07 | 2025-03-07 | 20d | 0d |  | CPT |  |  |  | CPT | CPT | 323.71 | 5.0 | Migration | Green | GREEN | T1-MI-2000 | PSG | T1 |  |
| 1929 | 1.8.10.4 | Load Shaping Service switched on (M13*) - Late Exit | milestone | 0d | 2025-06-06 | 2025-06-06 | 1928FS+65d |  |  | 2025-06-06 | 2025-06-06 | 0d | 2025-06-06 | 2025-06-06 | 515d |  |  | CPT |  |  |  | CPT | CPT | 414.71 | 5.0 | Migration | Green | GREEN | T2-MI-2500 | PSG | T1 |  |
| 1930 | 1.8.10.5 | Start of 18-month migration for UMS / Advanced (M11) | milestone | 0d | 2025-04-04 | 2025-04-04 | 1926FS+20d, 1928 |  |  | 2025-04-04 | 2025-04-04 | 0d | 2025-04-04 | 2025-04-04 | 0d |  |  | CPT |  |  |  | CPT | CPT | 351.71 | 5.0 | Migration | Green | GREEN | T1-MI-3000 | PSG | T1 |  |
| 1931 | 1.8.10.6 | Start of 18-month migration for UMS / Advanced (M11*) - Late Exit | milestone | 0d | 2025-07-04 | 2025-07-04 | 1930FS+65d |  |  | 2025-07-04 | 2025-07-04 | 0d | 2025-07-04 | 2025-07-04 | 495d |  |  | CPT |  |  |  | CPT | CPT | 442.71 | 5.0 | Migration | Green | GREEN | T2-MI-3500 | PSG | T1 |  |
| 1932 | 1.8.10.7 | Start of 18-month migration for Smart / Non-smart (M12) | milestone | 0d | 2025-04-04 | 2025-04-04 | 1926FS+20d, 1928 |  |  | 2025-04-04 | 2025-04-04 | 0d | 2025-04-04 | 2025-04-04 | 495d | 0d |  | CPT |  |  |  | CPT | CPT | 351.71 | 5.0 | Migration | Green | GREEN | T1-MI-4000 | PSG | T1 |  |
| 1933 | 1.8.10.8 | Start of 18-month migration for Smart / Non-smart (M12*) - Late Exit | milestone | 0d | 2025-07-04 | 2025-07-04 | 1932FS+65d |  |  | 2025-07-04 | 2025-07-04 | 0d | 2025-07-04 | 2025-07-04 | 495d |  |  | CPT |  |  |  | CPT | CPT | 442.71 | 5.0 | Migration | Green | GREEN | T2-MI-4500 | PSG | T1 |  |
| 1934 | 1.8.10.9 | All suppliers must be able to access MPANs under the new TOM (M14) | milestone | 0d | 2026-03-12 | 2026-03-12 | 1602, 1571, 1576, 1581, 1586, 1591, 1596, 1601 |  |  | 2026-03-16 | 2026-03-16 | 0d | 2026-03-16 | 2026-03-16 | 250d | 0d |  | CPT |  |  |  | CPT | CPT | 693.71 | 5.0 | Migration | Green | GREEN | T1-MI-5000 | PSG | T1 |  |
| 1935 | 1.8.10.10 | All suppliers must be able to access MPANs under the new TOM (M14*) - Late Exit | milestone | 0d | 2026-06-12 | 2026-06-12 | 1934FS+66d |  |  | 2026-06-16 | 2026-06-16 | 0d | 2026-06-16 | 2026-06-16 | 250d |  |  | CPT |  |  |  | CPT | CPT | 785.71 | 5.0 | Migration | Green | GREEN | T1-MI-5500 | PSG | T1 |  |
| 1936 | 1.8.10.11 | Full transition complete (M15) | milestone | 0d | 2026-10-05 | 2026-10-05 | 1900FF, 1903FF, 1906FF, 1901FF, 1904FF, 1907FF |  |  | 2026-10-05 | 2026-10-05 | 0d | 2026-10-05 | 2026-10-05 | 0d |  |  | CPT |  |  |  | CPT | CPT | 900.71 | 5.0 | Migration | Green | GREEN | T1-MI-6000 | PSG | T1 |  |
| 1937 | 1.8.10.12 | Full transition complete (M15*) - Late Exit | milestone | 0d | 2027-01-05 | 2027-01-05 | 1936FS+66d |  |  | 2027-01-05 | 2027-01-05 | 0d | 2027-01-05 | 2027-01-05 | 103d |  |  | CPT |  |  |  | CPT | CPT | 992.71 | 5.0 | Migration | Green | GREEN | T2-MI-6500 | PSG | T1 |  |

Notes:
- 1912: 26/9 - ST - MHHS engagement on track, decision awaits OFGEM review
- 1926: Text3: Central systems ready for migrating MPANs
- 1927: Text3: Central systems ready for migrating MPANs
- 1928: Text3: Load Shaping Service switched on
- 1929: Text3: Load Shaping Service switched on
- 1930: Text3: Start of 1 year migration for UMS / Advanced
- 1931: Text3: Start of 1 year migration for UMS / Advanced
- 1932: Text3: Start of 1 year migration for Smart / Non-smart
- 1933: Text3: Start of 1 year migration for Smart / Non-smart
- 1934: Text3: All suppliers must be able to accept MPANs under the new TOM (one way gate)
- 1935: Text3: All suppliers must be able to accept MPANs under the new TOM (one way gate)
- 1936: Text3: Full transition complete
- 1937: Text3: Full transition complete

| ID | WBS | Task | Type | Duration | Start | Finish | Predecessors | Complete | Remaining | Baseline start | Baseline finish | Baseline duration | Baseline 1 start | Baseline 1 finish | Total slack | Free slack | Constraint | Resources | Work | Actual work | Baseline cost | Responsible | Involved | MHHS Programme Phase | Update Version | Sched Status | RAG | Milestone ID | Text29 | Tier | Task Status | Artefact ID | Action |
| --- | --- | --- | --- | --- | --- | --- | --- | --- | --- | --- | --- | --- | --- | --- | --- | --- | --- | --- | --- | --- | --- | --- | --- | --- | --- | --- | --- | --- | --- | --- | --- | --- | --- |
| 1938 | 1.9 | **BUSINESS & OPERATIONAL READINESS** |  | 964d | 2023-09-19 A | 2027-05-28 |  | 6% | 905.21d | 2023-09-19 | 2027-05-28 | 964d | 2023-03-01 | 2026-12-07 | 0d |  |  | N/A | 49065.7h | 4427.75h | -0 | N/A | N/A | Business & Operational Readiness |  |  |  |  |  |  |  |  |  |
| 1939 | 1.9.1 | **Service Management** |  | 840d | 2023-09-19 A | 2026-12-07 |  | 22% | 658.54d | 2023-09-19 | 2026-12-07 | 840d | 2023-03-01 | 2026-12-07 | 124d |  |  | N/A | 17568h | 3947.67h | -0 | N/A | N/A | Business & Operational Readiness | 5.0 |  |  |  |  |  |  |  |  |
| 1940 | 1.9.1.1 | **Service Management Strategy** |  | 116d | 2023-09-19 A | 2024-02-27 A |  | 100% |  | 2023-09-19 | 2024-02-27 | 116d | 2023-03-01 | 2023-05-31 |  |  |  | N/A | 1848h | 1848h | -0 | N/A | N/A | Business & Operational Readiness | 5.0 |  |  |  |  |  |  |  |  |
| 1941 | 1.9.1.1.1 | Develop document with relevant participants (incl. review of the design baseline to ensure service management arrangements are in place across the solution architecture) |  | 84d | 2023-09-19 A | 2024-01-12 A |  | 100% |  | 2023-09-19 | 2024-01-12 | 84d | 2023-03-01 | 2023-04-28 |  |  | start no earlier than 2023-09-19 | Matthew Breen | 672h | 672h |  | SI Design |  | Business & Operational Readiness | 5.0 | Complete | COMPLETE |  |  |  |  |  |  |
| 1942 | 1.9.1.1.2 | Artefact review (via relevant Advisory Group) and updates |  | 31d | 2024-01-15 A | 2024-02-26 A | 1941 | 100% |  | 2024-01-15 | 2024-02-26 | 31d | 2023-05-01 | 2023-05-24 |  |  |  | Matthew Breen | 248h | 248h |  | PP | SI Design,IPA | Business & Operational Readiness | 5.0 | Complete | COMPLETE |  |  |  |  |  |  |
| 1943 | 1.9.1.1.3 | Service Management Strategy approved | milestone | 0d | 2024-02-27 A | 2024-02-27 A | 1942FS+1d | 100% |  | 2024-02-27 | 2024-02-27 | 0d | 2023-05-31 | 2023-05-31 |  |  |  | Matthew Breen |  |  |  | SI Design | PP | Business & Operational Readiness | 5.16 | Complete | COMPLETE | T3-BC-0010 | MCAG | T3 |  |  |  |
| 1944 | 1.9.1.2 | **Early Life Support Model** |  | 85d | 2024-02-28 A | 2024-06-25 |  | 53% | 40d | 2024-02-28 | 2024-06-25 | 85d |  |  | 723d |  |  | N/A | 1224h | 648h | -0 | N/A | N/A |  | 5.16 |  |  |  |  |  | -441.67 |  |  |
| 1945 | 1.9.1.2.1 | Draft Document |  | 55d | 2024-02-28 A | 2024-05-14 | 1943 | 65% | 19d | 2024-02-28 | 2024-05-14 | 55d |  |  | 723d | 0d |  | Matthew Breen | 440h | 288h |  | SI Transition | SI Transition,PP,SRO |  | 5.16 | Green | GREEN |  |  |  |  |  |  |
| 1946 | 1.9.1.2.2 | Share document with SRO |  | 1d | 2024-05-15 | 2024-05-15 | 1945 |  |  | 2024-05-15 | 2024-05-15 | 1d |  |  | 723d | 0d |  | Matthew Breen | 8h |  |  | SI Transition | SI Transition,PP,SRO |  | 5.16 | Green | GREEN |  |  |  | 27.33 |  |  |
| 1947 | 1.9.1.2.3 | Industry Consultation |  | 11d | 2024-05-21 | 2024-06-04 | 1946FS+3d |  |  | 2024-05-21 | 2024-06-04 | 11d |  |  | 723d | 0d |  | Matthew Breen | 88h |  |  | SI Transition | SI Transition,PP,SRO |  | 5.16 | Green | GREEN |  |  |  | 33.33 |  |  |
| 1948 | 1.9.1.2.4 | Assurance Meeting |  | 1d | 2024-06-11 | 2024-06-11 | 1947FS+4d |  |  | 2024-06-11 | 2024-06-11 | 1d |  |  | 723d | 0d |  | Matthew Breen | 8h |  |  | SI Transition | SI Transition,PP,SRO |  | 5.16 | Green | GREEN |  |  |  | 54.33 |  |  |
| 1949 | 1.9.1.2.5 | MCAG Approval of Early Life Support Model | milestone | 0d | 2024-06-25 | 2024-06-25 | 1948FS+10d |  |  | 2024-06-25 | 2024-06-25 | 0d |  |  | 723d | 138d |  | Matthew Breen |  |  |  | SI Transition | PP,SRO,SI Transition |  | 5.19 | Green | GREEN | T3-MI-0033 | MCAG |  | 68.71 |  |  |
| 1950 | 1.9.1.3 | **Service Management Arrangements Implementation** |  | 456d | 2025-03-10 | 2026-12-07 |  |  |  | 2025-03-10 | 2026-12-07 | 456d | 2025-03-10 | 2026-12-07 | 124d |  |  | N/A | 7776h |  |  | N/A | N/A | Business & Operational Readiness | 5.0 |  |  |  |  |  |  |  |  |
| 1951 | 1.9.1.3.1 | Hypercare post M10 |  | 80d | 2025-03-10 | 2025-06-27 | 1926 |  |  | 2025-03-10 | 2025-06-27 | 80d | 2025-03-10 | 2025-06-27 | 500d |  |  | Matthew Breen | 640h |  |  | SI Design | PP | Business & Operational Readiness | 5.0 | Green | GREEN |  |  |  | 326.33 |  |  |
| 1952 | 1.9.1.3.2 | Monitor Elexon implementation of Service Management arrangements |  | 436d | 2025-04-07 | 2026-12-07 | 1900SS |  |  | 2025-04-07 | 2026-12-07 | 436d | 2025-04-07 | 2026-12-07 | 124d |  |  | Matthew Breen | 3488h |  |  | PP | SI Design | Business & Operational Readiness | 5.0 | Green | GREEN |  |  |  | 354.33 |  |  |
| 1953 | 1.9.2 | **Implement Early Life Support Plan** |  | 40d | 2025-01-06 | 2025-02-28 |  |  |  | 2025-01-06 | 2025-02-28 | 40d | 2025-01-06 | 2025-02-28 | 585d |  |  | N/A | 640h |  | -0 | N/A | N/A | Business & Operational Readiness | 5.0 |  |  |  |  |  |  |  |  |
| 1954 | 1.9.2.1 | Implement Early Life Support Plan |  | 40d | 2025-01-06 | 2025-02-28 | 1949 |  |  | 2025-01-06 | 2025-02-28 | 40d | 2025-02-28 | 2025-02-28 | 585d |  | start no earlier than 2025-01-06 | Matthew Breen | 320h |  |  | SI Transition | SI Transition,CPT | Business & Operational Readiness | 5.0 | Green | GREEN |  |  |  | 263.33 | MHHS-ART095 |  |
| 1955 | 1.9.3 | **Business Continuity and Disaster Recovery Plan** |  | 40d | 2025-01-13 | 2025-03-07 |  |  |  | 2025-01-13 | 2025-03-07 | 40d | 2025-01-13 | 2025-03-07 | 580d |  |  | N/A | 640h |  |  | N/A | N/A | Business & Operational Readiness | 5.0 |  |  |  |  |  |  |  | 19/3: Lee C - does it sit with Ian |
| 1956 | 1.9.3.1 | Develop document |  | 20d | 2025-01-13 | 2025-02-07 | 1757FS-40d |  |  | 2025-01-13 | 2025-02-07 | 20d | 2025-01-13 | 2025-02-07 | 580d | 0d |  | Matthew Breen | 160h |  |  | SI Design |  | Business & Operational Readiness | 5.0 | Green | GREEN |  |  |  | 270.33 |  | 19/3: Lee C - does it sit with Ian |
| 1957 | 1.9.3.2 | Document review and update |  | 20d | 2025-02-10 | 2025-03-07 | 1956 |  |  | 2025-02-10 | 2025-03-07 | 20d | 2025-02-10 | 2025-03-07 | 580d | 0d |  | Matthew Breen | 160h |  |  | PP | SI Design | Business & Operational Readiness | 5.0 | Green | GREEN |  |  |  | 298.33 |  | 19/3: Lee C - does it sit with Ian |
| 1958 | 1.9.3.3 | Business Continuity and Disaster Recovery Plan approved by SRO | milestone | 0d | 2025-03-07 | 2025-03-07 | 1957 |  |  | 2025-03-07 | 2025-03-07 | 0d | 2025-03-07 | 2025-03-07 | 580d |  |  | Matthew Breen |  |  |  | SRO Design | SI Design | Business & Operational Readiness | 5.0 | Green | GREEN |  |  |  | 323.71 | MHHS-ART064 | 19/3: Lee C - does it sit with Ian |
| 1959 | 1.9.4 | **Operations Support Guide** |  | 40d | 2025-02-03 | 2025-03-28 |  |  |  | 2025-02-03 | 2025-03-28 | 40d | 2025-02-03 | 2025-03-28 | 565d |  |  | N/A | 640h |  |  | N/A | N/A | Business & Operational Readiness | 5.0 |  |  |  |  |  |  |  |  |
| 1960 | 1.9.4.1 | Develop document |  | 20d | 2025-02-03 | 2025-02-28 | 1932FS-45d |  |  | 2025-02-03 | 2025-02-28 | 20d | 2025-02-03 | 2025-02-28 | 565d | 0d |  | Warren Fulton | 160h |  |  | SRO | SRO | Business & Operational Readiness | 5.0 | Green | GREEN |  |  |  | 291.33 |  |  |
| 1961 | 1.9.4.2 | Document review and update |  | 20d | 2025-03-03 | 2025-03-28 | 1960 |  |  | 2025-03-03 | 2025-03-28 | 20d | 2025-03-03 | 2025-03-28 | 565d | 0d |  | Warren Fulton | 160h |  |  | SRO | SRO | Business & Operational Readiness | 5.0 | Green | GREEN |  |  |  | 319.33 |  |  |
| 1962 | 1.9.4.3 | Operations Support Guide approved | milestone | 0d | 2025-03-28 | 2025-03-28 | 1961 |  |  | 2025-03-28 | 2025-03-28 | 0d | 2025-03-28 | 2025-03-28 | 565d |  |  | Warren Fulton |  |  |  | SRO | SRO | Business & Operational Readiness | 5.0 | Green | GREEN |  |  |  | 344.71 | MHHS-ART116 |  |

Notes:
- 1943: 17/1 - Baseline change approved at TMAG to change date from 21/2/24 to 27/2/24. Changed because MCAG has been scheduled for 27/2/24. Approved at TMAG on 7/1/24
- 1949: 16/1 - New milestone for Feb MCAG approval. 27/2 - Approved at MCAG on 27/2/24

| ID | WBS | Task | Type | Duration | Start | Finish | Predecessors | Baseline start | Baseline finish | Baseline duration | Baseline 1 start | Baseline 1 finish | Total slack | Free slack | Constraint | Resources | Work | Baseline cost | Responsible | Involved | Update Version | MHHS Programme Phase | Task Status | Sched Status | RAG | Artefact ID | Milestone ID | Text29 | Tier |
| --- | --- | --- | --- | --- | --- | --- | --- | --- | --- | --- | --- | --- | --- | --- | --- | --- | --- | --- | --- | --- | --- | --- | --- | --- | --- | --- | --- | --- | --- |
| 1963 | 1.9.5 | **Training and Support Materials** |  | 40d | 2025-02-03 | 2025-03-28 |  | 2025-02-03 | 2025-03-28 | 40d | 2025-02-03 | 2025-03-28 | 565d |  |  | N/A | 640h |  | N/A | N/A | 5.0 | Business & Operational Readiness |  |  |  |  |  |  |  |
| 1964 | 1.9.5.1 | Develop document |  | 20d | 2025-02-03 | 2025-02-28 | 1932FS-45d | 2025-02-03 | 2025-02-28 | 20d | 2025-02-03 | 2025-02-28 | 565d | 0d |  | Matthew Breen | 160h |  | SI Migration | CPT | 5.0 | Business & Operational Readiness | 291.33 | Green | GREEN |  |  |  |  |
| 1965 | 1.9.5.2 | Document review and update |  | 20d | 2025-03-03 | 2025-03-28 | 1964 | 2025-03-03 | 2025-03-28 | 20d | 2025-03-03 | 2025-03-28 | 565d | 0d |  | Matthew Breen | 160h |  | SI Migration | PMO,CPT,IPA,PP | 5.0 | Business & Operational Readiness | 319.33 | Green | GREEN |  |  |  |  |
| 1966 | 1.9.5.3 | Training and Support Materials approved | milestone | 0d | 2025-03-28 | 2025-03-28 | 1965 | 2025-03-28 | 2025-03-28 | 0d | 2025-03-28 | 2025-03-28 | 565d |  |  | Matthew Breen |  |  | SI Migration | PMO,CPT | 5.0 | Business & Operational Readiness | 344.71 | Green | GREEN | MHHS-ART118 |  |  |  |
| 1967 | 1.9.6 | **PP Business Change** |  | 129d | 2025-02-03 | 2025-07-31 |  | 2025-02-03 | 2025-07-31 | 129d | 2025-02-03 | 2025-07-31 | 476d |  |  | N/A | 7224h |  | N/A | N/A | 5.0 | Business & Operational Readiness | M11 |  |  |  |  |  |  |
| 1968 | 1.9.6.1 | Plan stakeholder management |  | 129d | 2025-02-03 | 2025-07-31 |  | 2025-02-03 | 2025-07-31 | 129d | 2025-02-03 | 2025-07-31 | 476d |  | start no earlier than 2025-02-03 | Matthew Breen | 1032h |  | PP | PPC | 5.0 | Business & Operational Readiness | 291.33 | Green | GREEN |  |  |  |  |
| 1969 | 1.9.6.2 | Manage stakeholders |  | 129d | 2025-02-03 | 2025-07-31 |  | 2025-02-03 | 2025-07-31 | 129d | 2025-02-03 | 2025-07-31 | 476d |  | start no earlier than 2025-02-03 | Matthew Breen | 1032h |  | PP | PPC | 5.0 | Business & Operational Readiness | 291.33 | Green | GREEN |  |  |  |  |
| 1970 | 1.9.6.3 | Develop & implement changes to KPIs, organisation & people management |  | 129d | 2025-02-03 | 2025-07-31 |  | 2025-02-03 | 2025-07-31 | 129d | 2025-02-03 | 2025-07-31 | 476d |  | start no earlier than 2025-02-03 | Matthew Breen | 1032h |  | PP | PPC | 5.0 | Business & Operational Readiness | 291.33 | Green | GREEN |  |  |  |  |
| 1971 | 1.9.6.4 | Develop & test changes to business processes |  | 129d | 2025-02-03 | 2025-07-31 |  | 2025-02-03 | 2025-07-31 | 129d | 2025-02-03 | 2025-07-31 | 476d |  | start no earlier than 2025-02-03 | Matthew Breen | 1032h |  | PP | PPC | 5.0 | Business & Operational Readiness | 291.33 | Green | GREEN |  |  |  |  |
| 1972 | 1.9.6.5 | Develop and deliver training |  | 129d | 2025-02-03 | 2025-07-31 |  | 2025-02-03 | 2025-07-31 | 129d | 2025-02-03 | 2025-07-31 | 476d |  | start no earlier than 2025-02-03 | Matthew Breen | 1032h |  | PP | PPC | 5.0 | Business & Operational Readiness | 291.33 | Green | GREEN |  |  |  |  |
| 1973 | 1.9.6.6 | Programme support for PP Business Change activities |  | 129d | 2025-02-03 | 2025-07-31 |  | 2025-02-03 | 2025-07-31 | 129d | 2025-02-03 | 2025-07-31 | 476d |  | start no earlier than 2025-02-03 | Matthew Breen | 1032h |  | PPC | PP | 5.0 | Business & Operational Readiness | 291.33 | Green | GREEN |  |  |  |  |
| 1974 | 1.9.7 | **Supplier Business Readiness for Cutover** |  | 283d | 2025-10-01 | 2026-10-30 |  | 2025-10-01 | 2026-10-30 | 283d | 2025-10-01 | 2026-10-30 | 150d |  |  | N/A | 4528h |  | N/A | N/A | 5.0 | Business & Operational Readiness | M11 |  |  |  |  |  |  |
| 1975 | 1.9.7.1 | Programme support for Supplier Business Readiness for Cutover activities (incl. setup, management and evaluation of dress rehearsals) |  | 283d | 2025-10-01 | 2026-10-30 |  | 2025-10-01 | 2026-10-30 | 283d | 2025-10-01 | 2026-10-30 | 150d |  | start no earlier than 2025-10-01 | Matthew Breen | 2264h |  | PPC | PP | 5.0 | Business & Operational Readiness | 531.33 | Green | GREEN |  |  |  |  |
| 1976 | 1.9.8 | **Transition to New Settlement Timetable (M16)** |  | 560d | 2025-04-04 | 2027-05-28 |  | 2025-04-04 | 2027-05-28 | 560d |  |  | 0d |  |  | N/A | 9952h | -0 | N/A | N/A | 5.15 |  | -434.67 |  |  |  |  |  |  |
| 1977 | 1.9.8.1 | Elexon to produce Settlement Calendar for Settlement Year 2025/2026 | milestone | 0d | 2025-04-04 | 2025-04-04 | 1930 | 2025-04-04 | 2025-04-04 | 0d |  |  | 0d |  |  | Matthew Breen |  |  | PP | PP, Code Bodies | 5.15 |  | 351.71 | Green | GREEN |  |  |  |  |
| 1978 | 1.9.8.2 | Elexon monitor settlement data of migrated MPANs |  | 436d | 2025-04-07 | 2026-12-07 | 1977 | 2025-04-07 | 2026-12-07 | 436d |  |  | 0d |  |  | Matthew Breen | 3488h |  | PP | PP, Code Bodies | 5.15 |  | 354.33 | Green | GREEN |  |  |  |  |
| 1979 | 1.9.8.3 | M16 Checkpoint 1 | milestone | 0d | 2025-12-08 | 2025-12-08 | 1977FS+176d | 2025-12-08 | 2025-12-08 | 0d |  |  | 0d |  |  | Matthew Breen |  |  | PP | PP, Code Bodies | 5.15 |  | 599.71 | Green | GREEN |  |  |  |  |
| 1980 | 1.9.8.4 | Confirm if M16 date retained as 07/12/2026 | milestone | 0d | 2026-01-05 | 2026-01-05 | 1979FS+20d | 2026-01-05 | 2026-01-05 | 0d |  |  | 0d |  |  | Matthew Breen |  |  | CPT | PP | 5.15 |  | 627.71 | Green | GREEN |  |  |  |  |
| 1981 | 1.9.8.5 | Readiness assessment of participants' readiness to transition to new Settlement Timetable | milestone | 0d | 2026-02-02 | 2026-02-02 | 1980FS+20d | 2026-02-02 | 2026-02-02 | 0d |  |  | 0d |  |  | Matthew Breen |  |  | CPT | PP | 5.15 |  | 655.71 | Green | GREEN |  |  |  |  |
| 1982 | 1.9.8.6 | Elexon to produce Settlement Calendar for Settlement Year 2026 up until day before M16 cutover | milestone | 0d | 2026-04-01 | 2026-04-01 | 1981FS+42d | 2026-04-01 | 2026-04-01 | 0d |  |  | 0d |  |  | Matthew Breen |  |  | PP | PP, Code Bodies | 5.15 |  | 713.71 | Green | GREEN |  |  |  |  |
| 1983 | 1.9.8.7 | M16 Checkpoint 2 | milestone | 0d | 2026-09-15 | 2026-09-15 | 1982FS+119d | 2026-09-15 | 2026-09-15 | 0d |  |  | 0d |  |  | Matthew Breen |  |  | PP | PP, Code Bodies | 5.15 |  | 880.71 | Green | GREEN |  |  |  |  |
| 1984 | 1.9.8.8 | Readiness assessment of participants' readiness to transition to new Settlement Timetable | milestone | 0d | 2026-09-30 | 2026-09-30 | 1983FS+11d | 2026-09-30 | 2026-09-30 | 0d |  |  | 0d |  |  | Matthew Breen |  |  | CPT | PP | 5.15 |  | 895.71 | Green | GREEN |  |  |  |  |
| 1985 | 1.9.8.9 | Confirm M16 Date | milestone | 0d | 2026-10-13 | 2026-10-13 | 1984FS+9d | 2026-10-13 | 2026-10-13 | 1d |  |  | 0d |  |  | Matthew Breen |  |  | CPT | Code Bodies,CPT,PP,SRO | 5.3 | Early Live Running | 908.71 | Green | GREEN |  | T2-EL-0100 | PSG/BSC PAB | T2 |
| 1986 | 1.9.8.10 | Raise fast track change to ISD (November publish) | milestone | 0d | 2026-10-13 | 2026-10-13 | 1985 | 2026-10-13 | 2026-10-13 | 0d |  |  | 39d |  |  | Matthew Breen |  |  | PP | PP,CPT,Code Bodies | 5.15 |  | 908.71 | Green | GREEN |  |  |  |  |

| ID | WBS | Task | Type | Duration | Start | Finish | Predecessors | Baseline start | Baseline finish | Baseline duration | Baseline 1 start | Baseline 1 finish | Total slack | Free slack | Resources | Work | Responsible | Involved | Update Version | MHHS Programme Phase | Task Status | Sched Status | RAG | Milestone ID | Text29 | Tier | Text3 | Artefact ID |
| --- | --- | --- | --- | --- | --- | --- | --- | --- | --- | --- | --- | --- | --- | --- | --- | --- | --- | --- | --- | --- | --- | --- | --- | --- | --- | --- | --- | --- |
| 1987 | 1.9.8.11 | **M16 Approval Window** |  | 124d | 2026-12-07 | 2027-05-28 |  | 2026-12-07 | 2027-05-28 | 124d | 2026-12-07 | 2027-05-24 | 0d |  | N/A | 1984h | N/A | N/A | 5.0 | Early Live Running |  |  |  |  |  |  |  |  |
| 1988 | 1.9.8.11.1 | Panel approval that M16 criteria met | milestone | 0d | 2026-12-07 | 2026-12-07 | 1985FS+39d | 2026-12-07 | 2026-12-07 | 0d | 2026-12-07 | 2026-12-07 | 0d |  | Matthew Breen |  | Panel | Code Bodies,CPT,PP,SRO | 5.0 | Early Live Running | 963.71 | Green | GREEN |  |  |  |  |  |
| 1989 | 1.9.8.11.2 | Cut over to new settlement timetable (M16) | milestone | 0d | 2026-12-07 | 2026-12-07 | 1988, 1936FS+45d, 1978, 1986 | 2026-12-07 | 2026-12-07 | 0d | 2026-12-07 | 2026-12-07 | 0d |  | Matthew Breen |  | CPT | PP | 5.0 | Early Live Running | 963.71 | Green | GREEN | T1-EL-1000 | PSG | T1 |  |  |
| 1990 | 1.9.8.11.3 | Maximum 6-month window for approval of M16 |  | 124d | 2026-12-08 | 2027-05-28 | 1989 | 2026-12-08 | 2027-05-28 | 124d | 2026-12-08 | 2027-05-24 | 0d |  | Matthew Breen | 992h | CPT |  | 5.0 | Early Live Running | 964.33 | Green | GREEN |  |  |  |  |  |
| 1991 | 1.9.8.11.4 | Cut over to new settlement timetable (M16*) - Late Exit | milestone | 0d | 2027-05-28 | 2027-05-28 | 1990 | 2027-05-28 | 2027-05-28 | 0d | 2027-05-24 | 2027-05-24 | 0d |  | Matthew Breen |  | CPT | PP | 5.0 | Early Live Running | 1135.71 | Green | GREEN | T1-EL-2000 | PSG | T1 |  |  |
| 1992 | 1.10 | **EARLY LIVE RUNNING** |  | 45d | 2026-10-06 | 2026-12-07 |  | 2024-01-02 | 2027-05-28 | 889d | 2024-01-02 | 2027-05-28 | 124d |  | N/A | 1440h | N/A | N/A |  | Early Live Running |  |  |  |  |  |  | 1 Nov 2025 - 30 Apr 2026 |  |
| 1993 | 1.10.1 | **Early Live Running Stabilisation Period** |  | 45d | 2026-10-06 | 2026-12-07 |  | 2026-10-06 | 2026-12-07 | 45d | 2026-10-06 | 2026-12-07 | 124d |  | N/A | 1080h | N/A | N/A | 5.0 | Early Live Running |  |  |  |  |  |  |  |  |
| 1994 | 1.10.1.1 | Manage Early Live Running stabilisation period |  | 45d | 2026-10-06 | 2026-12-07 | 1936 | 2026-10-06 | 2026-12-07 | 45d | 2026-10-06 | 2026-12-07 | 124d | 0d | Matthew Breen | 360h | Code Bodies | PP | 5.0 | Early Live Running | 901.33 | Green | GREEN |  |  |  |  |  |
| 1995 | 1.10.1.2 | Monitor Early Live Running stabilisation period |  | 45d | 2026-10-06 | 2026-12-07 | 1994SS | 2026-10-06 | 2026-12-07 | 45d | 2026-10-06 | 2026-12-07 | 124d |  | Matthew Breen | 360h | SI Migration | Code Bodies,PP | 5.0 | Early Live Running | 901.33 | Green | GREEN |  |  |  |  |  |
| 1996 | 1.11 | **PROGRAMME CLOSURE** |  | 85d | 2026-08-04 | 2026-11-30 |  | 2026-08-04 | 2026-11-30 | 85d | 2026-08-04 | 2026-11-30 | 129d |  | N/A | 4560h | N/A | N/A |  | Programme Closure |  |  |  |  |  |  |  |  |
| 1997 | 1.11.1 | **Handover Pack** |  | 85d | 2026-08-04 | 2026-11-30 |  | 2026-08-04 | 2026-11-30 | 85d | 2026-08-04 | 2026-11-30 | 129d |  | N/A | 1320h | N/A | N/A | 5.0 | Programme Closure |  |  |  |  |  |  |  |  |
| 1998 | 1.11.1.1 | **Draft Handover Pack (for M15)** |  | 40d | 2026-08-04 | 2026-09-28 |  | 2026-08-04 | 2026-09-28 | 40d | 2026-08-04 | 2026-09-28 | 174d |  | N/A | 320h | N/A | N/A | 5.0 | Programme Closure |  |  |  |  |  |  |  |  |
| 1999 | 1.11.1.1.1 | Develop document |  | 20d | 2026-08-04 | 2026-08-31 | 1936FS-45d | 2026-08-04 | 2026-08-31 | 20d | 2026-08-04 | 2026-08-31 | 174d | 0d |  |  | PMO | CPT | 5.0 | Programme Closure | 838.33 | Green | GREEN |  |  |  |  |  |
| 2000 | 1.11.1.1.2 | Document review and update |  | 20d | 2026-09-01 | 2026-09-28 | 1999 | 2026-09-01 | 2026-09-28 | 20d | 2026-09-01 | 2026-09-28 | 174d | 0d |  |  | SRO | PMO,CPT,IPA,PP | 5.0 | Programme Closure | 866.33 | Green | GREEN |  |  |  |  |  |
| 2001 | 1.11.1.1.3 | Draft Handover Pack approved | milestone | 0d | 2026-09-28 | 2026-09-28 | 2000 | 2026-09-28 | 2026-09-28 | 0d | 2026-09-28 | 2026-09-28 | 174d |  |  |  | SRO | PMO,CPT | 5.0 | Programme Closure | 893.71 | Green | GREEN |  |  |  |  | MHHS-ART126 |
| 2002 | 1.11.1.2 | **Master Handover Pack (for M16)** |  | 40d | 2026-10-06 | 2026-11-30 |  | 2026-10-06 | 2026-11-30 | 40d | 2026-10-06 | 2026-11-30 | 129d |  | N/A | 320h | N/A | N/A | 5.0 | Programme Closure |  |  |  |  |  |  |  |  |
| 2003 | 1.11.1.2.1 | Update document |  | 20d | 2026-10-06 | 2026-11-02 | 1989FS-45d | 2026-10-06 | 2026-11-02 | 20d | 2026-10-06 | 2026-11-02 | 129d | 0d |  |  | PMO | CPT | 5.0 | Programme Closure | 901.33 | Green | GREEN |  |  |  |  |  |
| 2004 | 1.11.1.2.2 | Document review and update |  | 20d | 2026-11-03 | 2026-11-30 | 2003 | 2026-11-03 | 2026-11-30 | 20d | 2026-11-03 | 2026-11-30 | 129d | 0d |  |  | SRO | PMO,CPT,IPA,PP | 5.0 | Programme Closure | 929.33 | Green | GREEN |  |  |  |  |  |
| 2005 | 1.11.1.2.3 | Master Handover Pack approved | milestone | 0d | 2026-11-30 | 2026-11-30 | 2004 | 2026-11-30 | 2026-11-30 | 0d | 2026-11-30 | 2026-11-30 | 129d |  |  |  | SRO | PMO,CPT | 5.0 | Programme Closure | 956.71 | Green | GREEN |  |  |  |  | MHHS-ART126 |
| 2006 | 1.11.2 | **Programme Lessons Learned** |  | 40d | 2026-08-04 | 2026-09-28 |  | 2026-08-04 | 2026-09-28 | 40d | 2026-08-04 | 2026-09-28 | 174d |  | N/A | 320h | N/A | N/A | 5.0 | Programme Closure |  |  |  |  |  |  |  |  |
| 2007 | 1.11.2.1 | Develop document |  | 20d | 2026-08-04 | 2026-08-31 | 1936FS-45d | 2026-08-04 | 2026-08-31 | 20d | 2026-08-04 | 2026-08-31 | 174d | 0d |  |  | PMO | CPT | 5.0 | Programme Closure | 838.33 | Green | GREEN |  |  |  |  |  |
| 2008 | 1.11.2.2 | Document review and update |  | 20d | 2026-09-01 | 2026-09-28 | 2007 | 2026-09-01 | 2026-09-28 | 20d | 2026-09-01 | 2026-09-28 | 174d | 0d |  |  | SRO | PMO,CPT,IPA | 5.0 | Programme Closure | 866.33 | Green | GREEN |  |  |  |  |  |
| 2009 | 1.11.2.3 | Programme Lessons Learned document approved | milestone | 0d | 2026-09-28 | 2026-09-28 | 2008 | 2026-09-28 | 2026-09-28 | 0d | 2026-09-28 | 2026-09-28 | 174d |  |  |  | SRO | PMO,CPT | 5.0 | Programme Closure | 893.71 | Green | GREEN |  |  |  |  | MHHS-ART131 |
| 2010 | 1.11.3 | **Programme Closure Report** |  | 40d | 2026-08-04 | 2026-09-28 |  | 2026-08-04 | 2026-09-28 | 40d | 2026-08-04 | 2026-09-28 | 174d |  | N/A | 320h | N/A | N/A | 5.0 | Programme Closure |  |  |  |  |  |  |  |  |
| 2011 | 1.11.3.1 | Develop document |  | 20d | 2026-08-04 | 2026-08-31 | 1936FS-45d | 2026-08-04 | 2026-08-31 | 20d | 2026-08-04 | 2026-08-31 | 174d | 0d |  |  | PMO | CPT | 5.0 | Programme Closure | 838.33 | Green | GREEN |  |  |  |  |  |
| 2012 | 1.11.3.2 | Document review and update |  | 20d | 2026-09-01 | 2026-09-28 | 2011 | 2026-09-01 | 2026-09-28 | 20d | 2026-09-01 | 2026-09-28 | 174d | 0d |  |  | Ofgem | PMO,CPT,IPA,SRO | 5.0 | Programme Closure | 866.33 | Green | GREEN |  |  |  |  |  |
| 2013 | 1.11.3.3 | Programme Closure Report approved | milestone | 0d | 2026-09-28 | 2026-09-28 | 2012 | 2026-09-28 | 2026-09-28 | 0d | 2026-09-28 | 2026-09-28 | 174d |  |  |  | Ofgem | PMO,CPT,IPA,SRO | 5.0 | Programme Closure | 893.71 | Green | GREEN |  |  |  |  | MHHS-ART130 |

| ID | WBS | Task | Type | Duration | Start | Finish | Predecessors | Complete | Remaining | Baseline start | Baseline finish | Baseline duration | Baseline 1 start | Baseline 1 finish | Total slack | Free slack | Resources | Work | Actual work | Responsible | Involved | Update Version | MHHS Programme Phase | Task Status | Sched Status | RAG | Artefact ID | Milestone ID | Text29 | Tier |
| --- | --- | --- | --- | --- | --- | --- | --- | --- | --- | --- | --- | --- | --- | --- | --- | --- | --- | --- | --- | --- | --- | --- | --- | --- | --- | --- | --- | --- | --- | --- |
| 2014 | 1.11.4 | **Benefit Realisation Report** |  | 45d | 2026-08-04 | 2026-10-05 |  |  |  | 2026-08-04 | 2026-10-05 | 45d | 2026-08-04 | 2026-10-05 | 169d |  | N/A | 360h |  | N/A | N/A | 5.0 | Programme Closure |  |  |  |  |  |  |  |
| 2015 | 1.11.4.1 | Develop document |  | 20d | 2026-08-04 | 2026-08-31 | 1936FS-45d |  |  | 2026-08-04 | 2026-08-31 | 20d | 2026-08-04 | 2026-08-31 | 169d | 0d |  |  |  | PMO | CPT | 5.0 | Programme Closure | 838.33 | Green | GREEN |  |  |  |  |
| 2016 | 1.11.4.2 | Document review and update |  | 20d | 2026-09-01 | 2026-09-28 | 2015 |  |  | 2026-09-01 | 2026-09-28 | 20d | 2026-09-01 | 2026-09-28 | 169d | 0d |  |  |  | PP | PMO,CPT,IPA,SRO | 5.0 | Programme Closure | 866.33 | Green | GREEN |  |  |  |  |
| 2017 | 1.11.4.3 | Benefit Realisation Report approved | milestone | 0d | 2026-10-05 | 2026-10-05 | 2016FS+5d |  |  | 2026-10-05 | 2026-10-05 | 0d | 2026-10-05 | 2026-10-05 | 169d |  |  |  |  | PMO | CPT,PP,IPA,SRO | 5.0 | Programme Closure | 900.71 | Green | GREEN | MHHS-ART124 | T3-PC-0010 | PSG | T3 |
| 2018 | 1.11.5 | **Operating Model Gap Review with recommendations** |  | 45d | 2026-08-04 | 2026-10-05 |  |  |  | 2026-08-04 | 2026-10-05 | 45d | 2026-08-04 | 2026-10-05 | 169d |  | N/A | 360h |  | N/A | N/A | 5.0 | Programme Closure |  |  |  |  |  |  |  |
| 2019 | 1.11.5.1 | Develop document |  | 20d | 2026-08-04 | 2026-08-31 | 1936FS-45d |  |  | 2026-08-04 | 2026-08-31 | 20d | 2026-08-04 | 2026-08-31 | 169d | 0d |  |  |  | PMO | CPT | 5.0 | Programme Closure | 838.33 | Green | GREEN |  |  |  |  |
| 2020 | 1.11.5.2 | Document review and update |  | 20d | 2026-09-01 | 2026-09-28 | 2019 |  |  | 2026-09-01 | 2026-09-28 | 20d | 2026-09-01 | 2026-09-28 | 169d | 0d |  |  |  | PP | PMO,CPT,IPA,SRO | 5.0 | Programme Closure | 866.33 | Green | GREEN |  |  |  |  |
| 2021 | 1.11.5.3 | Operating Model Gap Review with recommendations approved | milestone | 0d | 2026-10-05 | 2026-10-05 | 2020FS+5d |  |  | 2026-10-05 | 2026-10-05 | 0d | 2026-10-05 | 2026-10-05 | 169d |  | Paul Pettitt |  |  | Paul Pettitt | CPT,PP,IPA,SRO | 5.0 | Programme Closure | 900.71 | Green | GREEN | MHHS-ART128 | T3-PC-0020 | DAG | T3 |
| 2022 | 1.11.6 | **Post-Implementation Review** |  | 45d | 2026-08-04 | 2026-10-05 |  |  |  | 2026-08-04 | 2026-10-05 | 45d | 2026-08-04 | 2026-10-05 | 169d |  | N/A | 360h |  | N/A | N/A | 5.0 | Programme Closure |  |  |  |  |  |  |  |
| 2023 | 1.11.6.1 | Develop document |  | 20d | 2026-08-04 | 2026-08-31 | 1936FS-45d |  |  | 2026-08-04 | 2026-08-31 | 20d | 2026-08-04 | 2026-08-31 | 169d | 0d |  |  |  | PMO | CPT | 5.0 | Programme Closure | 838.33 | Green | GREEN |  |  |  |  |
| 2024 | 1.11.6.2 | Document review and update |  | 20d | 2026-09-01 | 2026-09-28 | 2023 |  |  | 2026-09-01 | 2026-09-28 | 20d | 2026-09-01 | 2026-09-28 | 169d | 0d |  |  |  | PP | PMO,CPT,IPA,SRO | 5.0 | Programme Closure | 866.33 | Green | GREEN |  |  |  |  |
| 2025 | 1.11.6.3 | Post-Implementation Review approved | milestone | 0d | 2026-10-05 | 2026-10-05 | 2024FS+5d |  |  | 2026-10-05 | 2026-10-05 | 0d | 2026-10-05 | 2026-10-05 | 169d |  |  |  |  | PMO | CPT,PP,IPA,SRO | 5.0 | Programme Closure | 900.71 | Green | GREEN | MHHS-ART129 | T3-PC-0030 | PSG | T3 |
| 2026 | 1.11.7 | **Reinforcement Guide** |  | 45d | 2026-08-04 | 2026-10-05 |  |  |  | 2026-08-04 | 2026-10-05 | 45d | 2026-08-04 | 2026-10-05 | 169d |  | N/A | 360h |  | N/A | N/A | 5.0 | Programme Closure |  |  |  |  |  |  |  |
| 2027 | 1.11.7.1 | Develop document |  | 20d | 2026-08-04 | 2026-08-31 | 1936FS-45d |  |  | 2026-08-04 | 2026-08-31 | 20d | 2026-08-04 | 2026-08-31 | 169d | 0d |  |  |  | PMO | CPT | 5.0 | Programme Closure | 838.33 | Green | GREEN |  |  |  |  |
| 2028 | 1.11.7.2 | Document review and update |  | 20d | 2026-09-01 | 2026-09-28 | 2027 |  |  | 2026-09-01 | 2026-09-28 | 20d | 2026-09-01 | 2026-09-28 | 169d | 0d |  |  |  | PP | PMO,CPT,IPA,SRO | 5.0 | Programme Closure | 866.33 | Green | GREEN |  |  |  |  |
| 2029 | 1.11.7.3 | Reinforcement Guide approved | milestone | 0d | 2026-10-05 | 2026-10-05 | 2028FS+5d |  |  | 2026-10-05 | 2026-10-05 | 0d | 2026-10-05 | 2026-10-05 | 169d |  |  |  |  | PMO | CPT,PP,IPA,SRO | 5.0 | Programme Closure | 900.71 | Green | GREEN | MHHS-ART133 | T3-PC-0040 | PSG | T3 |
| 2030 | 1.11.8 | **Material and Licenses Transfer** |  | 60d | 2026-09-08 | 2026-11-30 |  |  |  | 2026-09-08 | 2026-11-30 | 60d | 2026-09-08 | 2026-11-30 | 129d |  | N/A | 480h |  | N/A | N/A | 5.0 | Programme Closure |  |  |  |  |  |  |  |
| 2031 | 1.11.8.1 | Transfer of Programme material to Elexon and perpetual licenses as appropriate |  | 60d | 2026-09-08 | 2026-11-30 | 1989FF-5d |  |  | 2026-09-08 | 2026-11-30 | 60d | 2026-09-08 | 2026-11-30 | 129d |  |  |  |  | PMO | CPT,PP | 5.0 | Programme Closure | 873.33 | Green | GREEN | MHHS-ART139 |  |  |  |
| 2032 | 1.12 | **READINESS ASSESSMENTS** |  | 849d | 2023-09-05 A | 2026-12-04 |  | 23% | 657.29d | 2023-09-05 | 2026-12-04 | 849d | 2023-09-11 | 2026-12-04 | 125d |  | N/A | 13264h | 2230.45h | N/A | N/A |  | Readiness Assessments |  |  |  |  |  |  |  |
| 2033 | 1.12.1 | **Readiness Assessment 3 - Design and Build Progress Check and CP2 Check** |  | 60d | 2023-09-05 A | 2023-11-27 A |  | 100% |  | 2023-09-05 | 2023-11-13 | 50d | 2023-09-11 | 2023-11-17 |  |  | N/A | 1040h | 1040h | N/A | N/A | 5.5 | Readiness Assessments | M5,M6 |  |  |  |  |  |  |
| 2034 | 1.12.1.1 | Launch Readiness Assessment survey | milestone | 0d | 2023-09-05 A | 2023-09-05 A | 1004FS-40d | 100% |  | 2023-09-05 | 2023-09-05 | 0d | 2023-09-11 | 2023-09-11 |  |  | PPC |  |  | PPC |  | 5.5 | Readiness Assessments |  | Complete | COMPLETE |  |  |  |  |
| 2035 | 1.12.1.2 | PPs submit survey responses |  | 15d | 2023-09-05 A | 2023-09-25 A | 2034 | 100% |  | 2023-09-05 | 2023-09-25 | 15d | 2023-09-11 | 2023-09-29 |  |  | PPC | 120h | 120h | PP | PPC | 5.5 | Readiness Assessments |  | Complete | COMPLETE |  |  |  |  |
| 2036 | 1.12.1.3 | Analyse survey responses |  | 15d | 2023-09-26 A | 2023-10-16 A | 2035 | 100% |  | 2023-09-26 | 2023-10-16 | 15d | 2023-10-02 | 2023-10-20 |  |  | PPC | 120h | 120h | PPC | CPT | 5.5 | Readiness Assessments |  | Complete | COMPLETE |  |  |  |  |
| 2037 | 1.12.1.4 | Conduct deep-dive interviews (sample of PPs) |  | 15d | 2023-09-26 A | 2023-10-16 A | 2035 | 100% |  | 2023-09-26 | 2023-10-16 | 15d | 2023-10-02 | 2023-10-20 |  |  | PPC | 120h | 120h | PPC | CPT | 5.5 | Readiness Assessments |  | Complete | COMPLETE |  |  |  |  |
| 2038 | 1.12.1.5 | Produce Readiness Assessment Reports (Overall Report & Individual Participant Reports) |  | 25d | 2023-10-17 A | 2023-11-20 A | 2036, 2037 | 100% |  | 2023-10-17 | 2023-11-06 | 15d | 2023-10-23 | 2023-11-10 |  |  | PPC | 200h | 200h | PPC |  | 5.5 | Readiness Assessments |  | Complete | COMPLETE |  |  |  |  |
| 2039 | 1.12.1.6 | Readiness Assessment 3 - Design & Build Checkpoint 1 - Completed (incl. Readiness Assessment Report approval) | milestone | 0d | 2023-11-27 A | 2023-11-27 A | 2038FS+5d | 100% |  | 2023-11-13 | 2023-11-13 | 0d | 2023-11-17 | 2023-11-17 |  |  | PPC |  |  | CPT | PPC | 5.13 | Readiness Assessments |  | Complete | COMPLETE |  | T2-RA-0200 | PSG | T2 |

Notes:
- 2021: Action: 5/2 - PP said ask MB if belonged to him. MB says doesn't sit with him
- 2037: 16/11- FD confirmed activity didn't take place for RA3 because responses did not warrant follow-up
- 2039: 16/11-RA3 outputs and initial findings shared with PSG to support M9 decision making. Individual reports and final closure report being finalised. No impact to Programme timelines or activities

| ID | WBS | Task | Type | Duration | Start | Finish | Predecessors | Baseline start | Baseline finish | Baseline duration | Baseline 1 start | Baseline 1 finish | Total slack | Free slack | Constraint | Resources | Work | Responsible | Involved | Text3 | Task Status | Update Version | MHHS Programme Phase | Sched Status | RAG | Milestone ID | Text29 | Tier |
| --- | --- | --- | --- | --- | --- | --- | --- | --- | --- | --- | --- | --- | --- | --- | --- | --- | --- | --- | --- | --- | --- | --- | --- | --- | --- | --- | --- | --- |
| 2040 | 1.12.2 | **Readiness Assessment 5 / 6 - Start of Qualification and Participant Readiness for M10 and M11 and CP3/CP4 check** |  | 47d | 2024-11-12 | 2025-01-15 |  | 2024-11-12 | 2025-01-17 | 49d | 2024-11-12 | 2025-01-17 | 617d |  |  | N/A | 856h | N/A | N/A | D25 - RA6 Readiness Report | M11 | 5.0 | Readiness Assessments |  |  |  |  |  |
| 2041 | 1.12.2.1 | Launch Readiness Assessment survey | milestone | 0d | 2024-11-12 | 2024-11-12 | 1569FS-50d | 2024-11-12 | 2024-11-12 | 0d | 2024-11-12 | 2024-11-12 | 617d | 0d |  | PPC |  | PPC |  |  | 208.33 | 5.0 | Readiness Assessments | Green | GREEN |  |  |  |
| 2042 | 1.12.2.2 | PPs submit survey responses |  | 15d | 2024-11-12 | 2024-12-02 | 2041 | 2024-11-12 | 2024-12-02 | 15d | 2024-11-12 | 2024-12-02 | 617d | 0d |  | PPC | 120h | PP | PPC |  | 208.33 | 5.0 | Readiness Assessments | Green | GREEN |  |  |  |
| 2043 | 1.12.2.3 | Analyse survey responses |  | 15d | 2024-12-03 | 2024-12-23 | 2042 | 2024-12-03 | 2024-12-23 | 15d | 2024-12-03 | 2024-12-23 | 617d | 0d |  | PPC | 120h | PPC | CPT |  | 229.33 | 5.0 | Readiness Assessments | Green | GREEN |  |  |  |
| 2044 | 1.12.2.4 | Conduct deep-dive interviews (sample of PPs) |  | 15d | 2024-12-03 | 2024-12-23 | 2042 | 2024-12-03 | 2024-12-23 | 15d | 2024-12-03 | 2024-12-23 | 617d | 0d |  | PPC | 120h | PPC | CPT |  | 229.33 | 5.0 | Readiness Assessments | Green | GREEN |  |  |  |
| 2045 | 1.12.2.5 | Produce Readiness Assessment Reports (Overall Report & Individual Participant Reports) |  | 15d | 2024-12-24 | 2025-01-13 | 2043, 2044 | 2024-12-24 | 2025-01-13 | 15d | 2024-12-24 | 2025-01-13 | 617d | 0d |  | PPC | 120h | PPC |  |  | 250.33 | 5.0 | Readiness Assessments | Green | GREEN |  |  |  |
| 2046 | 1.12.2.6 | Readiness Assessment 5 / 6 - Start of Qualification and Participant Readiness for M10 and M11 and CP3/CP4 check (incl. Readiness Assessment Report approval) Completed | milestone | 0d | 2025-01-15 | 2025-01-15 | 2045FS+2d | 2025-01-17 | 2025-01-17 | 0d | 2025-01-17 | 2025-01-17 | 617d |  |  | PPC |  | CPT | PPC |  | 272.71 | 5.18 | Readiness Assessments | Green | GREEN | T2-RA-0400 | PSG | T2 |
| 2047 | 1.12.3 | **Readiness Assessment 7 - Migration Checkpoint** |  | 49d | 2025-08-04 | 2025-10-09 |  | 2025-08-04 | 2025-10-09 | 49d | 2025-08-04 | 2025-10-09 | 0d |  |  | N/A | 872h | N/A | N/A | D29 - RA8 Readiness Report | M14 | 5.0 | Readiness Assessments |  |  |  |  |  |
| 2048 | 1.12.3.1 | Launch Readiness Assessment survey | milestone | 0d | 2025-08-04 | 2025-08-04 |  | 2025-08-04 | 2025-08-04 | 0d | 2025-08-04 | 2025-08-04 | 0d |  | must start on 2025-08-04 | PPC |  | PPC |  |  | 473.33 | 5.0 | Readiness Assessments | Green | GREEN |  |  |  |
| 2049 | 1.12.3.2 | PPs submit survey responses |  | 15d | 2025-08-04 | 2025-08-22 | 2048 | 2025-08-04 | 2025-08-22 | 15d | 2025-08-04 | 2025-08-22 | 426d | 0d |  | PPC | 120h | PP | PPC |  | 473.33 | 5.0 | Readiness Assessments | Green | GREEN |  |  |  |
| 2050 | 1.12.3.3 | Analyse survey responses |  | 15d | 2025-08-25 | 2025-09-12 | 2049 | 2025-08-25 | 2025-09-12 | 15d | 2025-08-25 | 2025-09-12 | 426d | 0d |  | PPC | 120h | PPC | CPT |  | 494.33 | 5.0 | Readiness Assessments | Green | GREEN |  |  |  |
| 2051 | 1.12.3.4 | Conduct deep-dive interviews (sample of PPs) |  | 15d | 2025-08-25 | 2025-09-12 | 2049 | 2025-08-25 | 2025-09-12 | 15d | 2025-08-25 | 2025-09-12 | 426d | 0d |  | PPC | 120h | PPC | CPT |  | 494.33 | 5.0 | Readiness Assessments | Green | GREEN |  |  |  |
| 2052 | 1.12.3.5 | Produce Readiness Assessment Reports (Overall Report & Individual Participant Reports) |  | 15d | 2025-09-15 | 2025-10-03 | 2050, 2051 | 2025-09-15 | 2025-10-03 | 15d | 2025-09-15 | 2025-10-03 | 426d | 0d |  | PPC | 120h | PPC |  |  | 515.33 | 5.0 | Readiness Assessments | Green | GREEN |  |  |  |
| 2053 | 1.12.3.6 | Readiness Assessment 7 - Migration Checkpoint - Completed (incl. Readiness Assessment Report approval) | milestone | 0d | 2025-10-09 | 2025-10-09 | 2052FS+4d | 2025-10-09 | 2025-10-09 | 0d | 2025-10-09 | 2025-10-09 | 426d |  |  | PPC |  | CPT | PPC |  | 539.71 | 5.0 | Readiness Assessments | Green | GREEN | T2-RA-0600 | PSG | T2 |
| 2054 | 1.12.4 | **Readiness Assessment 8 - Ready to Accept New MPANs** |  | 49d | 2026-01-02 | 2026-03-11 |  | 2026-01-06 | 2026-03-13 | 49d | 2026-01-06 | 2026-03-13 | 317d |  |  | N/A | 872h | N/A | N/A | D29 - RA8 Readiness Report | M14 | 5.0 | Readiness Assessments |  |  |  |  |  |
| 2055 | 1.12.4.1 | Launch Readiness Assessment survey | milestone | 0d | 2026-01-02 | 2026-01-02 | 1934FS-50d | 2026-01-06 | 2026-01-06 | 0d | 2026-01-06 | 2026-01-06 | 317d | 0d |  | PPC |  | PPC |  |  | 624.33 | 5.0 | Readiness Assessments | Green | GREEN |  |  |  |
| 2056 | 1.12.4.2 | PPs submit survey responses |  | 15d | 2026-01-02 | 2026-01-22 | 2055 | 2026-01-06 | 2026-01-26 | 15d | 2026-01-06 | 2026-01-26 | 317d | 0d |  | PPC | 120h | PP | PPC |  | 624.33 | 5.0 | Readiness Assessments | Green | GREEN |  |  |  |
| 2057 | 1.12.4.3 | Analyse survey responses |  | 15d | 2026-01-23 | 2026-02-12 | 2056 | 2026-01-27 | 2026-02-16 | 15d | 2026-01-27 | 2026-02-16 | 317d | 0d |  | PPC | 120h | PPC | CPT |  | 645.33 | 5.0 | Readiness Assessments | Green | GREEN |  |  |  |
| 2058 | 1.12.4.4 | Conduct deep-dive interviews (sample of PPs) |  | 15d | 2026-01-23 | 2026-02-12 | 2056 | 2026-01-27 | 2026-02-16 | 15d | 2026-01-27 | 2026-02-16 | 317d | 0d |  | PPC | 120h | PPC | CPT |  | 645.33 | 5.0 | Readiness Assessments | Green | GREEN |  |  |  |
| 2059 | 1.12.4.5 | Produce Readiness Assessment Reports (Overall Report & Individual Participant Reports) |  | 15d | 2026-02-13 | 2026-03-05 | 2057, 2058 | 2026-02-17 | 2026-03-09 | 15d | 2026-02-17 | 2026-03-09 | 317d | 0d |  | PPC | 120h | PPC |  |  | 666.33 | 5.0 | Readiness Assessments | Green | GREEN |  |  |  |
| 2060 | 1.12.4.6 | Readiness Assessment 8 - Ready to Accept New MPANs - Completed (incl. Readiness Assessment Report approval) | milestone | 0d | 2026-03-11 | 2026-03-11 | 2059FS+4d | 2026-03-13 | 2026-03-13 | 0d | 2026-03-13 | 2026-03-13 | 317d |  |  | PPC |  | CPT | PPC |  | 692.71 | 5.0 | Readiness Assessments | Green | GREEN | T2-RA-0700 | PSG | T2 |
| 2061 | 1.12.5 | **Readiness Assessment 9 - Ready for New Settlement Timetable and CP5 Check** |  | 49d | 2026-09-29 | 2026-12-04 |  | 2026-09-29 | 2026-12-04 | 49d | 2026-09-29 | 2026-12-04 | 125d |  |  | N/A | 872h | N/A | N/A | D32 - RA10 Readiness Report | M16 | 5.0 | Readiness Assessments |  |  |  |  |  |
| 2062 | 1.12.5.1 | Launch Readiness Assessment survey | milestone | 0d | 2026-09-29 | 2026-09-29 | 1989FS-50d | 2026-09-29 | 2026-09-29 | 0d | 2026-09-29 | 2026-09-29 | 125d | 0d |  | PPC |  | PPC |  |  | 894.33 | 5.0 | Readiness Assessments | Green | GREEN |  |  |  |
| 2063 | 1.12.5.2 | PPs submit survey responses |  | 15d | 2026-09-29 | 2026-10-19 | 2062 | 2026-09-29 | 2026-10-19 | 15d | 2026-09-29 | 2026-10-19 | 125d | 0d |  | PPC | 120h | PP | PPC |  | 894.33 | 5.0 | Readiness Assessments | Green | GREEN |  |  |  |
| 2064 | 1.12.5.3 | Analyse survey responses |  | 15d | 2026-10-20 | 2026-11-09 | 2063 | 2026-10-20 | 2026-11-09 | 15d | 2026-10-20 | 2026-11-09 | 125d | 0d |  | PPC | 120h | PPC | CPT |  | 915.33 | 5.0 | Readiness Assessments | Green | GREEN |  |  |  |
| 2065 | 1.12.5.4 | Conduct deep-dive interviews (sample of PPs) |  | 15d | 2026-10-20 | 2026-11-09 | 2063 | 2026-10-20 | 2026-11-09 | 15d | 2026-10-20 | 2026-11-09 | 125d | 0d |  | PPC | 120h | PPC | CPT |  | 915.33 | 5.0 | Readiness Assessments | Green | GREEN |  |  |  |
| 2066 | 1.12.5.5 | Produce Readiness Assessment Reports (Overall Report & Individual Participant Reports) |  | 15d | 2026-11-10 | 2026-11-30 | 2064, 2065 | 2026-11-10 | 2026-11-30 | 15d | 2026-11-10 | 2026-11-30 | 125d | 0d |  | PPC | 120h | PPC |  |  | 936.33 | 5.0 | Readiness Assessments | Green | GREEN |  |  |  |
| 2067 | 1.12.5.6 | Readiness Assessment 9 - Readiness for New Settlement Timetable - Completed (incl. Readiness Assessment Report approval) | milestone | 0d | 2026-12-04 | 2026-12-04 | 2066FS+4d | 2026-12-04 | 2026-12-04 | 0d | 2026-12-04 | 2026-12-04 | 125d |  |  | PPC |  | CPT | PPC |  | 960.71 | 5.0 | Readiness Assessments | Green | GREEN | T2-RA-0800 | PSG | T2 |

Notes:
- 2046: 08/02/2024 Name change approval at PSG on 07/02/24 from 'Readiness Assessment 5 - Start of Qualification - Completed (incl. Readiness Assessment Report approval)'

| ID | WBS | Task | Type | Duration | Start | Finish | Predecessors | Complete | Remaining | Baseline start | Baseline finish | Baseline duration | Baseline 1 start | Baseline 1 finish | Total slack | Free slack | Constraint | Resources | Work | Actual work | Responsible | Involved | Update Version | MHHS Programme Phase | Task Status | Sched Status | RAG | Milestone ID | Text29 | Tier | Text3 |
| --- | --- | --- | --- | --- | --- | --- | --- | --- | --- | --- | --- | --- | --- | --- | --- | --- | --- | --- | --- | --- | --- | --- | --- | --- | --- | --- | --- | --- | --- | --- | --- |
| 2068 | 1.12.6 | **Readiness Assessments - Tier 1 Milestones** |  | 435d | 2025-04-04 | 2026-12-04 |  |  |  | 2023-11-13 | 2026-12-04 | 799d | 2023-11-17 | 2026-12-04 | 125d |  |  | N/A | 3480h |  | N/A | N/A | 5.0 | Readiness Assessments |  |  |  |  |  |  |  |
| 2069 | 1.12.6.1 | Readiness Assessment 6 - Start of Migration - Completed (incl. Readiness Assessment Report approval) | milestone | 0d | 2025-04-04 | 2025-04-04 |  |  |  | 2025-04-04 | 2025-04-04 | 0d | 2025-04-04 | 2025-04-04 | 560d |  | finish no earlier than 2025-04-04 | PPC |  |  | CPT | PPC | 5.0 | Readiness Assessments | 351.71 | Green | GREEN | T2-RA-0500 | PSG | T2 |  |
| 2070 | 1.12.6.2 | Readiness Assessment 7 - Migration Checkpoint - Completed (incl. Readiness Assessment Report approval) | milestone | 0d | 2025-10-09 | 2025-10-09 | 2052FS+4d |  |  | 2025-10-09 | 2025-10-09 | 0d | 2025-10-09 | 2025-10-09 | 426d |  |  | PPC |  |  | CPT | PPC | 5.0 | Readiness Assessments | 539.71 | Green | GREEN | T2-RA-0600 | PSG | T2 |  |
| 2071 | 1.12.6.3 | Readiness Assessment 8 - Ready to Accept New MPANs - Completed (incl. Readiness Assessment Report approval) | milestone | 0d | 2026-03-11 | 2026-03-11 | 2059FS+4d |  |  | 2026-03-13 | 2026-03-13 | 0d | 2026-03-13 | 2026-03-13 | 317d |  |  | PPC |  |  | CPT | PPC | 5.0 | Readiness Assessments | 692.71 | Green | GREEN | T2-RA-0700 | PSG | T2 |  |
| 2072 | 1.12.6.4 | Readiness Assessment 9 - Readiness for New Settlement Timetable - Completed (incl. Readiness Assessment Report approval) | milestone | 0d | 2026-12-04 | 2026-12-04 | 2066FS+4d |  |  | 2026-12-04 | 2026-12-04 | 0d | 2026-12-04 | 2026-12-04 | 125d |  |  | PPC |  |  | CPT | PPC | 5.0 | Readiness Assessments | 960.71 | Green | GREEN | T2-RA-0800 | PSG | T2 |  |
| 2073 | 1.13 | **CONTROL POINTS** |  | 1063d | 2022-11-10 A | 2026-12-07 |  | 51% | 522.49d | 2022-11-10 | 2026-12-07 | 1063d | 2022-11-10 | 2026-12-07 | 124d |  |  | N/A | 14424h | 680h | N/A | N/A |  | Control Points |  |  |  |  |  |  |  |
| 2074 | 1.13.1 | **Control Point 1 - Start of System Design, Build & Test** |  | 20d | 2022-11-10 A | 2022-12-07 A |  | 100% |  | 2022-11-10 | 2022-12-07 | 20d | 2022-11-10 | 2022-12-07 |  |  |  | N/A | 280h | 280h | N/A | N/A | 5.0 | Control Points |  |  |  |  |  |  |  |
| 2075 | 1.13.1.1 | Control Point 1 Preparation (incl. Control Point Report development and review) |  | 15d | 2022-11-10 A | 2022-11-30 A | 2076SS-20d | 100% |  | 2022-11-10 | 2022-11-30 | 15d | 2022-11-10 | 2022-11-30 |  |  |  | PMO | 120h | 120h | CPT | PMO | 5.0 | Control Points |  | Complete | COMPLETE |  |  |  |  |
| 2076 | 1.13.1.2 | Control Point 1 - Start of System Design, Build & Test (incl. Control Point Report approval) | milestone | 0d | 2022-12-07 A | 2022-12-07 A |  | 100% |  | 2022-12-07 | 2022-12-07 | 0d | 2022-12-07 | 2022-12-07 |  |  | must finish on 2022-12-07 | PMO |  |  | CPT | PMO | 5.0 | Control Points |  | Complete | COMPLETE | T1-CP-1000 | PSG | T1 | D24 - CP2 Approval |
| 2077 | 1.13.2 | **Control Point 2 - Start of Integration & Test** |  | 20d | 2023-10-02 A | 2023-10-30 A |  | 100% |  | 2023-10-03 | 2023-10-30 | 20d | 2023-10-02 | 2023-10-30 |  |  |  | N/A | 280h | 280h | N/A | N/A | 5.0 | Control Points |  |  |  |  |  |  |  |
| 2078 | 1.13.2.1 | Control Point 2 Preparation (incl. Control Point Report development and review) |  | 15d | 2023-10-02 A | 2023-10-20 A | 2079SS-20d | 100% |  | 2023-10-03 | 2023-10-23 | 15d | 2023-10-02 | 2023-10-20 |  |  |  | PMO | 120h | 120h | CPT | PMO | 5.0 | Control Points |  | Complete | COMPLETE |  |  |  |  |
| 2079 | 1.13.2.2 | Control Point 2 - Start of Integration & Test (incl. Control Point Report approval) | milestone | 0d | 2023-10-30 A | 2023-10-30 A | 1004 | 100% |  | 2023-10-30 | 2023-10-30 | 0d | 2023-10-30 | 2023-10-30 |  |  |  | PMO |  |  | CPT | PMO | 5.11 | Control Points |  | Complete | COMPLETE | T1-CP-2000 | PSG | T1 | D24 - CP2 Approval |
| 2080 | 1.13.3 | **Control Point 3/4 - Readiness for Migration** |  | 20d | 2025-02-28 | 2025-03-27 |  |  |  | 2025-03-03 | 2025-03-28 | 20d | 2025-03-03 | 2025-03-28 | 566d |  |  | N/A | 272h |  | N/A | N/A | 5.0 | Control Points |  |  |  |  |  |  | D26 - CP3 Approval |
| 2081 | 1.13.3.1 | Control Point 3/4 Preparation (incl. Control Point Report development and review) |  | 14d | 2025-02-28 | 2025-03-19 | 2082SS-20d |  |  | 2025-03-03 | 2025-03-20 | 14d | 2025-03-03 | 2025-03-21 | 572d |  |  | PMO | 112h |  | CPT | PMO | 5.0 | Control Points | 316.33 | Green | GREEN |  |  |  |  |
| 2082 | 1.13.3.2 | Control Point 3/4 - Readiness for Migration (incl. Control Point Report approval) | milestone | 0d | 2025-03-27 | 2025-03-27 | 1611FS+9d |  |  | 2025-03-28 | 2025-03-28 | 0d | 2025-03-28 | 2025-03-28 | 566d | 0d |  | PMO |  |  | CPT | PMO | 5.0 | Control Points | 343.71 | Green | GREEN | T1-CP-3000 | PSG | T1 |  |
| 2083 | 1.13.4 | **Control Point 5 - Cut Over to New Settlement Timetable** |  | 20d | 2026-11-10 | 2026-12-07 |  |  |  | 2026-11-10 | 2026-12-07 | 20d | 2026-11-10 | 2026-12-07 | 124d |  |  | N/A | 280h |  | N/A | N/A | 5.0 | Control Points | M16 |  |  |  |  |  | D33 - Control Point 6 Approval |
| 2084 | 1.13.4.1 | Control Point 5 Preparation (incl. Control Point Report development and review) |  | 15d | 2026-11-10 | 2026-11-30 | 2085SS-20d |  |  | 2026-11-10 | 2026-11-30 | 15d | 2026-11-10 | 2026-11-30 | 129d |  |  | PMO | 120h |  | CPT | PP | 5.0 | Control Points | 936.33 | Green | GREEN |  |  |  |  |
| 2085 | 1.13.4.2 | Control Point 5 - Cut Over to New Settlement Timetable (incl. Control Point Report approval) | milestone | 0d | 2026-12-07 | 2026-12-07 | 1989 |  |  | 2026-12-07 | 2026-12-07 | 0d | 2026-12-07 | 2026-12-07 | 124d | 0d |  | PMO |  |  | CPT | CPT | 5.0 | Control Points | 963.71 | Green | GREEN | T1-CP-4000 | PSG | T1 | D33 - Control Point 6 Approval |
| 2086 | 1.13.5 | **Control Points - Tier 1 Milestones** |  | 1043d | 2022-12-07 A | 2026-12-07 |  |  | 1043d | 2022-12-07 | 2026-12-07 | 1043d | 2022-12-07 | 2026-12-07 | 124d |  |  | N/A | 4808h |  | N/A | N/A | 5.0 | Control Points |  |  |  |  |  |  |  |
| 2087 | 1.13.5.1 | Control Point 1 - Start of System Design, Build & Test (incl. Control Point Report approval) | milestone | 0d | 2022-12-07 A | 2022-12-07 A | 2076SS | 100% |  | 2022-12-07 | 2022-12-07 | 0d | 2022-12-07 | 2022-12-07 |  |  |  | PMO |  |  | CPT | PMO | 5.0 | Control Points |  | Complete | COMPLETE | T1-CP-1000 | PSG | T1 |  |
| 2088 | 1.13.5.2 | Control Point 2 - Start of Integration & Test (incl. Control Point Report approval) | milestone | 0d | 2023-10-30 A | 2023-10-30 A | 2079SS | 100% |  | 2023-10-30 | 2023-10-30 | 0d | 2023-10-30 | 2023-10-30 |  |  |  | PMO |  |  | CPT | PMO | 5.11 | Control Points |  | Complete | COMPLETE | T1-CP-2000 | PSG | T1 | D24 - CP2 Approval |
| 2089 | 1.13.5.3 | Control Point 3/4 - Readiness for Migration (incl. Control Point Report approval) | milestone | 0d | 2025-03-27 | 2025-03-27 | 2082SS |  |  | 2025-03-28 | 2025-03-28 | 0d | 2025-03-28 | 2025-03-28 | 566d |  |  | PMO |  |  | CPT | PMO | 5.0 | Control Points | 343.71 | Green | GREEN | T1-CP-3000 | PSG | T1 |  |
| 2090 | 1.13.5.4 | Control Point 5 - Cut Over to New Settlement Timetable (incl. Control Point Report approval) | milestone | 0d | 2026-12-07 | 2026-12-07 | 2085SS |  |  | 2026-12-07 | 2026-12-07 | 0d | 2026-12-07 | 2026-12-07 | 124d |  |  | PMO |  |  | CPT | CPT | 5.0 | Control Points | 963.71 | Green | GREEN | T1-CP-4000 | PSG | T1 | D33 - Control Point 6 Approval |
| 2091 | 1.14 | **MILESTONE RANGE CHECKPOINTS** |  | 436d | 2025-01-13 | 2026-09-15 |  |  |  | 2025-01-13 | 2026-09-15 | 436d | 2025-01-13 | 2026-09-15 | 184d |  |  | N/A | 3488h |  | N/A | N/A |  | Milestone Range Checkpoints |  |  |  |  |  |  |  |
| 2092 | 1.14.1 | **M10, M11, M12 and M13 milestone checkpoint** |  | 0d | 2025-01-13 | 2025-01-13 |  |  |  | 2025-01-13 | 2025-01-13 | 0d | 2025-01-13 | 2025-01-13 | 620d |  |  | N/A |  |  | N/A | N/A | 5.0 | Milestone Range Checkpoints |  |  |  |  |  |  |  |
| 2093 | 1.14.1.1 | M10, M11, M12, and M13 milestone checkpoint - date approval | milestone | 0d | 2025-01-13 | 2025-01-13 | 1926FS-3mo, 1930FS-3mo, 1932FS-3mo, 1928FS-3mo |  |  | 2025-01-13 | 2025-01-13 | 0d | 2025-01-13 | 2025-01-13 | 620d |  |  | PMO |  |  | CPT | CPT | 5.0 | Milestone Range Checkpoints | 270.33 | Green | GREEN | T2-MR-0100 | PSG | T2 |  |

| ID | WBS | Task | Type | Duration | Start | Finish | Predecessors | Baseline start | Baseline finish | Baseline duration | Baseline 1 start | Baseline 1 finish | Total slack | Resources | Responsible | Involved | Update Version | MHHS Programme Phase | Task Status | Sched Status | RAG | Milestone ID | Text29 | Tier |
| --- | --- | --- | --- | --- | --- | --- | --- | --- | --- | --- | --- | --- | --- | --- | --- | --- | --- | --- | --- | --- | --- | --- | --- | --- |
| 2094 | 1.14.2 | **M14 milestone checkpoint** |  | 0d | 2025-12-19 | 2025-12-19 |  | 2025-12-23 | 2025-12-23 | 0d | 2025-12-23 | 2025-12-23 | 376d | N/A | N/A | N/A | 5.0 | Milestone Range Checkpoints |  |  |  |  |  |  |
| 2095 | 1.14.2.1 | M14 milestone checkpoint - date approval | milestone | 0d | 2025-12-19 | 2025-12-19 | 1934FS-3mo | 2025-12-23 | 2025-12-23 | 0d | 2025-12-23 | 2025-12-23 | 376d | PMO | CPT | CPT | 5.0 | Milestone Range Checkpoints | 610.33 | Green | GREEN | T2-MR-0200 | PSG | T2 |
| 2096 | 1.14.3 | **M15 milestone checkpoint** |  | 0d | 2026-07-14 | 2026-07-14 |  | 2026-07-14 | 2026-07-14 | 0d | 2026-07-14 | 2026-07-14 | 229d | N/A | N/A | N/A | 5.0 | Milestone Range Checkpoints |  |  |  |  |  |  |
| 2097 | 1.14.3.1 | M15 milestone checkpoint - date approval | milestone | 0d | 2026-07-14 | 2026-07-14 | 1936FS-3mo | 2026-07-14 | 2026-07-14 | 0d | 2026-07-14 | 2026-07-14 | 229d | PMO | CPT | CPT | 5.0 | Milestone Range Checkpoints | 817.33 | Green | GREEN | T2-MR-0300 | PSG | T2 |
| 2098 | 1.14.4 | **M16 milestone checkpoint** |  | 0d | 2026-09-15 | 2026-09-15 |  | 2026-09-15 | 2026-09-15 | 0d | 2026-09-15 | 2026-09-15 | 184d | N/A | N/A | N/A | 5.0 | Milestone Range Checkpoints |  |  |  |  |  |  |
| 2099 | 1.14.4.1 | M16 milestone checkpoint - date approval | milestone | 0d | 2026-09-15 | 2026-09-15 | 1989FS-3mo | 2026-09-15 | 2026-09-15 | 0d | 2026-09-15 | 2026-09-15 | 184d | PMO | CPT | CPT | 5.0 | Milestone Range Checkpoints | 880.33 | Green | GREEN | T2-MR-0400 | PSG | T2 |
